# Outline ELEXON Plan_kc

Schedule from MS Project, 2022-10-31 to 2027-05-28, status date 2024-06-26, A marks actual dates.

## Calendars

- Standard: Mon-Fri 08:00-12:00, 13:00-17:00; Sat-Sun off.

## Resources

| Resource |
| --- |
| PMO |
| SI |
| PPC |
| Lead Workstream |
| CPT |
| PP |
| SI Design |
| SI Design |
| SI Design |
| Design |
| SI DevOps |
| SI Test |
| PSG |
| DAG |
| TMAG |
| CCAG |
| Code drafters (SRO Design Team |
| Code Bodies) |
| CCAG PM |
| Programme Participants |
| Code drafters |
| CDWG |
| SRO Design Team |
| Code Bodies |
| Ofgem |
| Elexon resources TBC |
| LDP Programme Manager |
| SRO Client Programme Director |
| IPA |
| LDP |
| SRO |
| )) |
| ? |
| TBC |
| OOC |
| MHHSP |
| Adrian Page |
| Amy Clayton |
| Anand Kaveripatna |
| Berlinda Kugara |
| Cesar Lopes |
| Charlie Blanks |
| Chetan Ubale |
| Daniel Callender |
| Daniel Gee |
| David Hollinshead |
| Dean Bailey |
| Dominic Mooney |
| Elayaraja Jeyaraman |
| Georgi Rabotov |
| Giles Clayden |
| Helen Richardson |
| Ishti Bhatti |
| Jafer Shah |
| Jason Brogden |
| John Edmonds Bell |
| John Wiggins |
| Karthikeyan Ganesan |
| Kasimali Hajiyani |
| Kate Goodman |
| Keegan Moodley |
| Keith Clark |
| Keith Lawlor |
| kevin Davis |
| Kishore Konduru |
| Kyle Abraham |
| Mahjabeen Newaz |
| Martin Freeman |
| Matt Hall |
| Matthew Breen |
| Michael Inije |
| Michael Walton |
| Ming Li |
| Nathalia Revlien |
| Nick Sewell |
| Nigel Hunt |
| Oskar Cahill |
| Paul Pettitt |
| Rakhee Shah |
| Rebecca Farooq |
| Renu Rathor |
| Robert Short |
| Robert Topley |
| Saadia Sajjad |
| Sean Tuffy |
| Shaid Hussain |
| Sharmeen Shaikh |
| Simon Berry |
| Steve Bradford |
| Steve Weston |
| Taaran Suri |
| Waseem Mohammed |
| Zak Hussain |
| berli |
| SI Migration |
| v |
| Andrew Margan |
| Lee Cox |
| DIP SP |
| DIPS SP |
| DIPSP |
| Ian Smith |
| N/A |
| SIT Component Integration Testing 2 Preparation Complete (incl. approval of SI SIT Component Integration Test Readiness Report) |
| Nich |
| Nicola Farley |
| Warren Fulton |
| Richard Puddephatt |
| Matthew Bray |
| Programme |
| LDSOs |
| Ben Wickins |
| paul |
| LDSO |
| Simon chidwick |
| Stuart Scott |
| MHHS Programme |
| Claire Silk |
| Laura Kennedy |

## Schedule

| ID | WBS | Task | Type | Duration | Start | Finish | Complete | Remaining | Baseline start | Baseline finish | Baseline duration | Baseline 1 start | Baseline 1 finish | Total slack | Constraint | Resources | Work | Actual work | Baseline cost | Responsible | Involved | Update Version | Sched Status | RAG | Task Status | Text3 |
| --- | --- | --- | --- | --- | --- | --- | --- | --- | --- | --- | --- | --- | --- | --- | --- | --- | --- | --- | --- | --- | --- | --- | --- | --- | --- | --- |
| 1 | 1 | **PROGRAMME PLAN** |  | 1195d | 2022-10-31 A | 2027-05-28 | 46% | 640.45d | 2022-10-31 | 2027-05-28 | 1195d |  |  | 0d |  | N/A | 1171946h | 473082h | -0 | N/A | N/A | 5.0 |  |  |  |  |
| 2 | 1.1 | MHHS Programme Start | milestone | 0d | 2022-10-31 A | 2022-10-31 A | 100% |  | 2022-10-31 | 2022-10-31 | 0d |  |  |  |  | N/A |  |  |  | N/A | N/A | 5.7 | Complete | COMPLETE |  |  |
| 3 | 1.2 | **PROGRAMME MANAGEMENT** |  | 1089d | 2022-10-31 A | 2026-12-31 | 40% | 658.73d | 2022-10-31 | 2026-12-31 | 1089d | 2022-10-31 | 2026-12-31 | 106d |  | N/A | 247224h | 94896.8h |  | N/A | N/A | 5.0 |  |  |  |  |
| 4 | 1.2.1 | **Programme Management** |  | 1089d | 2022-10-31 A | 2026-12-31 | 39% | 666d | 2022-10-31 | 2026-12-31 | 1089d | 2022-10-31 | 2026-12-31 | 106d |  | N/A | 60984h | 23688h |  | N/A | N/A | 5.0 |  |  | M10 |  |
| 5 | 1.2.1.1 | Sprint-based prioritisation planning and execution |  | 1089d | 2022-10-31 A | 2026-12-31 | 39% | 666d | 2022-10-31 | 2026-12-31 | 1089d | 2022-10-31 | 2026-12-31 | 106d | finish no earlier than 2026-12-31 | N/A | 8712h | 3384h |  | PMO | CPT | 5.0 | Green | GREEN |  |  |
| 6 | 1.2.1.2 | Programme governance secretariat |  | 1089d | 2022-10-31 A | 2026-12-31 | 39% | 666d | 2022-10-31 | 2026-12-31 | 1089d | 2022-10-31 | 2026-12-31 | 106d |  | N/A | 8712h | 3384h |  | PMO | CPT | 5.0 | Green | GREEN |  |  |
| 7 | 1.2.1.3 | RAID management and reporting |  | 1089d | 2022-10-31 A | 2026-12-31 | 39% | 666d | 2022-10-31 | 2026-12-31 | 1089d | 2022-10-31 | 2026-12-31 | 106d |  | N/A | 8712h | 3384h |  | PMO | CPT | 5.0 | Green | GREEN |  |  |
| 8 | 1.2.1.4 | Tracking against Programme outcomes and KPIs |  | 1089d | 2022-10-31 A | 2026-12-31 | 39% | 666d | 2022-10-31 | 2026-12-31 | 1089d | 2022-10-31 | 2026-12-31 | 106d |  | N/A | 8712h | 3384h |  | PMO | CPT | 5.0 | Green | GREEN |  |  |
| 9 | 1.2.1.5 | Change control and reporting |  | 1089d | 2022-10-31 A | 2026-12-31 | 39% | 666d | 2022-10-31 | 2026-12-31 | 1089d | 2022-10-31 | 2026-12-31 | 106d |  | N/A | 8712h | 3384h |  | PMO | CPT | 5.0 | Green | GREEN |  |  |
| 10 | 1.2.1.6 | Ongoing identification of lessons learned relating to the PMO and implementation of improvements |  | 1089d | 2022-10-31 A | 2026-12-31 | 39% | 666d | 2022-10-31 | 2026-12-31 | 1089d | 2022-10-31 | 2026-12-31 | 106d |  | N/A | 8712h | 3384h |  | PMO | CPT | 5.0 | Green | GREEN |  |  |
| 11 | 1.2.2 | **Programme Internal Assurance Reviews** |  | 1089d | 2022-10-31 A | 2026-12-31 | 39% | 666d | 2022-10-31 | 2026-12-31 | 1089d | 2022-10-31 | 2026-12-31 | 106d |  | N/A | 17424h | 6768h |  | N/A | N/A | 5.0 |  |  | M9 | D18A - Quarterly Assurance Report |
| 12 | 1.2.2.1 | Programme Internal Assurance Reviews |  | 1089d | 2022-10-31 A | 2026-12-31 | 39% | 666d | 2022-10-31 | 2026-12-31 | 1089d | 2022-10-31 | 2026-12-31 | 106d |  | N/A | 8712h | 3384h |  | CPT | PMO | 5.0 | Green | GREEN |  | D18A - Quarterly Assurance Report |
| 13 | 1.2.3 | **Engagement with PPs** |  | 1089d | 2022-10-31 A | 2026-12-31 | 39% | 665.9d | 2022-10-31 | 2026-12-31 | 1089d | 2022-10-31 | 2026-12-31 | 106d |  | N/A | 95808h | 37224.8h |  | N/A | N/A | 5.0 |  |  | M5,M6 |  |
| 14 | 1.2.3.1 | Ongoing PP liaison activities |  | 1089d | 2022-10-31 A | 2026-12-31 | 39% | 666d | 2022-10-31 | 2026-12-31 | 1089d | 2022-10-31 | 2026-12-31 | 106d |  | N/A | 8712h | 3384h |  | PPC | CPT | 5.0 | Green | GREEN |  |  |
| 15 | 1.2.3.2 | Milestone and Control Point objective setting |  | 1089d | 2022-10-31 A | 2026-12-31 | 39% | 666d | 2022-10-31 | 2026-12-31 | 1089d | 2022-10-31 | 2026-12-31 | 106d |  | N/A | 8712h | 3384h |  | PPC | CPT | 5.0 | Green | GREEN |  |  |
| 16 | 1.2.3.3 | Reporting |  | 1089d | 2022-10-31 A | 2026-12-31 | 39% | 666d | 2022-10-31 | 2026-12-31 | 1089d | 2022-10-31 | 2026-12-31 | 106d |  | N/A | 8712h | 3384h |  | PPC |  | 5.0 | Green | GREEN |  |  |
| 17 | 1.2.3.4 | **PP Engagement Events** |  | 1089d | 2022-10-31 A | 2026-12-31 | 39% | 666d | 2022-10-31 | 2026-12-31 | 1089d | 2022-10-31 | 2026-12-31 | 106d |  | N/A | 34848h | 13536h |  | N/A | N/A | 5.0 |  |  |  |  |
| 18 | 1.2.3.4.1 | Bilateral meetings |  | 1089d | 2022-10-31 A | 2026-12-31 | 39% | 666d | 2022-10-31 | 2026-12-31 | 1089d | 2022-10-31 | 2026-12-31 | 106d |  | N/A | 8712h | 3384h |  | PPC | CPT | 5.0 | Green | GREEN |  |  |
| 19 | 1.2.3.4.2 | Monthly webinars |  | 1089d | 2022-10-31 A | 2026-12-31 | 39% | 666d | 2022-10-31 | 2026-12-31 | 1089d | 2022-10-31 | 2026-12-31 | 106d |  | N/A | 8712h | 3384h |  | PPC | CPT | 5.0 | Green | GREEN |  |  |
| 20 | 1.2.3.4.3 | Open days |  | 1089d | 2022-10-31 A | 2026-12-31 | 39% | 666d | 2022-10-31 | 2026-12-31 | 1089d | 2022-10-31 | 2026-12-31 | 106d |  | N/A | 8712h | 3384h |  | PPC | CPT | 5.0 | Green | GREEN |  |  |
| 21 | 1.2.3.5 | **PP Communications** |  | 1088d | 2022-10-31 A | 2026-12-30 | 39% | 665d | 2022-10-31 | 2026-12-30 | 1088d | 2022-10-31 | 2026-12-30 | 107d |  | N/A | 26112h | 10152h |  | N/A | N/A | 5.0 |  |  |  |  |
| 22 | 1.2.3.5.1 | The Clock updates (weekly) |  | 1088d | 2022-10-31 A | 2026-12-30 | 39% | 665d | 2022-10-31 | 2026-12-30 | 1088d | 2022-10-31 | 2026-12-30 | 107d |  | N/A | 8704h | 3384h |  | PPC |  | 5.0 | Green | GREEN |  |  |
| 23 | 1.2.3.5.2 | Maintain and update content on public-facing Portal (and ongoing feedback reviews to identify and implement Portal improvements) |  | 1088d | 2022-10-31 A | 2026-12-30 | 39% | 665d | 2022-10-31 | 2026-12-30 | 1088d | 2022-10-31 | 2026-12-30 | 107d |  | N/A | 8704h | 3384h |  | PPC |  | 5.0 | Green | GREEN |  |  |
| 24 | 1.2.4 | **Code Change Support / Other Programme Alignment** |  | 1089d | 2022-10-31 A | 2026-12-31 | 39% | 666d | 2022-10-31 | 2026-12-31 | 1089d | 2022-10-31 | 2026-12-31 | 106d |  | N/A | 60984h | 23688h |  | N/A | N/A | 5.0 |  |  | M6 | D17 - Code Change Report & Recommendations |
| 25 | 1.2.4.1 | Support DCC/BEIS on SEC change |  | 1089d | 2022-10-31 A | 2026-12-31 | 39% | 666d | 2022-10-31 | 2026-12-31 | 1089d | 2022-10-31 | 2026-12-31 | 106d |  | N/A | 8712h | 3384h |  | CPT |  | 5.0 | Green | GREEN |  |  |
| 26 | 1.2.4.2 | Support on Smart Meters Act changes |  | 1089d | 2022-10-31 A | 2026-12-31 | 39% | 666d | 2022-10-31 | 2026-12-31 | 1089d | 2022-10-31 | 2026-12-31 | 106d |  | N/A | 8712h | 3384h |  | CPT |  | 5.0 | Green | GREEN |  |  |
| 27 | 1.2.4.3 | Support DCC/RECCo on CSS change |  | 1089d | 2022-10-31 A | 2026-12-31 | 39% | 666d | 2022-10-31 | 2026-12-31 | 1089d | 2022-10-31 | 2026-12-31 | 106d |  | N/A | 8712h | 3384h |  | CPT |  | 5.0 | Green | GREEN |  |  |
| 28 | 1.2.4.4 | Support Elexon on BSC change |  | 1089d | 2022-10-31 A | 2026-12-31 | 39% | 666d | 2022-10-31 | 2026-12-31 | 1089d | 2022-10-31 | 2026-12-31 | 106d |  | N/A | 8712h | 3384h |  | CPT |  | 5.0 | Green | GREEN |  |  |
| 29 | 1.2.4.5 | Support code change inside & outside CCIAG |  | 1089d | 2022-10-31 A | 2026-12-31 | 39% | 666d | 2022-10-31 | 2026-12-31 | 1089d | 2022-10-31 | 2026-12-31 | 106d |  | N/A | 8712h | 3384h |  | CPT |  | 5.0 | Green | GREEN |  |  |
| 30 | 1.2.4.6 | Support code change inside & outside CCAG |  | 1089d | 2022-10-31 A | 2026-12-31 | 39% | 666d | 2022-10-31 | 2026-12-31 | 1089d | 2022-10-31 | 2026-12-31 | 106d |  | N/A | 8712h | 3384h |  | CPT |  | 5.0 | Green | GREEN |  |  |

| ID | WBS | Task | Type | Duration | Start | Finish | Predecessors | Complete | Remaining | Baseline start | Baseline finish | Baseline duration | Baseline 1 start | Baseline 1 finish | Total slack | Constraint | Resources | Work | Actual work | Baseline cost | Responsible | Involved | Task Status | Update Version | Sched Status | RAG | Milestone ID | Text29 | Tier | Text3 | MHHS Programme Phase | Artefact ID |
| --- | --- | --- | --- | --- | --- | --- | --- | --- | --- | --- | --- | --- | --- | --- | --- | --- | --- | --- | --- | --- | --- | --- | --- | --- | --- | --- | --- | --- | --- | --- | --- | --- |
| 31 | 1.2.5 | **Programme Replan Baseline** |  | 163d | 2022-10-31 A | 2023-06-14 A |  | 100% |  | 2022-10-31 | 2023-06-14 | 163d | 2022-10-31 | 2023-06-14 |  |  | N/A | 3312h | 3312h |  | N/A | N/A | M5+ | 5.0 |  |  |  |  |  |  |  |  |
| 32 | 1.2.5.1 | Round 3 consultation preparation |  | 32d | 2022-10-31 A | 2022-12-13 A |  | 100% |  | 2022-10-31 | 2022-12-13 | 32d | 2022-10-31 | 2022-12-13 |  |  | N/A | 256h | 256h |  | PMO | CPT |  | 5.0 | Complete | COMPLETE |  |  |  |  |  |  |
| 33 | 1.2.5.2 | PSG decision to launch Round 3 consultation | milestone | 0d | 2022-12-07 A | 2022-12-07 A | 32FS-5d | 100% |  | 2022-12-07 | 2022-12-07 | 0d | 2022-12-07 | 2022-12-07 |  |  | N/A |  |  |  | PMO | PPC |  | 5.0 | Complete | COMPLETE |  |  |  |  |  |  |
| 34 | 1.2.5.3 | Round 3 consultation (incl. walkthroughs and Q&A) |  | 35d | 2022-12-14 A | 2023-01-31 A | 33FS+5d | 100% |  | 2022-12-14 | 2023-01-31 | 35d | 2022-12-14 | 2023-01-31 |  |  | N/A | 280h | 280h |  | PP | PMO, PPC,IPA |  | 5.0 | Complete | COMPLETE |  |  |  |  |  |  |
| 35 | 1.2.5.4 | Review and uplift of foundational testing documents to align with replan approach |  | 92d | 2022-12-14 A | 2023-04-20 A | 34SS | 100% |  | 2022-12-14 | 2023-04-20 | 92d | 2022-12-14 | 2023-04-20 |  |  | N/A | 736h | 736h |  | SI Test | CPT |  | 5.0 | Complete | COMPLETE |  |  |  |  |  |  |
| 36 | 1.2.5.5 | Round 3 consultation responses analysis (incl. identification of SIT volunteers) |  | 10d | 2023-02-01 A | 2023-02-14 A | 34 | 100% |  | 2023-02-01 | 2023-02-14 | 10d | 2023-02-01 | 2023-02-14 |  |  | N/A | 80h | 80h |  | PMO | CPT |  | 5.0 | Complete | COMPLETE |  |  |  |  |  |  |
| 37 | 1.2.5.6 | Replan re-drafting and supporting artefact updates (incl. engagement with Ofgem) |  | 26d | 2023-02-15 A | 2023-03-22 A | 36 | 100% |  | 2023-02-15 | 2023-03-22 | 26d | 2023-02-15 | 2023-03-22 |  |  | N/A | 208h | 208h |  | PMO | CPT,IPA,Ofgem |  | 5.0 | Complete | COMPLETE |  |  |  |  |  |  |
| 38 | 1.2.5.7 | Draft Replan Change Request |  | 31d | 2023-02-15 A | 2023-03-29 A | 36 | 100% |  | 2023-02-15 | 2023-03-29 | 31d | 2023-02-15 | 2023-03-29 |  |  | N/A | 248h | 248h |  | PMO | CPT |  | 5.0 | Complete | COMPLETE |  |  |  |  |  |  |
| 39 | 1.2.5.8 | PSG decision to issue CR for industry impact assessment | milestone | 0d | 2023-04-05 A | 2023-04-05 A | 38FS+5d | 100% |  | 2023-04-05 | 2023-04-05 | 0d | 2023-04-05 | 2023-04-05 |  |  | N/A |  |  |  | PMO | CPT |  | 5.0 | Complete | COMPLETE |  |  |  |  |  |  |
| 40 | 1.2.5.9 | Industry impact assessment |  | 10d | 2023-04-06 A | 2023-04-19 A | 39 | 100% |  | 2023-04-06 | 2023-04-19 | 10d | 2023-04-06 | 2023-04-19 |  |  | N/A | 80h | 80h |  | PP | PMO,PPC |  | 5.0 | Complete | COMPLETE |  |  |  |  |  |  |
| 41 | 1.2.5.10 | Replan playbacks (to assist PPs in impact assessment) |  | 5d | 2023-04-11 A | 2023-04-17 A | 40SS+3d | 100% |  | 2023-04-11 | 2023-04-17 | 5d | 2023-04-11 | 2023-04-17 |  |  | N/A | 40h | 40h |  | CPT | PPC,PP |  | 5.0 | Complete | COMPLETE |  |  |  |  |  |  |
| 42 | 1.2.5.11 | Industry impact assessment responses analysis |  | 5d | 2023-04-20 A | 2023-04-26 A | 40 | 100% |  | 2023-04-20 | 2023-04-26 | 5d | 2023-04-20 | 2023-04-26 |  |  | N/A | 40h | 40h |  | PMO | CPT |  | 5.0 | Complete | COMPLETE |  |  |  |  |  |  |
| 43 | 1.2.5.12 | Extraordinary PSG decision to agree baseline recommendation | milestone | 0d | 2023-05-03 A | 2023-05-03 A | 42FS+5d | 100% |  | 2023-05-03 | 2023-05-03 | 0d | 2023-05-03 | 2023-05-03 |  |  | N/A |  |  |  | CPT | PMO,PP |  | 5.0 | Complete | COMPLETE |  |  |  |  |  |  |
| 44 | 1.2.5.13 | Plan Rebaselined (subject to Ofgem decision) | milestone | 0d | 2023-06-08 A | 2023-06-08 A | 43FS+25d | 100% |  | 2023-06-08 | 2023-06-08 | 0d? | 2023-06-07 | 2023-06-07 |  | start no earlier than 2023-06-08 | N/A |  |  | -0 | CPT | PMO,PP |  | 5.0 | Complete | COMPLETE | T1-PM-1000 | PSG | T1 |  |  |  |
| 45 | 1.2.5.14 | Programme Replan playbacks and drop-in sessions |  | 5d | 2023-06-08 A | 2023-06-14 A | 44 | 100% |  | 2023-06-08 | 2023-06-14 | 5d | 2023-06-08 | 2023-06-14 |  |  | N/A | 40h | 40h |  | PMO | PPC, PP |  | 5.0 | Complete | COMPLETE |  |  |  |  |  |  |
| 46 | 1.3 | **DESIGN, BUILD & TEST (PIT)** |  | 1101d | 2022-10-31 A | 2027-01-18 |  | 79% | 231.41d | 2022-10-31 | 2027-01-18 | 1101d | 2022-10-31 | 2027-01-18 | 94d |  | N/A | 220216h | 129000h | -0 | N/A | N/A |  |  |  |  |  |  |  | 1 May 2022 - 31 Jul 2023 | Design, Build & Test (PIT) |  |
| 47 | 1.3.1 | **Design Baseline & Enduring PP Support** |  | 1101d | 2022-10-31 A | 2027-01-18 |  | 71% | 319.69d | 2022-10-31 | 2027-01-18 | 1101d | 2022-10-31 | 2027-01-18 | 94d |  | N/A | 45872h | 23112h | -0 | N/A | N/A |  | 5.0 |  |  |  |  |  |  | Design, Build & Test (PIT) |  |
| 48 | 1.3.1.1 | Physical design baselined (M5) | milestone | 0d | 2022-10-31 A | 2022-10-31 A |  | 100% |  | 2022-10-31 | 2022-10-31 | 0d | 2022-10-31 | 2022-10-31 |  |  | Paul Pettitt |  |  |  | SRO Design | SI Design,PP,IPA |  | 5.0 | Complete | COMPLETE | T1-DB-1000 | PSG | T1 |  | Design, Build & Test (PIT) | MHHS-ART001 |
| 49 | 1.3.1.2 | **M5 Design Work-Off Plan Implementation & Approval** |  | 79d | 2022-10-31 A | 2023-02-16 A |  | 100% |  | 2022-10-31 | 2023-02-16 | 79d | 2022-10-31 | 2023-02-16 |  |  | N/A | 1224h | 1224h |  | N/A | N/A |  | 5.0 |  |  |  |  |  |  | Design, Build & Test (PIT) |  |
| 50 | 1.3.1.2.1 | Implementation of M5 design Work-Off Plan |  | 74d | 2022-10-31 A | 2023-02-09 A | 48 | 100% |  | 2022-10-31 | 2023-02-09 | 74d | 2022-10-31 | 2023-02-09 |  |  | Paul Pettitt | 592h | 592h |  | SI Design | PP |  | 5.0 | Complete | COMPLETE |  |  |  |  | Design, Build & Test (PIT) |  |
| 51 | 1.3.1.2.2 | M5 design Work-Off Plan completion approved | milestone | 0d | 2023-02-16 A | 2023-02-16 A | 50FS+5d | 100% |  | 2023-02-16 | 2023-02-16 | 0d | 2023-02-16 | 2023-02-16 |  |  | Paul Pettitt |  |  |  | SI Design | PP |  | 5.0 | Complete | COMPLETE | T3-DB-0014 | DAG | T3 |  | Design, Build & Test (PIT) |  |
| 52 | 1.3.1.3 | **Enduring PP Design Support** |  | 1089d | 2022-10-31 A | 2026-12-31 A |  | 100% |  | 2022-10-31 | 2026-12-31 | 1089d | 2022-10-31 | 2026-12-31 |  |  | N/A | 18344h | 18344h |  | N/A | N/A |  | 5.0 |  |  |  |  |  |  | Design, Build & Test (PIT) |  |
| 53 | 1.3.1.3.1 | Design playbacks and drop-in sessions |  | 45d | 2022-10-31 A | 2022-12-30 A | 48 | 100% |  | 2022-10-31 | 2022-12-30 | 45d | 2022-10-31 | 2022-12-30 |  |  | Paul Pettitt | 360h | 360h |  | SI Design | PMO,PPC, SRO Design |  | 5.0 | Complete | COMPLETE |  |  |  |  | Design, Build & Test (PIT) |  |
| 54 | 1.3.1.3.2 | Support participants on E2E MHHS Design |  | 1089d | 2022-10-31 A | 2026-12-31 A | 48 | 100% |  | 2022-10-31 | 2026-12-31 | 1089d | 2022-10-31 | 2026-12-31 |  |  | Paul Pettitt | 8712h | 8712h |  | SI Design | PP |  | 5.0 | Complete | COMPLETE |  |  |  |  | Design, Build & Test (PIT) |  |
| 55 | 1.3.1.3.3 | DIP Onboarding Support |  | 70d | 2022-11-14 A | 2023-02-17 A |  | 100% |  | 2022-11-14 | 2023-02-17 | 70d | 2022-11-14 | 2023-02-17 |  | must start on 2022-11-14 | Paul Pettitt | 560h | 560h |  | SI Design | SRO Design |  | 5.0 | Complete | COMPLETE |  |  |  |  | Design, Build & Test (PIT) |  |
| 56 | 1.3.1.3.4 | iServer Launch | milestone | 0d | 2023-02-16 A | 2023-02-16 A | 51 | 100% |  | 2023-02-16 | 2023-02-16 | 0d | 2023-02-16 | 2023-02-16 |  |  | Paul Pettitt |  |  |  | SI Design | PP |  | 5.0 | Complete | COMPLETE |  |  |  |  | Design, Build & Test (PIT) |  |

| ID | WBS | Task | Type | Duration | Start | Finish | Predecessors | Complete | Remaining | Baseline start | Baseline finish | Baseline duration | Baseline 1 start | Baseline 1 finish | Total slack | Constraint | Resources | Work | Actual work | Baseline cost | Responsible | Involved | Update Version | MHHS Programme Phase | Sched Status | RAG | Milestone ID | Text29 | Tier |
| --- | --- | --- | --- | --- | --- | --- | --- | --- | --- | --- | --- | --- | --- | --- | --- | --- | --- | --- | --- | --- | --- | --- | --- | --- | --- | --- | --- | --- | --- |
| 57 | 1.3.1.4 | **Establish Design Change Management Processes** |  | 1101d | 2022-10-31 A | 2027-01-18 |  | 36% | 706.22d | 2022-10-31 | 2027-01-18 | 1101d | 2022-10-31 | 2027-01-18 | 94d |  | N/A | 17264h | 3312h |  | N/A | N/A | 5.0 | Design, Build & Test (PIT) |  |  |  |  |  |
| 58 | 1.3.1.4.1 | Internal review of internal change management processes |  | 35d | 2022-10-31 A | 2022-12-16 A |  | 100% |  | 2022-10-31 | 2022-12-16 | 35d | 2022-10-31 | 2022-12-16 |  |  | Paul Pettitt | 280h | 280h |  | SRO | SI Design | 5.0 | Design, Build & Test (PIT) | Complete | COMPLETE |  |  |  |
| 59 | 1.3.1.4.2 | SRO approval of internal change management processes | milestone | 0d | 2022-12-16 A | 2022-12-16 A | 58FF | 100% |  | 2022-12-16 | 2022-12-16 | 0d | 2022-12-16 | 2022-12-16 |  |  | Paul Pettitt |  |  |  | SRO | SI Design | 5.0 | Design, Build & Test (PIT) | Complete | COMPLETE |  |  |  |
| 60 | 1.3.1.4.3 | Change Process Webinar | milestone | 0d | 2023-01-16 A | 2023-01-16 A |  | 100% |  | 2023-01-16 | 2023-01-16 | 0d | 2023-01-16 | 2023-01-16 |  | must start on 2023-01-16 | Paul Pettitt |  |  |  | SI Design | PP | 5.0 | Design, Build & Test (PIT) | Complete | COMPLETE |  |  |  |
| 61 | 1.3.1.4.4 | Enduring change management process approved | milestone | 0d | 2023-02-16 A | 2023-02-16 A | 51FF | 100% |  | 2023-02-16 | 2023-02-16 | 0d | 2023-02-16 | 2023-02-16 |  |  | Paul Pettitt |  |  |  | SI Design | PP | 5.0 | Design, Build & Test (PIT) | Complete | COMPLETE | T3-DB-0016 | DAG | T3 |
| 62 | 1.3.1.4.5 | Maintain E2E MHHS Design (post-M5 design change management processes operational) |  | 1022d | 2023-02-17 A | 2027-01-18 | 61 | 34% | 678d | 2023-02-17 | 2027-01-18 | 1022d | 2023-02-17 | 2027-01-18 | 94d |  | Paul Pettitt | 8176h | 2752h |  | SI Design | PP | 5.0 | Design, Build & Test (PIT) | Green | GREEN |  |  |  |
| 63 | 1.3.1.5 | **Design Authority Mobilisation** |  | 29d | 2022-12-14 A | 2023-01-23 A |  | 100% |  | 2022-12-14 | 2023-01-23 | 29d | 2022-12-14 | 2023-01-23 |  |  | N/A | 232h | 232h |  | N/A | N/A | 5.0 | Design, Build & Test (PIT) |  |  |  |  |  |
| 64 | 1.3.1.5.1 | Design Authority ToR approved | milestone | 0d | 2022-12-14 A | 2022-12-14 A |  | 100% |  | 2022-12-14 | 2022-12-14 | 0d | 2022-12-14 | 2022-12-14 |  | must start on 2022-12-14 | Paul Pettitt |  |  |  | SI Design | PP | 5.0 | Design, Build & Test (PIT) | Complete | COMPLETE | T3-DB-0010 | DAG | T3 |
| 65 | 1.3.1.5.2 | Inaugural Design Authority | milestone | 0d | 2023-01-23 A | 2023-01-23 A | 64FS+29d | 100% |  | 2023-01-23 | 2023-01-23 | 0d | 2023-01-23 | 2023-01-23 |  |  | Paul Pettitt |  |  |  | SI Design | PP | 5.0 | Design, Build & Test (PIT) | Complete | COMPLETE |  |  |  |
| 66 | 1.3.1.6 | **Network Operation Services Adaptor Procurement** |  | 0d | 2023-05-23 A | 2023-05-23 A |  | 100% |  | 2023-05-23 | 2023-05-23 | 0d | 2023-02-01 | 2025-03-14 |  |  | N/A |  |  | -0 | N/A | N/A | 5.0 | Design, Build & Test (PIT) |  |  |  |  |  |
| 67 | 1.3.1.6.1 | All SIT LDSOs have procured their adapter providers | milestone | 0d | 2023-05-23 A | 2023-05-23 A | 524SS | 100% |  | 2023-05-23 | 2023-05-23 | 0d | 2023-05-23 | 2023-05-23 |  |  | Paul Pettitt |  |  |  | SI Design | PP | 5.0 | Design, Build & Test (PIT) | Complete | COMPLETE | T3-DB-0020 | DAG | T3 |
| 68 | 1.3.2 | **PP Mobilisation** |  | 67d | 2022-10-31 A | 2023-01-31 A |  | 100% |  | 2022-10-31 | 2023-01-31 | 67d | 2022-10-31 | 2023-01-31 |  |  | N/A | 3216h | 3216h |  | N/A | N/A | 5.0 | Design, Build & Test (PIT) |  |  |  |  |  |
| 69 | 1.3.2.1 | Set up governance |  | 67d | 2022-10-31 A | 2023-01-31 A |  | 100% |  | 2022-10-31 | 2023-01-31 | 67d | 2022-10-31 | 2023-01-31 |  |  | PP | 536h | 536h |  | PP |  | 5.0 | Design, Build & Test (PIT) | Complete | COMPLETE |  |  |  |
| 70 | 1.3.2.2 | Set up reporting |  | 67d | 2022-10-31 A | 2023-01-31 A |  | 100% |  | 2022-10-31 | 2023-01-31 | 67d | 2022-10-31 | 2023-01-31 |  |  | PP | 536h | 536h |  | PP |  | 5.0 | Design, Build & Test (PIT) | Complete | COMPLETE |  |  |  |
| 71 | 1.3.2.3 | Obtain funding |  | 67d | 2022-10-31 A | 2023-01-31 A |  | 100% |  | 2022-10-31 | 2023-01-31 | 67d | 2022-10-31 | 2023-01-31 |  |  | PP | 536h | 536h |  | PP |  | 5.0 | Design, Build & Test (PIT) | Complete | COMPLETE |  |  |  |
| 72 | 1.3.2.4 | Earmark resources |  | 67d | 2022-10-31 A | 2023-01-31 A |  | 100% |  | 2022-10-31 | 2023-01-31 | 67d | 2022-10-31 | 2023-01-31 |  |  | PP | 536h | 536h |  | PP |  | 5.0 | Design, Build & Test (PIT) | Complete | COMPLETE |  |  |  |
| 73 | 1.3.2.5 | Mobilise initial team |  | 67d | 2022-10-31 A | 2023-01-31 A |  | 100% |  | 2022-10-31 | 2023-01-31 | 67d | 2022-10-31 | 2023-01-31 |  |  | PP | 536h | 536h |  | PP |  | 5.0 | Design, Build & Test (PIT) | Complete | COMPLETE |  |  |  |
| 74 | 1.3.3 | **PIT Stub Specification and Delivery** |  | 435d | 2022-10-31 A | 2024-06-28 |  | 99% | 0d | 2022-10-31 | 2024-06-21 | 430d | 2022-10-31 | 2023-05-31 | 760d |  | N/A | 12064h | 7048h | -0 | N/A | N/A | 5.0 | Design, Build & Test (PIT) |  |  |  |  |  |
| 75 | 1.3.3.1 | **DIP Simulator** |  | 108d | 2022-10-31 A | 2023-03-29 A |  | 100% |  | 2022-10-31 | 2023-03-29 | 108d | 2022-10-31 | 2023-03-29 |  |  | N/A | 3208h | 3208h |  | N/A | N/A | 5.0 | Design, Build & Test (PIT) |  |  |  |  |  |
| 76 | 1.3.3.1.1 | Build & Test |  | 95d | 2022-10-31 A | 2023-03-10 A | 48 | 100% |  | 2022-10-31 | 2023-03-10 | 95d | 2022-10-31 | 2023-03-10 |  |  | Rebecca Farooq | 760h | 760h |  | SI DevOps |  | 5.0 | Design, Build & Test (PIT) | Complete | COMPLETE |  |  |  |
| 77 | 1.3.3.1.2 | UAT |  | 85d | 2022-11-14 A | 2023-03-10 A | 76SS+10d | 100% |  | 2022-11-14 | 2023-03-10 | 85d | 2022-11-14 | 2023-03-10 |  |  | Rebecca Farooq | 680h | 680h |  | SI Test |  | 5.0 | Design, Build & Test (PIT) | Complete | COMPLETE |  |  |  |
| 78 | 1.3.3.1.3 | Beta test |  | 95d | 2022-10-31 A | 2023-03-10 A | 76SS | 100% |  | 2022-10-31 | 2023-03-10 | 95d | 2022-10-31 | 2023-03-10 |  |  | Rebecca Farooq | 760h | 760h |  | PP | SI Test | 5.0 | Design, Build & Test (PIT) | Complete | COMPLETE |  |  |  |
| 79 | 1.3.3.1.4 | Prepare for release |  | 18d | 2023-03-06 A | 2023-03-29 A | 78FS-5d | 100% |  | 2023-03-06 | 2023-03-29 | 18d | 2023-03-06 | 2023-03-29 |  |  | Rebecca Farooq | 144h | 144h |  | SI DevOps |  | 5.0 | Design, Build & Test (PIT) | Complete | COMPLETE |  |  |  |
| 80 | 1.3.3.1.5 | DIP Simulator released | milestone | 0d | 2023-03-29 A | 2023-03-29 A | 79FF | 100% |  | 2023-03-29 | 2023-03-29 | 0d | 2023-03-29 | 2023-03-29 |  | start no earlier than 2023-01-30 | Rebecca Farooq |  |  |  | SI DevOps |  | 5.0 | Design, Build & Test (PIT) | Complete | COMPLETE | T3-DB-0018 | SITAG | T3 |

| ID | WBS | Task | Type | Duration | Start | Finish | Predecessors | Complete | Remaining | Baseline start | Baseline finish | Baseline duration | Baseline 1 start | Baseline 1 finish | Total slack | Constraint | Resources | Work | Actual work | Baseline cost | Responsible | Involved | Update Version | MHHS Programme Phase | Sched Status | RAG | Milestone ID | Text29 | Tier | Task Status |
| --- | --- | --- | --- | --- | --- | --- | --- | --- | --- | --- | --- | --- | --- | --- | --- | --- | --- | --- | --- | --- | --- | --- | --- | --- | --- | --- | --- | --- | --- | --- |
| 81 | 1.3.3.2 | **DIP Simulator Uplifts** |  | 257d | 2023-07-06 A | 2024-06-28 |  | 99% | 0d | 2023-07-06 | 2024-06-21 | 252d |  |  | 760d |  | N/A | 3184h | 1344h | -0 | N/A | N/A | 5.1 | Design, Build & Test (PIT) |  |  |  |  |  |  |
| 82 | 1.3.3.2.1 | DIP Simulator uplifted to align with design releases - design/build/test |  | 27d | 2023-07-06 A | 2023-08-11 A | 118 | 100% |  | 2023-07-06 | 2023-08-11 | 27d |  |  |  |  | Rebecca Farooq | 216h | 216h |  | SI DevOps |  | 5.1 | Design, Build & Test (PIT) | Complete | COMPLETE |  |  |  |  |
| 83 | 1.3.3.2.2 | DIP Simulator uplifted to align with Interim Release 2 | milestone | 0d | 2023-08-11 A | 2023-08-11 A | 82 | 100% |  | 2023-08-11 | 2023-08-11 | 0d |  |  |  |  | Rebecca Farooq |  |  |  | SI DevOps |  | 5.1 | Design, Build & Test (PIT) | Complete | COMPLETE | T3-DB-0035 | SITAG | T3 |  |
| 84 | 1.3.3.2.3 | DIP Simulator uplifted to align with design releases - design/build/test |  | 20d | 2023-10-09 A | 2023-11-03 A | 127FS+2d | 100% |  | 2023-10-09 | 2023-11-03 | 20d |  |  |  |  | Rebecca Farooq | 160h | 160h |  | SI DevOps |  | 5.3 | Design, Build & Test (PIT) | Complete | COMPLETE |  |  |  |  |
| 85 | 1.3.3.2.4 | DIP Simulator uplifted to align with Interim Release 5 | milestone | 0d | 2023-11-03 A | 2023-11-03 A | 84 | 100% |  | 2023-11-03 | 2023-11-03 | 0d |  |  |  |  | Rebecca Farooq |  |  |  | SI DevOps |  | 5.11 | Design, Build & Test (PIT) | Complete | COMPLETE | T3-DB-0039 | SITAG | T3 |  |
| 86 | 1.3.3.2.5 | DIP Simulator uplifted to align with design releases - design/build/test |  | 37d | 2024-02-01 A | 2024-03-22 A | 135 | 100% |  | 2024-02-01 | 2024-03-22 | 37d |  |  |  |  | Matthew Bray | 296h | 296h |  | SI DevOps | PP,SRO,Testing | 5.14 | Design, Build & Test (PIT) | Complete | COMPLETE |  |  |  |  |
| 87 | 1.3.3.2.6 | DIP Simulator uplifted to align with Interim Release 7 | milestone | 0d | 2024-03-22 A | 2024-03-22 A | 86 | 100% |  | 2024-03-22 | 2024-03-22 | 0d |  |  |  |  | Matthew Bray |  |  |  | SI DevOps | PP,SRO,Testing | 5.14 | Design, Build & Test (PIT) | Complete | COMPLETE | T3-DB-0182 | SITAG | T3 |  |
| 88 | 1.3.3.2.7 | DIP Simulator uplifted to align with design releases - design/build/test |  | 57d | 2024-04-04 A | 2024-06-21 A | 139 | 100% |  | 2024-04-04 | 2024-06-21 | 57d |  |  |  |  | Matthew Bray | 456h | 456h |  | SI DevOps | PP,SRO,Testing | 5.14 | Design, Build & Test (PIT) | Complete | COMPLETE |  |  |  |  |
| 89 | 1.3.3.2.8 | DIP Simulator uplifted to align with Interim Release 8 | milestone | 0d | 2024-06-28 | 2024-06-28 | 88FS+5d |  |  | 2024-06-21 | 2024-06-21 | 0d |  |  | 760d |  | Matthew Bray |  |  |  | SI DevOps | PP,SRO,Testing | 5.27 | Design, Build & Test (PIT) | yellow | RED | T3-DB-0183 | SITAG | T3 | 1.71 |
| 90 | 1.3.3.3 | **Data Generator** |  | 130d | 2022-12-01 A | 2023-05-31 A |  | 100% |  | 2022-12-01 | 2023-05-31 | 130d | 2022-12-01 | 2023-05-31 |  |  | N/A | 2192h | 2192h |  | N/A | N/A | 5.0 | Design, Build & Test (PIT) |  |  |  |  |  |  |
| 91 | 1.3.3.3.1 | Design | manual | 15d | 2022-12-01 A | 2022-12-21 A |  | 100% |  | 2022-12-01 | 2022-12-21 | 15d | 2022-12-01 | 2022-12-21 |  |  | Rebecca Farooq | 120h | 120h |  | SI DevOps |  | 5.0 | Design, Build & Test (PIT) | Complete | COMPLETE |  |  |  |  |
| 92 | 1.3.3.3.2 | Build & Test |  | 50d | 2023-02-16 A | 2023-04-26 A | 91FS+40d | 100% |  | 2023-02-16 | 2023-04-26 | 50d | 2023-02-16 | 2023-04-26 |  |  | Rebecca Farooq | 400h | 400h |  | SI DevOps |  | 5.0 | Design, Build & Test (PIT) | Complete | COMPLETE |  |  |  |  |
| 93 | 1.3.3.3.3 | UAT |  | 10d | 2023-04-27 A | 2023-05-10 A | 92 | 100% |  | 2023-04-27 | 2023-05-10 | 10d | 2023-04-27 | 2023-05-10 |  |  | Rebecca Farooq | 80h | 80h |  | SI Test |  | 5.0 | Design, Build & Test (PIT) | Complete | COMPLETE |  |  |  |  |
| 94 | 1.3.3.3.4 | Beta test |  | 45d | 2023-03-30 A | 2023-05-31 A | 92FS-20d, 96FF | 100% |  | 2023-03-30 | 2023-05-31 | 45d | 2023-03-30 | 2023-05-31 |  |  | Rebecca Farooq | 360h | 360h |  | PP | SI Test | 5.0 | Design, Build & Test (PIT) | Complete | COMPLETE |  |  |  |  |
| 95 | 1.3.3.3.5 | Prepare for release |  | 24d | 2023-04-27 A | 2023-05-30 A | 93SS | 100% |  | 2023-04-27 | 2023-05-30 | 24d | 2023-04-27 | 2023-05-30 |  |  | Rebecca Farooq | 192h | 192h |  | SI DevOps |  | 5.0 | Design, Build & Test (PIT) | Complete | COMPLETE |  |  |  |  |
| 96 | 1.3.3.3.6 | Data Generator released | milestone | 0d | 2023-05-31 A | 2023-05-31 A | 95FS+1d | 100% |  | 2023-05-31 | 2023-05-31 | 0d | 2023-05-31 | 2023-05-31 |  |  | Rebecca Farooq |  |  |  | SI DevOps |  | 5.0 | Design, Build & Test (PIT) | Complete | COMPLETE | T3-DB-0022 | SITAG | T3 |  |
| 97 | 1.3.4 | **Design Artefact Releases** |  | 398d | 2023-02-22 A | 2024-08-30 |  | 97% | 10.7d | 2023-02-22 | 2024-08-30 | 398d | 2023-02-22 | 2023-09-29 | 5d |  | N/A | 13144h | 6609.41h | -0 | N/A | N/A | 5.0 | Design, Build & Test (PIT) |  |  |  |  |  |  |
| 98 | 1.3.4.1 | **Interim release 1** |  | 79d | 2023-02-22 A | 2023-06-12 A |  | 100% |  | 2023-02-22 | 2023-06-12 | 79d | 2023-02-22 | 2023-06-28 |  |  | N/A | 1416h | 1416h |  | N/A | N/A | 5.0 | Design, Build & Test (PIT) |  |  |  |  |  |  |
| 99 | 1.3.4.1.1 | Prioritise DINs and CR |  | 1d | 2023-02-22 A | 2023-02-22 A |  | 100% |  | 2023-02-22 | 2023-02-22 | 1d | 2023-02-22 | 2023-02-22 |  | must start on 2023-02-22 | Paul Pettitt | 8h | 8h |  | SI Design |  | 5.0 | Design, Build & Test (PIT) | Complete | COMPLETE |  |  |  |  |
| 100 | 1.3.4.1.2 | **Industry input session** |  | 7d | 2023-02-23 A | 2023-03-03 A |  | 100% |  | 2023-02-23 | 2023-03-03 | 7d | 2023-02-23 | 2023-03-03 |  |  | N/A | 96h | 96h |  | N/A | N/A | 5.0 | Design, Build & Test (PIT) |  |  |  |  |  |  |
| 101 | 1.3.4.1.2.1 | Raise a CR covering prioritized assessment cluster |  | 1d | 2023-02-23 A | 2023-02-23 A | 99 | 100% |  | 2023-02-23 | 2023-02-23 | 1d | 2023-02-23 | 2023-02-23 |  |  | Paul Pettitt | 8h | 8h |  | SI Design |  | 5.0 | Design, Build & Test (PIT) | Complete | COMPLETE |  |  |  |  |
| 102 | 1.3.4.1.2.2 | Organize Industry Input session to go through significant items to reach consensus |  | 1d | 2023-02-23 A | 2023-02-23 A | 101SS | 100% |  | 2023-02-23 | 2023-02-23 | 1d | 2023-02-23 | 2023-02-23 |  |  | Paul Pettitt; Berlinda Kugara | 16h | 16h |  | SI Design | PP | 5.0 | Design, Build & Test (PIT) | Complete | COMPLETE |  |  |  |  |
| 103 | 1.3.4.1.2.3 | Conduct Meeting |  | 1d | 2023-03-03 A | 2023-03-03 A | 102FS+5d | 100% |  | 2023-03-03 | 2023-03-03 | 1d | 2023-03-03 | 2023-03-03 |  |  | Paul Pettitt; Berlinda Kugara | 16h | 16h |  | SI Design | PP | 5.0 | Design, Build & Test (PIT) | Complete | COMPLETE |  |  |  |  |
| 104 | 1.3.4.1.3 | Update baselined artefacts |  | 10d | 2023-03-24 A | 2023-04-06 A |  | 100% |  | 2023-03-24 | 2023-04-06 | 10d | 2023-03-24 | 2023-04-06 |  |  | Paul Pettitt | 80h | 80h |  | SI Design |  | 5.0 | Design, Build & Test (PIT) | Complete | COMPLETE |  |  |  |  |

Notes:
- 85: Amber as S&E couldn't view design docs, & assess scope changes. Required workload likely more than 2 sprints (original estimate). Additional MS work & CIT testing support has stretched capacity further. Delivery could be delayed. / Action: 26/7/23 - forecast changed from 15/12/23 - 3/11/23 - Changed from Interim Release 6 to 5. Updated in milestone register
- 87: 11/12- Add new milestone to reflect confirmation of Interim Release Delivery dates. 20/12 - Approved at TMAG on 20/12
- 89: 20/6: Date missed because a decision was taken and agreed with SRO to bundle IR8 and IR8.1, meaning a later combined release date of 28/6. No PP impact as PIT for SIT Cycle 3 will be baselined against IR8.1

| ID | WBS | Task | Type | Duration | Start | Finish | Predecessors | Complete | Remaining | Baseline start | Baseline finish | Baseline duration | Baseline 1 start | Baseline 1 finish | Total slack | Constraint | Resources | Work | Actual work | Baseline cost | Responsible | Involved | Update Version | MHHS Programme Phase | Sched Status | RAG | Milestone ID | Text29 | Tier | Action |
| --- | --- | --- | --- | --- | --- | --- | --- | --- | --- | --- | --- | --- | --- | --- | --- | --- | --- | --- | --- | --- | --- | --- | --- | --- | --- | --- | --- | --- | --- | --- |
| 105 | 1.3.4.1.4 | **Participant review and impact assess changes** |  | 18d | 2023-04-14 A | 2023-05-09 A |  | 100% |  | 2023-04-14 | 2023-05-09 | 18d | 2023-04-14 | 2023-05-09 |  |  | N/A | 288h | 288h |  | N/A | N/A | 5.0 | Design, Build & Test (PIT) |  |  |  |  |  |  |
| 106 | 1.3.4.1.4.1 | Issue Redline Version of documents |  | 1d | 2023-04-14 A | 2023-04-14 A | 104FS+5d | 100% |  | 2023-04-14 | 2023-04-14 | 1d | 2023-04-14 | 2023-04-14 |  |  | Paul Pettitt | 8h | 8h |  | SI Design |  | 5.0 | Design, Build & Test (PIT) | Complete | COMPLETE |  |  |  |  |
| 107 | 1.3.4.1.4.2 | Participants provide review comments to common log |  | 17d | 2023-04-17 A | 2023-05-09 A | 106 | 100% |  | 2023-04-17 | 2023-05-09 | 17d | 2023-04-17 | 2023-05-09 |  |  | Paul Pettitt | 136h | 136h |  | PP |  | 5.0 | Design, Build & Test (PIT) | Complete | COMPLETE |  |  |  |  |
| 108 | 1.3.4.1.5 | **Assurance review** |  | 19d | 2023-05-10 A | 2023-06-05 A |  | 100% |  | 2023-05-10 | 2023-06-05 | 19d | 2023-05-10 | 2023-06-05 |  |  | N/A | 304h | 304h |  | N/A | N/A | 5.0 | Design, Build & Test (PIT) |  |  |  |  |  |  |
| 109 | 1.3.4.1.5.1 | SI Design Review and Respond to Comments |  | 5d | 2023-05-10 A | 2023-05-16 A | 107 | 100% |  | 2023-05-10 | 2023-05-16 | 5d | 2023-05-10 | 2023-05-16 |  |  | Paul Pettitt | 40h | 40h |  | SI Design |  | 5.0 | Design, Build & Test (PIT) | Complete | COMPLETE |  |  |  |  |
| 110 | 1.3.4.1.5.2 | Prep for Assurance Review Meeting |  | 7d | 2023-05-17 A | 2023-05-25 A | 109 | 100% |  | 2023-05-17 | 2023-05-25 | 7d | 2023-05-17 | 2023-05-25 |  |  | Paul Pettitt | 56h | 56h |  | SI Design |  | 5.0 | Design, Build & Test (PIT) | Complete | COMPLETE |  |  |  |  |
| 111 | 1.3.4.1.5.3 | Conduct Assurance Review Meeting |  | 1d | 2023-05-26 A | 2023-05-26 A | 110 | 100% |  | 2023-05-26 | 2023-05-26 | 1d | 2023-05-26 | 2023-05-26 |  |  | Paul Pettitt | 8h | 8h |  | SI Design |  | 5.0 | Design, Build & Test (PIT) | Complete | COMPLETE |  |  |  |  |
| 112 | 1.3.4.1.5.4 | Update Artefacts following Assurance Review |  | 6d | 2023-05-29 A | 2023-06-05 A | 111 | 100% |  | 2023-05-29 | 2023-06-05 | 6d | 2023-05-29 | 2023-06-05 |  |  | Paul Pettitt | 48h | 48h |  | SI Design |  | 5.0 | Design, Build & Test (PIT) | Complete | COMPLETE |  |  |  |  |
| 113 | 1.3.4.1.6 | PSG Approval of interim release plan |  | 1d | 2023-06-08 A | 2023-06-08 A |  | 100% |  | 2023-06-08 | 2023-06-08 | 1d |  |  |  | must start on 2023-06-08 | Paul Pettitt | 8h | 8h |  | PP | SI Design | 5.1 | Design, Build & Test (PIT) | Complete | COMPLETE |  |  |  |  |
| 114 | 1.3.4.1.7 | Publish updated baselined artefacts | milestone | 0d | 2023-06-06 A | 2023-06-12 A | 112 | 100% |  | 2023-06-06 | 2023-06-12 | 5d | 2023-06-15 | 2023-06-21 |  |  | Paul Pettitt |  |  |  | SI Design |  | 5.0 | Design, Build & Test (PIT) | Complete | COMPLETE |  |  |  |  |
| 115 | 1.3.4.1.8 | Interim release 1 Go live | milestone | 0d | 2023-06-12 A | 2023-06-12 A | 114 | 100% |  | 2023-06-12 | 2023-06-12 | 0d | 2023-06-28 | 2023-06-28 |  |  | Paul Pettitt |  |  |  | SI Design |  | 5.0 | Design, Build & Test (PIT) | Complete | COMPLETE | T3-DB-0095 | DAG | T3 |  |
| 116 | 1.3.4.2 | **Interim release 2** |  | 27d | 2023-05-30 A | 2023-07-05 A |  | 100% |  | 2023-05-30 | 2023-07-05 | 27d | 2023-05-24 | 2023-07-28 |  |  | N/A | 432h | 432h |  | N/A | N/A | 5.0 | Design, Build & Test (PIT) |  |  |  |  |  |  |
| 117 | 1.3.4.2.1 | Update baselined artefacts |  | 27d | 2023-05-30 A | 2023-07-05 A |  | 100% |  | 2023-05-30 | 2023-07-05 | 27d |  |  |  | must start on 2023-05-30 | Paul Pettitt | 216h | 216h |  | SI Design | PP | 5.1 | Design, Build & Test (PIT) | Complete | COMPLETE |  |  |  |  |
| 118 | 1.3.4.2.2 | Interim release 2 Go live | milestone | 0d | 2023-07-05 A | 2023-07-05 A | 117 | 100% |  | 2023-07-05 | 2023-07-05 | 0d | 2023-07-28 | 2023-07-28 |  |  | Paul Pettitt |  |  |  | SI Design |  | 5.0 | Design, Build & Test (PIT) | Complete | COMPLETE | T3-DB-0096 | DAG | T3 |  |
| 119 | 1.3.4.3 | **Interim release 3** |  | 35d | 2023-06-15 A | 2023-08-02 A |  | 100% |  | 2023-06-15 | 2023-08-02 | 35d | 2023-06-29 | 2023-09-29 |  |  | N/A | 560h | 560h |  | N/A | N/A | 5.0 | Design, Build & Test (PIT) |  |  |  |  |  |  |
| 120 | 1.3.4.3.1 | Update baselined artefacts |  | 35d | 2023-06-15 A | 2023-08-02 A |  | 100% |  | 2023-06-15 | 2023-08-02 | 35d |  |  |  | must start on 2023-06-15 | Paul Pettitt | 280h | 280h |  | SI Design | PP | 5.1 | Design, Build & Test (PIT) | Complete | COMPLETE |  |  |  |  |
| 121 | 1.3.4.3.2 | Interim release 3 Go live | milestone | 0d | 2023-08-02 A | 2023-08-02 A | 120 | 100% |  | 2023-08-02 | 2023-08-02 | 0d | 2023-09-29 | 2023-09-29 |  |  | Paul Pettitt |  |  |  | SI Design |  | 5.0 | Design, Build & Test (PIT) | Complete | COMPLETE | T3-DB-0097 | DAG | T3 |  |
| 122 | 1.3.4.4 | **Interim release 4** |  | 36d | 2023-07-12 A | 2023-08-30 A |  | 100% |  | 2023-07-12 | 2023-08-30 | 36d |  |  |  |  | N/A | 576h | 576h |  | N/A | N/A | 5.1 | Design, Build & Test (PIT) |  |  |  |  |  |  |
| 123 | 1.3.4.4.1 | Update baselined artefacts |  | 36d | 2023-07-12 A | 2023-08-30 A |  | 100% |  | 2023-07-12 | 2023-08-30 | 36d |  |  |  | must start on 2023-07-12 | Paul Pettitt | 288h | 288h |  | SI Design | PP | 5.1 | Design, Build & Test (PIT) | Complete | COMPLETE |  |  |  |  |
| 124 | 1.3.4.4.2 | Interim release 4 Go live | milestone | 0d | 2023-08-30 A | 2023-08-30 A | 123 | 100% |  | 2023-08-30 | 2023-08-30 | 0d |  |  |  |  | Paul Pettitt |  |  |  | SI Design |  | 5.1 | Design, Build & Test (PIT) | Complete | COMPLETE | T3-DB-0081 | DAG | T3 |  |
| 125 | 1.3.4.5 | **Interim release 5** |  | 147d | 2023-08-17 A | 2024-03-08 |  | 99% | 0d | 2023-08-17 | 2024-03-08 | 147d |  |  | 0d |  | N/A | 1536h | 632.22h | -0 | N/A | N/A | 5.1 | Design, Build & Test (PIT) |  |  |  |  |  |  |
| 126 | 1.3.4.5.1 | Update baselined artefacts |  | 35d | 2023-08-17 A | 2023-10-04 A |  | 100% |  | 2023-08-17 | 2023-10-04 | 35d |  |  |  | must start on 2023-08-17 | Paul Pettitt | 280h | 280h |  | SI Design | PP | 5.1 | Design, Build & Test (PIT) | Complete | COMPLETE |  |  |  |  |
| 127 | 1.3.4.5.2 | Interim release 5 Go live | milestone | 0d | 2023-10-04 A | 2023-10-04 A | 126 | 100% |  | 2023-10-04 | 2023-10-04 | 0d |  |  |  |  | Paul Pettitt |  |  |  | SI Design |  | 5.1 | Design, Build & Test (PIT) | Complete | COMPLETE | T3-DB-0083 | DAG | T3 | 11/8 - successor is SIT functional (starts in march) |
| 128 | 1.3.4.5.3 | Interim Release 5 Deployed to SIT |  | 10d | 2024-02-26 A | 2024-03-08 A | 127FS+102d | 100% |  | 2024-02-26 | 2024-03-08 | 10d |  |  |  |  | Lee Cox | 80h | 80h |  | SI Testing | PP | 5.16 |  | Complete | COMPLETE |  |  |  |  |

| ID | WBS | Task | Type | Duration | Start | Finish | Predecessors | Complete | Remaining | Baseline start | Baseline finish | Baseline duration | Baseline 1 start | Baseline 1 finish | Total slack | Free slack | Constraint | Resources | Work | Actual work | Baseline cost | Responsible | Involved | Update Version | MHHS Programme Phase | Sched Status | RAG | Milestone ID | Text29 | Tier | Action | Task Status |
| --- | --- | --- | --- | --- | --- | --- | --- | --- | --- | --- | --- | --- | --- | --- | --- | --- | --- | --- | --- | --- | --- | --- | --- | --- | --- | --- | --- | --- | --- | --- | --- | --- |
| 129 | 1.3.4.6 | **Interim release 6** |  | 192d | 2023-09-14 A | 2024-06-07 |  | 99% | 0d | 2023-09-14 | 2024-06-07 | 192d |  |  | 0d |  |  | N/A | 1896h | 632.22h | -0 | N/A | N/A | 5.1 | Design, Build & Test (PIT) |  |  |  |  |  |  |  |
| 130 | 1.3.4.6.1 | Update baselined artefacts |  | 35d | 2023-09-14 A | 2023-11-01 A |  | 100% |  | 2023-09-14 | 2023-10-27 | 32d |  |  |  |  | must start on 2023-09-14 | Paul Pettitt | 280h | 280h |  | SI Design | PP | 5.1 | Design, Build & Test (PIT) | Complete | COMPLETE |  |  |  |  |  |
| 131 | 1.3.4.6.2 | Interim release 6 Go live | milestone | 0d | 2023-11-01 A | 2023-11-01 A | 130 | 100% |  | 2023-10-27 | 2023-10-27 | 0d |  |  |  |  |  | Paul Pettitt |  |  |  | SI Design |  | 5.11 | Design, Build & Test (PIT) | Complete | COMPLETE | T3-DB-0085 | DAG | T3 |  |  |
| 132 | 1.3.4.6.3 | Interim Release 6 Deployed to SIT |  | 10d | 2024-05-27 A | 2024-06-07 A | 131FS+147d | 100% |  | 2024-05-27 | 2024-06-07 | 10d |  |  |  |  |  | Lee Cox | 80h | 80h |  | SI Testing | PP | 5.16 |  | Complete | COMPLETE |  |  |  |  |  |
| 133 | 1.3.4.7 | **Interim release 7** |  | 168d | 2023-10-18 A | 2024-06-07 |  | 99% | 0d | 2023-10-18 | 2024-06-07 | 168d |  |  | 0d |  |  | N/A | 2032h | 1169.66h | -0 | N/A | N/A | 5.5 | Design, Build & Test (PIT) |  |  |  |  |  |  |  |
| 134 | 1.3.4.7.1 | Update baselined artefacts |  | 76d | 2023-10-18 A | 2024-01-31 A |  | 100% |  | 2023-10-18 | 2024-01-31 | 76d |  |  |  |  | start no earlier than 2023-10-18 | Paul Pettitt | 608h | 608h |  | SI Design | PP | 5.5 | Design, Build & Test (PIT) | Complete | COMPLETE |  |  |  |  |  |
| 135 | 1.3.4.7.2 | Interim release 7 Go live | milestone | 0d | 2024-01-31 A | 2024-01-31 A | 134 | 100% |  | 2024-01-31 | 2024-01-31 | 0d |  |  |  |  |  | Paul Pettitt |  |  |  | SI Design | PP | 5.14 | Design, Build & Test (PIT) | Complete | COMPLETE | T3-DB-0098 | DAG | T3 | 4/8 - add as t3 milestones. Awaiting approval at TMAG |  |
| 136 | 1.3.4.7.3 | Interim Release 7 Deployed to SIT |  | 10d | 2024-05-27 A | 2024-06-07 A | 135FS+82d | 100% |  | 2024-05-27 | 2024-06-07 | 10d |  |  |  |  |  | Lee Cox | 80h | 80h |  | SI Testing | PP | 5.16 |  | Complete | COMPLETE |  |  |  |  |  |
| 137 | 1.3.4.8 | **Interim release 8** |  | 143d | 2024-02-14 A | 2024-08-30 |  | 78% | 31.09d | 2024-02-14 | 2024-08-30 | 143d |  |  | 5d |  |  | N/A | 1512h | 1183.31h | -0 | N/A | N/A | 5.5 | Design, Build & Test (PIT) |  |  |  |  |  |  |  |
| 138 | 1.3.4.8.1 | Update baselined artefacts |  | 36d | 2024-02-14 A | 2024-04-03 A |  | 100% |  | 2024-02-14 | 2024-04-03 | 36d |  |  |  |  | start no earlier than 2024-02-14 | Paul Pettitt | 288h | 288h |  | SI Design | PP | 5.5 | Design, Build & Test (PIT) | Complete | COMPLETE |  |  |  |  |  |
| 139 | 1.3.4.8.2 | Interim release 8 Go live | milestone | 0d | 2024-04-03 A | 2024-04-03 A | 138 | 100% |  | 2024-04-03 | 2024-04-03 | 0d |  |  |  |  | start no earlier than 2024-01-10 | Paul Pettitt |  |  |  | SI Design | PP | 5.14 | Design, Build & Test (PIT) | Complete | COMPLETE | T3-DB-0099 | DAG | T3 | 4/8 - add as t3 milestones. Awaiting approval at TMAG |  |
| 140 | 1.3.4.8.3 | Interim Release 8 Deployed to SIT |  | 10d | 2024-08-19 | 2024-08-30 | 139FS+97d |  |  | 2024-08-19 | 2024-08-30 | 10d |  |  | 5d | 0d |  | Lee Cox | 80h |  |  | SI Testing | PP | 5.16 |  | Green | GREEN |  |  |  |  | 53.33 |
| 141 | 1.3.5 | **Queries Support / Knowledgebase & Tool Roll-Out (Systems)** |  | 325d | 2023-01-03 A | 2024-04-01 |  | 99% | 0d | 2023-01-03 | 2024-04-01 | 325d | 2023-01-03 | 2024-04-01 | 0d |  |  | N/A | 11920h | 10184h |  | N/A | N/A | 5.0 | Design, Build & Test (PIT) |  |  |  |  |  |  |  |
| 142 | 1.3.5.1 | **Query Management** |  | 325d | 2023-01-03 A | 2024-04-01 A |  | 100% |  | 2023-01-03 | 2024-04-01 | 325d | 2023-01-03 | 2024-04-01 |  |  |  | N/A | 7800h | 7800h |  | N/A | N/A | 5.0 | Design, Build & Test (PIT) |  |  |  |  |  |  |  |
| 143 | 1.3.5.1.1 | Respond to Participant Queries |  | 325d | 2023-01-03 A | 2024-04-01 A |  | 100% |  | 2023-01-03 | 2024-04-01 | 325d | 2023-01-03 | 2024-04-01 |  |  | must start on 2023-01-03 | Paul Pettitt | 2600h | 2600h |  | SI Design | PP | 5.0 | Design, Build & Test (PIT) | Complete | COMPLETE |  |  |  | 11/8 - runs out to end of the programme |  |
| 144 | 1.3.5.1.2 | Respond to Programme Queries |  | 325d | 2023-01-03 A | 2024-04-01 A | 143SS | 100% |  | 2023-01-03 | 2024-04-01 | 325d | 2023-01-03 | 2024-04-01 |  |  |  | Paul Pettitt | 2600h | 2600h |  | SI Design | PP | 5.0 | Design, Build & Test (PIT) | Complete | COMPLETE |  |  |  | 11/8 - runs out to end of the programme |  |
| 145 | 1.3.5.2 | **Query Support tooling (FreshDesk)** |  | 23d | 2023-06-01 A | 2023-07-03 A |  | 100% |  | 2023-06-01 | 2023-07-03 | 23d | 2023-06-01 | 2023-07-03 |  |  |  | N/A | 368h | 368h |  | N/A | N/A | 5.0 | Design, Build & Test (PIT) |  |  |  |  |  |  |  |
| 146 | 1.3.5.2.1 | Migrate to Standalone Freshdesk |  | 10d | 2023-06-01 A | 2023-06-14 A |  | 100% |  | 2023-06-01 | 2023-06-14 | 10d | 2023-06-01 | 2023-06-14 |  |  | must start on 2023-06-01 | Paul Pettitt | 80h | 80h |  | SI Design |  | 5.0 | Design, Build & Test (PIT) | Complete | COMPLETE |  |  |  |  |  |
| 147 | 1.3.5.2.2 | Develop reporting dashboard |  | 5d | 2023-06-15 A | 2023-06-21 A | 146 | 100% |  | 2023-06-15 | 2023-06-21 | 5d | 2023-06-15 | 2023-06-21 |  |  |  | Paul Pettitt | 40h | 40h |  | SI Design |  | 5.0 | Design, Build & Test (PIT) | Complete | COMPLETE |  |  |  |  |  |
| 148 | 1.3.5.2.3 | Issue to SRO for Review |  | 5d | 2023-06-22 A | 2023-06-28 A | 147 | 100% |  | 2023-06-22 | 2023-06-28 | 5d | 2023-06-22 | 2023-06-28 |  |  |  | Paul Pettitt | 40h | 40h |  | SI Design |  | 5.0 | Design, Build & Test (PIT) | Complete | COMPLETE |  |  |  |  |  |
| 149 | 1.3.5.2.4 | Update following review |  | 2d | 2023-06-29 A | 2023-06-30 A | 148 | 100% |  | 2023-06-29 | 2023-06-30 | 2d | 2023-06-29 | 2023-06-30 |  |  |  | Paul Pettitt | 16h | 16h |  | SI Design |  | 5.0 | Design, Build & Test (PIT) | Complete | COMPLETE |  |  |  |  |  |
| 150 | 1.3.5.2.5 | Sign off |  | 1d | 2023-07-03 A | 2023-07-03 A | 149 | 100% |  | 2023-07-03 | 2023-07-03 | 1d | 2023-07-03 | 2023-07-03 |  |  |  | Paul Pettitt | 8h | 8h |  | SI Design |  | 5.0 | Design, Build & Test (PIT) | Complete | COMPLETE |  |  |  |  |  |
| 151 | 1.3.5.3 | **KnowledgeBase Development** |  | 72d | 2023-06-01 A | 2023-09-08 A |  | 100% |  | 2023-06-01 | 2023-09-08 | 72d | 2023-06-01 | 2023-09-08 |  |  |  | N/A | 1152h | 1152h |  | N/A | N/A | 5.0 | Design, Build & Test (PIT) |  |  |  |  |  |  |  |
| 152 | 1.3.5.3.1 | Define Scope of KB |  | 1d | 2023-06-01 A | 2023-06-01 A | 146SS | 100% |  | 2023-06-01 | 2023-06-01 | 1d | 2023-06-01 | 2023-06-01 |  |  |  | Paul Pettitt | 8h | 8h |  | SI Design |  | 5.0 | Design, Build & Test (PIT) | Complete | COMPLETE |  |  |  |  |  |
| 153 | 1.3.5.3.2 | Capture Existing KB artefacts |  | 20d | 2023-06-02 A | 2023-06-29 A | 152 | 100% |  | 2023-06-02 | 2023-06-29 | 20d | 2023-06-02 | 2023-06-29 |  |  |  | Paul Pettitt | 160h | 160h |  | SI Design |  | 5.0 | Design, Build & Test (PIT) | Complete | COMPLETE |  |  |  |  |  |
| 154 | 1.3.5.3.3 | Tag artefacts |  | 5d | 2023-06-30 A | 2023-07-06 A | 153 | 100% |  | 2023-06-30 | 2023-07-06 | 5d | 2023-06-30 | 2023-07-06 |  |  |  | Paul Pettitt | 40h | 40h |  | SI Design |  | 5.0 | Design, Build & Test (PIT) | Complete | COMPLETE |  |  |  |  |  |
| 155 | 1.3.5.3.4 | Develop Participant Interfaces |  | 20d | 2023-07-07 A | 2023-08-03 A | 154 | 100% |  | 2023-07-07 | 2023-08-03 | 20d | 2023-07-07 | 2023-08-03 |  |  |  | Paul Pettitt | 160h | 160h |  | SI Design |  | 5.0 | Design, Build & Test (PIT) | Complete | COMPLETE |  |  |  |  |  |
| 156 | 1.3.5.3.5 | Promote to Collaboration Portal |  | 21d | 2023-08-04 A | 2023-09-01 A | 155 | 100% |  | 2023-08-04 | 2023-09-01 | 21d | 2023-08-04 | 2023-09-01 |  |  |  | Paul Pettitt | 168h | 168h |  | SI Design |  | 5.0 | Design, Build & Test (PIT) | Complete | COMPLETE |  |  |  |  |  |
| 157 | 1.3.5.3.6 | Link into FreshDesk |  | 5d | 2023-09-04 A | 2023-09-08 A | 156 | 100% |  | 2023-09-04 | 2023-09-08 | 5d | 2023-09-04 | 2023-09-08 |  |  |  | Paul Pettitt | 40h | 40h |  | SI Design |  | 5.0 | Design, Build & Test (PIT) | Complete | COMPLETE |  |  |  |  |  |

Notes:
- 134: 4/8 - Added in as per PPs advice
- 135: 27/11- Red because forecast date has changed to align with Testing Release Management. Discussed with no objections at FTIG on 23/11. To be taken to Dec DAG for noting
- 138: 4/8 - Added in as per PPs advice
- 139: 27/11- Amber because forecast date has changed to align with Testing Release Management. Discussed with no objections at FTIG on 23/11. To be taken to Dec DAG for noting

| ID | WBS | Task | Type | Duration | Start | Finish | Predecessors | Complete | Remaining | Baseline start | Baseline finish | Baseline duration | Baseline 1 start | Baseline 1 finish | Total slack | Resources | Work | Actual work | Baseline cost | Responsible | Involved | Update Version | MHHS Programme Phase | Sched Status | RAG | Task Status | Milestone ID | Text29 | Tier |
| --- | --- | --- | --- | --- | --- | --- | --- | --- | --- | --- | --- | --- | --- | --- | --- | --- | --- | --- | --- | --- | --- | --- | --- | --- | --- | --- | --- | --- | --- |
| 158 | 1.3.6 | **PP Design, Build & Test (DBT)** |  | 495d | 2022-10-31 A | 2024-09-20 |  | 94% | 31.27d | 2022-10-31 | 2024-09-20 | 495d | 2022-10-31 | 2026-02-16 | 3d | N/A | 63280h | 51868.4h | -0 | N/A | N/A | 5.0 | Design, Build & Test (PIT) |  |  |  |  |  |  |
| 159 | 1.3.6.1 | **PP Impact Assessment, Planning & Procurement** |  | 110d | 2022-10-31 A | 2023-03-31 A |  | 100% |  | 2022-10-31 | 2023-03-31 | 110d | 2022-10-31 | 2023-03-31 |  | N/A | 6040h | 6040h |  | N/A | N/A | 5.0 | Design, Build & Test (PIT) |  |  |  |  |  |  |
| 160 | 1.3.6.1.1 | **PP Impact Assessment** |  | 67d | 2022-10-31 A | 2023-01-31 A |  | 100% |  | 2022-10-31 | 2023-01-31 | 67d | 2022-10-31 | 2023-01-31 |  | N/A | 1608h | 1608h |  | N/A | N/A | 5.0 | Design, Build & Test (PIT) |  |  |  |  |  |  |
| 161 | 1.3.6.1.1.1 | Develop heatmap for impact of MHHS |  | 67d | 2022-10-31 A | 2023-01-31 A | 48 | 100% |  | 2022-10-31 | 2023-01-31 | 67d | 2022-10-31 | 2023-01-31 |  | PP | 536h | 536h |  | PP |  | 5.0 | Design, Build & Test (PIT) | Complete | COMPLETE |  |  |  |  |
| 162 | 1.3.6.1.1.2 | Develop detailed impact assessment |  | 67d | 2022-10-31 A | 2023-01-31 A | 48 | 100% |  | 2022-10-31 | 2023-01-31 | 67d | 2022-10-31 | 2023-01-31 |  | PP | 536h | 536h |  | PP |  | 5.0 | Design, Build & Test (PIT) | Complete | COMPLETE |  |  |  |  |
| 163 | 1.3.6.1.2 | **PP Planning** |  | 67d | 2022-10-31 A | 2023-01-31 A |  | 100% |  | 2022-10-31 | 2023-01-31 | 67d | 2022-10-31 | 2023-01-31 |  | N/A | 1792h | 1792h |  | N/A | N/A | 5.0 | Design, Build & Test (PIT) |  |  |  |  |  |  |
| 164 | 1.3.6.1.2.1 | Develop detailed short-term plan |  | 23d | 2022-10-31 A | 2022-11-30 A | 48 | 100% |  | 2022-10-31 | 2022-11-30 | 23d | 2022-10-31 | 2022-11-30 |  | PP | 184h | 184h |  | PP |  | 5.0 | Design, Build & Test (PIT) | Complete | COMPLETE |  |  |  |  |
| 165 | 1.3.6.1.2.2 | Develop overall project plan for implementation |  | 67d | 2022-10-31 A | 2023-01-31 A | 48 | 100% |  | 2022-10-31 | 2023-01-31 | 67d | 2022-10-31 | 2023-01-31 |  | PP | 536h | 536h |  | PP |  | 5.0 | Design, Build & Test (PIT) | Complete | COMPLETE |  |  |  |  |
| 166 | 1.3.6.1.2.3 | Develop procurement plan |  | 67d | 2022-10-31 A | 2023-01-31 A | 48 | 100% |  | 2022-10-31 | 2023-01-31 | 67d | 2022-10-31 | 2023-01-31 |  | PP | 536h | 536h |  | PP |  | 5.0 | Design, Build & Test (PIT) | Complete | COMPLETE |  |  |  |  |
| 167 | 1.3.6.1.3 | **PP Software/Service Procurement** |  | 110d | 2022-10-31 A | 2023-03-31 A |  | 100% |  | 2022-10-31 | 2023-03-31 | 110d | 2022-10-31 | 2023-03-31 |  | N/A | 1760h | 1760h |  | N/A | N/A | 5.0 | Design, Build & Test (PIT) |  |  |  |  |  |  |
| 168 | 1.3.6.1.3.1 | Run tender process |  | 67d | 2022-10-31 A | 2023-01-31 A | 48 | 100% |  | 2022-10-31 | 2023-01-31 | 67d | 2022-10-31 | 2023-01-31 |  | PP | 536h | 536h |  | PP |  | 5.0 | Design, Build & Test (PIT) | Complete | COMPLETE |  |  |  |  |
| 169 | 1.3.6.1.3.2 | Select provider & sign commercials |  | 43d | 2023-02-01 A | 2023-03-31 A | 168 | 100% |  | 2023-02-01 | 2023-03-31 | 43d | 2023-02-01 | 2023-03-31 |  | PP | 344h | 344h |  | PP |  | 5.0 | Design, Build & Test (PIT) | Complete | COMPLETE |  |  |  |  |
| 170 | 1.3.6.2 | **Central Systems DBT** |  | 325d | 2022-10-31 A | 2024-01-26 A |  | 100% |  | 2022-10-31 | 2024-02-23 | 345d | 2022-10-31 | 2024-05-13 |  | N/A | 27448h | 27448h | -0 | N/A | N/A | 5.0 | Design, Build & Test (PIT) |  |  | -316.67 |  |  |  |
| 171 | 1.3.6.2.1 | **Elexon Central Systems DBT CIT (Entering at Interval 1)** |  | 248d | 2022-10-31 A | 2023-10-11 A |  | 100% |  | 2022-10-31 | 2023-10-12 | 249d | 2022-10-31 | 2023-09-29 |  | N/A | 10552h | 10552h | -0 | N/A | N/A | 5.0 | Design, Build & Test (PIT) |  |  |  |  |  |  |
| 172 | 1.3.6.2.1.1 | **Design and Build** |  | 235d | 2022-10-31 A | 2023-09-22 A |  | 100% |  | 2022-10-31 | 2023-09-29 | 240d | 2022-10-31 | 2023-09-29 |  | N/A | 3760h | 3760h |  | N/A | N/A | 5.0 | Design, Build & Test (PIT) |  |  | -259.67 |  |  |  |
| 173 | 1.3.6.2.1.1.1 | Helix Design and Build |  | 235d | 2022-10-31 A | 2023-09-22 A | 2 | 100% |  | 2022-10-31 | 2023-09-29 | 240d | 2022-10-31 | 2023-09-29 |  | Lee Cox | 1880h | 1880h |  | PP | SI Test | 5.0 | Design, Build & Test (PIT) | Complete | COMPLETE |  |  |  |  |
| 174 | 1.3.6.2.1.2 | **Test Approach & Plan** |  | 235d | 2022-10-31 A | 2023-09-22 A |  | 100% |  | 2022-10-31 | 2023-09-22 | 235d | 2022-10-31 | 2023-07-21 |  | N/A | 3320h | 3320h | -0 | N/A | N/A | 5.0 | Design, Build & Test (PIT) |  |  |  |  |  |  |
| 175 | 1.3.6.2.1.2.1 | Develop Test Approach & Plan |  | 180d | 2022-10-31 A | 2023-07-07 A |  | 100% |  | 2022-10-31 | 2023-07-07 | 180d | 2022-10-31 | 2023-07-07 |  | Lee Cox | 1440h | 1440h |  | PP | SI Test | 5.0 | Design, Build & Test (PIT) | Complete | COMPLETE |  |  |  |  |
| 176 | 1.3.6.2.1.2.2 | Elexon Central Systems Test Approach & Plan (PIT) submitted to Programme for assurance | milestone | 0d | 2023-07-13 A | 2023-07-13 A | 175FF+4d | 100% |  | 2023-07-13 | 2023-07-13 | 0d | 2023-07-07 | 2023-07-07 |  | Lee Cox |  |  |  | PP | SI Test | 5.0 | Design, Build & Test (PIT) | Complete | COMPLETE |  | T3-DB-0029 | SITAG | T3 |
| 177 | 1.3.6.2.1.2.3 | Elexon Central Systems Test Approach & Plan (PIT) V2 resubmitted to Programme for assurance | milestone, manual | 0d | 2023-07-27 A | 2023-07-27 A | 176FS+9d | 100% |  | 2023-07-27 | 2023-07-27 | 0d |  |  |  | Lee Cox |  |  |  | PP | SI Test | 5.4 | Design, Build & Test (PIT) | Complete | COMPLETE |  |  |  |  |
| 178 | 1.3.6.2.1.2.4 | Elexon Central Systems Test Approach & Plan (PIT) V3 resubmitted to Programme for assurance | milestone | 0d | 2023-08-18 A | 2023-08-18 A | 177FS+17d | 100% |  | 2023-08-18 | 2023-08-18 | 0d |  |  |  | Lee Cox |  |  |  | PP | SI Test | 5.4 | Design, Build & Test (PIT) | Complete | COMPLETE |  |  |  |  |
| 179 | 1.3.6.2.1.2.5 | Elexon Central Systems Test approach and plan MHHS Review Completed | milestone | 0d | 2023-09-22 A | 2023-09-22 A | 178FS+25d | 100% |  | 2023-09-22 | 2023-09-22 | 0d | 2023-07-10 | 2023-07-21 |  | Lee Cox |  |  |  | SI Test | PP | 5.8 | Design, Build & Test (PIT) | Complete | COMPLETE |  | T3-DB-0106 | SITAG | T3 |
| 180 | 1.3.6.2.1.3 | **Test Readiness Report** |  | 16d | 2023-07-28 A | 2023-08-18 A |  | 100% |  | 2023-08-03 | 2023-10-12 | 51d | 2023-07-21 | 2023-09-29 |  | N/A | 256h | 256h |  | N/A | N/A | 5.0 | Design, Build & Test (PIT) |  |  |  |  |  |  |
| 181 | 1.3.6.2.1.3.1 | Test readiness reporting |  | 16d | 2023-07-28 A | 2023-08-18 A | 176FS+10d | 100% |  | 2023-08-03 | 2023-10-12 | 51d | 2023-07-21 | 2023-09-29 |  | Lee Cox | 128h | 128h |  | PP | 109 | 5.0 | Design, Build & Test (PIT) | Complete | COMPLETE |  |  |  |  |

Notes:
- 179: 1/9 - to be raised as new T3 at TMAG. Approved at TMAG on 20/9

| ID | WBS | Task | Type | Duration | Start | Finish | Predecessors | Complete | Baseline start | Baseline finish | Baseline duration | Baseline 1 start | Baseline 1 finish | Constraint | Resources | Work | Actual work | Baseline cost | Responsible | Involved | Update Version | MHHS Programme Phase | Artefact ID | Sched Status | RAG | Milestone ID | Text29 | Tier |
| --- | --- | --- | --- | --- | --- | --- | --- | --- | --- | --- | --- | --- | --- | --- | --- | --- | --- | --- | --- | --- | --- | --- | --- | --- | --- | --- | --- | --- |
| 182 | 1.3.6.2.1.4 | **Requirements to test Traceability Matrix (RTTM)** |  | 35d | 2023-08-04 A | 2023-09-22 A |  | 100% | 2023-08-04 | 2023-09-22 | 35d | 2022-10-31 | 2023-08-18 |  | N/A | 280h | 280h | -0 | N/A | N/A | 5.0 | Design, Build & Test (PIT) |  |  |  |  |  |  |
| 183 | 1.3.6.2.1.4.1 | Elexon Central Systems RTTM submitted to Programme for assurance | milestone | 0d | 2023-08-04 A | 2023-08-04 A | 176 | 100% | 2023-08-04 | 2023-08-04 | 0d | 2023-08-04 | 2023-08-04 | start no earlier than 2023-04-28 | Lee Cox |  |  |  | PP | SI Test | 5.0 | Design, Build & Test (PIT) | MHHS-ART009 | Complete | COMPLETE | T3-DB-0030 | SITAG | T3 |
| 184 | 1.3.6.2.1.4.2 | Elexon Central Systems RTTM MHHS Review Completed | milestone | 0d | 2023-09-22 A | 2023-09-22 A | 183FS+35d | 100% | 2023-09-22 | 2023-09-22 | 0d | 2023-08-07 | 2023-08-18 |  | Lee Cox |  |  |  | SI Test | PP | 5.8 | Design, Build & Test (PIT) |  | Complete | COMPLETE | T3-DB-0107 | SITAG | T3 |
| 185 | 1.3.6.2.1.5 | **Test Scenarios** |  | 35d | 2023-08-04 A | 2023-09-22 A |  | 100% | 2023-08-04 | 2023-09-22 | 35d | 2022-10-31 | 2023-08-18 |  | N/A | 280h | 280h | -0 | N/A | N/A | 5.0 | Design, Build & Test (PIT) |  |  |  |  |  |  |
| 186 | 1.3.6.2.1.5.1 | Elexon Central Systems test scenarios submitted to Programme for assurance | milestone | 0d | 2023-08-04 A | 2023-08-04 A | 176 | 100% | 2023-08-04 | 2023-08-04 | 0d | 2023-08-04 | 2023-08-04 |  | Lee Cox |  |  |  | PP | SI Test | 5.0 | Design, Build & Test (PIT) |  | Complete | COMPLETE | T3-DB-0032 | SITAG | T3 |
| 187 | 1.3.6.2.1.5.2 | Elexon Central Systems Test scenarios MHHS Review Completed | milestone | 0d | 2023-09-22 A | 2023-09-22 A | 186FS+35d | 100% | 2023-09-22 | 2023-09-22 | 0d | 2023-08-07 | 2023-08-18 |  | Lee Cox |  |  |  | SI Test | PP | 5.8 | Design, Build & Test (PIT) |  | Complete | COMPLETE | T3-DB-0108 | SITAG | T3 |
| 188 | 1.3.6.2.1.6 | **PIT Execution** |  | 38d | 2023-08-21 A | 2023-10-11 A |  | 100% | 2022-10-31 | 2023-10-11 | 248d | 2022-10-31 | 2023-09-29 |  | N/A | 672h | 672h | -0 | N/A | N/A | 5.0 | Design, Build & Test (PIT) |  |  |  |  |  |  |
| 189 | 1.3.6.2.1.6.1 | PIT Test Execution Progress Report |  | 18d | 2023-09-04 A | 2023-09-27 A | 181FS+10d | 100% | 2022-10-31 | 2023-09-22 | 235d | 2022-10-31 | 2023-09-22 |  | Lee Cox | 144h | 144h |  | PP | SI Test | 5.1 | Design, Build & Test (PIT) |  | Complete | COMPLETE |  |  |  |
| 190 | 1.3.6.2.1.6.2 | Elexon Central Systems PIT Execution |  | 28d | 2023-08-21 A | 2023-09-27 A | 181 | 100% | 2022-11-08 | 2023-10-09 | 240d | 2022-10-31 | 2023-09-29 |  | Lee Cox | 224h | 224h |  | PP | SI Test | 5.1 | Design, Build & Test (PIT) |  | Complete | COMPLETE |  |  |  |
| 191 | 1.3.6.2.1.6.3 | Elexon Central Systems PIT Completion Report submitted to Programme for assurance | milestone | 0d | 2023-09-27 A | 2023-09-27 A | 190 | 100% | 2023-09-27 | 2023-09-27 | 0d | 2024-01-05 | 2024-01-05 |  | Lee Cox |  |  |  | PP | SI Test | 5.8 | Design, Build & Test (PIT) |  | Complete | COMPLETE | T3-DB-0109 | SITAG | T3 |
| 192 | 1.3.6.2.1.6.4 | Elexon Central Systems PIT Completion Report MHHS Review Completed | milestone | 0d | 2023-10-11 A | 2023-10-11 A | 184, 187, 189, 191FS+10d, 179 | 100% | 2023-10-11 | 2023-10-11 | 0d |  |  |  | Lee Cox |  |  |  | SI Test | PP | 5.8 | Design, Build & Test (PIT) |  | Complete | COMPLETE | T3-DB-0110 | SITAG | T3 |
| 193 | 1.3.6.2.2 | **DIP DBT CIT (Entering at Interval 1)** |  | 221d | 2023-01-02 A | 2023-11-06 A |  | 100% | 2022-10-31 | 2023-11-06 | 266d | 2022-10-31 | 2023-09-29 |  | N/A | 5552h | 5552h | -0 | N/A | N/A | 5.0 | Design, Build & Test (PIT) |  |  |  |  |  |  |
| 194 | 1.3.6.2.2.1 | Design |  | 80d | 2023-01-02 A | 2023-04-21 A |  | 100% | 2023-01-02 | 2023-04-21 | 80d | 2023-01-02 | 2023-04-21 | must start on 2023-01-02 | Lee Cox | 640h | 640h |  | PP | SI Design | 5.0 | Design, Build & Test (PIT) |  | Complete | COMPLETE |  |  |  |
| 195 | 1.3.6.2.2.2 | Build |  | 155d | 2023-01-09 A | 2023-08-11 A | 194SS+5d | 100% | 2023-01-09 | 2023-08-11 | 155d | 2023-01-09 | 2023-08-11 |  | Lee Cox | 1240h | 1240h |  | PP |  | 5.5 | Design, Build & Test (PIT) |  | Complete | COMPLETE |  |  |  |
| 196 | 1.3.6.2.2.3 | **Test Approach & Plan** |  | 9d | 2023-07-07 A | 2023-07-20 A |  | 100% | 2022-10-31 | 2023-07-21 | 190d | 2022-10-31 | 2023-07-21 |  | N/A | 72h | 72h |  | N/A | N/A | 5.0 | Design, Build & Test (PIT) |  |  |  |  |  |  |
| 197 | 1.3.6.2.2.3.1 | DIP Test Approach & Plan (PIT) submitted to Programme for assurance | milestone | 0d | 2023-07-07 A | 2023-07-07 A |  | 100% | 2023-07-07 | 2023-07-07 | 0d | 2023-07-07 | 2023-07-07 |  | Lee Cox |  |  |  | PP | SI Test | 5.0 | Design, Build & Test (PIT) | MHHS-ART073 | Complete | COMPLETE | T3-DB-0026 | SITAG | T3 |
| 198 | 1.3.6.2.2.3.2 | DIP Test Approach & Plan (PIT) MHHS Review Completed | milestone | 0d | 2023-07-20 A | 2023-07-20 A | 197FS+9d | 100% | 2023-07-10 | 2023-07-21 | 10d | 2023-07-10 | 2023-07-21 |  | Lee Cox |  |  |  | SI Test | PP | 5.0 | Design, Build & Test (PIT) |  | Complete | COMPLETE |  |  |  |
| 199 | 1.3.6.2.2.4 | **PIT Test Readiness Report** |  | 31d | 2023-07-21 A | 2023-09-01 A |  | 100% | 2023-07-21 | 2023-09-29 | 51d | 2023-07-21 | 2023-09-29 |  | N/A | 496h | 496h |  | N/A | N/A | 5.0 | Design, Build & Test (PIT) |  |  |  |  |  |  |
| 200 | 1.3.6.2.2.4.1 | Test readiness reporting |  | 31d | 2023-07-21 A | 2023-09-01 A | 197FS+9d | 100% | 2023-07-21 | 2023-09-29 | 51d | 2023-07-21 | 2023-09-29 |  | Lee Cox | 248h | 248h |  | SI Test | 109 | 5.0 | Design, Build & Test (PIT) |  | Complete | COMPLETE |  |  |  |
| 201 | 1.3.6.2.2.5 | **Requirements to test Traceability Matrix (RTTM)** |  | 18d | 2023-08-04 A | 2023-08-30 A |  | 100% | 2022-10-31 | 2023-08-18 | 210d | 2022-10-31 | 2023-08-18 |  | N/A | 144h | 144h |  | N/A | N/A | 5.0 | Design, Build & Test (PIT) |  |  |  |  |  |  |
| 202 | 1.3.6.2.2.5.1 | DIP RTTM submitted to Programme for assurance | milestone | 0d | 2023-08-04 A | 2023-08-04 A | 197FS+15d | 100% | 2023-08-04 | 2023-08-04 | 0d | 2023-08-04 | 2023-08-04 |  | Lee Cox |  |  |  | PP | SI Test | 5.6 | Design, Build & Test (PIT) | MHHS-ART009 | Complete | COMPLETE | T3-DB-0034 | SITAG | T3 |
| 203 | 1.3.6.2.2.5.2 | DIP RTTM MHHS Review Completed | milestone | 0d | 2023-08-30 A | 2023-08-30 A | 202FS+18d | 100% | 2023-08-07 | 2023-08-18 | 10d | 2023-08-07 | 2023-08-18 |  | Lee Cox |  |  |  | SI Test | PP | 5.0 | Design, Build & Test (PIT) |  | Complete | COMPLETE |  |  |  |
| 204 | 1.3.6.2.2.6 | **Test Scenarios** |  | 22d | 2023-07-31 A | 2023-08-30 A |  | 100% | 2022-10-31 | 2023-08-14 | 206d | 2022-10-31 | 2023-08-18 |  | N/A | 176h | 176h |  | N/A | N/A | 5.0 | Design, Build & Test (PIT) |  |  |  |  |  |  |
| 205 | 1.3.6.2.2.6.1 | DIP PIT test scenarios submitted to Programme for assurance | milestone | 0d | 2023-07-31 A | 2023-07-31 A | 197FS+15d | 100% | 2023-07-31 | 2023-07-31 | 0d | 2023-08-04 | 2023-08-04 |  | Lee Cox |  |  |  | PP | SI Test | 5.0 | Design, Build & Test (PIT) |  | Complete | COMPLETE | T3-DB-0036 | SITAG | T3 |
| 206 | 1.3.6.2.2.6.2 | DIP Test scenarios MHHS Review Completed | milestone | 0d | 2023-08-30 A | 2023-08-30 A | 205FS+22d | 100% | 2023-08-01 | 2023-08-14 | 10d | 2023-08-07 | 2023-08-18 |  | Lee Cox |  |  |  | SI Test | PP | 5.0 | Design, Build & Test (PIT) |  | Complete | COMPLETE |  |  |  |

Notes:
- 184: 1/9 - to be raised as new T3 at TMAG. Approved at TMAG on 20/9
- 187: 1/9 - to be raised as new T3 at TMAG. Approved at TMAG on 20/9
- 191: 1/9 - to be raised as new T3 at TMAG. Approved at TMAG on 20/9
- 192: 1/9 - to be raised as new T3 at TMAG. Approved at TMAG on 20/9
- 200: Action: 14/8 - Query from RG - IS this an SI Test deliverable or expected to be a DIP deliverable if so be more specific
- 202: RG confirmed Submitted on 10/8/23

| ID | WBS | Task | Type | Duration | Start | Finish | Predecessors | Complete | Baseline start | Baseline finish | Baseline duration | Baseline 1 start | Baseline 1 finish | Constraint | Resources | Work | Actual work | Baseline cost | Responsible | Involved | Update Version | MHHS Programme Phase | Sched Status | RAG | Milestone ID | Text29 | Tier |
| --- | --- | --- | --- | --- | --- | --- | --- | --- | --- | --- | --- | --- | --- | --- | --- | --- | --- | --- | --- | --- | --- | --- | --- | --- | --- | --- | --- |
| 207 | 1.3.6.2.2.7 | **PIT execution** |  | 50d | 2023-08-29 A | 2023-11-06 A |  | 100% | 2023-09-01 | 2023-11-06 | 47d | 2022-10-31 | 2023-09-29 |  | N/A | 1016h | 1016h | -0 | N/A | N/A | 5.0 | Design, Build & Test (PIT) |  |  |  |  |  |
| 208 | 1.3.6.2.2.7.1 | PIT Test Execution Progress Report |  | 37d | 2023-09-01 A | 2023-10-23 A | 209FF, 200 | 100% | 2023-09-01 | 2023-10-23 | 37d | 2022-10-31 | 2023-09-22 | start no earlier than 2023-08-29 | Lee Cox | 296h | 296h |  | PP | SI Test | 5.6 | Design, Build & Test (PIT) | Complete | COMPLETE |  |  |  |
| 209 | 1.3.6.2.2.7.2 | PIT Execution (Interim Release 1) |  | 30d | 2023-08-29 A | 2023-10-09 A |  | 100% | 2023-09-06 | 2023-10-09 | 24d | 2022-10-31 | 2023-09-29 | start no earlier than 2023-08-29 | Lee Cox | 240h | 240h |  | PP | SI Test | 5.6 | Design, Build & Test (PIT) | Complete | COMPLETE |  |  |  |
| 210 | 1.3.6.2.2.7.3 | PIT Execution (Interim Release 2) |  | 10d | 2023-10-10 A | 2023-10-23 A | 209 | 100% | 2023-10-10 | 2023-10-23 | 10d |  |  |  | Lee Cox | 80h | 80h |  | PP | SI Test | 5.6 | Design, Build & Test (PIT) | Complete | COMPLETE |  |  |  |
| 211 | 1.3.6.2.2.7.4 | DIP PIT Completion Report (Interim Release 1) submitted to Programme for assurance | milestone | 0d | 2023-10-09 A | 2023-10-09 A | 209 | 100% | 2023-10-09 | 2023-10-09 | 0d | 2024-01-05 | 2024-01-05 |  | Lee Cox |  |  |  | PP | SI Test | 5.8 | Design, Build & Test (PIT) | Complete | COMPLETE | T3-DB-0111 | SITAG | T3 |
| 212 | 1.3.6.2.2.7.5 | DIP PIT Completion Report (Interim Release 1) MHHS Review Completed | milestone | 0d | 2023-10-23 A | 2023-10-23 A | 211FS+10d | 100% | 2023-10-23 | 2023-10-23 | 0d |  |  |  | Lee Cox |  |  |  | SI Test | SI Test | 5.10 | Design, Build & Test (PIT) | Complete | COMPLETE | T3-DB-0112 | SITAG | T3 |
| 213 | 1.3.6.2.2.7.6 | DIP PIT Completion Report (Interim Release 2) submitted to Programme for assurance | milestone | 0d | 2023-10-23 A | 2023-10-23 A | 210, 208 | 100% | 2023-10-23 | 2023-10-23 | 0d | 2024-01-05 | 2024-01-05 |  | Lee Cox |  |  |  | PP | SI Test | 5.10 | Design, Build & Test (PIT) | Complete | COMPLETE | T3-DB-0113 | SITAG | T3 |
| 214 | 1.3.6.2.2.7.7 | DIP PIT Completion Report (Interim Release 2) MHHS Review Completed | milestone | 0d | 2023-11-06 A | 2023-11-06 A | 213FS+10d | 100% | 2023-11-06 | 2023-11-06 | 0d |  |  |  | Lee Cox |  |  |  | SI Test | SI Test | 5.14 | Design, Build & Test (PIT) | Complete | COMPLETE | T3-DB-0114 | SITAG | T3 |
| 215 | 1.3.6.2.3 | **DCC (DSP) DBT SIT Functional (Entering at SIT Functional)** |  | 325d | 2022-10-31 A | 2024-01-26 A |  | 100% | 2022-10-31 | 2024-02-23 | 345d | 2022-10-31 | 2024-01-05 |  | N/A | 4128h | 4128h | -0 | N/A | N/A | 5.18 | Design, Build & Test (PIT) |  |  |  |  |  |
| 216 | 1.3.6.2.3.1 | Design |  | 67d | 2022-10-31 A | 2023-01-31 A |  | 100% | 2022-10-31 | 2023-01-31 | 67d | 2022-10-31 | 2023-01-31 |  | Lee Cox | 536h | 536h |  | PP | SI Design | 5.18 | Design, Build & Test (PIT) | Complete | COMPLETE |  |  |  |
| 217 | 1.3.6.2.3.2 | **Test Approach & Plan** |  | 20d | 2023-11-17 A | 2023-12-15 A |  | 100% | 2023-11-17 | 2023-12-15 | 20d | 2022-10-31 | 2023-10-27 |  | N/A | 160h | 160h | -0 | N/A | N/A | 5.18 | Design, Build & Test (PIT) |  |  |  |  |  |
| 218 | 1.3.6.2.3.2.1 | DCC Test Approach & Plan (PIT) submitted to Programme for assurance | milestone | 0d | 2023-11-17 A | 2023-11-17 A | 216FS+208d | 100% | 2023-11-17 | 2023-11-17 | 0d | 2023-10-13 | 2023-10-13 |  | Lee Cox |  |  |  | PP | SI Test | 5.18 | Design, Build & Test (PIT) | Complete | COMPLETE | T3-DB-0068 | SITAG | T3 |
| 219 | 1.3.6.2.3.2.2 | DCC Test Approach & Plan (PIT) MHHS Review Completed | milestone | 0d | 2023-12-15 A | 2023-12-15 A | 218FS+20d | 100% | 2023-12-15 | 2023-12-15 | 0d | 2023-10-16 | 2023-10-27 |  | Lee Cox |  |  |  | SI Test | PP | 5.18 | Design, Build & Test (PIT) | Complete | COMPLETE | T3-DB-0115 | SITAG | T3 |
| 220 | 1.3.6.2.3.3 | **Test Readiness Report** |  | 22d | 2023-12-04 A | 2024-01-02 A |  | 100% | 2023-10-27 | 2024-01-05 | 51d | 2023-10-27 | 2024-01-05 |  | N/A | 352h | 352h |  | N/A | N/A | 5.18 | Design, Build & Test (PIT) |  |  |  |  |  |
| 221 | 1.3.6.2.3.3.1 | Test readiness reporting |  | 22d | 2023-12-04 A | 2024-01-02 A | 218FS+10d | 100% | 2023-10-27 | 2024-01-05 | 51d | 2023-10-27 | 2024-01-05 |  | Lee Cox | 176h | 176h |  | PP | 109 | 5.18 | Design, Build & Test (PIT) | Complete | COMPLETE |  |  |  |
| 222 | 1.3.6.2.3.4 | **Requirements to test Traceability Matrix (RTTM)** |  | 30d | 2023-12-15 A | 2024-01-26 A |  | 100% | 2023-12-15 | 2024-01-26 | 30d | 2022-10-31 | 2023-11-24 |  | N/A | 240h | 240h | -0 | N/A | N/A | 5.18 | Design, Build & Test (PIT) |  |  |  |  |  |
| 223 | 1.3.6.2.3.4.1 | DCC RTTM submitted to Programme for assurance | milestone | 0d | 2023-12-15 A | 2023-12-15 A | 218FS+20d | 100% | 2023-12-15 | 2023-12-15 | 0d | 2023-11-10 | 2023-11-10 | start no earlier than 2023-04-28 | Lee Cox |  |  |  | PP | SI Test | 5.18 | Design, Build & Test (PIT) | Complete | COMPLETE | T3-DB-0074 | SITAG | T3 |
| 224 | 1.3.6.2.3.4.2 | DCC RTTM MHHS Review Completed | milestone | 0d | 2024-01-26 A | 2024-01-26 A | 223FS+30d | 100% | 2024-01-26 | 2024-01-26 | 0d | 2023-11-13 | 2023-11-24 |  | Lee Cox |  |  |  | SI Test | PP | 5.18 | Design, Build & Test (PIT) | Complete | COMPLETE | T3-DB-0116 | SITAG | T3 |
| 225 | 1.3.6.2.3.5 | **Test Scenarios** |  | 30d | 2023-12-15 A | 2024-01-26 A |  | 100% | 2023-12-15 | 2024-01-26 | 30d | 2022-10-31 | 2023-11-24 |  | N/A | 240h | 240h | -0 | N/A | N/A | 5.18 | Design, Build & Test (PIT) |  |  |  |  |  |
| 226 | 1.3.6.2.3.5.1 | DCC test scenarios submitted to Programme for assurance | milestone | 0d | 2023-12-15 A | 2023-12-15 A | 218FS+20d | 100% | 2023-12-15 | 2023-12-15 | 0d | 2023-11-10 | 2023-11-10 |  | Lee Cox |  |  |  | PP | SI Test | 5.18 | Design, Build & Test (PIT) | Complete | COMPLETE | T3-DB-0078 | SITAG | T3 |
| 227 | 1.3.6.2.3.5.2 | DCC Test Scenarios MHHS Review Completed | milestone | 0d | 2024-01-26 A | 2024-01-26 A | 226FS+30d | 100% | 2024-01-26 | 2024-01-26 | 0d | 2023-11-13 | 2023-11-24 |  | Lee Cox |  |  |  | SI Test | PP | 5.18 | Design, Build & Test (PIT) | Complete | COMPLETE | T3-DB-0117 | SITAG | T3 |
| 228 | 1.3.6.2.4 | **RECCo (EES) DBT CIT (Entering at Interval 6)** |  | 71d | 2023-10-13 A | 2024-01-19 A |  | 100% | 2022-10-31 | 2024-01-19 | 320d | 2022-10-31 | 2024-01-05 |  | N/A | 2272h | 2272h | -0 | N/A | N/A | 5.0 | Design, Build & Test (PIT) |  |  |  |  |  |
| 229 | 1.3.6.2.4.1 | **Test Approach & Plan** |  | 20d | 2023-10-13 A | 2023-11-09 A |  | 100% | 2023-10-13 | 2023-11-09 | 20d | 2022-10-31 | 2023-10-27 |  | N/A | 160h | 160h | -0 | N/A | N/A | 5.0 | Design, Build & Test (PIT) |  |  |  |  |  |
| 230 | 1.3.6.2.4.1.1 | EES Test Approach & Plan (PIT) submitted to Programme for assurance | milestone | 0d | 2023-10-13 A | 2023-10-13 A |  | 100% | 2023-10-13 | 2023-10-13 | 0d | 2023-10-13 | 2023-10-13 | start no earlier than 2023-10-13 | Lee Cox |  |  |  | PP | SI Test | 5.8 | Design, Build & Test (PIT) | Complete | COMPLETE | T3-DB-0066 | SITAG | T3 |
| 231 | 1.3.6.2.4.1.2 | EES Test approach and plan (PIT) MHHS Review Completed | milestone | 0d | 2023-11-09 A | 2023-11-09 A | 230FS+20d | 100% | 2023-11-09 | 2023-11-09 | 0d | 2023-10-16 | 2023-10-27 |  | Lee Cox |  |  |  | SI Test | PP | 5.8 | Design, Build & Test (PIT) | Complete | COMPLETE | T3-DB-0119 | SITAG | T3 |

Notes:
- 208: 21/8 - due to complete 9/10 - advised by RG
- 209: 21/8 - due to complete 9/10 - advised by RG
- 210: 21/8 - new line added date are 9/10 - 23/10 - advised by RG.
- 211: 1/9 - to be raised as new T3 at TMAG. Approved at TMAG on 20/9. 9/10 - RG - After discussions with DM it was decided a completion report for IR1 wasn't required as we are entering IR2 ahead of schedule & draft completion report already submitted & assured
- 212: 1/9 - to be raised as new T3 at TMAG. Approved at TMAG on 20/9
- 213: 1/9 - to be raised as new T3 at TMAG. Approved at TMAG on 20/9
- 214: 7/11- Red because further clarity around remaining open low severity defect work off plan requested. No impact. Completed on 8/12 / Guidance: 6/10 - LC - Successor should be SIT Component Integration Testing 1 Preparation Complete but not linked as DIP test completion plus 10 day review breaks logic. Decision will be made to proceed without a conclusion of the report review
- 218: 21/11- Red because not received. Currently no impact. 30/1 - Completed on 26/1
- 219: 1/9 - to be raised as new T3 at TMAG DCC no longer in CIT, new dates relate to SIT Functional. Approved at TMAG on 20/9. 19/12 - Red because not received
- 223: 19/12- Red because not received. 30/1 - Completed on 26/1
- 224: 23/1- Amber because of potential late delivery of RTTM. No impact. No action. 30/1 - Completed on 26/1
- 226: 5/12- Red because of late delivery of PIT approach and plan. No impact. No action. 30/1 - Completed on 26/1
- 227: 23/1- Amber because of potential late delivery of test scenarios. No impact. No action. 30/1 - Completed on 26/1
- 228: Assumption that Migration/Reverse Migration DBT is not applicable to RECCo.
- 230: 12/9 - TMAG for name change. Approved at TMAG on 20/9. 17/10 - Red because document not yet received. No impact currently. Issuance from RECCo requested
- 231: 1/9 - to be raised as new T3 at TMAG. Approved at TMAG on 20/9. 17/10 - Amber because Late delivery of document plus earlier intervals backlog. Currently no impact

| ID | WBS | Task | Type | Duration | Start | Finish | Predecessors | Complete | Baseline start | Baseline finish | Baseline duration | Baseline 1 start | Baseline 1 finish | Constraint | Resources | Work | Actual work | Baseline cost | Responsible | Involved | Update Version | MHHS Programme Phase | Sched Status | RAG | Artefact ID | Milestone ID | Text29 | Tier |
| --- | --- | --- | --- | --- | --- | --- | --- | --- | --- | --- | --- | --- | --- | --- | --- | --- | --- | --- | --- | --- | --- | --- | --- | --- | --- | --- | --- | --- |
| 232 | 1.3.6.2.4.2 | **Test Readiness Report** |  | 10d | 2023-10-27 A | 2023-11-09 A |  | 100% | 2023-10-27 | 2024-01-05 | 51d | 2023-10-27 | 2024-01-05 |  | N/A | 160h | 160h |  | N/A | N/A | 5.0 | Design, Build & Test (PIT) |  |  |  |  |  |  |
| 233 | 1.3.6.2.4.2.1 | Test readiness reporting |  | 10d | 2023-10-27 A | 2023-11-09 A | 230FS+10d | 100% | 2023-10-27 | 2024-01-05 | 51d | 2023-10-27 | 2024-01-05 |  | Lee Cox | 80h | 80h |  | PP | 109 | 5.0 | Design, Build & Test (PIT) | Complete | COMPLETE |  |  |  |  |
| 234 | 1.3.6.2.4.3 | **Requirements to test Traceability Matrix (RTTM)** |  | 20d | 2023-11-02 A | 2023-11-30 A |  | 100% | 2023-11-02 | 2023-11-30 | 20d | 2022-10-31 | 2023-11-24 |  | N/A | 160h | 160h | -0 | N/A | N/A | 5.0 | Design, Build & Test (PIT) |  |  |  |  |  |  |
| 235 | 1.3.6.2.4.3.1 | EES RTTM submitted to Programme for assurance | milestone | 0d | 2023-11-02 A | 2023-11-02 A | 230FS+15d | 100% | 2023-11-02 | 2023-11-02 | 0d | 2023-11-10 | 2023-11-10 |  | Lee Cox |  |  |  | PP | SI Test | 5.8 | Design, Build & Test (PIT) | Complete | COMPLETE | MHHS-ART009 | T3-DB-0072 | SITAG | T3 |
| 236 | 1.3.6.2.4.3.2 | EES RTTM MHHS Review Completed | milestone | 0d | 2023-11-30 A | 2023-11-30 A | 235FS+20d | 100% | 2023-11-30 | 2023-11-30 | 0d | 2023-11-13 | 2023-11-24 |  | Lee Cox |  |  |  | SI Test | PP | 5.14 | Design, Build & Test (PIT) | Complete | COMPLETE |  | T3-DB-0120 | SITAG | T3 |
| 237 | 1.3.6.2.4.4 | **Test Scenarios** |  | 20d | 2023-11-02 A | 2023-11-30 A |  | 100% | 2023-11-02 | 2023-11-30 | 20d | 2022-10-31 | 2023-11-24 |  | N/A | 160h | 160h | -0 | N/A | N/A | 5.0 | Design, Build & Test (PIT) |  |  |  |  |  |  |
| 238 | 1.3.6.2.4.4.1 | EES test scenarios submitted to Programme for assurance | milestone | 0d | 2023-11-02 A | 2023-11-02 A | 230FS+15d | 100% | 2023-11-02 | 2023-11-02 | 0d | 2023-11-10 | 2023-11-10 |  | Lee Cox |  |  |  | PP | SI Test | 5.8 | Design, Build & Test (PIT) | Complete | COMPLETE |  | T3-DB-0031 | SITAG | T3 |
| 239 | 1.3.6.2.4.4.2 | EES Test scenarios MHHS Review Completed | milestone | 0d | 2023-11-30 A | 2023-11-30 A | 238FS+20d | 100% | 2023-11-30 | 2023-11-30 | 0d | 2023-11-13 | 2023-11-24 |  | Lee Cox |  |  |  | SI Test | PP | 5.14 | Design, Build & Test (PIT) | Complete | COMPLETE |  | T3-DB-0121 | SITAG | T3 |
| 240 | 1.3.6.2.4.5 | **PIT execution** |  | 51d | 2023-11-10 A | 2024-01-19 A |  | 100% | 2022-10-31 | 2024-01-19 | 320d | 2022-10-31 | 2024-01-05 |  | N/A | 1064h | 1064h | -0 | N/A | N/A | 5.0 | Design, Build & Test (PIT) |  |  |  |  |  |  |
| 241 | 1.3.6.2.4.5.1 | PIT Test Execution Progress Report |  | 41d | 2023-11-10 A | 2024-01-05 A | 233 | 100% | 2023-11-10 | 2024-01-05 | 41d | 2022-10-31 | 2023-12-29 |  | Lee Cox | 328h | 328h |  | PP | SI Test | 5.0 | Design, Build & Test (PIT) | Complete | COMPLETE |  |  |  |  |
| 242 | 1.3.6.2.4.5.2 | PIT Execution |  | 41d | 2023-11-10 A | 2024-01-05 A | 238FS+5d | 100% | 2022-10-31 | 2024-01-05 | 310d | 2022-10-31 | 2024-01-05 |  | Lee Cox | 328h | 328h |  | PP | SI Test | 5.0 | Design, Build & Test (PIT) | Complete | COMPLETE |  |  |  |  |
| 243 | 1.3.6.2.4.5.3 | EES PIT Completion Report submitted to Programme for assurance | milestone | 0d | 2024-01-05 A | 2024-01-05 A | 241, 242 | 100% | 2024-01-05 | 2024-01-05 | 0d | 2024-01-05 | 2024-01-05 |  | Lee Cox |  |  |  | PP | SI Test | 5.14 | Design, Build & Test (PIT) | Complete | COMPLETE |  | T3-DB-0122 | SITAG | T3 |
| 244 | 1.3.6.2.4.5.4 | EES PIT Completion Report MHHS Review Completed | milestone | 0d | 2024-01-19 A | 2024-01-19 A | 231, 236, 239, 243FS+10d | 100% | 2024-01-19 | 2024-01-19 | 0d |  |  |  | Lee Cox |  |  |  | SI Test | PP | 5.14 | Design, Build & Test (PIT) | Complete | COMPLETE |  | T3-DB-0123 | SITAG | T3 |
| 245 | 1.3.6.2.5 | **Registration Services DBT CIT (Entering at Interval 2)** |  | 70d | 2023-07-28 A | 2023-11-03 A |  | 100% | 2023-07-28 | 2023-11-03 | 70d | 2022-10-31 | 2024-02-28 |  | N/A | 2344h | 2344h | -0 | N/A | N/A | 5.0 | Design, Build & Test (PIT) |  |  |  |  |  |  |
| 246 | 1.3.6.2.5.1 | **Test Approach & Plan** |  | 40d | 2023-07-28 A | 2023-09-22 A |  | 100% | 2023-07-28 | 2023-09-22 | 40d | 2022-10-31 | 2023-08-11 |  | N/A | 320h | 320h | -0 | N/A | N/A | 5.0 | Design, Build & Test (PIT) |  |  |  |  |  |  |
| 247 | 1.3.6.2.5.1.1 | Registration Services Test Approach & Plan (PIT) submitted to Programme for assurance | milestone | 0d | 2023-07-28 A | 2023-07-28 A |  | 100% | 2023-07-28 | 2023-07-28 | 0d | 2023-07-28 | 2023-07-28 |  | Lee Cox |  |  |  | PP | SI Test | 5.0 | Design, Build & Test (PIT) | Complete | COMPLETE | MHHS-ART073 | T3-DB-0028 | SITAG | T3 |
| 248 | 1.3.6.2.5.1.2 | Registration Services Test approach and plan MHHS Review Completed | milestone | 0d | 2023-09-22 A | 2023-09-22 A | 247FS+40d | 100% | 2023-09-22 | 2023-09-22 | 0d | 2023-07-31 | 2023-08-11 |  | Lee Cox |  |  |  | SI Test | PP | 5.8 | Design, Build & Test (PIT) | Complete | COMPLETE |  | T3-DB-0124 | SITAG | T3 |
| 249 | 1.3.6.2.5.2 | **Test Readiness Report** |  | 20d | 2023-08-14 A | 2023-09-08 A |  | 100% | 2023-08-11 | 2023-10-20 | 51d | 2023-08-11 | 2023-10-20 |  | N/A | 320h | 320h |  | N/A | N/A | 5.0 | Design, Build & Test (PIT) |  |  |  |  |  |  |
| 250 | 1.3.6.2.5.2.1 | Test readiness reporting |  | 20d | 2023-08-14 A | 2023-09-08 A | 247FS+10d | 100% | 2023-08-11 | 2023-10-20 | 51d | 2023-08-11 | 2023-10-20 |  | Lee Cox | 160h | 160h |  | PP | 109 | 5.0 | Design, Build & Test (PIT) | Complete | COMPLETE |  |  |  |  |
| 251 | 1.3.6.2.5.3 | **Requirements to test Traceability Matrix (RTTM)** |  | 20d | 2023-09-01 A | 2023-09-29 A |  | 100% | 2023-09-01 | 2023-09-29 | 20d | 2022-10-31 | 2023-09-15 |  | N/A | 160h | 160h | -0 | N/A | N/A | 5.0 | Design, Build & Test (PIT) |  |  |  |  |  |  |
| 252 | 1.3.6.2.5.3.1 | Registration Services RTTM submitted to Programme for assurance | milestone | 0d | 2023-09-01 A | 2023-09-01 A | 247FS+15d | 100% | 2023-09-01 | 2023-09-01 | 0d | 2023-09-01 | 2023-09-01 | start no earlier than 2023-04-28 | Lee Cox |  |  |  | PP | SI Test | 5.6 | Design, Build & Test (PIT) | Complete | COMPLETE | MHHS-ART009 | T3-DB-0042 | SITAG | T3 |
| 253 | 1.3.6.2.5.3.2 | Registration Services RTTM MHHS Review Completed | milestone | 0d | 2023-09-29 A | 2023-09-29 A | 252FS+20d | 100% | 2023-09-29 | 2023-09-29 | 0d | 2023-09-04 | 2023-09-15 |  | Lee Cox |  |  |  | SI Test | PP | 5.8 | Design, Build & Test (PIT) | Complete | COMPLETE |  | T3-DB-0125 | SITAG | T3 |
| 254 | 1.3.6.2.5.4 | **Test Scenarios** |  | 20d | 2023-09-01 A | 2023-09-29 A |  | 100% | 2023-09-01 | 2023-09-29 | 20d | 2022-10-31 | 2023-09-15 |  | N/A | 160h | 160h | -0 | N/A | N/A | 5.0 | Design, Build & Test (PIT) |  |  |  |  |  |  |
| 255 | 1.3.6.2.5.4.1 | Registration Services test scenarios submitted to Programme for assurance | milestone | 0d | 2023-09-01 A | 2023-09-01 A | 247FS+15d | 100% | 2023-09-01 | 2023-09-01 | 0d | 2023-09-01 | 2023-09-01 |  | Lee Cox |  |  |  | PP | SI Test | 5.6 | Design, Build & Test (PIT) | Complete | COMPLETE |  | T3-DB-0044 | SITAG | T3 |
| 256 | 1.3.6.2.5.4.2 | Registration Services Test scenarios MHHS Review Completed | milestone | 0d | 2023-09-29 A | 2023-09-29 A | 255FS+20d | 100% | 2023-09-29 | 2023-09-29 | 0d | 2023-09-04 | 2023-09-15 |  | Lee Cox |  |  |  | SI Test | PP | 5.8 | Design, Build & Test (PIT) | Complete | COMPLETE |  | T3-DB-0126 | SITAG | T3 |

Notes:
- 235: 7/11 - Red because not submitted. No impact. No action
- 236: 5/12- Red because Assurance conducted. Comments issued and awaiting response. No impact. No action. Completed on 15/12
- 238: 7/11 - Red because not submitted. No impact. No action
- 239: 5/12- Red because Assurance conducted. Comments issued and awaiting response. No impact. No action. Completed on 15/12
- 243: 1/9 - to be raised as new T3 at TMAG. Approved at TMAG on 20/9. 19/12 - Completed on 15/12
- 244: 1/9 - to be raised as new T3 at TMAG. Approved at TMAG on 20/9. 19/12 - Completed on 15/12
- 248: 1/9 - to be raised as new T3 at TMAG. Approved at TMAG on 20/9
- 253: 1/9 - to be raised as new T3 at TMAG. Approved at TMAG on 20/9. 4/10 - Red because small number of comments still to be resolved, will be completed no later than 3/11 ahead of Interval 2 Readiness Assessment
- 256: 1/9 - to be raised as new T3 at TMAG

| ID | WBS | Task | Type | Duration | Start | Finish | Predecessors | Complete | Remaining | Baseline start | Baseline finish | Baseline duration | Baseline 1 start | Baseline 1 finish | Total slack | Constraint | Resources | Work | Actual work | Baseline cost | Responsible | Involved | Update Version | MHHS Programme Phase | Sched Status | RAG | Milestone ID | Text29 | Tier |
| --- | --- | --- | --- | --- | --- | --- | --- | --- | --- | --- | --- | --- | --- | --- | --- | --- | --- | --- | --- | --- | --- | --- | --- | --- | --- | --- | --- | --- | --- |
| 257 | 1.3.6.2.5.5 | **PIT execution** |  | 40d | 2023-09-11 A | 2023-11-03 A |  | 100% |  | 2023-09-11 | 2023-11-03 | 40d | 2023-01-02 | 2023-10-20 |  |  | N/A | 824h | 824h | -0 | N/A | N/A | 5.0 | Design, Build & Test (PIT) |  |  |  |  |  |
| 258 | 1.3.6.2.5.5.1 | PIT Test Execution Progress Report |  | 33d | 2023-09-11 A | 2023-10-25 A | 250 | 100% |  | 2023-09-11 | 2023-10-20 | 30d | 2023-01-02 | 2023-10-13 |  |  | Lee Cox | 264h | 264h |  | PP | SI Test | 5.0 | Design, Build & Test (PIT) | Complete | COMPLETE |  |  |  |
| 259 | 1.3.6.2.5.5.2 | PIT Execution |  | 30d | 2023-09-11 A | 2023-10-20 A | 255FS+5d | 100% |  | 2023-09-11 | 2023-10-20 | 30d | 2023-01-16 | 2023-10-20 |  |  | Lee Cox | 240h | 240h |  | PP | SI Test | 5.0 | Design, Build & Test (PIT) | Complete | COMPLETE |  |  |  |
| 260 | 1.3.6.2.5.5.3 | Registration Services PIT (CIT interval 2) Completion Report submitted to Programme for assurance | milestone | 0d | 2023-10-25 A | 2023-10-25 A | 258, 259 | 100% |  | 2023-10-20 | 2023-10-20 | 0d | 2024-01-05 | 2024-01-05 |  |  | Lee Cox |  |  |  | PP | SI Test | 5.10 | Design, Build & Test (PIT) | Complete | COMPLETE | T3-DB-0127 | SITAG | T3 |
| 261 | 1.3.6.2.5.5.4 | Registration Services PIT (CIT interval 2) Completion Report MHHS Review Completed | milestone | 0d | 2023-11-03 A | 2023-11-03 A | 248, 253, 256, 260FS+7d | 100% |  | 2023-11-03 | 2023-11-03 | 0d |  |  |  |  | Lee Cox |  |  |  | SI Test | PP | 5.11 | Design, Build & Test (PIT) | Complete | COMPLETE | T3-DB-0128 | SITAG | T3 |
| 262 | 1.3.6.3 | **SIT Participants DBT** |  | 291d | 2023-08-11 A | 2024-09-20 |  | 82% | 52.09d | 2022-10-31 | 2024-09-20 | 495d | 2022-10-31 | 2025-03-14 | 3d |  | N/A | 25832h | 18380.4h | -0 | N/A | N/A | 5.0 | Design, Build & Test (PIT) |  |  |  |  |  |
| 263 | 1.3.6.3.1 | **All Data Services DBT CIT (Entering at Interval 3)** |  | 71d | 2023-08-11 A | 2023-11-17 A |  | 100% |  | 2022-10-31 | 2023-11-17 | 275d | 2022-10-31 | 2023-11-03 |  |  | N/A | 2024h | 2024h | -0 | N/A | N/A | 5.0 | Design, Build & Test (PIT) |  |  |  |  |  |
| 264 | 1.3.6.3.1.1 | **Test Approach & Plan** |  | 30d | 2023-08-11 A | 2023-09-21 A |  | 100% |  | 2023-08-11 | 2023-09-21 | 29d | 2022-10-31 | 2023-08-25 |  |  | N/A | 240h | 240h | -0 | N/A | N/A | 5.0 | Design, Build & Test (PIT) |  |  |  |  |  |
| 265 | 1.3.6.3.1.1.1 | All Data Services Test Approach & Plans (PIT) submitted to Programme for assurance | milestone | 0d | 2023-08-11 A | 2023-08-11 A |  | 100% |  | 2023-08-11 | 2023-08-11 | 0d | 2023-08-11 | 2023-08-11 |  | start no earlier than 2023-08-11 | Lee Cox |  |  |  | PP | SI Test | 5.0 | Design, Build & Test (PIT) | Complete | COMPLETE | T3-DB-0038 | SITAG | T3 |
| 266 | 1.3.6.3.1.1.2 | All Data Services Test approach and plans MHHS Review Completed | milestone | 0d | 2023-09-21 A | 2023-09-21 A | 265FS+30d | 100% |  | 2023-09-21 | 2023-09-21 | 0d | 2023-08-14 | 2023-08-25 |  |  | Lee Cox |  |  |  | SI Test | PP | 5.11 | Design, Build & Test (PIT) | Complete | COMPLETE | T3-DB-0129 | SITAG | T3 |
| 267 | 1.3.6.3.1.2 | **Test Readiness Report** |  | 11d | 2023-08-25 A | 2023-09-08 A |  | 100% |  | 2023-08-25 | 2023-09-08 | 11d | 2023-08-25 | 2023-11-03 |  |  | N/A | 176h | 176h | -0 | N/A | N/A | 5.0 | Design, Build & Test (PIT) |  |  |  |  |  |
| 268 | 1.3.6.3.1.2.1 | Test readiness reporting |  | 11d | 2023-08-25 A | 2023-09-08 A | 265FS+10d | 100% |  | 2023-08-25 | 2023-09-08 | 11d | 2023-08-25 | 2023-11-03 |  |  | Lee Cox | 88h | 88h |  | PP | 109 | 5.0 | Design, Build & Test (PIT) | Complete | COMPLETE |  |  |  |
| 269 | 1.3.6.3.1.3 | **Requirements to test Traceability Matrix (RTTM)** |  | 7d | 2023-09-20 A | 2023-09-29 A |  | 100% |  | 2023-09-22 | 2023-09-29 | 5d | 2022-10-31 | 2023-10-06 |  |  | N/A | 56h | 56h | -0 | N/A | N/A | 5.0 | Design, Build & Test (PIT) |  |  |  |  |  |
| 270 | 1.3.6.3.1.3.1 | All Data Services RTTMs submitted to Programme for assurance | milestone | 0d | 2023-09-20 A | 2023-09-20 A | 265FS+29d | 100% |  | 2023-09-22 | 2023-09-22 | 0d | 2023-09-22 | 2023-09-22 |  |  | Lee Cox |  |  |  | PP | SI Test | 5.7 | Design, Build & Test (PIT) | Complete | COMPLETE | T3-DB-0058 | SITAG | T3 |
| 271 | 1.3.6.3.1.3.2 | All Data Services RTTMs MHHS Review Completed | milestone | 0d | 2023-09-29 A | 2023-09-29 A | 270FS+7d | 100% |  | 2023-09-29 | 2023-09-29 | 0d | 2023-09-25 | 2023-10-06 |  |  | Lee Cox |  |  |  | SI Test | PP | 5.8 | Design, Build & Test (PIT) | Complete | COMPLETE | T3-DB-0130 | SITAG | T3 |
| 272 | 1.3.6.3.1.4 | **Test Scenarios** |  | 6d | 2023-09-20 A | 2023-09-28 A |  | 100% |  | 2023-09-22 | 2023-09-28 | 4d | 2022-10-31 | 2023-10-06 |  |  | N/A | 48h | 48h | -0 | N/A | N/A | 5.0 | Design, Build & Test (PIT) |  |  |  |  |  |
| 273 | 1.3.6.3.1.4.1 | All Data Services test scenarios' submitted to Programme for assurance | milestone | 0d | 2023-09-20 A | 2023-09-20 A | 265FS+29d | 100% |  | 2023-09-22 | 2023-09-22 | 0d | 2023-09-22 | 2023-09-22 |  |  | Lee Cox |  |  |  | PP | SI Test | 5.7 | Design, Build & Test (PIT) | Complete | COMPLETE | T3-DB-0056 | SITAG | T3 |
| 274 | 1.3.6.3.1.4.2 | All Data Services Test scenarios' MHHS Review Completed | milestone | 0d | 2023-09-28 A | 2023-09-28 A | 273FS+6d | 100% |  | 2023-09-28 | 2023-09-28 | 0d | 2023-09-25 | 2023-10-06 |  |  | Lee Cox |  |  |  | SI Test | PP | 5.11 | Design, Build & Test (PIT) | Complete | COMPLETE | T3-DB-0131 | SITAG | T3 |
| 275 | 1.3.6.3.1.5 | **PIT execution** |  | 50d | 2023-09-11 A | 2023-11-17 A |  | 100% |  | 2022-10-31 | 2023-11-17 | 275d | 2022-10-31 | 2023-11-03 |  |  | N/A | 936h | 936h | -0 | N/A | N/A | 5.0 | Design, Build & Test (PIT) |  |  |  |  |  |
| 276 | 1.3.6.3.1.5.1 | PIT Test Execution Progress Report |  | 40d | 2023-09-11 A | 2023-11-03 A | 268 | 100% |  | 2022-10-31 | 2023-10-27 | 260d | 2022-10-31 | 2023-10-27 |  |  | Lee Cox | 320h | 320h |  | PP | SI Test | 5.0 | Design, Build & Test (PIT) | Complete | COMPLETE |  |  |  |
| 277 | 1.3.6.3.1.5.2 | PIT Execution |  | 27d | 2023-09-28 A | 2023-11-03 A | 273FS+5d | 100% |  | 2022-10-31 | 2023-11-03 | 265d | 2022-10-31 | 2023-11-03 |  |  | Lee Cox | 216h | 216h |  | PP | SI Test | 5.0 | Design, Build & Test (PIT) | Complete | COMPLETE |  |  |  |
| 278 | 1.3.6.3.1.5.3 | All Data Services PIT Completion Reports submitted to Programme for assurance | milestone | 0d | 2023-11-03 A | 2023-11-03 A | 276, 277 | 100% |  | 2023-11-03 | 2023-11-03 | 0d | 2024-01-05 | 2024-01-05 |  |  | Lee Cox |  |  |  | PP | SI Test | 5.11 | Design, Build & Test (PIT) | Complete | COMPLETE | T3-DB-0132 | SITAG | T3 |
| 279 | 1.3.6.3.1.5.4 | All Data Services PIT Completion Reports MHHS Review Completed | milestone | 0d | 2023-11-17 A | 2023-11-17 A | 266, 271, 274, 278FS+10d | 100% |  | 2023-11-17 | 2023-11-17 | 0d |  |  |  |  | Lee Cox |  |  |  | SI Test | PP | 5.13 | Design, Build & Test (PIT) | Complete | COMPLETE | T3-DB-0133 | SITAG | T3 |
| 280 | 1.3.6.3.2 | **All Metering Services DBT CIT (Entering at Interval 4)** |  | 70d | 2023-08-25 A | 2023-12-01 A |  | 100% |  | 2022-10-31 | 2023-12-01 | 285d | 2022-10-31 | 2023-11-17 |  |  | N/A | 2568h | 2568h | -0 | N/A | N/A | 5.0 | Design, Build & Test (PIT) |  |  |  |  |  |
| 281 | 1.3.6.3.2.1 | **Test Approach & Plan** |  | 40d | 2023-08-25 A | 2023-10-20 A |  | 100% |  | 2023-08-25 | 2023-10-20 | 40d | 2022-10-31 | 2023-09-08 |  |  | N/A | 320h | 320h | -0 | N/A | N/A | 5.0 | Design, Build & Test (PIT) |  |  |  |  |  |
| 282 | 1.3.6.3.2.1.1 | All Metering Services Test Approach & Plans (PIT) submitted to Programme for assurance | milestone | 0d | 2023-08-25 A | 2023-08-25 A |  | 100% |  | 2023-08-25 | 2023-08-25 | 0d | 2023-08-25 | 2023-08-25 |  |  | Lee Cox |  |  |  | PP | SI Test | 5.6 | Design, Build & Test (PIT) | Complete | COMPLETE | T3-DB-0040 | SITAG | T3 |
| 283 | 1.3.6.3.2.1.2 | All Metering Services Test approach and plans MHHS Review Completed | milestone | 0d | 2023-10-20 A | 2023-10-20 A | 282FS+40d | 100% |  | 2023-10-20 | 2023-10-20 | 0d | 2023-08-28 | 2023-09-08 |  |  | Lee Cox |  |  |  | SI Test | PP | 5.8 | Design, Build & Test (PIT) | Complete | COMPLETE | T3-DB-0134 | SITAG | T3 |

Notes:
- 259: 17/10 - Amber because St Clements assessment. No impact. Being monitored
- 260: 1/9 - to be raised as new T3 at TMAG. Approved at TMAG on 20/9. 24/10 - Red because 3 day delay to SCS PIT completion. No impact to CIT Interval 2.
- 261: 1/9 - to be raised as new T3 at TMAG. Approved at TMAG on 20/9. 17/10 - Amber because St Clements assessment. No impact. Being monitored
- 266: 1/9 - to be raised as new T3 at TMAG. Approved at TMAG on 20/9. Red due to high volume to be reviewed. Date change under consideration. Review will be completed no later than 17/11 ahead of Interval 3 Readiness Assessment
- 271: 1/9 - to be raised as new T3 at TMAG Approved at TMAG on 20/9. Red due to high volume to be reviewed. Date change under consideration. Review will be completed no later than 17/11 ahead of Interval 3 Readiness Assessment
- 274: 1/9 - to be raised as new T3 at TMAG. Approved at TMAG on 20/9. Red due to high volume to be reviewed. Date change under consideration. Review will be completed no later than 17/11 ahead of Interval 3 Readiness Assessment
- 276: 10/10 - LC - red because date in the past, not all participants have provided reports. No impact. No action
- 277: 10/10 - LC - red because date in the past, acceptable for some participants to have not started PIT yet
- 278: 1/9 - to be raised as new T3 at TMAG. Approved at TMAG on 20/9
- 279: 1/9 - to be raised as new T3 at TMAG. Approved at TMAG on 20/9. 21/11-Red because 1 report remains outstanding due to close 22/11. Completed on 22/11
- 283: 7/10 - Red due to high volume to be reviewed. Date change under consideration. Review will be completed no later than 04/12 ahead of Interval 4 Readiness Assessment

| ID | WBS | Task | Type | Duration | Start | Finish | Predecessors | Complete | Remaining | Baseline start | Baseline finish | Baseline duration | Baseline 1 start | Baseline 1 finish | Total slack | Constraint | Resources | Work | Actual work | Baseline cost | Responsible | Involved | Update Version | MHHS Programme Phase | Sched Status | RAG | Artefact ID | Milestone ID | Text29 | Tier |
| --- | --- | --- | --- | --- | --- | --- | --- | --- | --- | --- | --- | --- | --- | --- | --- | --- | --- | --- | --- | --- | --- | --- | --- | --- | --- | --- | --- | --- | --- | --- |
| 284 | 1.3.6.3.2.2 | **Test Readiness Report** |  | 11d | 2023-09-11 A | 2023-09-25 A |  | 100% |  | 2023-09-08 | 2023-11-17 | 51d | 2023-09-08 | 2023-11-17 |  |  | N/A | 176h | 176h |  | N/A | N/A | 5.0 | Design, Build & Test (PIT) |  |  |  |  |  |  |
| 285 | 1.3.6.3.2.2.1 | Test readiness reporting |  | 11d | 2023-09-11 A | 2023-09-25 A | 282FS+10d | 100% |  | 2023-09-08 | 2023-11-17 | 51d | 2023-09-08 | 2023-11-17 |  |  | Lee Cox | 88h | 88h |  | PP | 109 | 5.0 | Design, Build & Test (PIT) | Complete | COMPLETE |  |  |  |  |
| 286 | 1.3.6.3.2.3 | **Requirements to test Traceability Matrix (RTTM)** |  | 30d | 2023-09-15 A | 2023-10-27 A |  | 100% |  | 2023-09-15 | 2023-10-27 | 30d | 2022-10-31 | 2023-09-29 |  |  | N/A | 240h | 240h | -0 | N/A | N/A | 5.0 | Design, Build & Test (PIT) |  |  |  |  |  |  |
| 287 | 1.3.6.3.2.3.1 | All Metering Services RTTMs submitted to Programme for assurance | milestone | 0d | 2023-09-15 A | 2023-09-15 A | 282FS+15d | 100% |  | 2023-09-15 | 2023-09-15 | 0d | 2023-09-15 | 2023-09-15 |  |  | Lee Cox |  |  |  | PP | SI Test | 5.8 | Design, Build & Test (PIT) | Complete | COMPLETE | MHHS-ART009 | T3-DB-0048 | SITAG | T3 |
| 288 | 1.3.6.3.2.3.2 | All Metering Services MHHS Reviews Completed | milestone | 0d | 2023-10-27 A | 2023-10-27 A | 287FS+30d | 100% |  | 2023-10-27 | 2023-10-27 | 0d | 2023-09-18 | 2023-09-29 |  |  | Lee Cox |  |  |  | SI Test | PP | 5.13 | Design, Build & Test (PIT) | Complete | COMPLETE |  | T3-DB-0135 | SITAG | T3 |
| 289 | 1.3.6.3.2.4 | **Test Scenarios** |  | 30d | 2023-09-15 A | 2023-10-27 A |  | 100% |  | 2023-09-15 | 2023-10-27 | 30d | 2022-10-31 | 2023-09-29 |  |  | N/A | 240h | 240h | -0 | N/A | N/A | 5.0 | Design, Build & Test (PIT) |  |  |  |  |  |  |
| 290 | 1.3.6.3.2.4.1 | All Metering Services test scenarios' submitted to Programme for assurance | milestone | 0d | 2023-09-15 A | 2023-09-15 A | 282FS+15d | 100% |  | 2023-09-15 | 2023-09-15 | 0d | 2023-09-15 | 2023-09-15 |  |  | Lee Cox |  |  |  | PP | SI Test | 5.8 | Design, Build & Test (PIT) | Complete | COMPLETE |  | T3-DB-0050 | SITAG | T3 |
| 291 | 1.3.6.3.2.4.2 | All Metering Services Test scenarios' MHHS Review Completed | milestone | 0d | 2023-10-27 A | 2023-10-27 A | 290FS+30d | 100% |  | 2023-10-27 | 2023-10-27 | 0d | 2023-09-18 | 2023-09-29 |  |  | Lee Cox |  |  |  | SI Test | PP | 5.13 | Design, Build & Test (PIT) | Complete | COMPLETE |  | T3-DB-0136 | SITAG | T3 |
| 292 | 1.3.6.3.2.5 | **PIT execution** |  | 50d | 2023-09-25 A | 2023-12-01 A |  | 100% |  | 2022-10-31 | 2023-12-01 | 285d | 2022-10-31 | 2023-11-17 |  |  | N/A | 1032h | 1032h | -0 | N/A | N/A | 5.0 | Design, Build & Test (PIT) |  |  |  |  |  |  |
| 293 | 1.3.6.3.2.5.1 | PIT Test Execution Progress Report |  | 39d | 2023-09-26 A | 2023-11-17 A | 285 | 100% |  | 2023-09-26 | 2023-11-17 | 39d | 2022-10-31 | 2023-11-10 |  |  | Lee Cox | 312h | 312h |  | PP | SI Test | 5.0 | Design, Build & Test (PIT) | Complete | COMPLETE |  |  |  |  |
| 294 | 1.3.6.3.2.5.2 | PIT Execution |  | 40d | 2023-09-25 A | 2023-11-17 A | 290FS+5d | 100% |  | 2022-10-31 | 2023-11-17 | 275d | 2022-10-31 | 2023-11-17 |  |  | Lee Cox | 320h | 320h |  | PP | SI Test | 5.0 | Design, Build & Test (PIT) | Complete | COMPLETE |  |  |  |  |
| 295 | 1.3.6.3.2.5.3 | All Metering Services PIT Completion Reports submitted to Programme for assurance | milestone | 0d | 2023-11-17 A | 2023-11-17 A | 293, 294 | 100% |  | 2023-11-17 | 2023-11-17 | 0d | 2024-01-05 | 2024-01-05 |  |  | Lee Cox |  |  |  | PP | SI Test | 5.13 | Design, Build & Test (PIT) | Complete | COMPLETE |  | T3-DB-0137 | SITAG | T3 |
| 296 | 1.3.6.3.2.5.4 | All Metering Services PIT Completion Reports MHHS Review Completed | milestone | 0d | 2023-12-01 A | 2023-12-01 A | 283, 288, 291, 295FS+10d | 100% |  | 2023-12-01 | 2023-12-01 | 0d |  |  |  |  | Lee Cox |  |  |  | SI Test | PP | 5.13 | Design, Build & Test (PIT) | Complete | COMPLETE |  | T3-DB-0138 | SITAG | T3 |
| 297 | 1.3.6.3.3 | **All SIT Programme Participants PIT (SIT Functional)** |  | 221d | 2023-11-17 A | 2024-09-20 |  | 60% | 87.32d | 2022-12-30 | 2024-09-20 | 451d | 2022-12-30 | 2024-02-16 | 3d |  | N/A | 11592h | 6468.36h | -0 | N/A | N/A | 5.0 | Design, Build & Test (PIT) |  |  |  |  |  |  |
| 298 | 1.3.6.3.3.1 | **Test Approach & Plans** |  | 40d | 2023-11-17 A | 2024-01-11 A |  | 100% |  | 2023-11-17 | 2024-01-11 | 40d | 2022-12-30 | 2023-11-30 |  |  | N/A | 320h | 320h | -0 | N/A | N/A | 5.2 | Design, Build & Test (PIT) |  |  |  |  |  |  |
| 299 | 1.3.6.3.3.1.1 | SIT Functional PIT Test Approach & Plan (PIT) submitted to Programme for assurance | milestone | 0d | 2023-11-17 A | 2023-11-17 A |  | 100% |  | 2023-11-17 | 2023-11-17 | 0d | 2023-11-16 | 2023-11-16 |  | start no earlier than 2023-11-17 | Lee Cox |  |  |  | PP | SI Test | 5.16 | Design, Build & Test (PIT) | Complete | COMPLETE |  | T3-DB-0093 | SITAG | T3 |
| 300 | 1.3.6.3.3.1.2 | All SIT Functional Test approach and plans MHHS Reviews Completed | milestone | 0d | 2024-01-11 A | 2024-01-11 A | 299FS+40d | 100% |  | 2024-01-11 | 2024-01-11 | 0d | 2023-11-17 | 2023-11-30 |  |  | Lee Cox |  |  |  | SI Test | PP | 5.8 | Design, Build & Test (PIT) | Complete | COMPLETE |  | T3-DB-0139 | SITAG | T3 |
| 301 | 1.3.6.3.3.2 | **Test Readiness Reports** |  | 11d | 2023-12-01 A | 2023-12-15 A |  | 100% |  | 2023-12-01 | 2024-02-09 | 51d | 2023-11-30 | 2024-02-08 |  |  | N/A | 176h | 176h |  | N/A | N/A | 5.2 | Design, Build & Test (PIT) |  |  |  |  |  |  |
| 302 | 1.3.6.3.3.2.1 | Test readiness reporting |  | 11d | 2023-12-01 A | 2023-12-15 A | 299FS+10d | 100% |  | 2023-12-01 | 2023-12-15 | 51d | 2023-11-30 | 2024-02-08 |  |  | Lee Cox | 88h | 88h |  | PP | 109 | 5.2 | Design, Build & Test (PIT) | Complete | COMPLETE |  |  |  |  |
| 303 | 1.3.6.3.3.3 | **Requirements to test Traceability Matrices (RTTM)** |  | 30d | 2023-12-07 A | 2024-01-18 A |  | 100% |  | 2023-12-07 | 2024-01-18 | 30d | 2023-01-06 | 2024-01-05 |  |  | N/A | 240h | 240h | -0 | N/A | N/A | 5.2 | Design, Build & Test (PIT) |  |  |  |  |  |  |
| 304 | 1.3.6.3.3.3.1 | SIT Functional PIT RTTM submitted to Programme for assurance | milestone | 0d | 2023-12-07 A | 2023-12-07 A | 299FS+15d | 100% |  | 2023-12-07 | 2023-12-07 | 0d | 2023-12-14 | 2023-12-14 |  |  | Lee Cox |  |  |  | PP | SI Test | 5.14 | Design, Build & Test (PIT) | Complete | COMPLETE |  | T3-DB-0091 | SITAG | T3 |
| 305 | 1.3.6.3.3.3.2 | All SIT Functional RTTMs MHHS Reviews Completed | milestone | 0d | 2024-01-18 A | 2024-01-18 A | 304FS+30d | 100% |  | 2024-01-18 | 2024-01-18 | 0d | 2023-12-15 | 2024-01-05 |  |  | Lee Cox |  |  |  | SI Test | PP | 5.14 | Design, Build & Test (PIT) | Complete | COMPLETE |  | T3-DB-0140 | SITAG | T3 |
| 306 | 1.3.6.3.3.4 | **Test Scenarios** |  | 30d | 2023-12-07 A | 2024-01-18 A |  | 100% |  | 2023-12-07 | 2024-01-18 | 30d | 2023-01-06 | 2024-01-05 |  |  | N/A | 240h | 240h | -0 | N/A | N/A | 5.2 | Design, Build & Test (PIT) |  |  |  |  |  |  |
| 307 | 1.3.6.3.3.4.1 | SIT Functional PIT test scenarios submitted to Programme for assurance | milestone | 0d | 2023-12-07 A | 2023-12-07 A | 299FS+15d | 100% |  | 2023-12-07 | 2023-12-07 | 0d | 2023-12-14 | 2023-12-14 |  |  | Lee Cox |  |  |  | PP | SI Test | 5.14 | Design, Build & Test (PIT) | Complete | COMPLETE |  | T3-DB-0089 | SITAG | T3 |
| 308 | 1.3.6.3.3.4.2 | All SIT Functional Test scenarios' MHHS Reviews Completed | milestone | 0d | 2024-01-18 A | 2024-01-18 A | 307FS+30d | 100% |  | 2024-01-18 | 2024-01-18 | 0d | 2023-12-15 | 2024-01-05 |  |  | Lee Cox |  |  |  | SI Test | PP | 5.14 | Design, Build & Test (PIT) | Complete | COMPLETE |  | T3-DB-0141 | SITAG | T3 |

Notes:
- 287: 13/9 - name change at TMAG. Red because 9/10 received. Approved at TMAG on 20/9
- 288: 1/9 - to be raised as new T3 at TMAG. Approved at TMAG on 20/9. 17/10 - Red because assurance reviews open comments remain outstanding. Final reviews will be completed no later than 4/12 ahead of Interval 4 Readiness Report
- 290: 13/9 - name change at TMAG Red because 9/10 . Approved at TMAG on 20/9
- 291: 1/9 - to be raised as new T3 at TMAG. Approved at TMAG on 20/9. 17/10 - Red because assurance reviews open comments remain outstanding. Final reviews will be completed no later than 4/12 ahead of Interval 4 Readiness Report
- 295: 1/9 - to be raised as new T3 at TMAG. Approved at TMAG on 20/9. 21/11-Red because not all test completion reports received. No impact. No action
- 296: 1/9 - to be raised as new T3 at TMAG. Approved at TMAG on 20/9.28/11 - Amber because late delivery of some completion reports impairing ability to conclude on time. Expediting reviews ahead of RA 4
- 299: 12/9 - name change to TMAG. Approved at TMAG on 20/9. 5/12-Red because not all test approach and plans received. Escalated at FTIG and PSG. Completed 4/1/24
- 300: 1/9 - to be raised as new T3 at TMAG. Approved at TMAG on 20/9. 16/1- All remaining / late artefacts now received and reviewed by Programme with feedback provided to PPs. Awaiting PPs final feedback. Approved complete at SITAG on 21/2/24
- 304: 12/9 - name and date change to TMAG. Approved at TMAG on 20/9. 20/02 - 1 PP artefact not yet received. Escalated at FTIG
- 305: 1/9 - to be raised as new T3 at TMAG. Approved at TMAG on 20/9. 23/01 - Late due to late delivery of PP artefacts for review
- 307: 12/9 - name and date change to TMAG. Approved at TMAG on 20/9. 20/02 - 2 PP artefacts not yet received. Escalated at FTIG
- 308: 1/9 - to be raised as new T3 at TMAG. Approved at TMAG on 20/9. 12/12 - Late due to late delivery of PP artefacts for review

| ID | WBS | Task | Type | Duration | Start | Finish | Predecessors | Complete | Remaining | Baseline start | Baseline finish | Baseline duration | Baseline 1 start | Baseline 1 finish | Total slack | Free slack | Constraint | Resources | Work | Actual work | Baseline cost | Responsible | Involved | Update Version | MHHS Programme Phase | Sched Status | RAG | Milestone ID | Text29 | Tier | Impact | Task Status |
| --- | --- | --- | --- | --- | --- | --- | --- | --- | --- | --- | --- | --- | --- | --- | --- | --- | --- | --- | --- | --- | --- | --- | --- | --- | --- | --- | --- | --- | --- | --- | --- | --- |
| 309 | 1.3.6.3.3.5 | **PIT execution** |  | 51d | 2023-12-15 A | 2024-02-23 A |  | 100% |  | 2022-12-30 | 2024-02-23 | 301d | 2022-12-30 | 2024-02-09 |  |  |  | N/A | 1056h | 1056h | -0 | N/A | N/A | 5.0 | Design, Build & Test (PIT) |  |  |  |  |  |  |  |
| 310 | 1.3.6.3.3.5.1 | PIT Test Execution Progress Reports |  | 40d | 2023-12-18 A | 2024-02-09 A | 302 | 100% |  | 2023-12-18 | 2024-02-09 | 40d | 2022-12-30 | 2024-02-01 |  |  |  | Lee Cox | 320h | 320h |  | PP | SI Test | 5.0 | Design, Build & Test (PIT) | Complete | COMPLETE |  |  |  |  |  |
| 311 | 1.3.6.3.3.5.2 | PIT Execution |  | 41d | 2023-12-15 A | 2024-02-09 A | 307FS+5d | 100% |  | 2022-12-30 | 2024-02-09 | 290d | 2022-12-30 | 2024-02-09 |  |  |  | Lee Cox | 328h | 328h |  | PP | SI Test | 5.0 | Design, Build & Test (PIT) | Complete | COMPLETE |  |  |  |  |  |
| 312 | 1.3.6.3.3.5.3 | All SIT Functional PIT Completion Reports submitted to Programme for Assurance | milestone | 0d | 2024-02-09 A | 2024-02-09 A | 310, 311 | 100% |  | 2024-02-09 | 2024-02-09 | 0d | 2024-01-05 | 2024-01-05 |  |  |  | Lee Cox |  |  |  | PP | SI Test | 5.19 | Design, Build & Test (PIT) | Complete | COMPLETE | T3-DB-0087 | SITAG | T3 |  |  |
| 313 | 1.3.6.3.3.5.4 | All SIT Functional PIT Completion Reports MHHS Review Completed | milestone | 0d | 2024-02-23 A | 2024-02-23 A | 300, 305, 308, 312FS+10d | 100% |  | 2024-02-23 | 2024-02-23 | 0d |  |  |  |  |  | Lee Cox |  |  |  | SI Test | PP | 5.19 | Design, Build & Test (PIT) | Complete | COMPLETE | T3-DB-0142 | SITAG | T3 |  |  |
| 314 | 1.3.6.3.3.6 | **All SIT Programme Participants PIT (SIT Migration)** |  | 71d | 2024-02-16 A | 2024-05-24 A |  | 100% |  | 2023-03-31 | 2024-05-24 | 301d |  |  |  |  |  | N/A | 2600h | 2600h | -0 | N/A | N/A | 5.1 | Design, Build & Test (PIT) |  |  |  |  |  |  |  |
| 315 | 1.3.6.3.3.6.1 | **Test Approach & Plans** |  | 40d | 2024-02-16 A | 2024-04-11 A |  | 100% |  | 2024-02-16 | 2024-04-11 | 40d |  |  |  |  |  | N/A | 320h | 320h | -0 | N/A | N/A | 5.2 | Design, Build & Test (PIT) |  |  |  |  |  |  |  |
| 316 | 1.3.6.3.3.6.1.1 | All SIT Migration PIT Test Approach & Plans submitted to Programme for assurance | milestone | 0d | 2024-02-16 A | 2024-02-16 A |  | 100% |  | 2024-02-16 | 2024-02-16 | 0d |  |  |  |  | start no earlier than 2024-02-16 | Lee Cox |  |  |  | PP | SI Test | 5.8 | Design, Build & Test (PIT) | Complete | COMPLETE | T3-DB-0143 | SITAG | T3 |  |  |
| 317 | 1.3.6.3.3.6.1.2 | All SIT Migration PIT Test approach and plans MHHS Reviews Completed | milestone | 0d | 2024-04-11 A | 2024-04-11 A | 316FS+40d | 100% |  | 2024-04-11 | 2024-04-11 | 0d |  |  |  |  |  | Lee Cox |  |  |  | SI Test | PP | 5.23 | Design, Build & Test (PIT) | Complete | COMPLETE | T3-DB-0144 | SITAG | T3 |  |  |
| 318 | 1.3.6.3.3.6.2 | **Test Readiness Reports** |  | 11d | 2024-03-01 A | 2024-03-15 A |  | 100% |  | 2024-03-01 | 2024-05-10 | 51d |  |  |  |  |  | N/A | 176h | 176h |  | N/A | N/A | 5.2 | Design, Build & Test (PIT) |  |  |  |  |  |  |  |
| 319 | 1.3.6.3.3.6.2.1 | Test readiness reporting |  | 11d | 2024-03-01 A | 2024-03-15 A | 316FS+10d | 100% |  | 2024-03-01 | 2024-05-10 | 51d |  |  |  |  |  | Lee Cox | 88h | 88h |  | PP | 109 | 5.2 | Design, Build & Test (PIT) | Complete | COMPLETE |  |  |  |  |  |
| 320 | 1.3.6.3.3.6.3 | **Requirements to test Traceability Matrices (RTTM)** |  | 30d | 2024-03-07 A | 2024-04-18 A |  | 100% |  | 2024-03-07 | 2024-04-18 | 30d |  |  |  |  |  | N/A | 240h | 240h | -0 | N/A | N/A | 5.2 | Design, Build & Test (PIT) |  |  |  |  |  |  |  |
| 321 | 1.3.6.3.3.6.3.1 | All SIT Migration PIT RTTMs submitted to Programme for assurance | milestone | 0d | 2024-03-07 A | 2024-03-07 A | 316FS+15d | 100% |  | 2024-03-07 | 2024-03-07 | 0d |  |  |  |  |  | Lee Cox |  |  |  | PP | SI Test | 5.23 | Design, Build & Test (PIT) | Complete | COMPLETE | T3-DB-0145 | SITAG | T3 |  |  |
| 322 | 1.3.6.3.3.6.3.2 | All SIT Migration RTTMs MHHS Reviews Completed | milestone | 0d | 2024-04-18 A | 2024-04-18 A | 321FS+30d | 100% |  | 2024-04-18 | 2024-04-18 | 0d |  |  |  |  |  | Lee Cox |  |  |  | SI Test | PP | 5.25 | Design, Build & Test (PIT) | Complete | COMPLETE | T3-DB-0146 | SITAG | T3 |  |  |
| 323 | 1.3.6.3.3.6.4 | **Test Scenarios** |  | 30d | 2024-03-07 A | 2024-04-18 A |  | 100% |  | 2024-03-07 | 2024-04-18 | 30d |  |  |  |  |  | N/A | 240h | 240h | -0 | N/A | N/A | 5.2 | Design, Build & Test (PIT) |  |  |  |  |  |  |  |
| 324 | 1.3.6.3.3.6.4.1 | All SIT Migration PIT test scenarios submitted to Programme for assurance | milestone | 0d | 2024-03-07 A | 2024-03-07 A | 316FS+15d | 100% |  | 2024-03-07 | 2024-03-07 | 0d |  |  |  |  |  | Lee Cox |  |  |  | PP | SI Test | 5.23 | Design, Build & Test (PIT) | Complete | COMPLETE | T3-DB-0147 | SITAG | T3 |  |  |
| 325 | 1.3.6.3.3.6.4.2 | All SIT Migration Test scenarios MHHS Reviews Completed | milestone | 0d | 2024-04-18 A | 2024-04-18 A | 324FS+30d | 100% |  | 2024-04-18 | 2024-04-18 | 0d |  |  |  |  |  | Lee Cox |  |  |  | SI Test | PP | 5.25 | Design, Build & Test (PIT) | Complete | COMPLETE | T3-DB-0148 | SITAG | T3 |  |  |
| 326 | 1.3.6.3.3.6.5 | **PIT execution** |  | 51d | 2024-03-15 A | 2024-05-24 A |  | 100% |  | 2023-03-31 | 2024-05-24 | 301d |  |  |  |  |  | N/A | 1056h | 1056h | -0 | N/A | N/A | 5.1 | Design, Build & Test (PIT) |  |  |  |  |  |  |  |
| 327 | 1.3.6.3.3.6.5.1 | PIT Test Execution Progress Reports |  | 40d | 2024-03-18 A | 2024-05-10 A | 319 | 100% |  | 2024-03-18 | 2024-05-10 | 40d |  |  |  |  |  | Lee Cox | 320h | 320h |  | PP | SI Test | 5.1 | Design, Build & Test (PIT) | Complete | COMPLETE |  |  |  |  |  |
| 328 | 1.3.6.3.3.6.5.2 | PIT Execution |  | 41d | 2024-03-15 A | 2024-05-10 A | 324FS+5d | 100% |  | 2023-03-31 | 2024-05-10 | 290d |  |  |  |  |  | Lee Cox | 328h | 328h |  | PP | SI Test | 5.1 | Design, Build & Test (PIT) | Complete | COMPLETE |  |  |  |  |  |
| 329 | 1.3.6.3.3.6.5.3 | All SIT Migration PIT Completion Reports submitted to Programme for assurance | milestone | 0d | 2024-05-10 A | 2024-05-10 A | 327, 328 | 100% |  | 2024-05-10 | 2024-05-10 | 0d | 2024-01-05 | 2024-01-05 |  |  |  | Lee Cox |  |  |  | PP | SI Test | 5.8 | Design, Build & Test (PIT) | Complete | COMPLETE | T3-DB-0149 | SITAG | T3 |  |  |
| 330 | 1.3.6.3.3.6.5.4 | All SIT Migration PIT Completion Reports MHHS Review Completed | milestone | 0d | 2024-05-24 A | 2024-05-24 A | 317, 322, 325, 329FS+10d | 100% |  | 2024-05-24 | 2024-05-24 | 0d |  |  |  |  |  | Lee Cox |  |  |  | SI Test | PP | 5.8 | Design, Build & Test (PIT) | Complete | COMPLETE | T3-DB-0150 | SITAG | T3 |  |  |
| 331 | 1.3.6.3.3.7 | **All SIT Programme Participants PIT (SIT Non Functional)** |  | 71d | 2024-05-10 A | 2024-08-16 |  | 42% | 41.35d | 2023-06-23 | 2024-08-16 | 301d |  |  | 11d |  |  | N/A | 2592h | 766.89h | -0 | N/A | N/A | 5.1 | Design, Build & Test (PIT) |  |  |  |  |  |  |  |
| 332 | 1.3.6.3.3.7.1 | **Test Approach & Plan** |  | 40d | 2024-05-10 | 2024-07-04 |  |  |  | 2024-05-10 | 2024-07-04 | 40d |  |  | 14d |  |  | N/A | 320h |  | -0 | N/A | N/A | 5.2 | Design, Build & Test (PIT) |  |  |  |  |  |  |  |
| 333 | 1.3.6.3.3.7.1.1 | SIT Non-Functional PIT Test Approach & Plan (PIT) submitted to Programme for assurance | milestone | 0d | 2024-05-10 | 2024-05-10 |  |  |  | 2024-05-10 | 2024-05-10 | 0d |  |  | 14d | 0d | start no earlier than 2024-05-10 | Lee Cox |  |  |  | PP | SI Test | 5.8 | Design, Build & Test (PIT) | Overdue Start | RED | T3-DB-0151 | SITAG | T3 | 26/6: Increased risk to non functional PIT completion | -47.67 |
| 334 | 1.3.6.3.3.7.1.2 | SIT Non-Functional Test approach and plan MHHS Review Completed | milestone | 0d | 2024-07-04 | 2024-07-04 | 333FS+40d |  |  | 2024-07-04 | 2024-07-04 | 0d |  |  | 42d | 31d |  | Lee Cox |  |  |  | SI Test | PP | 5.8 | Design, Build & Test (PIT) | Green | AMBER | T3-DB-0152 | SITAG | T3 | 26/6: Increased risk to non functional PIT completion | 7.71 |

Notes:
- 310: 16/4: completed 12/4
- 311: 16/4: completed 12/4
- 312: 1/9 - name change at TMAG. Approved at TMAG on 20/9. 20/2 - 23 reports received. The majority of late deliveries have been discussed and agreed with the Programme.5/3 - Approved 1/3 SITAG with work off
- 313: 1/9 - to be raised as new T3 at TMAG. Approved at TMAG on 20/9. 27/2 - Target date missed due to late delivery of some reports. 5/3 - Approved 1/3 SITAG with work off
- 316: 1/9 - to be raised as new T3 at TMAG. Approved at TMAG on 20/9.. 19/3 - 33/35 received
- 317: 1/9 - to be raised as new T3 at TMAG. Approved at TMAG on 20/9. 26/3: At risk because of late delivery of PIT test approach and plans by PPs. 16/4: All received. All but 1 reviewed
- 321: 1/9 - to be raised as new T3 at TMAG. Approved at TMAG on 20/9. 22/04: 33/34 received. Remainder to be chased
- 322: 1/9 - to be raised as new T3 at TMAG. Approved at TMAG on 20/9. 26/3: At risk because of late delivery of RTTMs by PPs 30/4: Late because of late delivery or RTTMS 33/34 reviewed
- 324: 1/9 - to be raised as new T3 at TMAG. Approved at TMAG on 20/9. 22/04: 31/34 received. Remainder to be chased
- 325: 1/9 - to be raised as new T3 at TMAG. Approved at TMAG on 20/9. 26/3: At risk because of late delivery of PIT test scenarios by PPs. 30/4: Late because of late delivery or Test scenarios. 33/34 reviewed
- 329: Sufficient PIT completion reports on track, some are known to be late. 11/6: 29/33 received. Small number of PPs will be PIT complete late, but before SIT migration. 1 PP will be post SIT Migration start. 11/6: eSITAG approved on 3/6 subject to Work-off
- 330: 1/9 - to be raised as new T3 at TMAG. Approved at TMAG on 20/9. 14/5: Won't deliver to forecast because of late delivery of by some PPs of PIT completion report. 11/6: eSITAG approved on 3/6 subject to Work-off
- 333: 1/9 - to be raised as new T3 at TMAG. Approved at TMAG on 20/9. 18/6: 30/34 received / Action: 26/6: Obtain outstanding test approach and plans. Can't reforecast as can't control PPs delivery / Issue: 26/6: 30/34 plans submitted
- 334: 1/9 - to be raised as new T3 at TMAG. Approved at TMAG on 20/9. 4/6: At risk because not all test approach and plans received / Action: 26/6: Obtain outstanding test approach and plans. Can't reforecast as can't control PPs delivery / Issue: 26/6: At risk because dependant on delivery of all test approach and plans

| ID | WBS | Task | Type | Duration | Start | Finish | Predecessors | Complete | Remaining | Baseline start | Baseline finish | Baseline duration | Baseline 1 start | Baseline 1 finish | Total slack | Free slack | Constraint | Resources | Work | Actual work | Baseline cost | Responsible | Involved | Update Version | MHHS Programme Phase | Sched Status | RAG | Task Status | Issue | Milestone ID | Text29 | Tier |
| --- | --- | --- | --- | --- | --- | --- | --- | --- | --- | --- | --- | --- | --- | --- | --- | --- | --- | --- | --- | --- | --- | --- | --- | --- | --- | --- | --- | --- | --- | --- | --- | --- |
| 335 | 1.3.6.3.3.7.2 | **Test Readiness Report** |  | 11d | 2024-05-24 A | 2024-06-07 A |  | 100% |  | 2024-05-24 | 2024-08-02 | 51d |  |  |  |  |  | N/A | 176h | 176h |  | N/A | N/A | 5.2 | Design, Build & Test (PIT) |  |  |  |  |  |  |  |
| 336 | 1.3.6.3.3.7.2.1 | Test readiness reporting |  | 11d | 2024-05-24 A | 2024-06-07 A | 333FS+10d | 100% |  | 2024-05-24 | 2024-08-02 | 51d |  |  |  |  |  | Lee Cox | 88h | 88h |  | PP | 109 | 5.2 | Design, Build & Test (PIT) | Complete | COMPLETE |  |  |  |  |  |
| 337 | 1.3.6.3.3.7.3 | **Requirements to test Traceability Matrix (RTTM)** |  | 30d | 2024-05-30 | 2024-07-11 |  |  |  | 2024-05-30 | 2024-07-11 | 30d |  |  | 37d |  |  | N/A | 240h |  | -0 | N/A | N/A | 5.2 | Design, Build & Test (PIT) |  |  |  |  |  |  |  |
| 338 | 1.3.6.3.3.7.3.1 | SIT Non-Functional PIT RTTM submitted to Programme for assurance | milestone | 0d | 2024-05-30 | 2024-05-30 | 333FS+15d |  |  | 2024-05-30 | 2024-05-30 | 0d |  |  | 37d | 0d |  | Lee Cox |  |  |  | PP | SI Test | 5.8 | Design, Build & Test (PIT) | Overdue Start | RED | -27.29 | 26/6: 28/34 submitted | T3-DB-0153 | SITAG | T3 |
| 339 | 1.3.6.3.3.7.3.2 | SIT Non-Functional RTTM MHHS Review Completed | milestone | 0d | 2024-07-11 | 2024-07-11 | 338FS+30d |  |  | 2024-07-11 | 2024-07-11 | 0d |  |  | 37d | 26d |  | Lee Cox |  |  |  | SI Test | PP | 5.8 | Design, Build & Test (PIT) | Green | AMBER | 14.71 |  | T3-DB-0154 | SITAG | T3 |
| 340 | 1.3.6.3.3.7.4 | **Test Scenarios** |  | 30d | 2024-05-30 | 2024-07-11 |  |  |  | 2024-05-30 | 2024-07-11 | 30d |  |  | 14d |  |  | N/A | 240h |  | -0 | N/A | N/A | 5.2 | Design, Build & Test (PIT) |  |  |  |  |  |  |  |
| 341 | 1.3.6.3.3.7.4.1 | SIT Non-Functional PIT test scenarios submitted to Programme for assurance | milestone | 0d | 2024-05-30 | 2024-05-30 | 333FS+15d |  |  | 2024-05-30 | 2024-05-30 | 0d |  |  | 14d | 0d |  | Lee Cox |  |  |  | PP | SI Test | 5.8 | Design, Build & Test (PIT) | Overdue Start | RED | -27.29 | 26/6: 28/34 | T3-DB-0155 | SITAG | T3 |
| 342 | 1.3.6.3.3.7.4.2 | SIT Non-Functional Test scenarios MHHS Review Completed | milestone | 0d | 2024-07-11 | 2024-07-11 | 341FS+30d |  |  | 2024-07-11 | 2024-07-11 | 0d |  |  | 37d | 26d |  | Lee Cox |  |  |  | SI Test | PP | 5.8 | Design, Build & Test (PIT) | Green | AMBER | 14.71 |  | T3-DB-0156 | SITAG | T3 |
| 343 | 1.3.6.3.3.7.5 | **PIT execution** |  | 51d | 2024-06-07 A | 2024-08-16 |  | 34% | 33.79d | 2023-06-23 | 2024-08-16 | 301d |  |  | 11d |  |  | N/A | 1048h | 353.7h | -0 | N/A | N/A | 5.1 | Design, Build & Test (PIT) |  |  |  |  |  |  |  |
| 344 | 1.3.6.3.3.7.5.1 | PIT Test Execution Progress Report |  | 39d | 2024-06-10 A | 2024-08-01 | 336 | 33% | 26d | 2024-06-10 | 2024-08-01 | 39d |  |  | 12d | 1d |  | Lee Cox | 312h | 104h |  | PP | SI Test | 5.1 | Design, Build & Test (PIT) | Green | GREEN |  |  |  |  |  |
| 345 | 1.3.6.3.3.7.5.2 | PIT Execution |  | 41d | 2024-06-07 A | 2024-08-02 | 341FS+5d | 34% | 27d | 2023-06-23 | 2024-08-02 | 290d |  |  | 11d | 0d |  | Lee Cox | 328h | 112h |  | PP | SI Test | 5.1 | Design, Build & Test (PIT) | yellow | GREEN |  |  |  |  |  |
| 346 | 1.3.6.3.3.7.5.3 | SIT Non-Functional PIT Completion Report submitted to Programme for assurance | milestone | 0d | 2024-08-02 | 2024-08-02 | 344, 345 |  |  | 2024-08-02 | 2024-08-02 | 0d | 2024-01-05 | 2024-01-05 | 11d | 0d |  | Lee Cox |  |  |  | PP | SI Test | 5.10 | Design, Build & Test (PIT) | Green | GREEN | 36.71 |  | T3-DB-0157 | SITAG | T3 |
| 347 | 1.3.6.3.3.7.5.4 | SIT Non-Functional PIT Completion Report MHHS Review Completed | milestone | 0d | 2024-08-16 | 2024-08-16 | 334, 339, 342, 346FS+10d |  |  | 2024-08-16 | 2024-08-16 | 0d |  |  | 11d | 6d |  | Lee Cox |  |  |  | SI Test | PP | 5.8 | Design, Build & Test (PIT) | Green | GREEN | 50.71 |  | T3-DB-0158 | SITAG | T3 |
| 348 | 1.3.6.3.3.8 | **All SIT Programme Participants PIT (SIT Operational)** |  | 71d | 2024-06-14 | 2024-09-20 |  |  |  | 2024-06-14 | 2024-09-20 | 71d |  |  | 3d |  |  | N/A | 2600h |  | -0 | N/A | N/A | 5.1 | Design, Build & Test (PIT) |  |  |  |  |  |  |  |
| 349 | 1.3.6.3.3.8.1 | **Test Approach & Plan** |  | 40d | 2024-06-14 | 2024-08-08 |  |  |  | 2024-06-14 | 2024-08-08 | 40d |  |  | 3d |  |  | N/A | 320h |  | -0 | N/A | N/A | 5.2 | Design, Build & Test (PIT) |  |  |  |  |  |  |  |
| 350 | 1.3.6.3.3.8.1.1 | SIT Operational PIT Test Approach & Plan (PIT) submitted to Programme for assurance | milestone | 0d | 2024-06-14 | 2024-06-14 |  |  |  | 2024-06-14 | 2024-06-14 | 0d |  |  | 3d | 0d | start no earlier than 2024-06-14 | Lee Cox |  |  |  | PP | SI Test | 5.8 | Design, Build & Test (PIT) | Overdue Start | RED | -12.67 | 26/6: 18/34 | T3-DB-0159 | SITAG | T3 |
| 351 | 1.3.6.3.3.8.1.2 | SIT Operational Test approach and plan MHHS Review Completed | milestone | 0d | 2024-08-08 | 2024-08-08 | 350FS+40d |  |  | 2024-08-08 | 2024-08-08 | 0d |  |  | 34d | 31d |  | Lee Cox |  |  |  | SI Test | PP | 5.8 | Design, Build & Test (PIT) | Green | AMBER | 42.71 |  | T3-DB-0160 | SITAG | T3 |
| 352 | 1.3.6.3.3.8.2 | **Test Readiness Report** |  | 11d | 2024-06-28 | 2024-07-12 |  |  |  | 2024-06-28 | 2024-09-06 | 51d |  |  | 3d |  |  | N/A | 176h |  |  | N/A | N/A | 5.2 | Design, Build & Test (PIT) |  |  |  |  |  |  |  |
| 353 | 1.3.6.3.3.8.2.1 | Test readiness reporting |  | 11d | 2024-06-28 | 2024-07-12 | 350FS+10d |  |  | 2024-06-28 | 2024-09-06 | 51d |  |  | 3d | 0d |  | Lee Cox | 88h |  |  | PP | 109 | 5.2 | Design, Build & Test (PIT) | Green | GREEN | 1.33 |  |  |  |  |
| 354 | 1.3.6.3.3.8.3 | **Requirements to test Traceability Matrix (RTTM)** |  | 30d | 2024-07-04 | 2024-08-15 |  |  |  | 2024-07-04 | 2024-08-15 | 30d |  |  | 29d |  |  | N/A | 240h |  | -0 | N/A | N/A | 5.2 | Design, Build & Test (PIT) |  |  |  |  |  |  |  |
| 355 | 1.3.6.3.3.8.3.1 | SIT Operational PIT RTTM submitted to Programme for assurance | milestone | 0d | 2024-07-04 | 2024-07-04 | 350FS+15d |  |  | 2024-07-04 | 2024-07-04 | 0d |  |  | 29d | 0d |  | Lee Cox |  |  |  | PP | SI Test | 5.8 | Design, Build & Test (PIT) | Green | GREEN | 7.71 |  | T3-DB-0161 | SITAG | T3 |
| 356 | 1.3.6.3.3.8.3.2 | SIT Operational RTTM MHHS Review Completed | milestone | 0d | 2024-08-15 | 2024-08-15 | 355FS+30d |  |  | 2024-08-15 | 2024-08-15 | 0d |  |  | 29d | 26d |  | Lee Cox |  |  |  | SI Test | PP | 5.8 | Design, Build & Test (PIT) | Green | GREEN | 49.71 |  | T3-DB-0162 | SITAG | T3 |
| 357 | 1.3.6.3.3.8.4 | **Test Scenarios** |  | 30d | 2024-07-04 | 2024-08-15 |  |  |  | 2024-07-04 | 2024-08-15 | 30d |  |  | 3d |  |  | N/A | 240h |  | -0 | N/A | N/A | 5.2 | Design, Build & Test (PIT) |  |  |  |  |  |  |  |
| 358 | 1.3.6.3.3.8.4.1 | SIT Operational PIT test scenarios submitted to Programme for assurance | milestone | 0d | 2024-07-04 | 2024-07-04 | 350FS+15d |  |  | 2024-07-04 | 2024-07-04 | 0d |  |  | 3d | 0d |  | Lee Cox |  |  |  | PP | SI Test | 5.8 | Design, Build & Test (PIT) | Green | GREEN | 7.71 |  | T3-DB-0163 | SITAG | T3 |
| 359 | 1.3.6.3.3.8.4.2 | SIT Operational Test scenarios MHHS Review Completed | milestone | 0d | 2024-08-15 | 2024-08-15 | 358FS+30d |  |  | 2024-08-15 | 2024-08-15 | 0d |  |  | 29d | 26d |  | Lee Cox |  |  |  | SI Test | PP | 5.8 | Design, Build & Test (PIT) | Green | GREEN | 49.71 |  | T3-DB-0164 | SITAG | T3 |

Notes:
- 338: 1/9 - to be raised as new T3 at TMAG. Approved at TMAG on 20/9. 18/6: 27/34 received
- 339: 1/9 - to be raised as new T3 at TMAG. Approved at TMAG on 20/9. 4/6: at risk due to late delivery of RTTMs
- 341: 1/9 - to be raised as new T3 at TMAG. Approved at TMAG on 20/9. 18/6 - 28/34 received
- 342: 1/9 - to be raised as new T3 at TMAG. Approved at TMAG on 20/9. 4/6 - At risk due to late delivery of PIT Test Scenarios
- 346: 1/9 - to be raised as new T3 at TMAG. Approved at TMAG on 20/9. 6/10 - Submit to TMAG for name change to remove IT. Approved for date change at TMAG on 23/10/23
- 347: 1/9 - to be raised as new T3 at TMAG. Approved at TMAG on 20/9.
- 350: 1/9 - to be raised as new T3 at TMAG. Approved at TMAG on 20/9. 18/6: 17/34 received
- 351: 1/9 - to be raised as new T3 at TMAG. Approved at TMAG on 20/9. 18/6: At risk due to potential late delivery of Test Approach and Plans
- 355: 1/9 - to be raised as new T3 at TMAG. Approved at TMAG on 20/9.
- 356: 1/9 - to be raised as new T3 at TMAG. Approved at TMAG on 20/9.
- 358: 1/9 - to be raised as new T3 at TMAG. Approved at TMAG on 20/9.
- 359: 1/9 - to be raised as new T3 at TMAG. Approved at TMAG on 20/9.

| ID | WBS | Task | Type | Duration | Start | Finish | Predecessors | Complete | Baseline start | Baseline finish | Baseline duration | Baseline 1 start | Baseline 1 finish | Total slack | Free slack | Constraint | Resources | Work | Actual work | Baseline cost | Responsible | Involved | Update Version | MHHS Programme Phase | Task Status | Sched Status | RAG | Milestone ID | Text29 | Tier | Artefact ID |
| --- | --- | --- | --- | --- | --- | --- | --- | --- | --- | --- | --- | --- | --- | --- | --- | --- | --- | --- | --- | --- | --- | --- | --- | --- | --- | --- | --- | --- | --- | --- | --- |
| 360 | 1.3.6.3.3.8.5 | **PIT execution** |  | 51d | 2024-07-12 | 2024-09-20 |  |  | 2024-07-12 | 2024-09-20 | 51d |  |  | 3d |  |  | N/A | 1056h |  | -0 | N/A | N/A | 5.1 | Design, Build & Test (PIT) |  |  |  |  |  |  |  |
| 361 | 1.3.6.3.3.8.5.1 | PIT Test Execution Progress Report |  | 40d | 2024-07-15 | 2024-09-06 | 353 |  | 2024-07-15 | 2024-09-06 | 40d |  |  | 3d | 0d |  | Lee Cox | 320h |  |  | PP | SI Test | 5.1 | Design, Build & Test (PIT) | 18.33 | Green | GREEN |  |  |  |  |
| 362 | 1.3.6.3.3.8.5.2 | PIT Execution |  | 41d | 2024-07-12 | 2024-09-06 | 358FS+5d |  | 2024-07-12 | 2024-09-06 | 41d |  |  | 3d | 0d |  | Lee Cox | 328h |  |  | PP | SI Test | 5.1 | Design, Build & Test (PIT) | 15.33 | Green | GREEN |  |  |  |  |
| 363 | 1.3.6.3.3.8.5.3 | SIT Operational PIT Completion Report submitted to Programme for assurance | milestone | 0d | 2024-09-06 | 2024-09-06 | 361, 362 |  | 2024-09-06 | 2024-09-06 | 0d | 2024-01-05 | 2024-01-05 | 3d | 0d |  | Lee Cox |  |  |  | PP | SI Test | 5.10 | Design, Build & Test (PIT) | 71.71 | Green | GREEN | T3-DB-0165 | SITAG | T3 |  |
| 364 | 1.3.6.3.3.8.5.4 | SIT Operational PIT Completion Report MHHS Review Completed | milestone | 0d | 2024-09-20 | 2024-09-20 | 351, 356, 359, 363FS+10d |  | 2024-09-20 | 2024-09-20 | 0d |  |  | 3d |  |  | Lee Cox |  |  |  | SI Test | PP | 5.8 | Design, Build & Test (PIT) | 85.71 | Green | GREEN | T3-DB-0166 | SITAG | T3 |  |
| 365 | 1.3.6.3.4 | **All Suppliers DBT CIT (Entering at Interval 5)** |  | 71d | 2023-09-15 A | 2023-12-22 A |  | 100% | 2022-10-31 | 2023-12-22 | 300d | 2022-10-31 | 2025-03-14 |  |  |  | N/A | 2280h | 2280h | -0 | N/A | N/A | 5.0 | Design, Build & Test (PIT) |  |  |  |  |  |  |  |
| 366 | 1.3.6.3.4.1 | **Test Approach & Plan** |  | 20d | 2023-09-15 A | 2023-10-12 A |  | 100% | 2023-09-15 | 2023-10-12 | 19d | 2022-10-31 | 2023-09-29 |  |  |  | N/A | 160h | 160h | -0 | N/A | N/A | 5.0 | Design, Build & Test (PIT) |  |  |  |  |  |  |  |
| 367 | 1.3.6.3.4.1.1 | All SIT Suppliers Test Approach & Plans (PIT) submitted to Programme for assurance | milestone | 0d | 2023-09-15 A | 2023-09-15 A |  | 100% | 2023-09-15 | 2023-09-15 | 0d | 2023-09-15 | 2023-09-15 |  |  | start no earlier than 2023-09-15 | Lee Cox |  |  |  | PP | SI Test | 5.8 | Design, Build & Test (PIT) |  | Complete | COMPLETE | T3-DB-0046 | SITAG | T3 |  |
| 368 | 1.3.6.3.4.1.2 | All SIT Suppliers Test Approach & Plans MHHS Review Completed | milestone | 0d | 2023-10-12 A | 2023-10-12 A | 367FS+20d | 100% | 2023-10-12 | 2023-10-12 | 0d | 2023-09-18 | 2023-09-29 |  |  |  | Lee Cox |  |  |  | SI Test | PP | 5.8 | Design, Build & Test (PIT) |  | Complete | COMPLETE | T3-DB-0167 | SITAG | T3 |  |
| 369 | 1.3.6.3.4.2 | **Test Readiness Report** |  | 11d | 2023-09-29 A | 2023-10-13 A |  | 100% | 2023-09-29 | 2023-12-08 | 51d | 2023-09-29 | 2023-12-08 |  |  |  | N/A | 176h | 176h |  | N/A | N/A | 5.0 | Design, Build & Test (PIT) |  |  |  |  |  |  |  |
| 370 | 1.3.6.3.4.2.1 | Test readiness reporting |  | 11d | 2023-09-29 A | 2023-10-13 A | 367FS+10d | 100% | 2023-09-29 | 2023-12-08 | 51d | 2023-09-29 | 2023-12-08 |  |  |  | Lee Cox | 88h | 88h |  | PP | 109 | 5.0 | Design, Build & Test (PIT) |  | Complete | COMPLETE |  |  |  |  |
| 371 | 1.3.6.3.4.3 | **Requirements to test Traceability Matrix (RTTM)** |  | 20d | 2023-10-06 A | 2023-11-03 A |  | 100% | 2023-10-06 | 2023-11-03 | 21d | 2022-10-31 | 2023-10-20 |  |  |  | N/A | 160h | 160h | -0 | N/A | N/A | 5.0 | Design, Build & Test (PIT) |  |  |  |  |  |  |  |
| 372 | 1.3.6.3.4.3.1 | All SIT Suppliers RTTMs submitted to Programme for assurance | milestone | 0d | 2023-10-06 A | 2023-10-06 A | 367FS+16d | 100% | 2023-10-06 | 2023-10-06 | 1d | 2023-10-06 | 2023-10-06 |  |  |  | Lee Cox |  |  |  | PP | SI Test | 5.8 | Design, Build & Test (PIT) |  | Complete | COMPLETE | T3-DB-0064 | SITAG | T3 | MHHS-ART009 |
| 373 | 1.3.6.3.4.3.2 | All SIT Suppliers RTTMs MHHS Review Completed | milestone | 0d | 2023-11-03 A | 2023-11-03 A | 372FS+20d | 100% | 2023-11-03 | 2023-11-03 | 0d | 2023-10-09 | 2023-10-20 |  |  |  | Lee Cox |  |  |  | SI Test | PP | 5.14 | Design, Build & Test (PIT) |  | Complete | COMPLETE | T3-DB-0168 | SITAG | T3 |  |
| 374 | 1.3.6.3.4.4 | **Test Scenarios** |  | 20d | 2023-10-05 A | 2023-11-02 A |  | 100% | 2023-10-05 | 2023-11-02 | 20d | 2022-10-31 | 2023-10-20 |  |  |  | N/A | 160h | 160h | -0 | N/A | N/A | 5.0 | Design, Build & Test (PIT) |  |  |  |  |  |  |  |
| 375 | 1.3.6.3.4.4.1 | All SIT Suppliers test scenarios' submitted to Programme for assurance | milestone | 0d | 2023-10-05 A | 2023-10-05 A | 367FS+15d | 100% | 2023-10-05 | 2023-10-05 | 0d | 2023-10-06 | 2023-10-06 |  |  |  | Lee Cox |  |  |  | PP | SI Test | 5.8 | Design, Build & Test (PIT) |  | Complete | COMPLETE | T3-DB-0037 | SITAG | T3 |  |
| 376 | 1.3.6.3.4.4.2 | All SIT Suppliers Test scenarios' MHHS Review Completed | milestone | 0d | 2023-11-02 A | 2023-11-02 A | 375FS+20d | 100% | 2023-11-02 | 2023-11-02 | 0d | 2023-10-09 | 2023-10-20 |  |  |  | Lee Cox |  |  |  | SI Test | PP | 5.14 | Design, Build & Test (PIT) |  | Complete | COMPLETE | T3-DB-0169 | SITAG | T3 |  |
| 377 | 1.3.6.3.4.5 | **PIT execution** |  | 51d | 2023-10-13 A | 2023-12-22 A |  | 100% | 2022-10-31 | 2023-12-22 | 300d | 2022-10-31 | 2023-12-08 |  |  |  | N/A | 1056h | 1056h | -0 | N/A | N/A | 5.0 | Design, Build & Test (PIT) |  |  |  |  |  |  |  |
| 378 | 1.3.6.3.4.5.1 | PIT Test Execution Progress Report |  | 40d | 2023-10-16 A | 2023-12-08 A | 375FS+5d, 370 | 100% | 2023-10-16 | 2023-12-08 | 40d | 2022-10-31 | 2023-12-01 |  |  |  | Lee Cox | 320h | 320h |  | PP | SI Test | 5.0 | Design, Build & Test (PIT) |  | Complete | COMPLETE |  |  |  |  |
| 379 | 1.3.6.3.4.5.2 | PIT Execution |  | 41d | 2023-10-13 A | 2023-12-08 A | 375FS+5d | 100% | 2022-10-31 | 2023-12-08 | 290d | 2022-10-31 | 2023-12-08 |  |  |  | Lee Cox | 328h | 328h |  | PP | SI Test | 5.0 | Design, Build & Test (PIT) |  | Complete | COMPLETE |  |  |  |  |
| 380 | 1.3.6.3.4.5.3 | All SIT Suppliers PIT Completion Reports submitted to Programme for assurance | milestone | 0d | 2023-12-08 A | 2023-12-08 A | 379, 378 | 100% | 2023-12-08 | 2023-12-08 | 0d | 2024-01-05 | 2024-01-05 |  |  |  | Lee Cox |  |  |  | PP | SI Test | 5.14 | Design, Build & Test (PIT) |  | Complete | COMPLETE | T3-DB-0170 | SITAG | T3 |  |
| 381 | 1.3.6.3.4.5.4 | All SIT Suppliers PIT Completion Reports MHHS Review Completed | milestone | 0d | 2023-12-22 A | 2023-12-22 A | 380FS+10d, 368, 373, 376 | 100% | 2023-12-22 | 2023-12-22 | 0d |  |  |  |  |  | Lee Cox |  |  |  | SI Test | PP | 5.14 | Design, Build & Test (PIT) |  | Complete | COMPLETE | T3-DB-0171 | SITAG | T3 |  |
| 382 | 1.3.6.3.5 | **All LDSO Network Operations DBT CIT (Entering at Interval 5)** |  | 71d | 2023-09-15 A | 2023-12-22 A |  | 100% | 2022-10-31 | 2024-01-05 | 310d | 2022-10-31 | 2025-03-14 |  |  |  | N/A | 2688h | 2688h | -0 | N/A | N/A | 5.0 | Design, Build & Test (PIT) |  |  |  |  |  |  |  |
| 383 | 1.3.6.3.5.1 | **Test Approach & Plan** |  | 71d | 2023-09-15 A | 2023-12-22 A |  | 100% | 2022-10-31 | 2024-01-05 | 310d | 2022-10-31 | 2023-08-11 |  |  |  | N/A | 2120h | 2120h | -0 | N/A | N/A | 5.0 | Design, Build & Test (PIT) |  |  |  |  |  |  |  |
| 384 | 1.3.6.3.5.1.1 | All Network Operation Test Approach & Plans (PIT) submitted to Programme for assurance | milestone | 0d | 2023-09-15 A | 2023-09-15 A |  | 100% | 2023-09-15 | 2023-09-15 | 0d | 2023-07-28 | 2023-07-28 |  |  | start no earlier than 2023-09-15 | Lee Cox |  |  |  | PP | SI Test | 5.8 | Design, Build & Test (PIT) |  | Complete | COMPLETE | T3-DB-0054 | SITAG | T3 |  |
| 385 | 1.3.6.3.5.1.2 | All Network Operation Test Approach & Plans MHHS Review Completed | milestone | 0d | 2023-10-12 A | 2023-10-12 A | 384FS+20d | 100% | 2023-10-12 | 2023-10-12 | 0d | 2023-07-31 | 2023-08-11 |  |  |  | Lee Cox |  |  |  | SI Test | PP | 5.8 | Design, Build & Test (PIT) |  | Complete | COMPLETE | T3-DB-0172 | SITAG | T3 |  |

Notes:
- 363: 1/9 - to be raised as new T3 at TMAG. Approved at TMAG on 20/9. 9/10 - Submit to TMAG for name change to remove IT. Approved for date change at TMAG on 23/10/23
- 364: 1/9 - to be raised as new T3 at TMAG. Approved at TMAG on 20/9.
- 367: 12/9 - TMAG for name change Red because 7/9 received. Approved at TMAG on 20/9
- 368: 7/11 - Red due to high volume to be reviewed. Date change under consideration. Initial reviews complete. Final review will be completed no later than 08/01/24 ahead of Interval 5 Readiness Assessment
- 372: 12/9 - TMAG for name change. Approved at TMAG on 20/9. 10/10 - Red because small number of RTTMs still outstanding
- 373: 17/10 - Red because open comments still outstanding. Assurance reviews complete. Review will be completed no later than 08/01/24 ahead of Interval 5 Readiness Report . Completed on 14/12
- 375: 12/9 - TMAG for name change. Approved at TMAG on 20/9. 10/10 - Red because small number of Test Scenarios still outstanding
- 376: 1/9 - to be raised as new T3 at TMAG. Approved at TMAG on 20/9. 17/10 - Red due to high volume and backlog to be reviewed. Review will be completed no later than 08/01/24 ahead of Interval 5 Readiness Report. Completed 14/12
- 380: 1/9 - to be raised as new T3 at TMAG. Approved at TMAG on 20/9. 12/12 - Red because not all received. No impact as of yet. No action. Completed 12/12
- 381: 1/9 - to be raised as new T3 at TMAG. Approved at TMAG on 20/9. 12/12 - Amber because not all artefacts received. No impact. No action. Completed 15/12
- 384: 12/9 - TMAG for name and date change Red because only received 1/2 test approach and plans. Approved at TMAG on 20/9
- 385: 11/9 - to be raised as new T3 at TMAG. Approved at TMAG on 20/9. Red due to high volume to be reviewed. Date change under consideration. Review will be completed no later than 08/01/24 ahead of Interval 5 Readiness Assessment

| ID | WBS | Task | Type | Duration | Start | Finish | Predecessors | Complete | Actual finish | Baseline start | Baseline finish | Baseline duration | Baseline 1 start | Baseline 1 finish | Constraint | Resources | Work | Actual work | Baseline cost | Responsible | Involved | Update Version | MHHS Programme Phase | Sched Status | RAG | Artefact ID | Milestone ID | Text29 | Tier |
| --- | --- | --- | --- | --- | --- | --- | --- | --- | --- | --- | --- | --- | --- | --- | --- | --- | --- | --- | --- | --- | --- | --- | --- | --- | --- | --- | --- | --- | --- |
| 386 | 1.3.6.3.5.1.3 | **Test Readiness Report** |  | 11d | 2023-09-29 A | 2023-10-13 A |  | 100% |  | 2023-08-11 | 2023-10-20 | 51d | 2023-08-11 | 2023-10-20 |  | N/A | 176h | 176h |  | N/A | N/A | 5.0 | Design, Build & Test (PIT) |  |  |  |  |  |  |
| 387 | 1.3.6.3.5.1.3.1 | Test readiness reporting |  | 11d | 2023-09-29 A | 2023-10-13 A | 384FS+10d | 100% |  | 2023-08-11 | 2023-10-20 | 51d | 2023-08-11 | 2023-10-20 |  | Lee Cox | 88h | 88h |  | PP | 109 | 5.0 | Design, Build & Test (PIT) | Complete | COMPLETE |  |  |  |  |
| 388 | 1.3.6.3.5.1.4 | **Requirements to test Traceability Matrix (RTTM)** |  | 20d | 2023-10-05 A | 2023-11-02 A |  | 100% |  | 2023-10-05 | 2023-11-02 | 20d | 2022-10-31 | 2023-09-15 |  | N/A | 160h | 160h | -0 | N/A | N/A | 5.0 | Design, Build & Test (PIT) |  |  |  |  |  |  |
| 389 | 1.3.6.3.5.1.4.1 | All Network Operation RTTMs submitted to Programme for assurance | milestone | 0d | 2023-10-05 A | 2023-10-05 A | 384FS+15d | 100% |  | 2023-10-05 | 2023-10-05 | 0d | 2023-09-01 | 2023-09-01 | start no earlier than 2023-04-28 | Lee Cox |  |  |  | PP | SI Test | 5.8 | Design, Build & Test (PIT) | Complete | COMPLETE | MHHS-ART009 | T3-DB-0062 | SITAG | T3 |
| 390 | 1.3.6.3.5.1.4.2 | All Network Operation RTTMs MHHS Review Completed | milestone | 0d | 2023-11-02 A | 2023-11-02 A | 389FS+20d | 100% |  | 2023-11-02 | 2023-11-02 | 0d | 2023-09-04 | 2023-09-15 |  | Lee Cox |  |  |  | SI Test | PP | 5.14 | Design, Build & Test (PIT) | Complete | COMPLETE |  | T3-DB-0173 | SITAG | T3 |
| 391 | 1.3.6.3.5.1.5 | **Test Scenarios** |  | 20d | 2023-10-05 A | 2023-11-02 A |  | 100% |  | 2023-10-05 | 2023-11-02 | 20d | 2022-10-31 | 2023-09-15 |  | N/A | 160h | 160h | -0 | N/A | N/A | 5.0 | Design, Build & Test (PIT) |  |  |  |  |  |  |
| 392 | 1.3.6.3.5.1.5.1 | All Network Operation test scenarios' submitted to Programme for assurance | milestone | 0d | 2023-10-05 A | 2023-10-05 A | 384FS+15d | 100% |  | 2023-10-05 | 2023-10-05 | 0d | 2023-09-01 | 2023-09-01 |  | Lee Cox |  |  |  | PP | SI Test | 5.8 | Design, Build & Test (PIT) | Complete | COMPLETE |  | T3-DB-0011 | SITAG | T3 |
| 393 | 1.3.6.3.5.1.5.2 | All Network Operation test scenarios' MHHS Review Completed | milestone | 0d | 2023-11-02 A | 2023-11-02 A | 392FS+20d | 100% |  | 2023-11-02 | 2023-11-02 | 0d | 2023-09-04 | 2023-09-15 |  | Lee Cox |  |  |  | SI Test | PP | 5.14 | Design, Build & Test (PIT) | Complete | COMPLETE |  | T3-DB-0174 | SITAG | T3 |
| 394 | 1.3.6.3.5.1.6 | **PIT execution** |  | 51d | 2023-10-13 A | 2023-12-22 A |  | 100% |  | 2022-10-31 | 2024-01-05 | 310d | 2022-10-31 | 2024-01-05 |  | N/A | 1056h | 1056h | -0 | N/A | N/A | 5.0 | Design, Build & Test (PIT) |  |  |  |  |  |  |
| 395 | 1.3.6.3.5.1.6.1 | PIT Test Execution Progress Report |  | 40d | 2023-10-16 A | 2023-12-08 A | 392FS+5d, 387 | 100% |  | 2022-10-31 | 2023-12-29 | 305d | 2022-10-31 | 2023-12-29 |  | Lee Cox | 320h | 320h |  | PP | SI Test | 5.0 | Design, Build & Test (PIT) | Complete | COMPLETE |  |  |  |  |
| 396 | 1.3.6.3.5.1.6.2 | PIT Execution |  | 41d | 2023-10-13 A | 2023-12-08 A | 392FS+5d | 100% |  | 2022-10-31 | 2024-01-05 | 310d | 2022-10-31 | 2024-01-05 |  | Lee Cox | 328h | 328h |  | PP | SI Test | 5.0 | Design, Build & Test (PIT) | Complete | COMPLETE |  |  |  |  |
| 397 | 1.3.6.3.5.1.6.3 | All Network Operation PIT (CIT interval 5) Completion Reports submitted to Programme for assurance | milestone | 0d | 2023-12-08 A | 2023-12-08 A | 396, 395 | 100% |  | 2023-12-08 | 2023-12-08 | 0d | 2024-01-05 | 2024-01-05 |  | Lee Cox |  |  |  | PP | SI Test | 5.0 | Design, Build & Test (PIT) | Complete | COMPLETE |  | T3-DB-0175 | SITAG | T3 |
| 398 | 1.3.6.3.5.1.6.4 | All Network Operation PIT (CIT interval 5) Completion Reports MHHS Review Completed | milestone | 0d | 2023-12-22 A | 2023-12-22 A | 397FS+10d, 385, 390, 393 | 100% |  | 2023-12-22 | 2023-12-22 | 0d |  |  |  | Lee Cox |  |  |  | SI Test | PP | 5.15 | Design, Build & Test (PIT) | Complete | COMPLETE |  | T3-DB-0176 | SITAG | T3 |
| 399 | 1.3.6.3.6 | **All UMSO DBT CIT (Entering at Interval 6)** |  | 81d | 2023-09-29 A | 2024-01-19 A |  | 100% |  | 2022-10-31 | 2024-01-19 | 320d | 2022-10-31 | 2024-05-13 |  | N/A | 2352h | 2352h | -0 | N/A | N/A | 5.0 | Design, Build & Test (PIT) |  |  |  |  |  |  |
| 400 | 1.3.6.3.6.1 | **Test Approach & Plan** |  | 20d | 2023-10-13 A | 2023-11-09 A |  | 100% |  | 2023-09-15 | 2023-11-09 | 40d | 2022-10-31 | 2023-09-29 |  | N/A | 160h | 160h | -0 | N/A | N/A | 5.0 | Design, Build & Test (PIT) |  |  |  |  |  |  |
| 401 | 1.3.6.3.6.1.1 | All UMSO Test Approach & Plans (PIT) submitted to Programme for assurance | milestone | 0d | 2023-10-13 A | 2023-10-13 A |  | 100% |  | 2023-09-15 | 2023-09-15 | 0d | 2023-09-15 | 2023-09-15 | start no earlier than 2023-10-13 | Lee Cox |  |  |  | PP | SI Test | 5.11 | Design, Build & Test (PIT) | Complete | COMPLETE |  | T3-DB-0052 | SITAG | T3 |
| 402 | 1.3.6.3.6.1.2 | All UMSO Test Approach & Plans MHHS Review Completed | milestone | 0d | 2023-11-09 A | 2023-11-09 A | 401FS+20d | 100% |  | 2023-11-09 | 2023-11-09 | 0d | 2023-09-18 | 2023-09-29 |  | Lee Cox |  |  |  | SI Test | PP | 5.10 | Design, Build & Test (PIT) | Complete | COMPLETE |  | T3-DB-0177 | SITAG | T3 |
| 403 | 1.3.6.3.6.2 | **Test Readiness Report** |  | 11d | 2023-09-29 A | 2023-10-13 |  | 100% | 2023-11-10 | 2023-10-27 | 2023-11-10 | 11d | 2023-09-29 | 2023-12-08 |  | N/A | 176h | 176h | -0 | N/A | N/A | 5.0 | Design, Build & Test (PIT) |  |  |  |  |  |  |
| 404 | 1.3.6.3.6.2.1 | Test readiness reporting |  | 11d | 2023-10-27 A | 2023-11-10 A | 401FS+10d | 100% |  | 2023-10-27 | 2023-11-10 | 11d | 2023-09-29 | 2023-12-08 |  | Lee Cox | 88h | 88h |  | PP | 109 | 5.0 | Design, Build & Test (PIT) | Complete | COMPLETE |  |  |  |  |
| 405 | 1.3.6.3.6.3 | **Requirements to test Traceability Matrix (RTTM)** |  | 20d | 2023-10-05 A | 2023-11-01 |  | 100% | 2023-11-30 | 2023-11-02 | 2023-11-30 | 20d | 2022-10-31 | 2023-10-20 |  | N/A | 160h | 160h | -0 | N/A | N/A | 5.0 | Design, Build & Test (PIT) |  |  |  |  |  |  |
| 406 | 1.3.6.3.6.3.1 | All UMSO RTTMs submitted to Programme for assurance | milestone | 0d | 2023-11-02 A | 2023-11-02 A | 401FS+15d | 100% |  | 2023-11-02 | 2023-11-02 | 0d | 2023-10-06 | 2023-10-06 |  | Lee Cox |  |  |  | PP | SI Test | 5.12 | Design, Build & Test (PIT) | Complete | COMPLETE | MHHS-ART009 | T3-DB-0060 | SITAG | T3 |
| 407 | 1.3.6.3.6.3.2 | All UMSO RTTMs MHHS Review Completed | milestone | 0d | 2023-11-30 A | 2023-11-30 A | 406FS+20d | 100% |  | 2023-11-30 | 2023-11-30 | 0d | 2023-10-09 | 2023-10-20 |  | Lee Cox |  |  |  | SI Test | PP | 5.12 | Design, Build & Test (PIT) | Complete | COMPLETE |  | T3-DB-0178 | SITAG | T3 |
| 408 | 1.3.6.3.6.4 | **Test Scenarios** |  | 20d | 2023-10-05 A | 2023-11-01 |  | 100% | 2023-11-30 | 2023-11-02 | 2023-11-30 | 20d | 2022-10-31 | 2023-10-20 |  | N/A | 160h | 160h | -0 | N/A | N/A | 5.0 | Design, Build & Test (PIT) |  |  |  |  |  |  |
| 409 | 1.3.6.3.6.4.1 | All UMSO test scenarios' submitted to Programme for assurance | milestone | 0d | 2023-11-02 A | 2023-11-02 A | 401FS+15d | 100% |  | 2023-11-02 | 2023-11-02 | 0d | 2023-10-06 | 2023-10-06 |  | Lee Cox |  |  |  | PP | SI Test | 5.12 | Design, Build & Test (PIT) | Complete | COMPLETE |  | T3-DB-0025 | SITAG | T3 |
| 410 | 1.3.6.3.6.4.2 | All UMSO Test scenarios' MHHS Review Completed | milestone | 0d | 2023-11-30 A | 2023-11-30 A | 409FS+20d | 100% |  | 2023-11-30 | 2023-11-30 | 0d | 2023-10-09 | 2023-10-20 |  | Lee Cox |  |  |  | SI Test | PP | 5.10 | Design, Build & Test (PIT) | Complete | COMPLETE |  | T3-DB-0179 | SITAG | T3 |

Notes:
- 389: 12/9 - TMAG for name and date change Approved at TMAG on 20/9. 10/10 - Red because 50% of RTTMs outstanding
- 390: 17/10 - Red because open comments still outstanding. Assurance reviews complete. Review will be completed no later than 08/01/24 ahead of Interval 5 Readiness Report . 19/12 - completed 14/12
- 392: 12/9 - TMAG for name and date change. Approved at TMAG on 20/9. 17/10 - Red because currently 50% have been received. Date change under consideration.
- 393: 17/10 - Red because open comments still outstanding. Assurance reviews complete. Review will be completed no later than 08/01/24 ahead of Interval 5 Readiness Assessment . 19/12 - completed 14/12
- 397: 11/9 - to be raised as new T3 at TMAG. Approved at TMAG on 20/9. 19/12 - completed 14/12
- 398: 11/9 - to be raised as new T3 at TMAG. Approved at TMAG on 20/9. 12/12 - Amber because all reviews complete, clarifications are requested
- 401: 12/9 - TMAG for name and date change. Approved at TMAG on 20/9. 17/10 - Red because not all received. Currently no impact. Issuance request sent. Complete 1/11
- 402: To go to TMAG for date change. Approved for date change at TMAG on 23/10/23. 7/11-Amber because of high volume and backlog to be reviewed. Review will be completed no later than 22/01/24 ahead of Interval 6 Readiness Assessment
- 406: 4/10 - Red because baseline date incorrect. To go to TMAG for date change. Approved for date change at TMAG on 23/10/23. 14/11-Red because up to 50% not received. No impact. No action
- 407: 1/9 - to be raised as new T3 at TMAG. Approved at TMAG on 20/9. 4/10 - Red because baseline date incorrect. To go to TMAG for date change. Approved for date change at TMAG on 23/10/23
- 409: Approved at TMAG on 20/9. 4/10 - Red because baseline date incorrect. To go to TMAG for date change. Approved for date change at TMAG on 23/10/23. 7/11-Red because not received. Expected 10/11. No impact No action
- 410: 1/9 - to be raised as new T3 at TMAG. Approved at TMAG on 20/9. 5/12 - Assurance review conducted, but outstanding comments to be addressed

| ID | WBS | Task | Type | Duration | Start | Finish | Predecessors | Complete | Remaining | Baseline start | Baseline finish | Baseline duration | Baseline 1 start | Baseline 1 finish | Total slack | Constraint | Resources | Work | Actual work | Baseline cost | Responsible | Involved | Update Version | MHHS Programme Phase | Sched Status | RAG | Milestone ID | Text29 | Tier | Task Status | Artefact ID |
| --- | --- | --- | --- | --- | --- | --- | --- | --- | --- | --- | --- | --- | --- | --- | --- | --- | --- | --- | --- | --- | --- | --- | --- | --- | --- | --- | --- | --- | --- | --- | --- |
| 411 | 1.3.6.3.6.5 | **PIT execution** |  | 51d | 2023-11-10 A | 2024-01-19 A |  | 100% |  | 2022-10-31 | 2024-01-19 | 320d | 2022-10-31 | 2023-12-08 |  |  | N/A | 1048h | 1048h | -0 | N/A | N/A | 5.0 | Design, Build & Test (PIT) |  |  |  |  |  |  |  |
| 412 | 1.3.6.3.6.5.1 | PIT Test Execution Progress Report |  | 40d | 2023-11-13 A | 2024-01-05 A | 409FS+5d, 404 | 100% |  | 2023-11-13 | 2024-01-05 | 40d | 2022-10-31 | 2023-12-01 |  |  | Lee Cox | 320h | 320h |  | PP | SI Test | 5.0 | Design, Build & Test (PIT) | Complete | COMPLETE |  |  |  |  |  |
| 413 | 1.3.6.3.6.5.2 | PIT Execution |  | 40d | 2023-11-10 A | 2024-01-04 A | 409FS+5d | 100% |  | 2022-10-31 | 2024-01-05 | 290d | 2022-10-31 | 2023-12-08 |  |  | Lee Cox | 320h | 320h |  | PP | SI Test | 5.0 | Design, Build & Test (PIT) | Complete | COMPLETE |  |  |  |  |  |
| 414 | 1.3.6.3.6.5.3 | All UMSO PIT (CIT interval 6) Completion Reports submitted to Programme for assurance | milestone | 0d | 2024-01-05 A | 2024-01-05 A | 413, 412 | 100% |  | 2024-01-05 | 2024-01-05 | 0d | 2024-01-05 | 2024-01-05 |  |  | Lee Cox |  |  |  | PP | SI Test | 5.10 | Design, Build & Test (PIT) | Complete | COMPLETE | T3-DB-0180 | SITAG | T3 |  |  |
| 415 | 1.3.6.3.6.5.4 | All UMSO PIT (CIT interval 6) Completion Reports MHHS Review Completed | milestone | 0d | 2024-01-19 A | 2024-01-19 A | 402, 407, 410, 414FS+10d | 100% |  | 2024-01-19 | 2024-01-19 | 0d |  |  |  |  | Lee Cox |  |  |  | SI Test | PP | 5.10 | Design, Build & Test (PIT) | Complete | COMPLETE | T3-DB-0181 | SITAG | T3 |  |  |
| 416 | 1.3.7 | **DBT Monitoring and Assurance** |  | 842d | 2022-10-31 A | 2026-01-20 |  | 61% | 325.97d | 2022-10-31 | 2026-01-20 | 842d | 2022-10-31 | 2026-01-19 | 353d |  | N/A | 61912h | 26962.4h |  | N/A | N/A | 5.0 | Design, Build & Test (PIT) |  |  |  |  |  |  |  |
| 417 | 1.3.7.1 | **Planning and DBT Progress Monitoring of PPs** |  | 696d | 2022-10-31 A | 2025-06-30 |  | 62% | 263d | 2022-10-31 | 2025-06-30 | 696d | 2022-10-31 | 2025-06-30 | 499d |  | N/A | 11136h | 6928h |  | N/A | N/A | 5.0 | Design, Build & Test (PIT) |  |  |  |  |  | M9 |  |
| 418 | 1.3.7.1.1 | Monitor Non-SIT PPs Planning and DBT1 progress (to inform confirmation of Qualification Testing Tranche participants milestones) |  | 696d | 2022-10-31 A | 2025-06-30 | 164SS | 62% | 263d | 2022-10-31 | 2025-06-30 | 696d | 2022-10-31 | 2025-06-30 | 499d |  | Lee Cox | 5568h | 3464h |  | Code Bodies | SI Test,PPC | 5.0 | Design, Build & Test (PIT) | Green | GREEN |  |  |  |  |  |
| 419 | 1.3.7.2 | **DBT Progress Monitoring of Consequential Change** |  | 774d | 2023-02-02 A | 2026-01-20 |  | 47% | 414d | 2023-02-02 | 2026-01-20 | 774d | 2023-02-01 | 2026-01-19 | 353d |  | N/A | 12384h | 5760h |  | N/A | N/A | 5.0 | Design, Build & Test (PIT) |  |  |  |  |  | M9 |  |
| 420 | 1.3.7.2.1 | Monitor & report data cleanse progress |  | 774d | 2023-02-02 A | 2026-01-20 |  | 47% | 414d | 2023-02-02 | 2026-01-20 | 774d | 2023-02-01 | 2026-01-19 | 353d |  | Matthew Breen | 6192h | 2880h |  | SI Test | PPC | 5.0 | Design, Build & Test (PIT) | Green | GREEN |  |  |  |  |  |
| 421 | 1.3.7.3 | **Design Assurance** |  | 713d | 2022-11-14 A | 2025-08-06 |  | 71% | 206.27d | 2022-11-14 | 2025-08-06 | 713d | 2022-11-14 | 2025-08-06 | 472d |  | N/A | 20520h | 10176h |  | N/A | N/A | 5.0 | Design, Build & Test (PIT) |  |  |  |  |  | M9 |  |
| 422 | 1.3.7.3.1 | **Design Assurance Readiness Assessment Preparation** |  | 39d | 2023-02-28 A | 2023-04-21 A |  | 100% |  | 2023-02-28 | 2023-04-21 | 39d | 2023-02-28 | 2023-04-21 |  |  | N/A | 728h | 728h |  | N/A | N/A | 5.0 | Design, Build & Test (PIT) |  |  |  |  |  |  |  |
| 423 | 1.3.7.3.1.1 | Set up FTIG |  | 15d | 2023-04-03 A | 2023-04-21 A |  | 100% |  | 2023-04-03 | 2023-04-21 | 15d | 2023-04-03 | 2023-04-21 |  | must start on 2023-04-03 | Paul Pettitt | 120h | 120h |  | SI Design |  | 5.0 | Design, Build & Test (PIT) | Complete | COMPLETE |  |  |  |  |  |
| 424 | 1.3.7.3.1.2 | Produce Draft Questions |  | 10d | 2023-02-28 A | 2023-03-13 A |  | 100% |  | 2023-02-28 | 2023-03-13 | 10d | 2023-02-28 | 2023-03-13 |  | must start on 2023-02-28 | Paul Pettitt | 80h | 80h |  | SI Design |  | 5.0 | Design, Build & Test (PIT) | Complete | COMPLETE |  |  |  |  |  |
| 425 | 1.3.7.3.1.3 | Pilot with SRO |  | 1d | 2023-03-14 A | 2023-03-14 A | 424 | 100% |  | 2023-03-14 | 2023-03-14 | 1d | 2023-03-14 | 2023-03-14 |  |  | Paul Pettitt | 8h | 8h |  | SI Design |  | 5.0 | Design, Build & Test (PIT) | Complete | COMPLETE |  |  |  |  |  |
| 426 | 1.3.7.3.1.4 | Finalise questions |  | 10d | 2023-03-15 A | 2023-03-28 A | 425 | 100% |  | 2023-03-15 | 2023-03-28 | 10d | 2023-03-15 | 2023-03-28 |  |  | Paul Pettitt | 80h | 80h |  | SI Design |  | 5.0 | Design, Build & Test (PIT) | Complete | COMPLETE |  |  |  |  |  |
| 427 | 1.3.7.3.1.5 | Prepare on-line RA tooling |  | 10d | 2023-03-29 A | 2023-04-11 A | 426 | 100% |  | 2023-03-29 | 2023-04-11 | 10d | 2023-03-29 | 2023-04-11 |  |  | Paul Pettitt | 80h | 80h |  | SI Design |  | 5.0 | Design, Build & Test (PIT) | Complete | COMPLETE |  |  |  |  |  |
| 428 | 1.3.7.3.1.6 | Prepare webinar content |  | 5d | 2023-03-20 A | 2023-03-24 A | 424FS+4d | 100% |  | 2023-03-20 | 2023-03-24 | 5d | 2023-03-20 | 2023-03-24 |  |  | Paul Pettitt | 40h | 40h |  | SI Design |  | 5.0 | Design, Build & Test (PIT) | Complete | COMPLETE |  |  |  |  |  |
| 429 | 1.3.7.3.1.7 | Conduct webinar |  | 1d | 2023-03-30 A | 2023-03-30 A | 428FS+3d | 100% |  | 2023-03-30 | 2023-03-30 | 1d | 2023-03-30 | 2023-03-30 |  |  | Paul Pettitt | 8h | 8h |  | SI Design | PP | 5.0 | Design, Build & Test (PIT) | Complete | COMPLETE |  |  |  |  |  |
| 430 | 1.3.7.3.2 | **Participant Design Assurance Approach** |  | 43d | 2022-11-14 A | 2023-01-11 A |  | 100% |  | 2022-11-14 | 2023-01-11 | 43d | 2022-11-14 | 2023-01-11 |  |  | N/A | 648h | 648h |  | N/A | N/A | 5.0 | Design, Build & Test (PIT) |  |  |  |  |  |  |  |
| 431 | 1.3.7.3.2.1 | Develop document |  | 20d | 2022-11-14 A | 2022-12-09 A | 48FS+10d | 100% |  | 2022-11-14 | 2022-12-09 | 20d | 2022-11-14 | 2022-12-09 |  | start no earlier than 2022-11-14 | Paul Pettitt | 160h | 160h |  | SI Design | PP | 5.0 | Design, Build & Test (PIT) | Complete | COMPLETE |  |  |  |  |  |
| 432 | 1.3.7.3.2.2 | Review document |  | 18d | 2022-12-12 A | 2023-01-04 A | 431 | 100% |  | 2022-12-12 | 2023-01-04 | 18d | 2022-12-12 | 2023-01-04 |  |  | Paul Pettitt | 144h | 144h |  | PP | SI Design,IPA | 5.0 | Design, Build & Test (PIT) | Complete | COMPLETE |  |  |  |  |  |
| 433 | 1.3.7.3.2.3 | Participant Design Assurance Approach approved | milestone | 0d | 2023-01-11 A | 2023-01-11 A | 432FF+5d | 100% |  | 2023-01-11 | 2023-01-11 | 0d | 2023-01-11 | 2023-01-11 |  |  | Paul Pettitt |  |  |  | SI Design | PP | 5.0 | Design, Build & Test (PIT) | Complete | COMPLETE | T3-DB-0012 | DAG | T3 |  |  |
| 434 | 1.3.7.3.3 | **Phase 1 - SIT Volunteers (Core Providers)** |  | 145d | 2023-04-10 A | 2023-10-27 A |  | 100% |  | 2023-04-10 | 2023-10-27 | 145d | 2023-04-10 | 2023-10-27 |  |  | N/A | 2768h | 2768h |  | N/A | N/A | 5.0 | Design, Build & Test (PIT) |  |  |  |  |  |  |  |
| 435 | 1.3.7.3.3.1 | Send on-line questionnaire to core capability providers and current SIT volunteers (from Round 3 consultation) |  | 1d | 2023-04-10 A | 2023-04-10 A |  | 100% |  | 2023-04-10 | 2023-04-10 | 1d | 2023-04-10 | 2023-04-10 |  | must start on 2023-04-10 | Paul Pettitt | 8h | 8h |  | SI Design | PP | 5.0 | Design, Build & Test (PIT) | Complete | COMPLETE |  |  |  |  |  |
| 436 | 1.3.7.3.3.2 | Participants Provide Responses to questionnaires |  | 15d | 2023-04-11 A | 2023-05-01 A | 435 | 100% |  | 2023-04-11 | 2023-05-01 | 15d | 2023-04-11 | 2023-05-01 |  |  | Paul Pettitt | 120h | 120h |  | PP |  | 5.0 | Design, Build & Test (PIT) | Complete | COMPLETE |  |  |  |  |  |
| 437 | 1.3.7.3.3.3 | Assess on-line responses and provided evidence |  | 5d | 2023-05-02 A | 2023-05-08 A | 436 | 100% |  | 2023-05-02 | 2023-05-08 | 5d | 2023-05-02 | 2023-05-08 |  |  | Paul Pettitt | 40h | 40h |  | SI Design |  | 5.0 | Design, Build & Test (PIT) | Complete | COMPLETE |  |  |  |  |  |
| 438 | 1.3.7.3.3.4 | Bi-lateral meeting with each responder, to walk and navigate through provided materials |  | 31d | 2023-05-09 A | 2023-06-20 A | 437 | 100% |  | 2023-05-09 | 2023-06-20 | 31d | 2023-05-09 | 2023-06-20 |  |  | Paul Pettitt | 248h | 248h |  | SI Design | PP | 5.0 | Design, Build & Test (PIT) | Complete | COMPLETE |  |  |  |  |  |
| 439 | 1.3.7.3.3.5 | Plan for, create and execute deep dive assurance interviews based on agreed priorities (participants, design areas) |  | 62d | 2023-06-07 A | 2023-08-31 A | 438FS-10d | 100% |  | 2023-06-07 | 2023-08-31 | 62d | 2023-06-07 | 2023-08-01 |  |  | Paul Pettitt | 496h | 496h |  | SI Design |  | 5.2 | Design, Build & Test (PIT) | Complete | COMPLETE |  |  |  |  |  |
| 440 | 1.3.7.3.3.6 | SI endorsement of participants’ design – assurance reports |  | 43d | 2023-08-02 A | 2023-09-29 A | 439FS-22d | 100% |  | 2023-08-02 | 2023-09-29 | 43d | 2023-08-02 | 2023-08-15 |  |  | Paul Pettitt | 344h | 344h |  | SI Design |  | 5.2 | Design, Build & Test (PIT) | Complete | COMPLETE |  |  |  |  |  |
| 441 | 1.3.7.3.3.7 | Post-assurance review of recommendations take-up by assured participants |  | 44d | 2023-08-29 A | 2023-10-27 A | 440SS+19d | 100% |  | 2023-10-02 | 2023-10-27 | 20d | 2023-08-16 | 2023-10-27 |  |  | Paul Pettitt | 352h | 352h |  | SI Design |  | 5.2 | Design, Build & Test (PIT) | Complete | COMPLETE |  |  |  |  |  |
| 442 | 1.3.7.3.3.8 | Phase 1 - SIT Volunteers (Core Providers) complete | milestone | 0d | 2023-10-27 A | 2023-10-27 A | 441 | 100% |  | 2023-10-27 | 2023-10-27 | 0d | 2023-10-27 | 2023-10-27 |  |  | Paul Pettitt |  |  |  | SI Design |  | 5.11 | Design, Build & Test (PIT) | Complete | COMPLETE | T2-DB-0100 | DAG | T2 |  | MHHS-ART002 |

Notes:
- 414: . 4/10 - Red because baseline date incorrect. To go to TMAG for date change. Approved for date change at TMAG on 23/10/23. 16/1 - Not all completion reports yet received. Completed on 21/2
- 415: Red because baseline date incorrect. To go to TMAG for date change. Approved for date change at TMAG on 23/10/23. 16/01 - Late due to late delivery of PP artefacts for review. Completed on 21/2
- 418: 15/9 - hold in plan until qualification sections updated
- 420: 15/9 - query with John Wiggins where this sits
- 442: 16/10 Awaiting the issuing of backlog reports. But no significant design impacts identified. No impact to commencing SIT

| ID | WBS | Task | Type | Duration | Start | Finish | Predecessors | Complete | Remaining | Baseline start | Baseline finish | Baseline duration | Baseline 1 start | Baseline 1 finish | Total slack | Constraint | Resources | Work | Actual work | Baseline cost | Responsible | Involved | Update Version | MHHS Programme Phase | Sched Status | RAG | Artefact ID | Milestone ID | Text29 | Tier | Task Status | Text3 |
| --- | --- | --- | --- | --- | --- | --- | --- | --- | --- | --- | --- | --- | --- | --- | --- | --- | --- | --- | --- | --- | --- | --- | --- | --- | --- | --- | --- | --- | --- | --- | --- | --- |
| 443 | 1.3.7.3.4 | **Phase 2 - SIT all other participants** |  | 143d | 2023-05-08 A | 2023-11-22 A |  | 100% |  | 2023-05-08 | 2023-11-22 | 143d | 2023-05-08 | 2023-11-22 |  |  | N/A | 3552h | 3552h |  | N/A | N/A | 5.0 | Design, Build & Test (PIT) |  |  |  |  |  |  |  |  |
| 444 | 1.3.7.3.4.1 | Send on-line questionnaire to core capability providers and current SIT volunteers (from Round 3 consultation) |  | 1d | 2023-05-08 A | 2023-05-08 A |  | 100% |  | 2023-05-08 | 2023-05-08 | 1d | 2023-05-08 | 2023-05-08 |  | must start on 2023-05-08 | Paul Pettitt | 8h | 8h |  | SI Design | PP | 5.0 | Design, Build & Test (PIT) | Complete | COMPLETE |  |  |  |  |  |  |
| 445 | 1.3.7.3.4.2 | Participants Provide Responses to questionnaires |  | 15d | 2023-05-09 A | 2023-05-29 A | 444 | 100% |  | 2023-05-09 | 2023-05-29 | 15d | 2023-05-09 | 2023-05-29 |  |  | Paul Pettitt | 120h | 120h |  | PP |  | 5.0 | Design, Build & Test (PIT) | Complete | COMPLETE |  |  |  |  |  |  |
| 446 | 1.3.7.3.4.3 | Assess on-line responses and provided evidence |  | 5d | 2023-05-30 A | 2023-06-05 A | 445 | 100% |  | 2023-05-30 | 2023-06-05 | 5d | 2023-05-30 | 2023-06-05 |  |  | Paul Pettitt | 40h | 40h |  | SI Design |  | 5.0 | Design, Build & Test (PIT) | Complete | COMPLETE |  |  |  |  |  |  |
| 447 | 1.3.7.3.4.4 | Bi-lateral meeting with each responder, to walk and navigate through provided materials |  | 84d | 2023-06-06 A | 2023-09-29 A | 446 | 100% |  | 2023-06-06 | 2023-09-29 | 84d | 2023-06-06 | 2023-07-18 |  |  | Paul Pettitt | 672h | 672h |  | SI Design | PP | 5.2 | Design, Build & Test (PIT) | Complete | COMPLETE |  |  |  |  |  |  |
| 448 | 1.3.7.3.4.5 | Plan for, create and execute deep dive assurance interviews based on agreed priorities (participants, design areas) |  | 69d | 2023-06-27 A | 2023-09-29 A | 447SS+15d | 100% |  | 2023-06-27 | 2023-09-29 | 69d | 2023-07-05 | 2023-08-29 |  |  | Paul Pettitt | 552h | 552h |  | SI Design |  | 5.2 | Design, Build & Test (PIT) | Complete | COMPLETE |  |  |  |  |  |  |
| 449 | 1.3.7.3.4.6 | SI endorsement of participants’ design – assurance reports |  | 54d | 2023-07-18 A | 2023-09-29 A | 448SS+15d | 100% |  | 2023-07-18 | 2023-09-29 | 54d | 2023-08-30 | 2023-09-12 |  |  | Paul Pettitt | 432h | 432h |  | SI Design |  | 5.2 | Design, Build & Test (PIT) | Complete | COMPLETE |  |  |  |  |  |  |
| 450 | 1.3.7.3.4.7 | Post-assurance review of recommendations take-up by assured participants |  | 73d | 2023-08-14 A | 2023-11-22 A | 449SS+19d | 100% |  | 2023-10-02 | 2023-11-22 | 38d | 2023-09-13 | 2023-11-22 |  |  | Paul Pettitt | 584h | 584h |  | SI Design |  | 5.2 | Design, Build & Test (PIT) | Complete | COMPLETE |  |  |  |  |  |  |
| 451 | 1.3.7.3.4.8 | SIT PPs design assurance (excl Migration/Reverse Migration) complete | milestone | 0d | 2023-11-22 A | 2023-11-22 A | 450 | 100% |  | 2023-11-22 | 2023-11-22 | 0d | 2023-11-22 | 2023-11-22 |  |  | Paul Pettitt |  |  |  | SI Design |  | 5.11 | Design, Build & Test (PIT) | Complete | COMPLETE | MHHS-ART002 | T2-DB-0200 | DAG | T2 |  |  |
| 452 | 1.3.7.3.5 | **Non-SIT PPs design assurance** |  | 445d | 2023-11-23 A | 2025-08-06 |  | 33% | 300d | 2023-11-23 | 2025-08-06 | 445d | 2023-11-23 | 2025-08-06 | 472d |  | N/A | 7120h | 2320h |  | N/A | N/A | 5.0 | Design, Build & Test (PIT) |  |  |  |  |  |  |  |  |
| 453 | 1.3.7.3.5.1 | Non-SIT PPs design assurance (risk-based sample) |  | 445d | 2023-11-23 A | 2025-08-06 | 451 | 33% | 300d | 2023-11-23 | 2025-08-06 | 445d | 2023-11-23 | 2025-08-06 | 472d |  | Paul Pettitt | 3560h | 1160h |  | SI Design | PPC | 5.0 | Design, Build & Test (PIT) | Green | GREEN |  |  |  |  |  |  |
| 454 | 1.3.7.4 | **Test Assurance** |  | 629d | 2023-02-01 A | 2025-06-30 |  | 58% | 263d | 2022-10-31 | 2025-06-30 | 696d | 2022-10-31 | 2025-06-30 | 499d |  | N/A | 10064h | 3026.4h |  | N/A | N/A | 5.0 | Design, Build & Test (PIT) |  |  |  |  |  |  | M9 |  |
| 455 | 1.3.7.4.1 | Non-SIT PPs test assurance |  | 629d | 2023-02-01 A | 2025-06-30 |  | 58% | 263d | 2023-02-01 | 2025-06-30 | 629d | 2023-02-01 | 2025-06-30 | 499d |  | Lee Cox | 5032h | 2928h |  | Code Bodies | PP,PPC,SI Test | 5.0 | Design, Build & Test (PIT) | Green | GREEN |  |  |  |  |  |  |
| 456 | 1.3.7.5 | **Pre-Qualification Guidance (PIT Guidance)** |  | 67d | 2022-10-31 A | 2023-01-31 A |  | 100% |  | 2022-10-31 | 2023-01-31 | 67d | 2022-10-31 | 2023-01-31 |  |  | N/A | 1072h | 1072h |  | N/A | N/A | 5.0 | Design, Build & Test (PIT) |  |  |  |  |  |  |  |  |
| 457 | 1.3.7.5.1 | Develop document (incl. collaboration with code bodies, as required) |  | 56d | 2022-10-31 A | 2023-01-16 A |  | 100% |  | 2022-10-31 | 2023-01-16 | 56d | 2022-10-31 | 2023-01-16 |  |  | Lee Cox | 448h | 448h |  | SI Test | Code Bodies | 5.0 | Design, Build & Test (PIT) | Complete | COMPLETE |  |  |  |  |  |  |
| 458 | 1.3.7.5.2 | Review, update and agree Pre-Qualification Guidance internally |  | 11d | 2023-01-17 A | 2023-01-31 A | 457 | 100% |  | 2023-01-17 | 2023-01-31 | 11d | 2023-01-17 | 2023-01-31 |  |  | Lee Cox | 88h | 88h |  | SRO Function | IPA,SI Test | 5.0 | Design, Build & Test (PIT) | Complete | COMPLETE |  |  |  |  |  |  |
| 459 | 1.3.7.6 | **External Programme Dependency Management** |  | 0d | 2022-11-03 A | 2022-11-03 A |  | 100% |  | 2022-11-03 | 2022-11-03 | 0d | 2022-11-03 | 2022-11-03 |  |  | N/A |  |  |  | N/A | N/A | 5.0 | Design, Build & Test (PIT) |  |  |  |  |  |  |  |  |
| 460 | 1.3.7.6.1 | **SLC47** |  | 0d | 2022-11-03 A | 2022-11-03 A |  | 100% |  | 2022-11-03 | 2022-11-03 | 0d | 2022-11-03 | 2022-11-03 |  |  | N/A |  |  |  | N/A | N/A | 5.0 | Design, Build & Test (PIT) |  |  |  |  |  |  |  |  |
| 461 | 1.3.7.6.1.1 | SLC47 implementation date | milestone | 0d | 2022-11-03 A | 2022-11-03 A |  | 100% |  | 2022-11-03 | 2022-11-03 | 0d | 2022-11-03 | 2022-11-03 |  | start no earlier than 2022-11-03 | Lee Cox |  |  |  | Ofgem |  | 5.0 | Design, Build & Test (PIT) | Complete | COMPLETE |  |  |  |  |  |  |
| 462 | 1.4 | **SYSTEMS INTEGRATION TESTING (SIT)** |  | 845d | 2022-10-31 A | 2026-01-23 |  | 53% | 398.58d | 2022-10-31 | 2026-01-19 | 841d | 2022-10-31 | 2026-01-19 | 350d |  | N/A | 298754h | 142966h | -0 | N/A | N/A |  | Systems Integration Testing (SIT) |  |  |  |  |  |  |  | 1 Aug 2023 - 30 Sep 2024 |
| 463 | 1.4.1 | **SIT Preparation** |  | 520d | 2022-10-31 A | 2024-10-25 |  | 96% | 20.95d | 2022-10-31 | 2025-03-03 | 611d | 2022-10-31 | 2025-03-10 | 675d |  | N/A | 147010h | 113994h | -0 | N/A | N/A | 5.0 | Systems Integration Testing (SIT) |  |  |  |  |  |  |  |  |
| 464 | 1.4.1.1 | **Test Artefact Development** |  | 472d | 2022-10-31 A | 2024-08-21 |  | 99% | 2.69d | 2022-10-31 | 2024-08-21 | 472d | 2022-10-31 | 2023-09-01 | 723d |  | N/A | 18208h | 11424h | -0 | N/A | N/A | 5.0 | Systems Integration Testing (SIT) |  |  |  |  |  |  | M9 |  |
| 465 | 1.4.1.1.1 | **Environment Approach & Plan** |  | 460d | 2022-11-16 A | 2024-08-21 |  | 99% | 0d | 2022-11-16 | 2024-08-21 | 460d | 2022-11-16 | 2023-06-30 | 0d |  | N/A | 4056h | 1256h | -0 | N/A | N/A | 5.0 | Systems Integration Testing (SIT) |  |  |  |  |  |  |  |  |
| 466 | 1.4.1.1.1.1 | Environment Approach & Plan approved | milestone | 0d | 2022-11-16 A | 2022-11-16 A |  | 100% |  | 2022-11-16 | 2022-11-16 | 0d | 2022-11-16 | 2022-11-16 |  | start no earlier than 2022-11-16 | Simon Berry |  |  |  | SI Test | PP | 5.0 | Systems Integration Testing (SIT) | Complete | COMPLETE | MHHS-ART139 | T3-TE-0010 | SITAG | T3 |  |  |
| 467 | 1.4.1.1.1.2 | Environment Approach & Plan - Work Off |  | 157d | 2022-11-17 A | 2023-06-23 A | 466FS+1d | 100% |  | 2022-11-17 | 2023-06-23 | 157d | 2022-11-17 | 2023-06-23 |  |  | Simon Berry | 1256h | 1256h |  | SI Test | PP | 5.0 | Systems Integration Testing (SIT) | Complete | COMPLETE |  |  |  |  |  |  |
| 468 | 1.4.1.1.1.3 | Environment Approach & Plan - Work Off Approved | milestone | 0d | 2023-08-16 A | 2023-08-16 A | 467FS+5d | 100% |  | 2023-08-16 | 2023-08-16 | 0d | 2023-06-30 | 2023-06-30 |  | start no earlier than 2023-08-16 | Simon Berry |  |  |  | SI Test | PP | 5.0 | Systems Integration Testing (SIT) | Complete | COMPLETE | MHHS-ART139 | T3-TE-0068 | SITAG | T3 |  |  |
| 469 | 1.4.1.1.1.4 | Environment Approach and Plan - SIT Functional | milestone | 0d | 2023-11-20 A | 2023-11-20 A |  | 100% |  | 2023-11-15 | 2023-11-15 | 0d |  |  |  | start no earlier than 2023-11-20 | Simon Berry |  |  |  | SI Test | PP | 5.12 | Systems Integration Testing (SIT) | Complete | COMPLETE | MHHS-DEL 618 | T3-TE-0090 | SITAG | T3 |  |  |
| 470 | 1.4.1.1.1.5 | Define Approach to Simulator for Non-SIT LDSO | milestone | 0d | 2023-11-15 A | 2023-11-15 A |  | 100% |  | 2023-11-15 | 2023-11-15 | 0d |  |  |  | start no earlier than 2023-11-15 | Simon Berry |  |  |  | SI Test | PP | 5.12 |  | Complete | COMPLETE |  |  |  |  |  |  |
| 471 | 1.4.1.1.1.6 | Environment Approach and Plan - Non SIT LDSO Testing | milestone | 0d | 2024-04-17 A | 2024-04-17 A |  | 100% |  | 2024-04-17 | 2024-04-17 | 0d |  |  |  | start no earlier than 2024-04-17 | Simon Berry |  |  |  | SI Test | PP | 5.22 | Systems Integration Testing (SIT) | Complete | COMPLETE | MHHS-DEL 619 | T3-TE-0091 | SITAG/QAG | T3 |  |  |
| 472 | 1.4.1.1.1.7 | Environment Approach and Plan - S and A Testing | milestone | 0d | 2024-07-17 A | 2024-07-17 A |  | 100% |  | 2024-07-17 | 2024-07-17 | 0d |  |  |  | start no earlier than 2024-07-17 | Simon Berry |  |  |  | SI Test | PP | 5.27 | Systems Integration Testing (SIT) | Complete | COMPLETE | MHHS-DEL 619 | T3-TE-0120 | SITAG/QAG | T3 |  |  |
| 473 | 1.4.1.1.1.8 | Environment Approach and Plan - SIT Non Functional | milestone | 0d | 2024-06-19 A | 2024-06-19 A |  | 100% |  | 2024-06-19 | 2024-06-19 | 0d |  |  |  | start no earlier than 2024-06-19 | Simon Berry |  |  |  | SI Test | PP | 5.27 | Systems Integration Testing (SIT) | Complete | COMPLETE | MHHS-DEL 620 | T3-TE-0092 | SITAG | T3 |  |  |
| 474 | 1.4.1.1.1.9 | Environment Approach and Plan - Sandbox | milestone | 0d | 2024-08-21 A | 2024-08-21 A |  | 100% |  | 2024-08-21 | 2024-08-21 | 0d |  |  |  | start no earlier than 2024-08-21 | Simon Berry |  |  |  | SI Test | PP | 5.27 | Systems Integration Testing (SIT) | Complete | COMPLETE | MHHS-DEL 621 | T3-TE-0093 | SITAG/QAG | T3 |  |  |

Notes:
- 450: 6/11 - last report sent out 27/10
- 451: 6/11 - last report sent out 27/10
- 455: 15/9 - keep in plan until qualification reviewed
- 463: Action: 11/3: Ask Simon B for the link (line 1312) dip onboarding to non sit ldso
- 465: Action: 16/8 - add to milestone register. Build out detail further
- 466: Action: 25/7 - Simon to provide update
- 467: Action: 25/7 - Simon to provide update
- 468: Action: 25/7 - Simon to provide update
- 469: The LDSO element is on hold whilst discussions are being held between Programme and Code Bodies re: LDSO testing. When concluded, that update will be re-planned by agreement with TMAG. 20/11- Approved at TMAG / Action: 16/8 - add to milestone register. Build out detail further
- 471: 25/03: To go to Apr QAG for name change as Non-SIT LDSO and S and A will deliver on different timelines so '& S and A' will be removed. 17/4: Approved for name change at SITAG on 17/4/24. / Action: 16/8 - add to milestone register. Build out detail further
- 472: . 25/03: New milestone to go to Apr QAG as Non-SIT LDSO and S and A will deliver on different timelines so need to create a new milestone for S and A. 17/4: Approved as new milestone at SITAG on 17/4/24. 19/6: Approved at SITAG on 19/6 / Action: 16/8 - add to milestone register. Build out detail further
- 473: 26/3/24: To go to April SITAG for date change approval. Because of dependency on NF test approach and plan. Currently under PP review 17/4: Approved date change at SITAG on 17/4/24. 19/6: Approved at SITAG on 19/6 / Action: 16/8 - add to milestone register. Build out detail further
- 474: Name change to remove 'qualification and' to reflect sandbox only scope. Name and date change approved at QAG on 21/3/24. 19/6: Approved at SITAG on 19/6 / Action: 16/8 - add to milestone register. Build out detail further

| ID | WBS | Task | Type | Duration | Start | Finish | Predecessors | Complete | Remaining | Baseline start | Baseline finish | Baseline duration | Baseline 1 start | Baseline 1 finish | Total slack | Constraint | Resources | Work | Actual work | Baseline cost | Responsible | Involved | Update Version | MHHS Programme Phase | Sched Status | RAG | Task Status | Milestone ID | Text29 | Tier |
| --- | --- | --- | --- | --- | --- | --- | --- | --- | --- | --- | --- | --- | --- | --- | --- | --- | --- | --- | --- | --- | --- | --- | --- | --- | --- | --- | --- | --- | --- | --- |
| 475 | 1.4.1.1.2 | **Overarching Test Scope (for all stages)** |  | 65d | 2022-10-31 A | 2023-01-27 A |  | 100% |  | 2022-10-31 | 2023-06-30 | 175d | 2022-10-31 | 2023-06-30 |  |  | N/A | 1560h | 1560h |  | N/A | N/A | 5.0 | Systems Integration Testing (SIT) |  |  |  |  |  |  |
| 476 | 1.4.1.1.2.1 | **Overarching Test Scope (excl. Migration/Reverse Migration, NFT and Ops components)** |  | 65d | 2022-10-31 A | 2023-01-27 A |  | 100% |  | 2022-10-31 | 2023-01-27 | 65d | 2022-10-31 | 2023-01-27 |  |  | N/A | 1040h | 1040h |  | N/A | N/A | 5.0 | Systems Integration Testing (SIT) |  |  |  |  |  |  |
| 477 | 1.4.1.1.2.1.1 | Develop document (excl Migration/Reverse Migration, NFT and Ops components) |  | 55d | 2022-10-31 A | 2023-01-13 A | 48 | 100% |  | 2022-10-31 | 2023-01-13 | 55d | 2022-10-31 | 2023-01-13 |  |  | Lee Cox | 440h | 440h |  | SI Test |  | 5.0 | Systems Integration Testing (SIT) | Complete | COMPLETE |  |  |  |  |
| 478 | 1.4.1.1.2.1.2 | Review, update & agree document (excl Migration/Reverse Migration, NFT and Ops components) |  | 10d | 2023-01-16 A | 2023-01-27 A | 477 | 100% |  | 2023-01-16 | 2023-01-27 | 10d | 2023-01-16 | 2023-01-27 |  |  | Lee Cox | 80h | 80h |  | SI Test | IPA,Code Bodies,PP | 5.0 | Systems Integration Testing (SIT) | Complete | COMPLETE |  |  |  |  |
| 479 | 1.4.1.1.3 | **Configuration and Release Management Approach & Plan** |  | 164d | 2022-11-01 A | 2023-06-16 A |  | 100% |  | 2022-11-01 | 2023-06-16 | 164d | 2022-11-01 | 2023-04-28 |  |  | N/A | 2368h | 2368h |  | N/A | N/A | 5.0 | Systems Integration Testing (SIT) |  |  | M9 |  |  |  |
| 480 | 1.4.1.1.3.1 | Develop document |  | 69d | 2022-11-01 A | 2023-06-16 A |  | 100% |  | 2022-11-01 | 2023-06-16 | 69d | 2022-11-01 | 2023-01-31 |  | start no earlier than 2022-11-01 | Simon Berry | 552h | 552h |  | SI Test |  | 5.0 | Systems Integration Testing (SIT) | Complete | COMPLETE |  |  |  |  |
| 481 | 1.4.1.1.3.2 | Review, update and agree Configuration and Release Management Approach & Plan internally |  | 63d | 2023-02-01 A | 2023-04-28 A | 480 | 100% |  | 2023-02-01 | 2023-04-28 | 63d | 2023-02-01 | 2023-04-28 |  |  | Simon Berry | 504h | 504h |  | SRO Function | IPA,SI Test | 5.0 | Systems Integration Testing (SIT) | Complete | COMPLETE |  |  |  |  |
| 482 | 1.4.1.1.4 | **Test Data Overarching Approach & Plan** |  | 179d | 2022-11-14 A | 2023-07-20 A |  | 100% |  | 2022-11-14 | 2023-07-20 | 179d | 2022-11-14 | 2023-05-18 |  |  | N/A | 2840h | 2840h |  | N/A | N/A | 5.0 | Systems Integration Testing (SIT) |  |  | M9 |  |  |  |
| 483 | 1.4.1.1.4.1 | Develop document |  | 20d | 2022-11-14 A | 2022-12-09 A |  | 100% |  | 2022-11-14 | 2022-12-09 | 20d | 2022-11-14 | 2022-12-09 |  | start no earlier than 2022-11-14 | Cesar Lopes | 160h | 160h |  | SI Test | PP | 5.0 | Systems Integration Testing (SIT) | Complete | COMPLETE |  |  |  |  |
| 484 | 1.4.1.1.4.2 | Document review and update |  | 155d | 2022-12-12 A | 2023-07-14 A | 483 | 100% |  | 2022-12-12 | 2023-07-14 | 155d | 2022-12-12 | 2023-05-17 |  |  | Cesar Lopes | 1240h | 1240h |  | PP | SI Test,IPA | 5.0 | Systems Integration Testing (SIT) | Complete | COMPLETE |  |  |  |  |
| 485 | 1.4.1.1.4.3 | Test Data Overarching Approach & Plan approved by TMAG | milestone | 0d | 2023-07-19 A | 2023-07-19 A | 484FS+3d | 100% |  | 2023-07-19 | 2023-07-19 | 0d | 2023-05-17 | 2023-05-17 |  |  | Cesar Lopes |  |  |  | SRO Test | PP,IPA,Code Bodies | 5.0 | Systems Integration Testing (SIT) | Complete | COMPLETE |  | T3-TE-0072 | SITAG | T3 |
| 486 | 1.4.1.1.4.4 | Document publication final version |  | 1d | 2023-07-20 A | 2023-07-20 A | 485 | 100% |  | 2023-07-20 | 2023-07-20 | 1d | 2023-05-18 | 2023-05-18 |  |  | Cesar Lopes | 8h | 8h |  | SI Test |  | 5.0 | Systems Integration Testing (SIT) | Complete | COMPLETE |  |  |  |  |
| 487 | 1.4.1.1.5 | **Interface Code of Connection (dates subject to DIP Service Provider's plan)** |  | 48d | 2023-03-01 A | 2023-05-05 A |  | 100% |  | 2023-03-01 | 2023-05-05 | 48d | 2023-03-01 | 2023-05-05 |  |  | N/A | 728h | 728h |  | N/A | N/A | 5.0 | Systems Integration Testing (SIT) |  |  |  |  |  |  |
| 488 | 1.4.1.1.5.1 | Develop Interface Code of Connection with DIP Service Provider |  | 43d | 2023-03-01 A | 2023-04-28 A |  | 100% |  | 2023-03-01 | 2023-04-28 | 43d | 2023-03-01 | 2023-04-28 |  | must start on 2023-03-01 | Lee Cox | 344h | 344h |  | DIP Provider | SI Test | 5.0 | Systems Integration Testing (SIT) | Complete | COMPLETE |  |  |  |  |
| 489 | 1.4.1.1.5.2 | Interface Code of Connection approved at SDWG | milestone | 0d | 2023-05-05 A | 2023-05-05 A | 488FS+5d | 100% |  | 2023-05-05 | 2023-05-05 | 0d | 2023-05-05 | 2023-05-05 |  |  | Lee Cox |  |  |  | SI Test | PP | 5.0 | Systems Integration Testing (SIT) | Complete | COMPLETE |  |  |  |  |
| 490 | 1.4.1.1.6 | **Test Traceability** |  | 165d | 2023-06-01 A | 2024-01-17 |  | 98% | 2.71d | 2023-06-01 | 2024-01-17 | 165d | 2023-06-01 | 2023-09-01 | 877d |  | N/A | 3760h | 2576h | -0 | N/A | N/A | 5.0 | Systems Integration Testing (SIT) |  |  |  |  |  |  |
| 491 | 1.4.1.1.6.1 | RTM containing Method Statement Implied Requirements into Azure DevOps |  | 22d | 2023-06-01 A | 2023-06-30 A |  | 100% |  | 2023-06-01 | 2023-06-30 | 22d | 2023-06-01 | 2023-06-30 |  | must start on 2023-06-01 | Lee Cox | 176h | 176h |  | SI Test |  | 5.0 | Systems Integration Testing (SIT) | Complete | COMPLETE |  |  |  |  |
| 492 | 1.4.1.1.6.2 | RTM Containing Interface Catalogue Implied Requirements |  | 27d | 2023-06-01 A | 2023-07-07 A |  | 100% |  | 2023-06-01 | 2023-07-07 | 27d | 2023-06-01 | 2023-07-07 |  | must start on 2023-06-01 | Lee Cox | 216h | 216h |  | SI Test |  | 5.0 | Systems Integration Testing (SIT) | Complete | COMPLETE |  |  |  |  |
| 493 | 1.4.1.1.6.3 | SIT CIT Full Traceability & Coverage complete |  | 118d | 2023-07-10 A | 2023-12-20 A | 492, 491 | 100% |  | 2023-07-10 | 2023-12-08 | 110d | 2023-07-10 | 2023-07-28 |  |  | Lee Cox | 944h | 944h |  | SI Test |  | 5.0 | Systems Integration Testing (SIT) | Complete | COMPLETE |  |  |  |  |
| 494 | 1.4.1.1.6.4 | SIT Functional Full Traceability & Coverage complete |  | 138d | 2023-07-10 A | 2024-01-17 | 492, 491 | 96% | 5d | 2023-07-10 | 2024-01-17 | 138d | 2023-07-10 | 2023-09-01 | 877d |  | Lee Cox | 1104h | 1064h |  | SI Test |  | 5.0 | Systems Integration Testing (SIT) | Overdue | RED |  |  |  |  |
| 495 | 1.4.1.2 | **Test Tool Development** |  | 256d | 2022-10-31 A | 2023-10-23 A |  | 100% |  | 2022-10-31 | 2023-06-30 | 175d | 2022-10-31 | 2023-06-30 |  |  | N/A | 11272h | 11272h |  | N/A | N/A | 5.0 | Systems Integration Testing (SIT) |  |  |  |  |  |  |
| 496 | 1.4.1.2.1 | **Test Management Tool** |  | 256d | 2022-10-31 A | 2023-10-23 A |  | 100% |  | 2022-10-31 | 2023-06-30 | 175d | 2022-10-31 | 2023-06-30 |  |  | N/A | 9224h | 9224h |  | N/A | N/A | 5.0 | Systems Integration Testing (SIT) |  |  |  |  |  |  |
| 497 | 1.4.1.2.1.1 | **Test Management Tool Implementation** |  | 256d | 2022-10-31 A | 2023-10-23 A |  | 100% |  | 2022-10-31 | 2023-06-30 | 175d | 2022-10-31 | 2023-06-30 |  |  | N/A | 4376h | 4376h |  | N/A | N/A | 5.0 | Systems Integration Testing (SIT) |  |  |  |  |  |  |
| 498 | 1.4.1.2.1.1.1 | Requirements identification |  | 40d | 2022-10-31 A | 2022-12-23 A |  | 100% |  | 2022-10-31 | 2022-12-23 | 40d | 2022-10-31 | 2022-12-23 |  |  | Simon Berry | 320h | 320h |  | SI DevOps | SI Test | 5.0 | Systems Integration Testing (SIT) | Complete | COMPLETE |  |  |  |  |
| 499 | 1.4.1.2.1.1.2 | Development |  | 125d | 2023-01-02 A | 2023-06-23 A | 498FS+5d | 100% |  | 2023-01-02 | 2023-06-23 | 125d | 2023-01-02 | 2023-06-23 |  |  | Simon Berry | 1000h | 1000h |  | SI DevOps | SI Test | 5.0 | Systems Integration Testing (SIT) | Complete | COMPLETE |  |  |  |  |
| 500 | 1.4.1.2.1.1.3 | Testing |  | 125d | 2023-01-02 A | 2023-06-23 A | 499FF | 100% |  | 2023-01-02 | 2023-06-23 | 125d | 2023-01-02 | 2023-06-23 |  |  | Simon Berry | 1000h | 1000h |  | SI DevOps | SI Test | 5.0 | Systems Integration Testing (SIT) | Complete | COMPLETE |  |  |  |  |
| 501 | 1.4.1.2.1.1.4 | Accept tool | milestone | 0d | 2023-06-23 A | 2023-06-23 A | 500FF | 100% |  | 2023-06-23 | 2023-06-23 | 0d | 2023-06-23 | 2023-06-23 |  |  | Simon Berry |  |  |  | SI DevOps | SI Test | 5.0 | Systems Integration Testing (SIT) | Complete | COMPLETE |  |  |  |  |
| 502 | 1.4.1.2.1.1.5 | Implementation |  | 1d | 2023-10-23 A | 2023-10-23 A | 501FS+85d | 100% |  | 2023-06-30 | 2023-06-30 | 1d | 2023-06-30 | 2023-06-30 |  |  | Simon Berry | 8h | 8h |  | SI DevOps | PPC | 5.0 | Systems Integration Testing (SIT) | Complete | COMPLETE |  |  |  |  |

Notes:
- 479: Action: 1280 DIP available for Onboarding (need to add a link - non sit ldso)
- 494: Stays red till delivery plan agreed at TMAG / Action: 25/7 - Activity to be replanned
- 495: Action: 25/7 - replan from start
- 496: Action: 25/7 - replan from start
- 497: Action: 25/7 - replan from start
- 498: Action: 25/7 - replan from start
- 499: Action: 25/7 - replan from start
- 500: Action: 25/7 - replan from start
- 501: Action: 25/7 - replan from start
- 502: Action: 25/7 - replan from start

| ID | WBS | Task | Type | Duration | Start | Finish | Predecessors | Complete | Baseline start | Baseline finish | Baseline duration | Baseline 1 start | Baseline 1 finish | Total slack | Free slack | Constraint | Resources | Work | Actual work | Responsible | Involved | Action | Update Version | MHHS Programme Phase | Sched Status | RAG | Task Status | Milestone ID | Text29 | Tier |
| --- | --- | --- | --- | --- | --- | --- | --- | --- | --- | --- | --- | --- | --- | --- | --- | --- | --- | --- | --- | --- | --- | --- | --- | --- | --- | --- | --- | --- | --- | --- |
| 503 | 1.4.1.2.1.2 | **Test Management Tool User Guide** |  | 115d | 2023-01-02 A | 2023-06-09 A |  | 100% | 2023-01-02 | 2023-06-09 | 115d | 2023-01-02 | 2023-06-09 |  |  |  | N/A | 1840h | 1840h | N/A | N/A | 25/7 - replan from start | 5.0 | Systems Integration Testing (SIT) |  |  |  |  |  |  |
| 504 | 1.4.1.2.1.2.1 | Develop document |  | 100d | 2023-01-02 A | 2023-05-19 A | 499SS, 500SS | 100% | 2023-01-02 | 2023-05-19 | 100d | 2023-01-02 | 2023-05-19 |  |  | start no earlier than 2023-01-02 | Lee Cox | 800h | 800h | SI DevOps |  | 25/7 - replan from start | 5.0 | Systems Integration Testing (SIT) | Complete | COMPLETE |  |  |  |  |
| 505 | 1.4.1.2.1.2.2 | Review, update and agree Test Management Tool User Guide internally |  | 15d | 2023-05-22 A | 2023-06-09 A | 504 | 100% | 2023-05-22 | 2023-06-09 | 15d | 2023-05-22 | 2023-06-09 |  |  |  | Lee Cox | 120h | 120h | SRO Function | SI DevOps,SI Test,IPA,PPC | 25/7 - replan from start | 5.0 | Systems Integration Testing (SIT) | Complete | COMPLETE |  |  |  |  |
| 506 | 1.4.1.2.1.3 | **Test Management Tool Configuration Guide** |  | 60d | 2023-01-02 A | 2023-03-24 A |  | 100% | 2023-01-02 | 2023-03-24 | 60d | 2023-01-02 | 2023-03-24 |  |  |  | N/A | 960h | 960h | N/A | N/A | 25/7 - replan from start | 5.0 | Systems Integration Testing (SIT) |  |  |  |  |  |  |
| 507 | 1.4.1.2.1.3.1 | Develop document |  | 45d | 2023-01-02 A | 2023-03-03 A | 498 | 100% | 2023-01-02 | 2023-03-03 | 45d | 2023-01-02 | 2023-03-03 |  |  | start no earlier than 2023-01-02 | Lee Cox | 360h | 360h | SI DevOps | SI Test,IPA | 25/7 - replan from start | 5.0 | Systems Integration Testing (SIT) | Complete | COMPLETE |  |  |  |  |
| 508 | 1.4.1.2.1.3.2 | Review, update and agree Test Management Tool Configuration Guide internally |  | 15d | 2023-03-06 A | 2023-03-24 A | 507 | 100% | 2023-03-06 | 2023-03-24 | 15d | 2023-03-06 | 2023-03-24 |  |  |  | Lee Cox | 120h | 120h | SRO Function | SI DevOps,SI Test,IPA | 25/7 - replan from start | 5.0 | Systems Integration Testing (SIT) | Complete | COMPLETE |  |  |  |  |
| 509 | 1.4.1.2.2 | **Test Query Tool** | inactive | 130d | 2022-10-31 | 2023-04-28 |  |  | 2022-10-31 | 2023-04-28 | 130d | 2022-10-31 | 2023-04-28 | 96d |  |  | N/A | 2592h |  | N/A | N/A | 25/7 - replan from start | 5.0 | Systems Integration Testing (SIT) |  |  |  |  |  |  |
| 510 | 1.4.1.2.2.1 | **Test Query Tool Implementation** | inactive | 130d | 2022-10-31 | 2023-04-28 |  |  | 2022-10-31 | 2023-04-28 | 130d | 2022-10-31 | 2023-04-28 | 96d |  |  | N/A | 1328h |  | N/A | N/A | 25/7 - replan from start | 5.0 | Systems Integration Testing (SIT) |  |  |  |  |  |  |
| 511 | 1.4.1.2.2.1.1 | Requirements identification | inactive | 20d | 2022-10-31 | 2022-11-25 |  |  | 2022-10-31 | 2022-11-25 | 20d | 2022-10-31 | 2022-11-25 | 96d |  |  | Lee Cox | 160h |  | SI DevOps | SI Test | 25/7 - replan from start | 5.0 | Systems Integration Testing (SIT) |  | RED | -604.67 |  |  |  |
| 512 | 1.4.1.2.2.1.2 | Development | inactive | 10d | 2023-04-11 | 2023-04-24 | 511 |  | 2023-04-11 | 2023-04-24 | 10d | 2023-04-11 | 2023-04-24 | 0d |  | must start on 2023-04-11 | Lee Cox | 80h |  | SI DevOps | SI Test | 25/7 - replan from start | 5.0 | Systems Integration Testing (SIT) |  | RED | -442.67 |  |  |  |
| 513 | 1.4.1.2.2.1.3 | Testing | inactive | 5d | 2023-04-18 | 2023-04-24 | 512FF |  | 2023-04-18 | 2023-04-24 | 5d | 2023-04-18 | 2023-04-24 | 1065d | 0d |  | Lee Cox | 40h |  | SI DevOps | SI Test | 25/7 - replan from start | 5.0 | Systems Integration Testing (SIT) |  | RED | -435.67 |  |  |  |
| 514 | 1.4.1.2.2.1.4 | Accept tool | milestone, inactive | 0d | 2023-04-24 | 2023-04-24 | 513FF |  | 2023-04-24 | 2023-04-24 | 0d | 2023-04-24 | 2023-04-24 | 1065d | 0d |  | Lee Cox |  |  | SI DevOps | SI Test | 25/7 - replan from start | 5.0 | Systems Integration Testing (SIT) |  | RED | -429.29 |  |  |  |
| 515 | 1.4.1.2.2.1.5 | Implementation | inactive | 1d | 2023-04-28 | 2023-04-28 | 514FS+3d |  | 2023-04-28 | 2023-04-28 | 1d | 2023-04-28 | 2023-04-28 | 1065d |  |  | Lee Cox | 8h |  | SI DevOps | PPC | 25/7 - replan from start | 5.0 | Systems Integration Testing (SIT) |  | RED | -425.67 |  |  |  |
| 516 | 1.4.1.2.2.2 | **Test Query Tool User Guide** | inactive | 14d | 2023-04-11 | 2023-04-28 |  |  | 2023-04-11 | 2023-04-28 | 14d | 2023-04-11 | 2023-04-28 | 1065d |  |  | N/A | 224h |  | N/A | N/A | 25/7 - replan from start | 5.0 | Systems Integration Testing (SIT) |  |  |  |  |  |  |
| 517 | 1.4.1.2.2.2.1 | Develop document | inactive | 10d | 2023-04-11 | 2023-04-24 | 512SS |  | 2023-04-11 | 2023-04-24 | 10d | 2023-04-11 | 2023-04-24 | 1065d | 0d | start no earlier than 2022-11-28 | Lee Cox | 80h |  | SI DevOps |  | 25/7 - replan from start | 5.0 | Systems Integration Testing (SIT) |  | RED | -442.67 |  |  |  |
| 518 | 1.4.1.2.2.2.2 | Review, update and agree Test Query Tool User Guide internally | inactive | 4d | 2023-04-25 | 2023-04-28 | 517 |  | 2023-04-25 | 2023-04-28 | 4d | 2023-04-25 | 2023-04-28 | 1065d |  |  | Lee Cox | 32h |  | SRO Function | IPA,SI Test | 25/7 - replan from start | 5.0 | Systems Integration Testing (SIT) |  | RED | -428.67 |  |  |  |
| 519 | 1.4.1.3 | **SIT Participation** |  | 147d | 2022-10-31 A | 2023-05-23 A |  | 100% | 2022-10-31 | 2023-05-23 | 147d | 2022-10-31 | 2023-05-23 |  |  |  | N/A | 2968h | 2968h | N/A | N/A |  | 5.0 | Systems Integration Testing (SIT) |  |  |  |  |  |  |
| 520 | 1.4.1.3.1 | PPs decide whether to volunteer to participate in SIT and inform Programme of decision via Round 3 Replan consultation |  | 67d | 2022-10-31 A | 2023-01-31 A | 34FF | 100% | 2022-10-31 | 2023-01-31 | 67d | 2022-10-31 | 2023-01-31 |  |  |  | Lee Cox | 536h | 536h | PP | SI Test,PMO |  | 5.0 | Systems Integration Testing (SIT) | Complete | COMPLETE |  |  |  |  |
| 521 | 1.4.1.3.2 | Assurance of SIT volunteers' plans (submitted via Round 3 Replan Consultation) |  | 10d | 2023-02-01 A | 2023-02-14 A | 520, 34 | 100% | 2023-02-01 | 2023-02-14 | 10d | 2023-02-01 | 2023-02-14 |  |  |  | Lee Cox | 80h | 80h | SI Test | PP |  | 5.0 | Systems Integration Testing (SIT) | Complete | COMPLETE |  |  |  |  |
| 522 | 1.4.1.3.3 | SIT Participant Volunteers Identified | milestone | 0d | 2023-02-14 A | 2023-02-14 A | 521FF | 100% | 2023-02-14 | 2023-02-14 | 0d | 2023-02-14 | 2023-02-14 |  |  |  | Lee Cox |  |  | SI Test | PP |  | 5.0 | Systems Integration Testing (SIT) | Complete | COMPLETE |  | T2-TE-0100 | SITAG | T2 |
| 523 | 1.4.1.3.4 | Engagement with SIT volunteers |  | 147d | 2022-10-31 A | 2023-05-23 A |  | 100% | 2022-10-31 | 2023-05-23 | 147d | 2022-10-31 | 2023-05-23 |  |  |  | Lee Cox | 1176h | 1176h | SI Test | PP |  | 5.0 | Systems Integration Testing (SIT) | Complete | COMPLETE |  |  |  |  |
| 524 | 1.4.1.3.5 | SIT Participants Agreed | milestone | 0d | 2023-05-23 A | 2023-05-23 A | 523, 581FS-74d | 100% | 2023-05-23 | 2023-05-23 | 0d | 2023-05-23 | 2023-05-23 |  |  |  | Lee Cox |  |  | SI Test | PP |  | 5.0 | Systems Integration Testing (SIT) | Complete | COMPLETE |  | T2-TE-0150 | SITAG | T2 |
| 525 | 1.4.1.4 | **Data Protection Impact Assessment (DPIA)** |  | 32d | 2023-06-01 A | 2023-07-14 A |  | 100% | 2023-06-01 | 2023-07-14 | 32d | 2023-06-01 | 2023-07-14 |  |  |  | N/A | 512h | 512h | N/A | N/A |  | 5.0 | Systems Integration Testing (SIT) |  |  |  |  |  |  |
| 526 | 1.4.1.4.1 | Conduct DPIA on Overall Test Data Approach |  | 22d | 2023-06-01 A | 2023-06-30 A | 485 | 100% | 2023-06-01 | 2023-06-30 | 22d | 2023-06-01 | 2023-06-30 |  |  | start no earlier than 2023-06-01 | Cesar Lopes | 176h | 176h | PP | SI Test |  | 5.0 | Systems Integration Testing (SIT) | Complete | COMPLETE |  |  |  |  |
| 527 | 1.4.1.4.2 | Revise Overarching Test Data Approach & plan for DPIA (if required), including engagement with DWG |  | 9d | 2023-07-03 A | 2023-07-13 A | 526 | 100% | 2023-07-03 | 2023-07-13 | 9d | 2023-07-03 | 2023-07-13 |  |  |  | Cesar Lopes | 72h | 72h | SI Test Data |  |  | 5.0 | Systems Integration Testing (SIT) | Complete | COMPLETE |  |  |  |  |
| 528 | 1.4.1.4.3 | Review (internal), update and approve revised Overarching Test Data Approach & Plan (if required) |  | 1d | 2023-07-14 A | 2023-07-14 A | 527 | 100% | 2023-07-14 | 2023-07-14 | 1d | 2023-07-14 | 2023-07-14 |  |  |  | Cesar Lopes | 8h | 8h | SI Test Data | PP,IPA |  | 5.0 | Systems Integration Testing (SIT) | Complete | COMPLETE |  |  |  |  |

| ID | WBS | Task | Type | Duration | Start | Finish | Predecessors | Complete | Remaining | Baseline start | Baseline finish | Baseline duration | Baseline 1 start | Baseline 1 finish | Total slack | Constraint | Resources | Work | Actual work | Baseline cost | Responsible | Involved | Task Status | Update Version | MHHS Programme Phase | Sched Status | RAG | Milestone ID | Text29 | Tier | Guidance | Artefact ID |
| --- | --- | --- | --- | --- | --- | --- | --- | --- | --- | --- | --- | --- | --- | --- | --- | --- | --- | --- | --- | --- | --- | --- | --- | --- | --- | --- | --- | --- | --- | --- | --- | --- |
| 529 | 1.4.1.5 | **Data Sharing Agreements** |  | 44d | 2023-07-17 A | 2023-09-14 A |  | 100% |  | 2023-07-17 | 2023-09-14 | 44d |  |  |  |  | N/A | 704h | 704h |  | N/A | N/A | -275.67 | 5.5 | Systems Integration Testing (SIT) |  |  |  |  |  |  |  |
| 530 | 1.4.1.5.1 | Produce Data Sharing Agreement for Industry Review |  | 15d | 2023-07-17 A | 2023-08-04 A | 528 | 100% |  | 2023-07-17 | 2023-08-04 | 15d |  |  |  |  | Cesar Lopes | 120h | 120h |  | SI Test Data | PPC, Elexon |  | 5.5 | Systems Integration Testing (SIT) | Complete | COMPLETE |  |  |  |  |  |
| 531 | 1.4.1.5.2 | Manage Participant Queries and Contract Agreement Execution |  | 29d | 2023-08-07 A | 2023-09-14 A | 530 | 100% |  | 2023-08-07 | 2023-09-14 | 29d |  |  |  |  | Cesar Lopes | 232h | 232h |  | SI Test Data | PPC, Elexon |  | 5.5 | Systems Integration Testing (SIT) | Complete | COMPLETE |  |  |  |  |  |
| 532 | 1.4.1.5.3 | Data Sharing Agreements Complete | milestone | 0d | 2023-09-14 A | 2023-09-14 A | 531 | 100% |  | 2023-09-14 | 2023-09-14 | 0d |  |  |  |  | Cesar Lopes |  |  |  | SI Test Data | PPC, Elexon |  | 5.5 | Systems Integration Testing (SIT) | Complete | COMPLETE | T3-TE-0086 | SITAG | T3 |  |  |
| 533 | 1.4.1.6 | **Production Data Cut & Data Obfuscation** |  | 109d | 2023-04-04 A | 2023-09-01 A |  | 100% |  | 2023-04-04 | 2023-09-01 | 109d | 2023-04-04 | 2023-09-01 |  |  | N/A | 3312h | 3312h |  | N/A | N/A |  | 5.0 | Systems Integration Testing (SIT) |  |  |  |  |  |  |  |
| 534 | 1.4.1.6.1 | **SI Data Cut Preparation & Infrastructure** |  | 99d | 2023-04-04 A | 2023-08-18 A |  | 100% |  | 2023-04-04 | 2023-08-18 | 99d | 2023-04-04 | 2023-07-31 |  |  | N/A | 1592h | 1592h |  | N/A | N/A |  | 5.0 | Systems Integration Testing (SIT) |  |  |  |  |  |  |  |
| 535 | 1.4.1.6.1.1 | SI Data Cut Planning activities (incl. pre-cut and post-cut cleansing and population approach) |  | 55d | 2023-04-04 A | 2023-06-19 A |  | 100% |  | 2023-04-04 | 2023-06-19 | 55d | 2023-04-04 | 2023-06-19 |  | must start on 2023-04-04 | Cesar Lopes | 440h | 440h |  | SI Test Data | SI Test |  | 5.0 | Systems Integration Testing (SIT) | Complete | COMPLETE |  |  |  |  |  |
| 536 | 1.4.1.6.1.2 | Set up SI database and transmission structure |  | 44d | 2023-06-19 A | 2023-08-17 A | 535 | 100% |  | 2023-06-19 | 2023-08-17 | 44d | 2023-06-19 | 2023-07-31 |  | must start on 2023-06-19 | Cesar Lopes | 352h | 352h |  | SI Test Data | SI Test |  | 5.0 | Systems Integration Testing (SIT) | Complete | COMPLETE |  |  |  |  |  |
| 537 | 1.4.1.6.1.3 | Mechanism for transfer of data in place |  | 1d | 2023-08-18 A | 2023-08-18 A | 536 | 100% |  | 2023-08-18 | 2023-08-18 | 1d | 2023-07-31 | 2023-07-31 |  |  | Cesar Lopes | 8h | 8h |  | SI Test Data | SI Test |  | 5.0 | Systems Integration Testing (SIT) | Complete | COMPLETE |  |  |  |  |  |
| 538 | 1.4.1.6.1.4 | SI Data Cut Preparation & Infrastructure Complete | milestone | 0d | 2023-08-18 A | 2023-08-18 A | 537 | 100% |  | 2023-08-18 | 2023-08-18 | 0d |  |  |  |  | Cesar Lopes |  |  |  | SI Test Data | SI Test |  | 5.5 | Systems Integration Testing (SIT) | Complete | COMPLETE | T3-TE-0087 | SITAG | T3 |  |  |
| 539 | 1.4.1.6.2 | **Production Data Cut** |  | 55d | 2023-06-19 A | 2023-09-01 A |  | 100% |  | 2023-06-19 | 2023-09-01 | 55d | 2023-06-19 | 2023-09-01 |  |  | N/A | 848h | 848h |  | N/A | N/A |  | 5.0 | Systems Integration Testing (SIT) |  |  |  |  |  |  |  |
| 540 | 1.4.1.6.2.1 | Notification of Production Data Cut issued to relevant participants | milestone | 0d | 2023-06-19 A | 2023-06-19 A | 485 | 100% |  | 2023-06-19 | 2023-06-19 | 0d | 2023-06-19 | 2023-06-19 |  |  | Cesar Lopes |  |  |  | SI Test Data | PP |  | 5.0 | Systems Integration Testing (SIT) | Complete | COMPLETE | T3-TE-0011 | SITAG | T3 |  |  |
| 541 | 1.4.1.6.2.2 | Coordinate relevant participants taking data cut from production systems |  | 40d | 2023-06-19 A | 2023-08-11 A | 540 | 100% |  | 2023-06-19 | 2023-08-11 | 40d | 2023-06-19 | 2023-08-11 |  |  | Cesar Lopes | 320h | 320h |  | SI Test Data | PP |  | 5.0 | Systems Integration Testing (SIT) | Complete | COMPLETE |  |  |  |  |  |
| 542 | 1.4.1.6.2.3 | Production data cut GONG decision | milestone | 0d | 2023-08-16 A | 2023-08-16 A | 541FS+3d | 100% |  | 2023-08-16 | 2023-08-16 | 0d | 2023-08-16 | 2023-08-16 |  |  | Cesar Lopes |  |  |  | SI Test Data | PP |  | 5.0 | Systems Integration Testing (SIT) | Complete | COMPLETE | T3-TE-0017 | SITAG | T3 |  |  |
| 543 | 1.4.1.6.2.4 | Relevant participants take data cut from production systems (Saturday 19 August) |  | 1d | 2023-08-21 A | 2023-08-21 A | 542FS+2d | 100% |  | 2023-08-21 | 2023-08-21 | 1d | 2023-08-21 | 2023-08-21 |  |  | Cesar Lopes | 8h | 8h |  | SI Test Data | SI Test |  | 5.0 | Systems Integration Testing (SIT) | Complete | COMPLETE |  |  |  |  |  |
| 544 | 1.4.1.6.2.5 | EES transmit request data to SI |  | 5d | 2023-08-21 A | 2023-08-25 A | 543SS | 100% |  | 2023-08-21 | 2023-08-25 | 5d | 2023-08-21 | 2023-08-25 |  |  | Cesar Lopes | 40h | 40h |  | SI Test Data | SI Test |  | 5.0 | Systems Integration Testing (SIT) | Complete | COMPLETE |  |  |  |  |  |
| 545 | 1.4.1.6.2.6 | Check data alignment and integrity of data cut |  | 5d | 2023-08-28 A | 2023-09-01 A | 544 | 100% |  | 2023-08-28 | 2023-09-01 | 5d | 2023-08-28 | 2023-09-01 |  |  | Cesar Lopes | 40h | 40h |  | SI Test Data | PP |  | 5.0 | Systems Integration Testing (SIT) | Complete | COMPLETE |  |  |  |  |  |
| 546 | 1.4.1.6.2.7 | Data cut from relevant participants' production systems completed (Saturday 19 August) | milestone | 0d | 2023-08-21 A | 2023-08-21 A | 543, 526 | 100% |  | 2023-08-21 | 2023-08-21 | 0d | 2023-08-21 | 2023-08-21 |  |  | Cesar Lopes |  |  |  | SI Test Data | PP |  | 5.0 | Systems Integration Testing (SIT) | Complete | COMPLETE | T2-TE-0200 | SITAG | T2 | 28/07 - Starts on Sat 19th Aug |  |
| 547 | 1.4.1.6.2.8 | Production Data Cut Complete | milestone | 0d | 2023-08-21 A | 2023-08-21 A | 546 | 100% |  | 2023-08-21 | 2023-08-21 | 0d |  |  |  |  | Cesar Lopes |  |  |  | SI Test Data | PP |  | 5.4 | Systems Integration Testing (SIT) | Complete | COMPLETE |  |  |  | 28/07 - Starts on Sat 19th Aug |  |
| 548 | 1.4.1.7 | **SIT Stage-Specific Preparation** |  | 520d | 2022-10-31 A | 2024-10-25 |  | 95% | 28.38d | 2022-10-31 | 2025-03-03 | 611d | 2022-10-31 | 2025-03-10 | 675d |  | N/A | 105874h | 83705.6h | -0 | N/A | N/A |  | 5.0 | Systems Integration Testing (SIT) |  |  |  |  |  |  |  |
| 549 | 1.4.1.7.1 | **SIT Component Integration Preparation** |  | 320d | 2022-10-31 A | 2024-01-19 |  | 99% | 0d | 2022-10-31 | 2024-01-22 | 321d | 2022-10-31 | 2024-01-22 | 0d |  | N/A | 40384h | 37868.7h | -0 | N/A | N/A |  | 5.0 | Systems Integration Testing (SIT) |  |  |  |  |  |  |  |
| 550 | 1.4.1.7.1.1 | **Test Approach & Plan** |  | 188d | 2022-10-31 A | 2023-07-19 A |  | 100% |  | 2022-10-31 | 2023-07-19 | 188d | 2022-10-31 | 2023-07-19 |  |  | N/A | 3008h | 3008h |  | N/A | N/A |  | 5.0 | Systems Integration Testing (SIT) |  |  |  |  |  |  |  |
| 551 | 1.4.1.7.1.1.1 | Develop document with SITWG |  | 159d | 2022-10-31 A | 2023-06-08 A |  | 100% |  | 2022-10-31 | 2023-06-08 | 159d | 2022-10-31 | 2023-05-12 |  |  | Lee Cox | 1272h | 1272h |  | SI Test |  |  | 5.0 | Systems Integration Testing (SIT) | Complete | COMPLETE |  |  |  |  |  |
| 552 | 1.4.1.7.1.1.2 | Industry consultation |  | 10d | 2023-06-09 A | 2023-06-22 A | 551 | 100% |  | 2023-06-09 | 2023-06-22 | 10d |  |  |  |  | Lee Cox | 80h | 80h |  | PP |  |  | 5.1 | Systems Integration Testing (SIT) | Complete | COMPLETE |  |  |  |  |  |
| 553 | 1.4.1.7.1.1.3 | Artefact review (via TMAG) and updates |  | 19d | 2023-06-23 A | 2023-07-19 A | 552 | 100% |  | 2023-06-23 | 2023-07-19 | 19d | 2023-06-09 | 2023-07-06 |  | finish no earlier than 2023-07-06 | Lee Cox | 152h | 152h |  | SI Test | PP,IPA,Code Bodies |  | 5.0 | Systems Integration Testing (SIT) | Complete | COMPLETE |  |  |  |  |  |
| 554 | 1.4.1.7.1.1.4 | SIT Component Integration Testing Test Approach & Plan approved | milestone | 0d | 2023-07-19 A | 2023-07-19 A | 553 | 100% |  | 2023-07-19 | 2023-07-19 | 0d | 2023-07-19 | 2023-07-19 |  | finish no earlier than 2023-07-19 | Lee Cox |  |  |  | SI Test | PP |  | 5.0 | Systems Integration Testing (SIT) | Complete | COMPLETE | T3-TE-0012 | SITAG | T3 |  | MHHS-ART073 |

Notes:
- 529: 3/8 - JW and CL Meeting - Added in to align with FTIG plan as critical programme activity
- 530: 3/8 - JW and CL - Added in to align with FTIG plan as critical programme activity
- 531: 3/8 - JW and CL - Added in to align with FTIG plan as critical programme activity
- 532: 22/8 - no issue as long as ready by 14/9 when data starts to be transmitted to Helix / Action: 3/8 - add as t3 milestones. Awaiting approval at TMAG
- 538: 3/8 - JW and CL Meeting - added in as new T3 milestone / Action: 3/8 - add as t3 milestones. Awaiting approval at TMAG. 8/8 - update name in register
- 547: Action: 2/8 - check isn't a duplicate of t2-te-0200

| ID | WBS | Task | Type | Duration | Start | Finish | Predecessors | Complete | Baseline start | Baseline finish | Baseline duration | Baseline 1 start | Baseline 1 finish | Constraint | Resources | Work | Actual work | Baseline cost | Responsible | Involved | Update Version | MHHS Programme Phase | Sched Status | RAG | Artefact ID | Milestone ID | Text29 | Tier | Task Status |
| --- | --- | --- | --- | --- | --- | --- | --- | --- | --- | --- | --- | --- | --- | --- | --- | --- | --- | --- | --- | --- | --- | --- | --- | --- | --- | --- | --- | --- | --- |
| 555 | 1.4.1.7.1.2 | **Test Data Approach & Plan** |  | 29d | 2023-06-09 A | 2023-07-19 A |  | 100% | 2023-06-09 | 2023-07-19 | 29d | 2023-06-09 | 2023-07-19 |  | N/A | 464h | 464h |  | N/A | N/A | 5.0 | Systems Integration Testing (SIT) |  |  |  |  |  |  |  |
| 556 | 1.4.1.7.1.2.1 | Industry consultation |  | 10d | 2023-06-09 A | 2023-06-22 A | 552SS | 100% | 2023-06-09 | 2023-06-22 | 10d |  |  |  | Cesar Lopes | 80h | 80h |  | PP |  | 5.1 | Systems Integration Testing (SIT) | Complete | COMPLETE |  |  |  |  |  |
| 557 | 1.4.1.7.1.2.2 | Artefact review (via TMAG) and updates |  | 19d | 2023-06-23 A | 2023-07-19 A | 556 | 100% | 2023-06-23 | 2023-07-19 | 19d | 2023-06-09 | 2023-07-06 |  | Cesar Lopes | 152h | 152h |  | SI Test | PP | 5.0 | Systems Integration Testing (SIT) | Complete | COMPLETE |  |  |  |  |  |
| 558 | 1.4.1.7.1.2.3 | SIT Component Integration Testing Test Data Approach & Plan approved | milestone | 0d | 2023-07-19 A | 2023-07-19 A | 557 | 100% | 2023-07-19 | 2023-07-19 | 0d | 2023-07-19 | 2023-07-19 |  | Cesar Lopes |  |  |  | SI Test | IPA | 5.0 | Systems Integration Testing (SIT) | Complete | COMPLETE |  |  |  |  |  |
| 559 | 1.4.1.7.1.3 | **Test scenarios** |  | 173d | 2023-01-02 A | 2023-08-30 A |  | 100% | 2023-01-02 | 2023-08-30 | 173d | 2023-01-02 | 2023-06-02 |  | N/A | 1472h | 1472h |  | N/A | N/A | 5.0 | Systems Integration Testing (SIT) |  |  |  |  |  |  |  |
| 560 | 1.4.1.7.1.3.1 | Development of test scenarios | milestone | 0d | 2023-01-02 A | 2023-04-28 A | 551SS+45d | 100% | 2023-01-02 | 2023-04-28 | 85d | 2023-01-02 | 2023-04-28 |  | Lee Cox |  |  |  | SI Test | PP, Code Bodies | 5.0 | Systems Integration Testing (SIT) | Complete | COMPLETE |  |  |  |  |  |
| 561 | 1.4.1.7.1.3.2 | Review test scenarios with SIT Working Group |  | 11d | 2023-02-01 A | 2023-08-09 A | 560SS+22d | 100% | 2023-02-01 | 2023-08-09 | 136d | 2023-02-01 | 2023-05-26 |  | Lee Cox | 88h | 88h |  | SI Test | PP, Code Bodies, IPA | 5.0 | Systems Integration Testing (SIT) | Complete | COMPLETE |  |  |  |  |  |
| 562 | 1.4.1.7.1.3.3 | SIT Component Integration Testing Test scenarios approved | milestone | 0d | 2023-08-30 A | 2023-08-30 A | 561FS+15d | 100% | 2023-08-30 | 2023-08-30 | 0d | 2023-06-02 | 2023-06-02 |  | Lee Cox |  |  |  | SI Test | PP | 5.6 | Systems Integration Testing (SIT) | Complete | COMPLETE | MHHS-ART148 | T3-TE-0014 | SITAG | T3 |  |
| 563 | 1.4.1.7.1.4 | **Test cases** |  | 160d | 2023-05-01 A | 2023-12-08 A |  | 100% | 2023-05-01 | 2023-12-08 | 160d | 2023-05-01 | 2023-09-01 |  | N/A | 4240h | 4240h |  | N/A | N/A | 5.6 | Systems Integration Testing (SIT) |  |  |  |  |  |  |  |
| 564 | 1.4.1.7.1.4.1 | **SI Test cases** |  | 160d | 2023-05-01 A | 2023-12-08 A |  | 100% | 2023-05-01 | 2023-12-08 | 160d | 2023-05-01 | 2023-09-01 |  | N/A | 2960h | 2960h |  | N/A | N/A | 5.6 | Systems Integration Testing (SIT) |  |  |  |  |  |  |  |
| 565 | 1.4.1.7.1.4.1.1 | **Batch 1 (CIT Intervals 1 and 2)** |  | 110d | 2023-05-01 A | 2023-09-29 A |  | 100% | 2023-05-01 | 2023-09-29 | 110d |  |  |  | N/A | 1256h | 1256h |  | N/A | N/A | 5.6 | Systems Integration Testing (SIT) |  |  |  |  |  |  | -290.67 |
| 566 | 1.4.1.7.1.4.1.1.1 | Develop Test cases |  | 100d | 2023-05-01 A | 2023-09-15 A | 560 | 100% | 2023-05-01 | 2023-09-15 | 100d | 2023-05-01 | 2023-07-28 |  | Lee Cox | 304h | 304h |  | SI Test |  | 5.6 | Systems Integration Testing (SIT) | Complete | COMPLETE |  |  |  |  |  |
| 567 | 1.4.1.7.1.4.1.1.2 | Review Test cases with SIT Working Group |  | 9d | 2023-09-18 A | 2023-09-28 A | 566 | 100% | 2023-09-18 | 2023-09-28 | 9d | 2023-05-26 | 2023-08-25 |  | Lee Cox | 72h | 72h |  | SI Test | PP,IPA | 5.6 | Systems Integration Testing (SIT) | Complete | COMPLETE |  |  |  |  |  |
| 568 | 1.4.1.7.1.4.1.1.3 | SIT Component Integration Testing Test cases Batch 1 (CIT Intervals 1 and 2) approved at ETMAG | milestone | 0d | 2023-09-29 A | 2023-09-29 A | 567FS+1d | 100% | 2023-09-29 | 2023-09-29 | 0d | 2023-09-01 | 2023-09-01 |  | Lee Cox |  |  |  | SI Test | PP | 5.6 | Systems Integration Testing (SIT) | Complete | COMPLETE | MHHS-ART073 | T3-TE-0069 | SITAG | T3 |  |
| 569 | 1.4.1.7.1.4.1.2 | **Batch 2 (CIT Intervals 3 and 4)** |  | 25d | 2023-10-02 A | 2023-11-03 A |  | 100% | 2023-10-02 | 2023-11-03 | 25d |  |  |  | N/A | 320h | 320h |  | N/A | N/A | 5.6 | Systems Integration Testing (SIT) |  |  |  |  |  |  | -290.67 |
| 570 | 1.4.1.7.1.4.1.2.1 | Develop Test cases |  | 15d | 2023-10-02 A | 2023-10-20 A | 568 | 100% | 2023-10-02 | 2023-10-20 | 15d | 2023-05-01 | 2023-07-28 |  | Lee Cox | 48h | 48h |  | SI Test |  | 5.6 | Systems Integration Testing (SIT) | Complete | COMPLETE |  |  |  |  |  |
| 571 | 1.4.1.7.1.4.1.2.2 | Review Test cases with SIT Working Group |  | 9d | 2023-10-23 A | 2023-11-02 A | 570 | 100% | 2023-10-23 | 2023-11-02 | 9d | 2023-05-26 | 2023-08-25 |  | Lee Cox | 72h | 72h |  | SI Test | PP,IPA | 5.6 | Systems Integration Testing (SIT) | Complete | COMPLETE |  |  |  |  |  |
| 572 | 1.4.1.7.1.4.1.2.3 | SIT Component Integration Testing Test cases Batch 2 (CIT Intervals 3 and 4) approved at ETMAG | milestone | 0d | 2023-11-03 A | 2023-11-03 A | 571FS+1d | 100% | 2023-11-03 | 2023-11-03 | 0d | 2023-09-01 | 2023-09-01 |  | Lee Cox |  |  |  | SI Test | PP | 5.11 | Systems Integration Testing (SIT) | Complete | COMPLETE |  | T3-TE-0104 | SITAG | T3 |  |
| 573 | 1.4.1.7.1.4.1.3 | **Batch 3 (CIT Intervals 5 and 6)** |  | 25d | 2023-11-03 A | 2023-12-08 A |  | 100% | 2023-11-03 | 2023-12-08 | 25d |  |  |  | N/A | 104h | 104h |  | N/A | N/A | 5.6 | Systems Integration Testing (SIT) |  |  |  |  |  |  | -290.67 |
| 574 | 1.4.1.7.1.4.1.3.1 | Develop Test cases |  | 15d | 2023-11-03 A | 2023-11-24 A | 572 | 100% | 2023-11-03 | 2023-11-24 | 15d | 2023-05-01 | 2023-07-28 |  | Lee Cox |  |  |  | SI Test |  | 5.6 | Systems Integration Testing (SIT) | Complete | COMPLETE |  |  |  |  |  |
| 575 | 1.4.1.7.1.4.1.3.2 | Review Test cases with SIT Working Group |  | 9d | 2023-11-27 A | 2023-12-07 A | 574 | 100% | 2023-11-27 | 2023-12-07 | 9d | 2023-05-26 | 2023-08-25 |  | Lee Cox | 72h | 72h |  | SI Test | PP,IPA | 5.6 | Systems Integration Testing (SIT) | Complete | COMPLETE |  |  |  |  |  |
| 576 | 1.4.1.7.1.4.1.3.3 | SIT Component Integration Testing Test cases Batch 3 (CIT Intervals 5 and 6) approved at ETMAG | milestone | 0d | 2023-12-08 A | 2023-12-08 A | 575FS+1d | 100% | 2023-12-08 | 2023-12-08 | 0d | 2023-09-01 | 2023-09-01 |  | Lee Cox |  |  |  | SI Test | PP | 5.14 | Systems Integration Testing (SIT) | Complete | COMPLETE |  | T3-TE-0105 | SITAG | T3 |  |
| 577 | 1.4.1.7.1.5 | **CIT Interval 1 Preparation** |  | 283d | 2022-11-16 A | 2023-12-15 A |  | 100% | 2022-11-16 | 2023-12-08 | 278d | 2022-11-16 | 2023-10-23 |  | N/A | 14632h | 14632h | -0 | N/A | N/A | 5.6 | Systems Integration Testing (SIT) |  |  |  |  |  |  |  |
| 578 | 1.4.1.7.1.5.1 | **Environments (SIT A)** |  | 246d | 2022-11-16 A | 2023-10-25 A |  | 100% | 2022-11-16 | 2023-10-16 | 239d | 2022-11-16 | 2023-10-06 |  | N/A | 6616h | 6616h |  | N/A | N/A | 5.0 | Systems Integration Testing (SIT) |  |  |  |  |  |  |  |
| 579 | 1.4.1.7.1.5.1.1 | PPs register PKI Officers and request PKI certificates |  | 5d | 2023-10-09 A | 2023-10-13 A |  | 100% | 2023-10-09 | 2023-10-13 | 5d | 2023-08-28 | 2023-09-01 | start no earlier than 2023-10-09 | Simon Berry | 40h | 40h |  | PP | DIP Provider | 5.5 | Systems Integration Testing (SIT) | Complete | COMPLETE |  |  |  |  |  |
| 580 | 1.4.1.7.1.5.1.2 | PPs register PKI Officers and request PKI certificates Complete - Interval 1 | milestone | 0d | 2023-10-25 A | 2023-10-25 A | 579FS+8d | 100% | 2023-10-13 | 2023-10-13 | 0d |  |  |  | Simon Berry |  |  |  | PP | DIP Provider | 5.10 | Systems Integration Testing (SIT) | Complete | COMPLETE |  | T3-TE-0094 | SITAG | T3 |  |
| 581 | 1.4.1.7.1.5.1.3 | PP SIT A environment preparation (incl. security certificates and security compliance) |  | 238d | 2022-11-16 A | 2023-10-13 A | 466 | 100% | 2022-11-16 | 2023-09-01 | 208d | 2022-11-16 | 2023-09-01 |  | Simon Berry | 1904h | 1904h |  | PP | SI Test | 5.8 | Systems Integration Testing (SIT) | Complete | COMPLETE |  |  |  |  |  |
| 582 | 1.4.1.7.1.5.1.4 | SI coordinate SIT Participants' SIT A environment preparation |  | 238d | 2022-11-16 A | 2023-10-13 A | 581SS | 100% | 2022-11-16 | 2023-09-01 | 208d | 2022-11-16 | 2023-09-01 |  | Simon Berry | 1904h | 1904h |  | SI Test | PP | 5.8 | Systems Integration Testing (SIT) | Complete | COMPLETE |  |  |  |  |  |
| 583 | 1.4.1.7.1.5.1.5 | PP submit self-declaration of environment preparation complete (incl. security certificates and security compliance) to Programme for assurance | milestone | 0d | 2023-10-13 A | 2023-10-13 A | 581FF | 100% | 2023-09-01 | 2023-09-01 | 0d | 2023-09-01 | 2023-09-01 | start no earlier than 2023-10-13 | Simon Berry |  |  |  | PP | SI Test | 5.8 | Systems Integration Testing (SIT) | Complete | COMPLETE |  |  |  |  |  |
| 584 | 1.4.1.7.1.5.1.6 | SI assure PPs' self-declaration of environment preparation complete (incl. security certificates and security compliance) |  | 5d | 2023-10-16 A | 2023-10-20 A | 583FF+5d | 100% | 2023-09-04 | 2023-09-08 | 5d | 2023-09-04 | 2023-09-08 |  | Simon Berry | 40h | 40h |  | SI Test | PP | 5.8 | Systems Integration Testing (SIT) | Complete | COMPLETE |  |  |  |  |  |
| 585 | 1.4.1.7.1.5.1.7 | SIT Participants' SIT A environments ready to start connectivity proving CIT Interval 1 | milestone | 0d | 2023-09-01 A | 2023-09-01 A | 583SS | 100% | 2023-09-01 | 2023-09-01 | 0d | 2023-09-01 | 2023-09-01 |  | Simon Berry |  |  |  | PP | PP,IPA | 5.6 | Systems Integration Testing (SIT) | Complete | COMPLETE | MHHS-ART139 | T3-TE-0019 | SITAG | T3 |  |
| 586 | 1.4.1.7.1.5.1.8 | PP SIT A environment connectivity proving |  | 10d | 2023-09-04 A | 2023-09-15 A | 585 | 100% | 2023-09-12 | 2023-10-09 | 20d | 2023-09-04 | 2023-09-29 |  | Simon Berry | 80h | 80h |  | PP | SI Test | 5.8 | Systems Integration Testing (SIT) | Complete | COMPLETE |  |  |  |  |  |
| 587 | 1.4.1.7.1.5.1.9 | SI coordinate SIT Participants' SIT A environment connectivity proving |  | 10d | 2023-09-04 A | 2023-09-15 A | 586SS | 100% | 2023-09-12 | 2023-10-09 | 20d | 2023-09-04 | 2023-09-29 |  | Simon Berry | 80h | 80h |  | SI Test | PP | 5.8 | Systems Integration Testing (SIT) | Complete | COMPLETE |  |  |  |  |  |
| 588 | 1.4.1.7.1.5.1.10 | PP deployment of MHHS solution code to SIT A environments |  | 10d | 2023-09-25 A | 2023-10-06 A | 629FF | 100% | 2023-09-26 | 2023-10-09 | 10d | 2023-09-18 | 2023-09-29 |  | Simon Berry | 80h | 80h |  | PP | SI Test | 5.0 | Systems Integration Testing (SIT) | Complete | COMPLETE |  |  |  |  |  |
| 589 | 1.4.1.7.1.5.1.11 | SI coordinate deployment of MHHS solution code to SIT Participants' SIT A environments |  | 10d | 2023-09-25 A | 2023-10-06 A | 629FF | 100% | 2023-09-26 | 2023-10-09 | 10d | 2023-09-18 | 2023-09-29 |  | Simon Berry | 80h | 80h |  | SI Test | PP | 5.0 | Systems Integration Testing (SIT) | Complete | COMPLETE |  |  |  |  |  |
| 590 | 1.4.1.7.1.5.1.12 | PP submit evidence of SIT A environment connectivity proving and code deployment completion to Programme for assurance |  | 30d | 2023-09-04 A | 2023-10-13 A | 586SS | 100% | 2023-09-12 | 2023-10-09 | 20d | 2023-09-04 | 2023-09-29 |  | Simon Berry | 240h | 240h |  | PP | SI Test | 5.8 | Systems Integration Testing (SIT) | Complete | COMPLETE |  |  |  |  |  |
| 591 | 1.4.1.7.1.5.1.13 | SI assurance of SIT Participants' SIT A environment connectivity proving and code deployment completion |  | 25d | 2023-09-18 A | 2023-10-20 A | 590FF+5d | 100% | 2023-09-12 | 2023-10-16 | 25d | 2023-09-04 | 2023-10-06 |  | Simon Berry | 200h | 200h |  | SI Test | PP | 5.8 | Systems Integration Testing (SIT) | Complete | COMPLETE |  |  |  |  |  |

Notes:
- 562: 17/8 - to go to ETMAG on 30/8
- 563: 18/8 - added in with LC to reflect his ppt slide
- 564: 18/8 - added in with LC to reflect his ppt slide
- 565: 18/8 - added in with LC to reflect his ppt slide
- 566: 18/8 - added in with LC to reflect his ppt slide
- 567: 18/8 - added in with LC to reflect his ppt slide
- 568: 18/8 - added in with LC to reflect his ppt slide / Guidance: 18/8 - needs to finish on 29/9 for ETWAG / Action: 18/8 - needs to finish on 29/9 for ETWAG. Update Milestone register after approval
- 569: 18/8 - added in with LC to reflect his ppt slide
- 570: 18/8 - added in with LC to reflect his ppt slide
- 571: 18/8 - added in with LC to reflect his ppt slide
- 572: 18/8 - added in with LC to reflect his ppt slide / Guidance: 18/8 - needs to finish on 3/11 for ETWAG / Action: 18/8 - needs to finish on 29/9 for ETWAG
- 573: 18/8 - added in with LC to reflect his ppt slide
- 574: 18/8 - added in with LC to reflect his ppt slide
- 575: 18/8 - added in with LC to reflect his ppt slide
- 576: 18/8 - added in with LC to reflect his ppt slide. 28/11 - Red because TMAG date has moved from 8/12 to 20/12 due to reduction in Dec TMAGs. No impact. No action. 20/12 - Approved at TMAG on 20/12 / Guidance: 28/11 - Red because TMAG date has moved from 8/12 to 20/12 due to reduction in Dec TMAGs. No impact. No action
- 580: 16/8- new milestones added in and date change. Approved at TMAG on 16/8. 18/10 - Red because there is an issue that is preventing the issue of PKI certificates. ~Avanade are working with GlobalSign to resolve.~A fix is in the process of being tested

| ID | WBS | Task | Type | Duration | Start | Finish | Predecessors | Complete | Baseline start | Baseline finish | Baseline duration | Resources | Work | Actual work | Baseline cost | Responsible | Involved | Task Status | Update Version | MHHS Programme Phase | Sched Status | RAG | Action | Milestone ID | Text29 | Tier | Artefact ID |
| --- | --- | --- | --- | --- | --- | --- | --- | --- | --- | --- | --- | --- | --- | --- | --- | --- | --- | --- | --- | --- | --- | --- | --- | --- | --- | --- | --- |
| 592 | 1.4.1.7.1.5.2 | **Test Data - ISD Creation** |  | 9d | 2023-08-22 A | 2023-09-01 A |  | 100% | 2023-08-22 | 2023-09-01 | 9d | N/A | 144h | 144h |  | N/A | N/A | -275.67 | 5.5 | Systems Integration Testing (SIT) |  |  |  |  |  |  |  |
| 593 | 1.4.1.7.1.5.2.1 | Set-up Market Participants and DIP ID Data |  | 8d | 2023-08-22 A | 2023-08-31 A | 547 | 100% | 2023-08-22 | 2023-08-31 | 8d | Cesar Lopes | 64h | 64h |  | SI Test Data | SI Test, DIP, Helix |  | 5.5 | Systems Integration Testing (SIT) | Complete | COMPLETE |  |  |  |  |  |
| 594 | 1.4.1.7.1.5.2.2 | Distribute ISD Data to Participants |  | 1d | 2023-09-01 A | 2023-09-01 A | 593 | 100% | 2023-09-01 | 2023-09-01 | 1d | Cesar Lopes | 8h | 8h |  | SI Test Data | SI Test, DIP, Helix |  | 5.5 | Systems Integration Testing (SIT) | Complete | COMPLETE |  |  |  |  |  |
| 595 | 1.4.1.7.1.5.2.3 | Test Data - ISD Creation Complete | milestone | 0d | 2023-09-01 A | 2023-09-01 A | 594 | 100% | 2023-09-01 | 2023-09-01 | 0d | Cesar Lopes |  |  |  | SI Test Data | SI Test, DIP, Helix |  | 5.5 | Systems Integration Testing (SIT) | Complete | COMPLETE | 3/8 - add as t3 milestones. Awaiting approval at TMAG | T3-TE-0083 | SITAG | T3 |  |
| 596 | 1.4.1.7.1.5.3 | **Test Data - SFTP Onboarding** |  | 70d | 2023-08-21 A | 2023-11-24 A |  | 100% | 2023-08-21 | 2023-11-24 | 70d | N/A | 664h | 664h | -0 | N/A | N/A | -275.67 | 5.5 | Systems Integration Testing (SIT) |  |  |  |  |  |  |  |
| 597 | 1.4.1.7.1.5.3.1 | Create Containers and Keys for Participants |  | 3d | 2023-08-21 A | 2023-08-23 A | 538 | 100% | 2023-08-21 | 2023-08-23 | 3d | Cesar Lopes | 24h | 24h |  | SI Test Data | SI Test |  | 5.5 | Systems Integration Testing (SIT) | Complete | COMPLETE |  |  |  |  |  |
| 598 | 1.4.1.7.1.5.3.2 | Share SFTP Access with Participants |  | 5d | 2023-08-24 A | 2023-08-30 A | 597 | 100% | 2023-08-24 | 2023-08-30 | 5d | Cesar Lopes | 40h | 40h |  | SI Test Data | SI Test, PP |  | 5.5 | Systems Integration Testing (SIT) | Complete | COMPLETE |  |  |  |  |  |
| 599 | 1.4.1.7.1.5.3.3 | Test SFTP Connectivity |  | 5d | 2023-08-31 A | 2023-09-06 A | 598 | 100% | 2023-08-31 | 2023-09-06 | 5d | Cesar Lopes | 40h | 40h |  | SI Test Data | SI Test, PP |  | 5.5 | Systems Integration Testing (SIT) | Complete | COMPLETE |  |  |  |  |  |
| 600 | 1.4.1.7.1.5.3.4 | Test Data - SFTP Onboarding Complete | milestone | 0d | 2023-11-24 A | 2023-11-24 A | 599FS+57d | 100% | 2023-11-24 | 2023-11-24 | 0d | Cesar Lopes |  |  |  | SI Test Data | SI Test, PP |  | 5.13 | Systems Integration Testing (SIT) | Complete | COMPLETE |  | T3-TE-0084 | SITAG | T3 |  |
| 601 | 1.4.1.7.1.5.4 | **Test Data - Provide Sample Files** |  | 10d | 2023-08-21 A | 2023-09-01 A |  | 100% | 2023-08-21 | 2023-09-01 | 10d | N/A | 160h | 160h |  | N/A | N/A | -275.67 | 5.5 | Systems Integration Testing (SIT) |  |  |  |  |  |  |  |
| 602 | 1.4.1.7.1.5.4.1 | Generate Sample Files off IF Messages |  | 8d | 2023-08-21 A | 2023-08-30 A | 538 | 100% | 2023-08-21 | 2023-08-30 | 8d | Cesar Lopes | 64h | 64h |  | SI Test Data | SI Test |  | 5.5 | Systems Integration Testing (SIT) | Complete | COMPLETE |  |  |  |  |  |
| 603 | 1.4.1.7.1.5.4.2 | Transmit Sample Files off IF Messages to Participants (More detail needs to be planned for a POC) |  | 2d | 2023-08-31 A | 2023-09-01 A | 602 | 100% | 2023-08-31 | 2023-09-01 | 2d | Cesar Lopes | 16h | 16h |  | SI Test Data | SI Test |  | 5.5 | Systems Integration Testing (SIT) | Complete | COMPLETE |  |  |  |  |  |
| 604 | 1.4.1.7.1.5.4.3 | Test Data - Provide Sample Files Complete | milestone | 0d | 2023-09-01 A | 2023-09-01 A | 603 | 100% | 2023-09-01 | 2023-09-01 | 0d | Cesar Lopes |  |  |  | SI Test Data | SI Test |  | 5.5 | Systems Integration Testing (SIT) | Complete | COMPLETE | 3/8 - add as t3 milestones. Awaiting approval at TMAG | T3-TE-0085 | SITAG | T3 |  |
| 605 | 1.4.1.7.1.5.5 | **Test Data - Detailed SIT Data Load Guidance** |  | 65d | 2023-09-07 A | 2023-12-06 A |  | 100% | 2023-09-07 | 2023-12-01 | 62d | N/A | 696h | 696h | -0 | N/A | N/A | -275.67 | 5.5 | Systems Integration Testing (SIT) |  |  |  |  |  |  |  |
| 606 | 1.4.1.7.1.5.5.1 | Document Guidance |  | 21d | 2023-09-07 A | 2023-10-05 A | 604FS+3d | 100% | 2023-09-07 | 2023-09-28 | 16d | Cesar Lopes | 168h | 168h |  | SI Test Data | SI Test |  | 5.9 | Systems Integration Testing (SIT) | Complete | COMPLETE |  |  |  |  |  |
| 607 | 1.4.1.7.1.5.5.2 | Provide Guidance to PPs |  | 1d | 2023-10-06 A | 2023-10-06 A | 606 | 100% | 2023-09-29 | 2023-09-29 | 1d | Cesar Lopes | 8h | 8h |  | SI Test Data | SI Test |  | 5.9 | Systems Integration Testing (SIT) | Complete | COMPLETE |  |  |  |  |  |
| 608 | 1.4.1.7.1.5.5.3 | Test Data - Detailed SIT Functional Data Load Guidance Complete | milestone | 0d | 2023-12-06 A | 2023-12-06 A | 607FS+43d | 100% | 2023-12-01 | 2023-12-01 | 0d | Richard Puddephatt |  |  |  | SI Test Data | SI Test |  | 5.13 | Systems Integration Testing (SIT) | Complete | COMPLETE |  | T3-TE-0095 | SITAG | T3 | MHHS-DEL 1545 |
| 609 | 1.4.1.7.1.5.6 | **Test Data - Population of Data Items for Testing Guidance - Draft** |  | 80d | 2023-08-17 A | 2023-12-06 A |  | 100% | 2023-08-17 | 2023-12-01 | 77d | N/A | 736h | 736h | -0 | N/A | N/A | -275.67 | 5.5 | Systems Integration Testing (SIT) |  |  |  |  |  |  |  |
| 610 | 1.4.1.7.1.5.6.1 | Document Guidance - Draft |  | 11d | 2023-08-17 A | 2023-08-31 A | 798 | 100% | 2023-08-17 | 2023-08-31 | 11d | Cesar Lopes | 88h | 88h |  | SI Test Data | SI Test |  | 5.6 | Systems Integration Testing (SIT) | Complete | COMPLETE |  |  |  |  |  |
| 611 | 1.4.1.7.1.5.6.2 | Provide Guidance to PPs - Draft |  | 1d | 2023-09-01 A | 2023-09-01 A | 610 | 100% | 2023-09-01 | 2023-09-01 | 1d | Cesar Lopes | 8h | 8h |  | SI Test Data | SI Test |  | 5.6 | Systems Integration Testing (SIT) | Complete | COMPLETE |  |  |  |  |  |
| 612 | 1.4.1.7.1.5.6.3 | Test Data - Population of Data Items for Testing Guidance - Draft Complete | milestone | 0d | 2023-12-06 A | 2023-12-06 A | 611FS+68d | 100% | 2023-12-01 | 2023-12-01 | 0d | Richard Puddephatt |  |  |  | SI Test Data | SI Test |  | 5.13 | Systems Integration Testing (SIT) | Complete | COMPLETE |  | T3-TE-0096 | SITAG | T3 | MHHS-DEL 816 |
| 613 | 1.4.1.7.1.5.7 | **Test Data - Population of Data Items for Testing Guidance - Final** |  | 87d | 2023-08-17 A | 2023-12-15 A |  | 100% | 2023-10-09 | 2023-12-08 | 45d | N/A | 1352h | 1352h |  | N/A | N/A | -275.67 | 5.5 | Systems Integration Testing (SIT) |  |  |  |  |  |  |  |
| 614 | 1.4.1.7.1.5.7.1 | Update Document Guidance With PPS Feedback |  | 81d | 2023-08-17 A | 2023-12-07 A | 610SS | 100% | 2023-10-09 | 2023-12-07 | 44d | Richard Puddephatt | 648h | 648h |  | SI Test Data | SI Test |  | 5.5 | Systems Integration Testing (SIT) | Complete | COMPLETE |  |  |  |  |  |
| 615 | 1.4.1.7.1.5.7.2 | Provide Final Guidance to PPs |  | 1d | 2023-12-08 A | 2023-12-08 A | 614 | 100% | 2023-12-08 | 2023-12-08 | 1d | Richard Puddephatt | 8h | 8h |  | SI Test Data | SI Test |  | 5.5 | Systems Integration Testing (SIT) | Complete | COMPLETE |  |  |  |  |  |
| 616 | 1.4.1.7.1.5.7.3 | Test Data - Population of Data Items for Testing Guidance - Final Complete | milestone | 0d | 2023-12-15 A | 2023-12-15 A | 615FS+5d | 100% | 2023-12-08 | 2023-12-08 | 0d | Richard Puddephatt |  |  |  | SI Test Data | SI Test |  | 5.14 | Systems Integration Testing (SIT) | Complete | COMPLETE |  | T3-TE-0097 | SITAG | T3 | MHHS-DEL 816 |

Notes:
- 592: 3/8 - JW and CL meeting - added in to give e more clarity around work being undertaken
- 593: 3/8 - JW and CL meeting - added in to give e more clarity around work being undertaken
- 594: 3/8 - JW and CL meeting - added in to give e more clarity around work being undertaken
- 595: 3/8 - JW and CL meeting - added in to give more clarity around work being undertaken
- 596: 3/8 - JW and CL meeting - added in to give more clarity around work being undertaken
- 597: 3/8 - JW and CL meeting - added in to give more clarity around work being undertaken
- 598: 3/8 - JW and CL meeting - added in to give more clarity around work being undertaken
- 599: 3/8 - JW and CL meeting - added in to give more clarity around work being undertaken
- 600: Approved at TMAG on 20/9. 26/9 - RP - Red because we have changed the approach to SFTP onboarding to be phased by interval. To go to TMAG for date change approval. Approved for date change at TMAG on 23/10/23
- 601: 3/8 - JW and CL meeting - added in to give more clarity around work being undertaken
- 602: 3/8 - JW and CL meeting - added in to give more clarity around work being undertaken
- 603: 3/8 - JW and CL meeting - added in to give more clarity around work being undertaken
- 604: 3/8 - JW and CL meeting - added in to give more clarity around work being undertaken
- 605: 3/8 - JW and CL meeting - added in to give more clarity around work being undertaken
- 606: 3/8 - JW and CL meeting - added in to give more clarity around work being undertaken
- 607: 3/8 - JW and CL meeting - added in to give more clarity around work being undertaken
- 608: 28/11- Red because of slow start to CIT Interval 3, doc timelines may need to be extended. Currently no impact on final doc. Aim to update the doc incrementally
- 609: 3/8 - JW and CL meeting - added in to give more clarity around work being undertaken
- 610: 3/8 - JW and CL meeting - added in to give more clarity around work being undertaken
- 611: 3/8 - JW and CL meeting - added in to give more clarity around work being undertaken
- 612: 28/11- Red because of slow start to CIT Interval 3, doc timelines may need to be extended. Currently no impact on final doc. Aim to update the doc incrementally
- 613: 3/8 - JW and CL meeting - added in to give more clarity around work being undertaken
- 614: 3/8 - JW and CL meeting - added in to give more clarity around work being undertaken
- 615: 3/8 - JW and CL meeting - added in to give more clarity around work being undertaken
- 616: 15/8 - JW and CL meeting - added in to give more clarity around work being undertaken. 12/12 - Red because we needed to provide the SRO 5 more working days to review. No impact. No action

| ID | WBS | Task | Type | Duration | Start | Finish | Predecessors | Complete | Baseline start | Baseline finish | Baseline duration | Baseline 1 start | Baseline 1 finish | Constraint | Resources | Work | Actual work | Baseline cost | Responsible | Involved | Update Version | MHHS Programme Phase | Sched Status | RAG | Artefact ID | Milestone ID | Text29 | Tier |
| --- | --- | --- | --- | --- | --- | --- | --- | --- | --- | --- | --- | --- | --- | --- | --- | --- | --- | --- | --- | --- | --- | --- | --- | --- | --- | --- | --- | --- |
| 617 | 1.4.1.7.1.5.8 | **Test Data (SIT A) Interval 1** |  | 40d | 2023-09-04 A | 2023-10-27 A |  | 100% | 2023-09-04 | 2023-09-29 | 20d | 2023-09-04 | 2023-09-29 |  | N/A | 472h | 472h |  | N/A | N/A | 5.0 | Systems Integration Testing (SIT) |  |  |  |  |  |  |
| 618 | 1.4.1.7.1.5.8.1 | Run data allocation |  | 4d | 2023-09-04 A | 2023-09-07 A | 545, 558, 547, 595 | 100% | 2023-09-04 | 2023-09-07 | 4d | 2023-09-04 | 2023-09-07 |  | Cesar Lopes | 32h | 32h |  | SI Test |  | 5.0 | Systems Integration Testing (SIT) | Complete | COMPLETE |  |  |  |  |
| 619 | 1.4.1.7.1.5.8.2 | Cleanse, anonymise and populate data post cut |  | 4d | 2023-09-08 A | 2023-09-13 A | 618 | 100% | 2023-09-08 | 2023-09-13 | 4d | 2023-09-08 | 2023-09-13 |  | Cesar Lopes | 32h | 32h |  | SI Test |  | 5.0 | Systems Integration Testing (SIT) | Complete | COMPLETE |  |  |  |  |
| 620 | 1.4.1.7.1.5.8.3 | Transmit data sets to PPs |  | 3d | 2023-09-15 A | 2023-09-19 A | 619, 532 | 100% | 2023-09-15 | 2023-09-15 | 1d | 2023-09-14 | 2023-09-15 |  | Cesar Lopes | 24h | 24h |  | SI Test |  | 5.0 | Systems Integration Testing (SIT) | Complete | COMPLETE |  |  |  |  |
| 621 | 1.4.1.7.1.5.8.4 | PP - Load test data to test environments |  | 7d | 2023-09-20 A | 2023-09-28 A | 620, 604 | 100% | 2023-09-18 | 2023-09-22 | 5d | 2023-09-18 | 2023-09-22 |  | Cesar Lopes | 56h | 56h |  | PP |  | 5.0 | Systems Integration Testing (SIT) | Complete | COMPLETE |  |  |  |  |
| 622 | 1.4.1.7.1.5.8.5 | PP Check data integrity on test environment |  | 1d | 2023-09-29 A | 2023-09-29 A | 621 | 100% | 2023-09-25 | 2023-09-29 | 5d | 2023-09-25 | 2023-09-29 |  | Cesar Lopes | 8h | 8h |  | PP |  | 5.0 | Systems Integration Testing (SIT) | Complete | COMPLETE |  |  |  |  |
| 623 | 1.4.1.7.1.5.8.6 | PP submit self-declaration to Programme to confirm loading & verification of test data | milestone | 0d | 2023-09-29 A | 2023-09-29 A | 622FF | 100% | 2023-09-29 | 2023-09-29 | 0d | 2023-09-29 | 2023-09-29 |  | Cesar Lopes |  |  |  | PP | SI Test | 5.0 | Systems Integration Testing (SIT) | Complete | COMPLETE |  |  |  |  |
| 624 | 1.4.1.7.1.5.8.7 | Test Data (SIT A) Interval 1 Complete | milestone | 0d | 2023-10-27 A | 2023-10-27 A | 623FS+20d | 100% | 2023-09-29 | 2023-09-29 | 0d |  |  |  | Cesar Lopes |  |  |  | SI Test | PP | 5.10 | Systems Integration Testing (SIT) | Complete | COMPLETE | MHHS-ART148/169 | T3-TE-0073 | SITAG | T3 |
| 625 | 1.4.1.7.1.5.9 | **Other Preparation** |  | 45d | 2023-07-03 A | 2023-09-01 A |  | 100% | 2023-07-03 | 2023-09-01 | 45d | 2023-07-03 | 2023-09-01 |  | N/A | 1080h | 1080h |  | N/A | N/A | 5.0 | Systems Integration Testing (SIT) |  |  |  |  |  |  |
| 626 | 1.4.1.7.1.5.9.1 | Onboarding of Test Participants to Test Management Tool (Azure DevOps) |  | 45d | 2023-07-03 A | 2023-09-01 A | 585SF | 100% | 2023-07-03 | 2023-09-01 | 45d | 2023-07-03 | 2023-09-01 |  | Lee Cox | 360h | 360h |  | SI Test | PP | 5.0 | Systems Integration Testing (SIT) | Complete | COMPLETE |  |  |  |  |
| 627 | 1.4.1.7.1.5.9.2 | Test Management Tool onboarding |  | 45d | 2023-07-03 A | 2023-09-01 A | 585SF | 100% | 2023-07-03 | 2023-09-01 | 45d | 2023-07-03 | 2023-09-01 |  | Lee Cox | 360h | 360h |  | PP | SI Test | 5.0 | Systems Integration Testing (SIT) | Complete | COMPLETE |  |  |  |  |
| 628 | 1.4.1.7.1.5.10 | **SIT Component Integration Test Readiness Report** |  | 28d | 2023-09-14 A | 2023-10-23 A |  | 100% | 2023-10-09 | 2023-10-20 | 9d | 2023-09-11 | 2023-10-20 |  | N/A | 448h | 448h |  | N/A | N/A | 5.6 | Systems Integration Testing (SIT) |  |  |  |  |  |  |
| 629 | 1.4.1.7.1.5.10.1 | PP submit Test Readiness Report to Programme for assurance | milestone | 0d | 2023-10-20 A | 2023-10-20 A | 627, 568, 624 | 100% | 2023-10-09 | 2023-10-09 | 0d | 2023-09-29 | 2023-09-29 | start no earlier than 2023-10-09 | Lee Cox |  |  |  | PP | SI Test | 5.6 | Systems Integration Testing (SIT) | Complete | COMPLETE |  |  |  |  |
| 630 | 1.4.1.7.1.5.10.2 | SI assure Test Participants' Test Readiness Reports |  | 1d | 2023-10-23 A | 2023-10-23 A | 629SS | 100% | 2023-10-10 | 2023-10-16 | 5d | 2023-10-02 | 2023-10-06 |  | Lee Cox | 8h | 8h |  | SI Test | PP,IPA | 5.6 | Systems Integration Testing (SIT) | Complete | COMPLETE |  |  |  |  |
| 631 | 1.4.1.7.1.5.10.3 | SI develop Overarching SIT Component Integration Test Readiness Report |  | 23d | 2023-09-14 A | 2023-10-16 A | 554FS+40d | 100% | 2023-10-10 | 2023-10-13 | 4d | 2023-09-11 | 2023-10-06 |  | Lee Cox | 184h | 184h |  | SI Test |  | 5.6 | Systems Integration Testing (SIT) | Complete | COMPLETE |  |  |  |  |
| 632 | 1.4.1.7.1.5.10.4 | Artefact review (via TMAG) and updates |  | 4d | 2023-10-17 A | 2023-10-20 A | 631 | 100% | 2023-10-16 | 2023-10-20 | 5d | 2023-10-09 | 2023-10-20 |  | Lee Cox | 32h | 32h |  | SI Test | PP,IPA | 5.6 | Systems Integration Testing (SIT) | Complete | COMPLETE |  |  |  |  |
| 633 | 1.4.1.7.1.5.11 | SIT Component Integration Testing 1 Preparation Complete (incl. approval of SI SIT Component Integration Test Readiness Report) | milestone | 0d | 2023-10-27 A | 2023-10-27 A | 632FS+1d, 629, 585, 627, 624, 198, 203, 192, 212, 213, 630 | 100% | 2023-10-23 | 2023-10-23 | 0d | 2023-10-23 | 2023-10-23 |  | Lee Cox |  |  |  | SI Test | PP,IPA | 5.11 | Systems Integration Testing (SIT) | Complete | COMPLETE | MHHS-ART071 | T2-TE-0250 | SITAG | T2 |
| 634 | 1.4.1.7.1.6 | **CIT Interval 2 Preparation** |  | 103d | 2023-07-03 A | 2023-11-22 A |  | 100% | 2023-07-03 | 2023-11-10 | 95d | 2022-11-16 | 2023-11-06 |  | N/A | 3752h | 3752h | -0 | N/A | N/A | 5.0 | Systems Integration Testing (SIT) |  |  |  |  |  |  |
| 635 | 1.4.1.7.1.6.1 | **Environments (SIT A)** |  | 43d | 2023-09-22 A | 2023-11-22 A |  | 100% | 2023-09-22 | 2023-11-10 | 35d | 2022-11-16 | 2023-10-27 |  | N/A | 552h | 552h | -0 | N/A | N/A | 5.0 | Systems Integration Testing (SIT) |  |  |  |  |  |  |
| 636 | 1.4.1.7.1.6.1.1 | SIT Participants' SIT A environments ready to start connectivity proving CIT Interval 2 | milestone | 0d | 2023-09-22 A | 2023-09-22 A |  | 100% | 2023-09-22 | 2023-09-22 | 0d | 2023-09-22 | 2023-09-22 |  | Simon Berry |  |  |  | PP | PP,IPA | 5.6 | Systems Integration Testing (SIT) | Complete | COMPLETE | MHHS-ART139 | T3-TE-0020 | SITAG | T3 |
| 637 | 1.4.1.7.1.6.1.2 | Programme Participants Ready to Start Connectivity Proving | milestone | 0d | 2023-09-22 A | 2023-09-22 A |  | 100% | 2023-09-22 | 2023-09-22 | 0d |  |  | finish no earlier than 2023-09-22 | Simon Berry |  |  |  | PP |  | 5.10 | Systems Integration Testing (SIT) | Complete | COMPLETE |  |  |  |  |
| 638 | 1.4.1.7.1.6.1.3 | Internal Connectivity Proving Phase |  | 10d | 2023-09-25 A | 2023-10-06 A | 637 | 100% | 2023-09-25 | 2023-10-06 | 10d |  |  |  | Simon Berry | 80h | 80h |  | PP |  | 5.10 | Systems Integration Testing (SIT) | Complete | COMPLETE |  |  |  |  |
| 639 | 1.4.1.7.1.6.1.4 | Internal Connectivity Proving Phase Complete | milestone | 0d | 2023-10-06 A | 2023-10-06 A | 638 | 100% | 2023-10-06 | 2023-10-06 | 0d |  |  | start no earlier than 2023-10-06 | Simon Berry |  |  |  | PP |  | 5.10 | Systems Integration Testing (SIT) | Complete | COMPLETE |  |  |  |  |
| 640 | 1.4.1.7.1.6.1.5 | DIP Onboarding Activity (1. PKI Officers and Certificates, 2. Set-up Validation, 3. End Point Creation, 4. Controlled Smoke Test ) |  | 28d | 2023-10-16 A | 2023-11-22 A | 639FS+5d | 100% | 2023-10-16 | 2023-11-10 | 20d |  |  |  | Simon Berry | 224h | 224h |  | PP |  | 5.10 | Systems Integration Testing (SIT) | Complete | COMPLETE |  |  |  |  |
| 641 | 1.4.1.7.1.6.1.6 | DIP Onboarding Complete | milestone | 0d | 2023-11-22 A | 2023-11-22 A | 640 | 100% | 2023-11-10 | 2023-11-10 | 0d |  |  |  | Simon Berry |  |  |  | PP |  | 5.10 | Systems Integration Testing (SIT) | Complete | COMPLETE |  |  |  |  |
| 642 | 1.4.1.7.1.6.1.7 | PPs Register PKI Officers and request PKI certificates Complete - Interval 2 | milestone | 0d | 2023-11-22 A | 2023-11-22 A | 641 | 100% | 2023-10-20 | 2023-10-20 | 0d |  |  |  | Simon Berry |  |  |  | PP | DIP Provider | 5.15 | Systems Integration Testing (SIT) | Complete | COMPLETE |  | T3-TE-0098 | SITAG | T3 |
| 643 | 1.4.1.7.1.6.1.8 | PP Code Deployment | milestone | 0d | 2023-10-20 A | 2023-10-20 A |  | 100% | 2023-10-20 | 2023-10-20 | 0d |  |  | start no earlier than 2023-10-20 | Simon Berry |  |  |  | PP |  | 5.10 | Systems Integration Testing (SIT) | Complete | COMPLETE |  |  |  |  |

Notes:
- 624: 28/7: CH: added in to be aT3 milestone. 10/10 - RP - Red because Avanade plan to load Test Data on week commencing 23/10, this is the earliest it can be planned due to latest code being required (M9 dependant) / Action: 28/7: CH: Needs to be set-up as a reporting milestone. 31/7: Check with Cesar if has been approved so can be baselined
- 628: Action: 21/8 - Rework with Lee
- 629: 18/8 - dates changed to reflect PIT Execution date changes advised by RG
- 630: 18/8 - dates changed to reflect PIT Execution date changes advised by RG / Action: 21/8 - Rework with Lee
- 631: 18/8 - dates changed to reflect PIT Execution date changes advised by RG / Action: 21/8 - Rework with Lee
- 632: 18/8 - dates changed to reflect PIT Execution date changes advised by RG / Action: 21/8 - Rework with Lee
- 633: Red because prep now dependant on an agreed work-off plan.
- 642: 5/12- Red because only 1 PP has successfully registered their PKI Officers; received their PKI certificates; set-up validation compete; end point creation complete; and completed controlled smoke test. The other PP is currently in Step 4 of E2E onboarding

| ID | WBS | Task | Type | Duration | Start | Finish | Predecessors | Complete | Baseline start | Baseline finish | Baseline duration | Baseline 1 start | Baseline 1 finish | Constraint | Resources | Work | Actual work | Baseline cost | Responsible | Involved | Update Version | MHHS Programme Phase | Sched Status | RAG | Artefact ID | Milestone ID | Text29 | Tier |
| --- | --- | --- | --- | --- | --- | --- | --- | --- | --- | --- | --- | --- | --- | --- | --- | --- | --- | --- | --- | --- | --- | --- | --- | --- | --- | --- | --- | --- |
| 644 | 1.4.1.7.1.6.2 | **Test Data (SIT A) Interval 2** |  | 43d | 2023-09-20 A | 2023-11-17 A |  | 100% | 2023-09-18 | 2023-10-20 | 25d | 2023-09-18 | 2023-10-20 |  | N/A | 808h | 808h |  | N/A | N/A | 5.0 | Systems Integration Testing (SIT) |  |  |  |  |  |  |
| 645 | 1.4.1.7.1.6.2.1 | Run data allocation |  | 7d | 2023-09-20 A | 2023-09-28 A | 621SS | 100% | 2023-09-18 | 2023-09-22 | 5d | 2023-09-18 | 2023-09-22 |  | Cesar Lopes | 56h | 56h |  | SI Test |  | 5.0 | Systems Integration Testing (SIT) | Complete | COMPLETE |  |  |  |  |
| 646 | 1.4.1.7.1.6.2.2 | Cleanse and populate data post cut |  | 2d | 2023-09-29 A | 2023-10-02 A | 645 | 100% | 2023-09-25 | 2023-09-29 | 5d | 2023-09-25 | 2023-09-29 |  | Cesar Lopes | 16h | 16h |  | SI Test |  | 5.0 | Systems Integration Testing (SIT) | Complete | COMPLETE |  |  |  |  |
| 647 | 1.4.1.7.1.6.2.3 | Transmit data sets to PPs |  | 1d | 2023-10-03 A | 2023-10-03 A | 646 | 100% | 2023-10-02 | 2023-10-03 | 2d | 2023-10-02 | 2023-10-03 |  | Cesar Lopes | 8h | 8h |  | SI Test |  | 5.0 | Systems Integration Testing (SIT) | Complete | COMPLETE |  |  |  |  |
| 648 | 1.4.1.7.1.6.2.4 | PP - Load test data to test environments |  | 33d | 2023-10-04 A | 2023-11-17 A | 647 | 100% | 2023-10-04 | 2023-10-13 | 8d | 2023-10-04 | 2023-10-13 |  | Cesar Lopes | 264h | 264h |  | PP |  | 5.0 | Systems Integration Testing (SIT) | Complete | COMPLETE |  |  |  |  |
| 649 | 1.4.1.7.1.6.2.5 | PP Check data integrity on test environment |  | 15d | 2023-10-23 A | 2023-11-17 A | 648FF | 100% | 2023-10-16 | 2023-10-20 | 5d | 2023-10-16 | 2023-10-20 |  | Cesar Lopes | 120h | 120h |  | PP |  | 5.0 | Systems Integration Testing (SIT) | Complete | COMPLETE |  |  |  |  |
| 650 | 1.4.1.7.1.6.2.6 | PP submit self-declaration to Programme to confirm loading & verification of test data | milestone | 0d | 2023-11-17 A | 2023-11-17 A | 649FF | 100% | 2023-10-20 | 2023-10-20 | 0d | 2023-10-20 | 2023-10-20 |  | Cesar Lopes |  |  |  | PP | SI Test | 5.0 | Systems Integration Testing (SIT) | Complete | COMPLETE |  |  |  |  |
| 651 | 1.4.1.7.1.6.2.7 | Test Data (SIT A) Interval 2 Complete | milestone | 0d | 2023-11-17 A | 2023-11-17 A | 650 | 100% | 2023-10-20 | 2023-10-20 | 0d |  |  |  | Cesar Lopes |  |  |  | SI Test | PP | 5.12 | Systems Integration Testing (SIT) | Complete | COMPLETE | MHHS-ART148/169 | T3-TE-0074 | SITAG | T3 |
| 652 | 1.4.1.7.1.6.3 | **Other Preparation** |  | 87d | 2023-07-03 A | 2023-10-31 A |  | 100% | 2023-07-03 | 2023-10-31 | 87d | 2023-07-03 | 2023-09-22 |  | N/A | 1392h | 1392h | -0 | N/A | N/A | 5.0 | Systems Integration Testing (SIT) |  |  |  |  |  |  |
| 653 | 1.4.1.7.1.6.3.1 | Onboarding of Test Participants to Test Management Tool (Azure DevOps) |  | 60d | 2023-07-03 A | 2023-09-22 A | 636SF | 100% | 2023-07-03 | 2023-09-22 | 60d | 2023-07-03 | 2023-09-22 |  | Lee Cox | 480h | 480h |  | SI Test | PP | 5.0 | Systems Integration Testing (SIT) | Complete | COMPLETE |  |  |  |  |
| 654 | 1.4.1.7.1.6.3.2 | Test Management Tool onboarding |  | 27d | 2023-09-25 A | 2023-10-31 A | 653 | 100% | 2023-09-25 | 2023-10-31 | 27d | 2023-07-03 | 2023-09-22 |  | Simon Berry | 216h | 216h |  | PP | SI Test | 5.0 | Systems Integration Testing (SIT) | Complete | COMPLETE |  |  |  |  |
| 655 | 1.4.1.7.1.6.4 | **SIT Component Integration Test Readiness Report** |  | 25d | 2023-10-02 A | 2023-11-03 A |  | 100% | 2023-10-02 | 2023-11-03 | 25d | 2023-10-02 | 2023-11-03 |  | N/A | 272h | 272h |  | N/A | N/A | 5.0 | Systems Integration Testing (SIT) |  |  |  |  |  |  |
| 656 | 1.4.1.7.1.6.4.1 | PP submit Test Readiness Report to Programme for assurance | milestone | 0d | 2023-10-25 A | 2023-10-25 A | 568FS+18d | 100% | 2023-10-20 | 2023-10-20 | 0d | 2023-10-20 | 2023-10-20 |  | Lee Cox |  |  |  | PP | SI Test | 5.0 | Systems Integration Testing (SIT) | Complete | COMPLETE |  |  |  |  |
| 657 | 1.4.1.7.1.6.4.2 | SI assure Test Participants' Test Readiness Reports |  | 2d | 2023-10-26 A | 2023-10-27 A | 656 | 100% | 2023-10-23 | 2023-10-27 | 5d | 2023-10-23 | 2023-10-27 |  | Lee Cox | 16h | 16h |  | SI Test | PP,IPA | 5.0 | Systems Integration Testing (SIT) | Complete | COMPLETE |  |  |  |  |
| 658 | 1.4.1.7.1.6.4.3 | SI develop Overarching SIT Component Integration Test Readiness Report |  | 20d | 2023-10-02 A | 2023-10-27 A | 657FF | 100% | 2023-10-02 | 2023-10-27 | 20d | 2023-10-02 | 2023-10-27 |  | Lee Cox | 160h | 160h |  | SI Test |  | 5.0 | Systems Integration Testing (SIT) | Complete | COMPLETE |  |  |  |  |
| 659 | 1.4.1.7.1.6.4.4 | Artefact review (via TMAG) and updates |  | 5d | 2023-10-30 A | 2023-11-03 A | 658 | 100% | 2023-10-30 | 2023-11-03 | 5d | 2023-10-30 | 2023-11-03 |  | Lee Cox | 40h | 40h |  | SI Test | PP,IPA | 5.0 | Systems Integration Testing (SIT) | Complete | COMPLETE |  |  |  |  |
| 660 | 1.4.1.7.1.6.5 | SIT Component Integration Testing 2 Preparation Complete (incl. approval of SI SIT Component Integration Test Readiness Report) | milestone | 0d | 2023-11-06 A | 2023-11-06 A | 654, 659FS+1d, 636, 261 | 100% | 2023-11-06 | 2023-11-06 | 0d | 2023-11-06 | 2023-11-06 |  | Lee Cox |  |  |  | SI Test | PP,IPA | 5.11 | Systems Integration Testing (SIT) | Complete | COMPLETE | MHHS-ART071 | T2-TE-0300 | SITAG | T2 |
| 661 | 1.4.1.7.1.7 | **CIT Interval 3 Preparation** |  | 54d | 2023-10-03 A | 2023-12-15 A |  | 100% | 2023-07-17 | 2023-11-20 | 91d | 2022-11-16 | 2023-11-20 |  | N/A | 2984h | 2984h | -0 | N/A | N/A | 5.0 | Systems Integration Testing (SIT) |  |  |  |  |  |  |
| 662 | 1.4.1.7.1.7.1 | **PIT Test Completion Report (incl. evidence)** |  | 26d | 2023-10-13 A | 2023-11-17 A |  | 100% | 2023-10-13 | 2023-11-10 | 21d | 2023-10-13 | 2023-11-10 |  | N/A | 416h | 416h |  | N/A | N/A | 5.0 | Systems Integration Testing (SIT) |  |  |  |  |  |  |
| 663 | 1.4.1.7.1.7.1.1 | Submit draft PIT Test Completion Report (incl. evidence) and submit to Programme for assurance |  | 11d | 2023-10-13 A | 2023-10-27 A |  | 100% | 2023-10-13 | 2023-10-13 | 1d | 2023-10-13 | 2023-10-13 | must start on 2023-10-13 | Lee Cox | 88h | 88h |  | PP | SI Test | 5.0 | Systems Integration Testing (SIT) | Complete | COMPLETE |  |  |  |  |
| 664 | 1.4.1.7.1.7.1.2 | Finalise PIT Test Completion Report (incl. evidence) |  | 5d | 2023-10-30 A | 2023-11-03 A | 663 | 100% | 2023-10-16 | 2023-11-03 | 15d | 2023-10-16 | 2023-11-03 |  | Lee Cox | 40h | 40h |  | PP | SI Test | 5.0 | Systems Integration Testing (SIT) | Complete | COMPLETE |  |  |  |  |
| 665 | 1.4.1.7.1.7.1.3 | PP PIT Completion Report (excl. Migration/Reverse Migration) submitted to Programme for assurance CIT Interval 3 | milestone | 0d | 2023-11-03 A | 2023-11-03 A | 664, 80, 96 | 100% | 2023-11-03 | 2023-11-03 | 0d | 2023-11-03 | 2023-11-03 |  | Lee Cox |  |  |  | PP | SI Test | 5.11 | Systems Integration Testing (SIT) | Complete | COMPLETE |  | T3-DB-0017 | SITAG | T3 |
| 666 | 1.4.1.7.1.7.1.4 | PP Final PIT Completion Reports assured by SI |  | 10d | 2023-11-06 A | 2023-11-17 A | 665 | 100% | 2023-11-06 | 2023-11-10 | 5d | 2023-11-06 | 2023-11-10 |  | Lee Cox | 80h | 80h |  | SI Test | PP | 5.0 | Systems Integration Testing (SIT) | Complete | COMPLETE |  |  |  |  |
| 667 | 1.4.1.7.1.7.2 | **Environments (SIT A)** |  | 51d | 2023-10-06 A | 2023-12-15 A |  | 100% | 2023-10-06 | 2023-11-10 | 26d | 2022-11-16 | 2023-11-10 |  | N/A | 672h | 672h | -0 | N/A | N/A | 5.0 | Systems Integration Testing (SIT) |  |  |  |  |  |  |
| 668 | 1.4.1.7.1.7.2.1 | Programme Participants Ready to Start Connectivity Proving | milestone | 0d | 2023-10-06 A | 2023-10-06 A |  | 100% | 2023-10-06 | 2023-10-06 | 0d |  |  | start no earlier than 2023-10-06 | Simon Berry |  |  |  | PP | PP.SI Test | 5.10 | Systems Integration Testing (SIT) | Complete | COMPLETE |  |  |  |  |
| 669 | 1.4.1.7.1.7.2.2 | SIT Participants' SIT A environments ready to start connectivity proving CIT Interval 3 | milestone | 0d | 2023-10-06 A | 2023-10-06 A | 668 | 100% | 2023-10-06 | 2023-10-06 | 0d | 2023-10-06 | 2023-10-06 |  | Simon Berry |  |  |  | PP | PP,SI Test | 5.10 | Systems Integration Testing (SIT) | Complete | COMPLETE | MHHS-ART139 | T3-TE-0021 | SITAG | T3 |
| 670 | 1.4.1.7.1.7.2.3 | Internal Connectivity Proving Phase |  | 10d | 2023-10-09 A | 2023-10-20 A | 668FS+1d | 100% | 2023-10-09 | 2023-10-20 | 10d |  |  |  | Simon Berry | 80h | 80h |  | PP | PP,SI Test | 5.10 | Systems Integration Testing (SIT) | Complete | COMPLETE |  |  |  |  |
| 671 | 1.4.1.7.1.7.2.4 | Internal Connectivity Proving Phase Complete | milestone | 0d | 2023-10-20 A | 2023-10-20 A | 670 | 100% | 2023-10-20 | 2023-10-20 | 0d |  |  |  | Simon Berry |  |  |  | PP | PP,SI Test | 5.10 | Systems Integration Testing (SIT) | Complete | COMPLETE |  |  |  |  |
| 672 | 1.4.1.7.1.7.2.5 | DIP Onboarding Activity (1. PKI Officers and Certificates, 2. Set-up Validation, 3. End Point Creation, 4. Controlled Smoke Test ) |  | 35d | 2023-10-30 A | 2023-12-15 A | 671FS+5d | 100% | 2023-10-30 | 2023-11-10 | 10d |  |  |  | Simon Berry | 280h | 280h |  | PP | PP,DIP Provider | 5.10 | Systems Integration Testing (SIT) | Complete | COMPLETE |  |  |  |  |
| 673 | 1.4.1.7.1.7.2.6 | DIP Onboarding Complete | milestone | 0d | 2023-12-15 A | 2023-12-15 A | 672 | 100% | 2023-11-10 | 2023-11-10 | 0d |  |  |  | Simon Berry |  |  |  | PP | PP,DIP Provider | 5.10 | Systems Integration Testing (SIT) | Complete | COMPLETE |  |  |  |  |
| 674 | 1.4.1.7.1.7.2.7 | PPs Register PKI Officers and Request PKI certificates Complete - Interval 3 | milestone | 0d | 2023-12-15 A | 2023-12-15 A | 673FF | 100% | 2023-11-10 | 2023-11-10 | 0d | 2023-10-02 | 2023-10-06 |  | Simon Berry |  |  |  | PP | PP,DIP Provider | 5.13 | Systems Integration Testing (SIT) | Complete | COMPLETE |  | T3-TE-0099 | SITAG | T3 |
| 675 | 1.4.1.7.1.7.2.8 | PP Code Deployment | milestone | 0d | 2023-11-10 A | 2023-11-10 A | 671FS+15d | 100% | 2023-11-10 | 2023-11-10 | 0d |  |  | start no earlier than 2023-10-20 | Simon Berry |  |  |  | PP | PP | 5.10 | Systems Integration Testing (SIT) | Complete | COMPLETE |  |  |  |  |

Notes:
- 651: 28/7: CH: added in to be aT3 milestone. 15/11 - Red because of Data Customisation requirement for St. Clements and additional DIP message requirement. Impact is CIT able to start on selected MPANS remaining MPANS to be fixed by 16/11 / Action: 28/7: CH: Needs to be set-up as a reporting milestone. 31/7: Check with Cesar if has been approved so can be baselined
- 660: Amber because of dependency on PPs PIT and known reduced window to review and prepare documentation. No impact currently known. No action. 7/11 - Approved at TMAG on 6/11 with work-off
- 669: Action: 30/8 - lee said date is 30/10
- 674: 09/01 - 1 participant yet to complete onboarding. Anticipated resolution unknown

| ID | WBS | Task | Type | Duration | Start | Finish | Predecessors | Complete | Remaining | Baseline start | Baseline finish | Baseline duration | Baseline 1 start | Baseline 1 finish | Total slack | Constraint | Resources | Work | Actual work | Baseline cost | Responsible | Involved | Update Version | MHHS Programme Phase | Sched Status | RAG | Artefact ID | Milestone ID | Text29 | Tier |
| --- | --- | --- | --- | --- | --- | --- | --- | --- | --- | --- | --- | --- | --- | --- | --- | --- | --- | --- | --- | --- | --- | --- | --- | --- | --- | --- | --- | --- | --- | --- |
| 676 | 1.4.1.7.1.7.3 | **Test Data (SIT A) Interval 3** |  | 34d | 2023-10-03 A | 2023-11-17 A |  | 100% |  | 2023-10-02 | 2023-11-03 | 25d | 2023-10-02 | 2023-11-03 |  |  | N/A | 544h | 544h |  | N/A | N/A | 5.0 | Systems Integration Testing (SIT) |  |  |  |  |  |  |
| 677 | 1.4.1.7.1.7.3.1 | Run data allocation |  | 4d | 2023-10-03 A | 2023-10-06 A | 647SS | 100% |  | 2023-10-02 | 2023-10-06 | 5d | 2023-10-02 | 2023-10-06 |  |  | Cesar Lopes | 32h | 32h |  | SI Test |  | 5.0 | Systems Integration Testing (SIT) | Complete | COMPLETE |  |  |  |  |
| 678 | 1.4.1.7.1.7.3.2 | Cleanse and populate data post cut |  | 5d | 2023-10-09 A | 2023-10-13 A | 677 | 100% |  | 2023-10-09 | 2023-10-13 | 5d | 2023-10-09 | 2023-10-13 |  |  | Cesar Lopes | 40h | 40h |  | SI Test |  | 5.0 | Systems Integration Testing (SIT) | Complete | COMPLETE |  |  |  |  |
| 679 | 1.4.1.7.1.7.3.3 | Transmit data sets to PPs |  | 2d | 2023-10-16 A | 2023-10-17 A | 678 | 100% |  | 2023-10-16 | 2023-10-17 | 2d | 2023-10-16 | 2023-10-17 |  |  | Cesar Lopes | 16h | 16h |  | SI Test |  | 5.0 | Systems Integration Testing (SIT) | Complete | COMPLETE |  |  |  |  |
| 680 | 1.4.1.7.1.7.3.4 | PP - Load test data to test environments |  | 8d | 2023-10-18 A | 2023-10-27 A | 679 | 100% |  | 2023-10-18 | 2023-10-27 | 8d | 2023-10-18 | 2023-10-27 |  |  | Cesar Lopes | 64h | 64h |  | PP |  | 5.0 | Systems Integration Testing (SIT) | Complete | COMPLETE |  |  |  |  |
| 681 | 1.4.1.7.1.7.3.5 | PP Check data integrity on test environment |  | 15d | 2023-10-30 A | 2023-11-17 A | 680 | 100% |  | 2023-10-30 | 2023-11-03 | 5d | 2023-10-30 | 2023-11-03 |  |  | Cesar Lopes | 120h | 120h |  | PP |  | 5.0 | Systems Integration Testing (SIT) | Complete | COMPLETE |  |  |  |  |
| 682 | 1.4.1.7.1.7.3.6 | PP submit self-declaration to Programme to confirm loading & verification of test data | milestone | 0d | 2023-11-17 A | 2023-11-17 A | 681FF | 100% |  | 2023-11-03 | 2023-11-03 | 0d | 2023-11-03 | 2023-11-03 |  |  | Cesar Lopes |  |  |  | PP | SI Test | 5.0 | Systems Integration Testing (SIT) | Complete | COMPLETE |  |  |  |  |
| 683 | 1.4.1.7.1.7.3.7 | Test Data (SIT A) Interval 3 Complete | milestone | 0d | 2023-11-17 A | 2023-11-17 A | 682 | 100% |  | 2023-11-03 | 2023-11-03 | 0d |  |  |  |  | Cesar Lopes |  |  |  | SI Test | PP | 5.13 | Systems Integration Testing (SIT) | Complete | COMPLETE | MHHS-ART148/169 | T3-TE-0075 | SITAG | T3 |
| 684 | 1.4.1.7.1.7.4 | **Other Preparation** |  | 25d | 2023-10-16 A | 2023-11-17 A |  | 100% |  | 2023-07-17 | 2023-10-06 | 60d | 2023-07-17 | 2023-10-06 |  |  | N/A | 600h | 600h |  | N/A | N/A | 5.0 | Systems Integration Testing (SIT) |  |  |  |  |  |  |
| 685 | 1.4.1.7.1.7.4.1 | Onboarding of Test Participants to Test Management Tool (Azure DevOps) |  | 25d | 2023-10-16 A | 2023-11-17 A |  | 100% |  | 2023-07-17 | 2023-10-06 | 60d | 2023-07-17 | 2023-10-06 |  | start no earlier than 2023-10-16 | Simon Berry | 200h | 200h |  | SI Test | PP | 5.0 | Systems Integration Testing (SIT) | Complete | COMPLETE |  |  |  |  |
| 686 | 1.4.1.7.1.7.4.2 | Test Management Tool onboarding |  | 25d | 2023-10-16 A | 2023-11-17 A |  | 100% |  | 2023-07-17 | 2023-10-06 | 60d | 2023-07-17 | 2023-10-06 |  | start no earlier than 2023-10-16 | Simon Berry | 200h | 200h |  | PP | SI Test | 5.0 | Systems Integration Testing (SIT) | Complete | COMPLETE |  |  |  |  |
| 687 | 1.4.1.7.1.7.5 | **SIT Component Integration Test Readiness Report** |  | 25d | 2023-10-16 A | 2023-11-17 A |  | 100% |  | 2023-10-16 | 2023-11-17 | 25d | 2023-10-16 | 2023-11-17 |  |  | N/A | 440h | 440h |  | N/A | N/A | 5.0 | Systems Integration Testing (SIT) |  |  |  |  |  |  |
| 688 | 1.4.1.7.1.7.5.1 | PP submit Test Readiness Report to Programme for assurance | milestone | 0d | 2023-11-03 A | 2023-11-03 A | 572 | 100% |  | 2023-11-03 | 2023-11-03 | 0d | 2023-11-03 | 2023-11-03 |  |  | Lee Cox |  |  |  | PP | SI Test | 5.0 | Systems Integration Testing (SIT) | Complete | COMPLETE |  |  |  |  |
| 689 | 1.4.1.7.1.7.5.2 | SI assure Test Participants' Test Readiness Reports |  | 5d | 2023-11-06 A | 2023-11-10 A | 688FF+5d | 100% |  | 2023-11-06 | 2023-11-10 | 5d | 2023-11-06 | 2023-11-10 |  |  | Lee Cox | 40h | 40h |  | SI Test | PP,IPA | 5.0 | Systems Integration Testing (SIT) | Complete | COMPLETE |  |  |  |  |
| 690 | 1.4.1.7.1.7.5.3 | SI develop Overarching SIT Component Integration Test Readiness Report |  | 20d | 2023-10-16 A | 2023-11-10 A | 689FF | 100% |  | 2023-10-16 | 2023-11-10 | 20d | 2023-10-16 | 2023-11-10 |  |  | Lee Cox | 160h | 160h |  | SI Test |  | 5.0 | Systems Integration Testing (SIT) | Complete | COMPLETE |  |  |  |  |
| 691 | 1.4.1.7.1.7.5.4 | Artefact review (via TMAG) and updates |  | 5d | 2023-11-13 A | 2023-11-17 A | 690 | 100% |  | 2023-11-13 | 2023-11-17 | 5d | 2023-11-13 | 2023-11-17 |  |  | Lee Cox | 40h | 40h |  | SI Test | PP,IPA | 5.0 | Systems Integration Testing (SIT) | Complete | COMPLETE |  |  |  |  |
| 692 | 1.4.1.7.1.7.6 | SIT Component Integration Testing 3 Preparation Complete (incl. approval of SI SIT Component Integration Test Readiness Report) | milestone | 0d | 2023-11-20 A | 2023-11-20 A | 691FS+1d, 665, 669, 688, 686, 683, 279 | 100% |  | 2023-11-20 | 2023-11-20 | 0d | 2023-11-20 | 2023-11-20 |  |  | Lee Cox |  |  |  | SI Test | PP,IPA | 5.12 | Systems Integration Testing (SIT) | Complete | COMPLETE | MHHS-ART071 | T2-TE-0350 | SITAG | T2 |
| 693 | 1.4.1.7.1.8 | **CIT Interval 4 Preparation** |  | 36d | 2023-10-16 A | 2023-12-04 |  | 99% | 0d | 2023-10-16 | 2023-12-04 | 36d | 2022-11-16 | 2023-12-04 | 0d |  | N/A | 2304h | 2252.66h | -0 | N/A | N/A | 5.0 | Systems Integration Testing (SIT) |  |  |  |  |  |  |
| 694 | 1.4.1.7.1.8.1 | **PIT Test Completion Report (incl. evidence)** |  | 21d | 2023-10-27 A | 2023-11-24 A |  | 100% |  | 2023-10-27 | 2023-11-24 | 21d | 2023-10-27 | 2023-11-24 |  |  | N/A | 336h | 336h |  | N/A | N/A | 5.0 | Systems Integration Testing (SIT) |  |  |  |  |  |  |
| 695 | 1.4.1.7.1.8.1.1 | Submit draft PIT Test Completion Report (incl. evidence) and submit to Programme for assurance |  | 1d | 2023-10-27 A | 2023-10-27 A |  | 100% |  | 2023-10-27 | 2023-10-27 | 1d | 2023-10-27 | 2023-10-27 |  | must start on 2023-10-27 | Lee Cox | 8h | 8h |  | PP | SI Test | 5.0 | Systems Integration Testing (SIT) | Complete | COMPLETE |  |  |  |  |
| 696 | 1.4.1.7.1.8.1.2 | Finalise PIT Test Completion Report (incl. evidence) |  | 15d | 2023-10-30 A | 2023-11-17 A | 695 | 100% |  | 2023-10-30 | 2023-11-17 | 15d | 2023-10-30 | 2023-11-17 |  |  | Lee Cox | 120h | 120h |  | PP | SI Test | 5.0 | Systems Integration Testing (SIT) | Complete | COMPLETE |  |  |  |  |
| 697 | 1.4.1.7.1.8.1.3 | PP PIT Completion Report (excl. Migration/Reverse Migration) submitted to Programme for assurance CIT Interval 4 | milestone | 0d | 2023-11-17 A | 2023-11-17 A | 696, 80, 96 | 100% |  | 2023-11-17 | 2023-11-17 | 0d | 2023-11-17 | 2023-11-17 |  |  | Lee Cox |  |  |  | PP | SI Test | 5.13 | Systems Integration Testing (SIT) | Complete | COMPLETE |  | T3-DB-0019 | SITAG | T3 |
| 698 | 1.4.1.7.1.8.1.4 | PP Final PIT Completion Reports assured by SI |  | 5d | 2023-11-20 A | 2023-11-24 A | 697 | 100% |  | 2023-11-20 | 2023-11-24 | 5d | 2023-11-20 | 2023-11-24 |  |  | Lee Cox | 40h | 40h |  | SI Test | PP | 5.0 | Systems Integration Testing (SIT) | Complete | COMPLETE |  |  |  |  |
| 699 | 1.4.1.7.1.8.2 | **Environments (SIT A)** |  | 25d | 2023-10-23 A | 2023-11-24 A |  | 100% |  | 2023-10-20 | 2023-11-24 | 25d | 2022-11-16 | 2023-11-24 |  |  | N/A | 264h | 264h | -0 | N/A | N/A | 5.0 | Systems Integration Testing (SIT) |  |  |  |  |  |  |
| 700 | 1.4.1.7.1.8.2.1 | Programme Participants Ready to Start Connectivity Proving | milestone | 0d | 2023-10-23 A | 2023-10-23 A |  | 100% |  | 2023-10-23 | 2023-10-23 | 0d |  |  |  | start no earlier than 2023-10-23 | Simon Berry |  |  |  | PP |  | 5.10 | Systems Integration Testing (SIT) | Complete | COMPLETE |  |  |  |  |
| 701 | 1.4.1.7.1.8.2.2 | SIT Participants' SIT A environments ready to start connectivity proving CIT Interval 4 | milestone | 0d | 2023-10-23 A | 2023-10-23 A | 700 | 100% |  | 2023-10-20 | 2023-10-20 | 0d | 2023-10-20 | 2023-10-20 |  |  | Simon Berry |  |  |  | PP | PP,IPA | 5.10 | Systems Integration Testing (SIT) | Complete | COMPLETE | MHHS-ART139 | T3-TE-0022 | SITAG | T3 |
| 702 | 1.4.1.7.1.8.2.3 | Internal Connectivity Proving Phase |  | 10d | 2023-10-23 A | 2023-11-03 A | 701 | 100% |  | 2023-10-23 | 2023-11-03 | 10d |  |  |  |  | Simon Berry | 80h | 80h |  | PP |  | 5.10 | Systems Integration Testing (SIT) | Complete | COMPLETE |  |  |  |  |
| 703 | 1.4.1.7.1.8.2.4 | Internal Connectivity Proving Phase Complete | milestone | 0d | 2023-11-03 A | 2023-11-03 A | 702 | 100% |  | 2023-11-03 | 2023-11-03 | 0d |  |  |  |  | Simon Berry |  |  |  | PP |  | 5.10 | Systems Integration Testing (SIT) | Complete | COMPLETE |  |  |  |  |
| 704 | 1.4.1.7.1.8.2.5 | DIP Onboarding Activity (1. PKI Officers and Certificates, 2. Set-up Validation, 3. End Point Creation, 4. Controlled Smoke Test ) |  | 10d | 2023-11-13 A | 2023-11-24 A | 703FS+5d | 100% |  | 2023-11-13 | 2023-11-24 | 10d |  |  |  |  | Simon Berry | 80h | 80h |  | PP |  | 5.10 | Systems Integration Testing (SIT) | Complete | COMPLETE |  |  |  |  |
| 705 | 1.4.1.7.1.8.2.6 | DIP Onboarding Complete | milestone | 0d | 2023-11-24 A | 2023-11-24 A | 704 | 100% |  | 2023-11-24 | 2023-11-24 | 0d |  |  |  |  | Simon Berry |  |  |  | PP |  | 5.10 | Systems Integration Testing (SIT) | Complete | COMPLETE |  |  |  |  |
| 706 | 1.4.1.7.1.8.2.7 | PPs register PKI Officers and Request PKI Certificates Complete - Interval 4 | milestone | 0d | 2023-11-24 A | 2023-11-24 A | 705 | 100% |  | 2023-11-24 | 2023-11-24 | 0d |  |  |  |  | Simon Berry |  |  |  | PP | DIP Provider | 5.16 | Systems Integration Testing (SIT) | Complete | COMPLETE |  | T3-TE-0100 | SITAG | T3 |
| 707 | 1.4.1.7.1.8.2.8 | PP Code Deployment | milestone | 0d | 2023-11-17 A | 2023-11-17 A |  | 100% |  | 2023-11-17 | 2023-11-17 | 0d |  |  |  | start no earlier than 2023-11-17 | Simon Berry |  |  |  | PP |  | 5.10 | Systems Integration Testing (SIT) | Complete | COMPLETE |  |  |  |  |

Notes:
- 683: 28/7: CH: added in to be aT3 milestone. 14/11-Red because 8 out of 9 participants complete. Final data checks from PP to be made this week. No impact to CIT interval 3 start. / Action: 28/7: CH: Needs to be set-up as a reporting milestone. 31/7: Check with Cesar if has been approved so can be baselined
- 697: 21/11-Red because not all received. Reminders sent. No impact. No issue
- 706: 16/02 - Red because 2 participants yet to complete onboarding. Completed 19/1/24

| ID | WBS | Task | Type | Duration | Start | Finish | Predecessors | Complete | Baseline start | Baseline finish | Baseline duration | Baseline 1 start | Baseline 1 finish | Constraint | Resources | Work | Actual work | Baseline cost | Responsible | Involved | Update Version | MHHS Programme Phase | Sched Status | RAG | Artefact ID | Milestone ID | Text29 | Tier |
| --- | --- | --- | --- | --- | --- | --- | --- | --- | --- | --- | --- | --- | --- | --- | --- | --- | --- | --- | --- | --- | --- | --- | --- | --- | --- | --- | --- | --- |
| 708 | 1.4.1.7.1.8.3 | **Test Data (SIT A) Interval 4** |  | 30d | 2023-10-23 A | 2023-12-01 A |  | 100% | 2023-10-16 | 2023-11-17 | 25d | 2023-10-16 | 2023-11-17 |  | N/A | 480h | 480h |  | N/A | N/A | 5.0 | Systems Integration Testing (SIT) |  |  |  |  |  |  |
| 709 | 1.4.1.7.1.8.3.1 | Run data allocation |  | 5d | 2023-10-23 A | 2023-10-27 A | 678FS+5d | 100% | 2023-10-16 | 2023-10-20 | 5d | 2023-10-16 | 2023-10-20 |  | Cesar Lopes | 40h | 40h |  | SI Test |  | 5.0 | Systems Integration Testing (SIT) | Complete | COMPLETE |  |  |  |  |
| 710 | 1.4.1.7.1.8.3.2 | Cleanse and populate data post cut |  | 2d | 2023-10-30 A | 2023-10-31 A | 709 | 100% | 2023-10-23 | 2023-10-27 | 5d | 2023-10-23 | 2023-10-27 |  | Cesar Lopes | 16h | 16h |  | SI Test |  | 5.0 | Systems Integration Testing (SIT) | Complete | COMPLETE |  |  |  |  |
| 711 | 1.4.1.7.1.8.3.3 | Transmit data sets to PPs |  | 5d | 2023-11-01 A | 2023-11-07 A | 710 | 100% | 2023-10-30 | 2023-10-31 | 2d | 2023-10-30 | 2023-10-31 |  | Cesar Lopes | 40h | 40h |  | SI Test |  | 5.0 | Systems Integration Testing (SIT) | Complete | COMPLETE |  |  |  |  |
| 712 | 1.4.1.7.1.8.3.4 | PP - Load test data to test environments |  | 5d | 2023-11-08 A | 2023-11-14 A | 711 | 100% | 2023-11-01 | 2023-11-10 | 8d | 2023-11-01 | 2023-11-10 |  | Cesar Lopes | 40h | 40h |  | PP |  | 5.0 | Systems Integration Testing (SIT) | Complete | COMPLETE |  |  |  |  |
| 713 | 1.4.1.7.1.8.3.5 | PP Check data integrity on test environment |  | 13d | 2023-11-15 A | 2023-12-01 A | 712 | 100% | 2023-11-13 | 2023-11-17 | 5d | 2023-11-13 | 2023-11-17 |  | Richard Puddephatt | 104h | 104h |  | PP |  | 5.0 | Systems Integration Testing (SIT) | Complete | COMPLETE |  |  |  |  |
| 714 | 1.4.1.7.1.8.3.6 | PP submit self-declaration to Programme to confirm loading & verification of test data | milestone | 0d | 2023-12-01 A | 2023-12-01 A | 713FF | 100% | 2023-11-17 | 2023-11-17 | 0d | 2023-11-17 | 2023-11-17 |  | Richard Puddephatt |  |  |  | PP | SI Test | 5.0 | Systems Integration Testing (SIT) | Complete | COMPLETE |  |  |  |  |
| 715 | 1.4.1.7.1.8.3.7 | Test Data (SIT A) Interval 4 Complete | milestone | 0d | 2023-12-01 A | 2023-12-01 A | 714 | 100% | 2023-11-17 | 2023-11-17 | 0d |  |  |  | Richard Puddephatt |  |  |  | SI Test | PP | 5.13 | Systems Integration Testing (SIT) | Complete | COMPLETE | MHHS-ART148/169 | T3-TE-0076 | SITAG | T3 |
| 716 | 1.4.1.7.1.8.4 | **Other Preparation** |  | 25d | 2023-10-30 A | 2023-12-01 A |  | 100% | 2023-10-30 | 2023-12-01 | 25d | 2023-07-31 | 2023-10-20 |  | N/A | 600h | 600h | -0 | N/A | N/A | 5.0 | Systems Integration Testing (SIT) |  |  |  |  |  |  |
| 717 | 1.4.1.7.1.8.4.1 | Onboarding of Test Participants to Test Management Tool (Azure DevOps) |  | 25d | 2023-10-30 A | 2023-12-01 A |  | 100% | 2023-10-30 | 2023-12-01 | 25d | 2023-07-31 | 2023-10-20 | start no earlier than 2023-10-30 | Simon Berry | 200h | 200h |  | SI Test | PP | 5.0 | Systems Integration Testing (SIT) | Complete | COMPLETE |  |  |  |  |
| 718 | 1.4.1.7.1.8.4.2 | Test Management Tool onboarding |  | 25d | 2023-10-30 A | 2023-12-01 A |  | 100% | 2023-10-30 | 2023-12-01 | 25d | 2023-07-31 | 2023-10-20 | start no earlier than 2023-10-30 | Simon Berry | 200h | 200h |  | PP | SI Test | 5.0 | Systems Integration Testing (SIT) | Complete | COMPLETE |  |  |  |  |
| 719 | 1.4.1.7.1.8.5 | **SIT Component Integration Test Readiness Report** |  | 27d | 2023-10-16 A | 2023-11-21 A |  | 100% | 2023-10-30 | 2023-12-01 | 25d | 2023-10-30 | 2023-12-01 |  | N/A | 472h | 472h |  | N/A | N/A | 5.0 | Systems Integration Testing (SIT) |  |  |  |  |  |  |
| 720 | 1.4.1.7.1.8.5.1 | PP submit Test Readiness Report to Programme for assurance | milestone | 0d | 2023-11-03 A | 2023-11-03 A | 572 | 100% | 2023-11-17 | 2023-11-17 | 0d | 2023-11-17 | 2023-11-17 |  | Lee Cox |  |  |  | PP | SI Test | 5.0 | Systems Integration Testing (SIT) | Complete | COMPLETE |  |  |  |  |
| 721 | 1.4.1.7.1.8.5.2 | SI assure Test Participants' Test Readiness Reports |  | 5d | 2023-11-06 A | 2023-11-10 A | 720FF+5d | 100% | 2023-11-20 | 2023-11-24 | 5d | 2023-11-20 | 2023-11-24 |  | Lee Cox | 40h | 40h |  | SI Test | PP,IPA | 5.0 | Systems Integration Testing (SIT) | Complete | COMPLETE |  |  |  |  |
| 722 | 1.4.1.7.1.8.5.3 | SI develop Overarching SIT Component Integration Test Readiness Report |  | 20d | 2023-10-16 A | 2023-11-10 A | 721FF | 100% | 2023-10-30 | 2023-11-24 | 20d | 2023-10-30 | 2023-11-24 |  | Lee Cox | 160h | 160h |  | SI Test |  | 5.0 | Systems Integration Testing (SIT) | Complete | COMPLETE |  |  |  |  |
| 723 | 1.4.1.7.1.8.5.4 | Artefact review (via SITAG) and updates |  | 7d | 2023-11-13 A | 2023-11-21 A | 722 | 100% | 2023-11-27 | 2023-12-01 | 5d | 2023-11-27 | 2023-12-01 |  | Lee Cox | 56h | 56h |  | SI Test | PP,IPA | 5.0 | Systems Integration Testing (SIT) | Complete | COMPLETE |  |  |  |  |
| 724 | 1.4.1.7.1.8.6 | SIT Component Integration Testing 4 Preparation Complete (incl. approval of SI SIT Component Integration Test Readiness Report) | milestone | 0d | 2023-12-04 A | 2023-12-04 A | 723FS+2d, 697, 701, 720, 715, 296FS+1d | 100% | 2023-12-04 | 2023-12-04 | 0d | 2023-12-04 | 2023-12-04 |  | Lee Cox |  |  |  | SI Test | PP,IPA | 5.13 | Systems Integration Testing (SIT) | Complete | COMPLETE | MHHS-ART071 | T2-TE-0400 | SITAG | T2 |
| 725 | 1.4.1.7.1.9 | **CIT Interval 5 Preparation** |  | 53d | 2023-11-01 A | 2024-01-12 A |  | 100% | 2023-10-30 | 2024-01-12 | 55d | 2022-11-16 | 2024-01-08 |  | N/A | 2624h | 2624h | -0 | N/A | N/A | 5.0 | Systems Integration Testing (SIT) |  |  |  |  |  |  |
| 726 | 1.4.1.7.1.9.1 | **PIT Test Completion Report (incl. evidence)** |  | 21d | 2023-11-17 A | 2023-12-15 A |  | 100% | 2023-11-17 | 2023-12-15 | 21d | 2023-11-17 | 2023-12-15 |  | N/A | 336h | 336h |  | N/A | N/A | 5.0 | Systems Integration Testing (SIT) |  |  |  |  |  |  |
| 727 | 1.4.1.7.1.9.1.1 | Submit draft PIT Test Completion Report (incl. evidence) and submit to Programme for assurance |  | 1d | 2023-11-17 A | 2023-11-17 A |  | 100% | 2023-11-17 | 2023-11-17 | 1d | 2023-11-17 | 2023-11-17 | must start on 2023-11-17 | Lee Cox | 8h | 8h |  | PP | SI Test | 5.0 | Systems Integration Testing (SIT) | Complete | COMPLETE |  |  |  |  |
| 728 | 1.4.1.7.1.9.1.2 | Finalise PIT Test Completion Report (incl. evidence) |  | 15d | 2023-11-20 A | 2023-12-08 A | 727 | 100% | 2023-11-20 | 2023-12-08 | 15d | 2023-11-20 | 2023-12-08 |  | Lee Cox | 120h | 120h |  | PP | SI Test | 5.0 | Systems Integration Testing (SIT) | Complete | COMPLETE |  |  |  |  |
| 729 | 1.4.1.7.1.9.1.3 | PP PIT Completion Report (excl. Migration/Reverse Migration) submitted to Programme for assurance CIT Interval 5 | milestone | 0d | 2023-12-08 A | 2023-12-08 A | 728, 80, 96 | 100% | 2023-12-08 | 2023-12-08 | 0d | 2023-12-08 | 2023-12-08 |  | Lee Cox |  |  |  | PP | SI Test | 5.14 | Systems Integration Testing (SIT) | Complete | COMPLETE |  | T3-DB-0021 | SITAG | T3 |
| 730 | 1.4.1.7.1.9.1.4 | PP Final PIT Completion Reports assured by SI |  | 5d | 2023-12-11 A | 2023-12-15 A | 729 | 100% | 2023-12-11 | 2023-12-15 | 5d | 2023-12-11 | 2023-12-15 |  | Lee Cox | 40h | 40h |  | SI Test | PP | 5.0 | Systems Integration Testing (SIT) | Complete | COMPLETE |  |  |  |  |
| 731 | 1.4.1.7.1.9.2 | **Environments (SIT A)** |  | 21d | 2023-11-10 A | 2023-12-08 A |  | 100% | 2023-11-10 | 2023-12-08 | 21d | 2022-11-16 | 2023-12-15 |  | N/A | 232h | 232h | -0 | N/A | N/A | 5.0 | Systems Integration Testing (SIT) |  |  |  |  |  |  |
| 732 | 1.4.1.7.1.9.2.1 | Programme Participants Ready to Start Connectivity Proving | milestone | 0d | 2023-11-10 A | 2023-11-10 A |  | 100% | 2023-11-10 | 2023-11-10 | 0d |  |  | start no earlier than 2023-11-10 | Simon Berry |  |  |  | PP |  | 5.10 | Systems Integration Testing (SIT) | Complete | COMPLETE |  |  |  |  |
| 733 | 1.4.1.7.1.9.2.2 | SIT Participants' SIT A environments ready to start connectivity proving CIT Interval 5 | milestone | 0d | 2023-11-10 A | 2023-11-10 A | 732 | 100% | 2023-11-10 | 2023-11-10 | 0d | 2023-11-10 | 2023-11-10 |  | Simon Berry |  |  |  | PP | PP,IPA | 5.6 | Systems Integration Testing (SIT) | Complete | COMPLETE | MHHS-ART139 | T3-TE-0023 | SITAG | T3 |
| 734 | 1.4.1.7.1.9.2.3 | Internal Connectivity Proving Phase |  | 10d | 2023-11-13 A | 2023-11-24 A | 732FS+1d | 100% | 2023-11-13 | 2023-11-24 | 10d |  |  |  | Simon Berry | 80h | 80h |  | PP |  | 5.10 | Systems Integration Testing (SIT) | Complete | COMPLETE |  |  |  |  |
| 735 | 1.4.1.7.1.9.2.4 | Internal Connectivity Proving Phase Complete | milestone | 0d | 2023-11-24 A | 2023-11-24 A | 734 | 100% | 2023-11-24 | 2023-11-24 | 0d |  |  |  | Simon Berry |  |  |  | PP |  | 5.10 | Systems Integration Testing (SIT) | Complete | COMPLETE |  |  |  |  |
| 736 | 1.4.1.7.1.9.2.5 | DIP Onboarding Activity (1. PKI Officers and Certificates, 2. Set-up Validation, 3. End Point Creation, 4. Controlled Smoke Test ) |  | 10d | 2023-11-27 A | 2023-12-08 A | 735 | 100% | 2023-11-27 | 2023-12-08 | 10d |  |  |  | Simon Berry | 80h | 80h |  | PP |  | 5.10 | Systems Integration Testing (SIT) | Complete | COMPLETE |  |  |  |  |
| 737 | 1.4.1.7.1.9.2.6 | DIP Onboarding Complete | milestone | 0d | 2023-12-08 A | 2023-12-08 A | 736 | 100% | 2023-12-08 | 2023-12-08 | 0d |  |  |  | Simon Berry |  |  |  | PP |  | 5.10 | Systems Integration Testing (SIT) | Complete | COMPLETE |  |  |  |  |
| 738 | 1.4.1.7.1.9.2.7 | PPs register PKI Officers and Request PKI Certificates Complete - Interval 5 | milestone | 0d | 2023-12-08 A | 2023-12-08 A | 737 | 100% | 2023-12-08 | 2023-12-08 | 0d | 2023-11-06 | 2023-11-10 |  | Simon Berry |  |  |  | PP | DIP Provider | 5.17 | Systems Integration Testing (SIT) | Complete | COMPLETE |  | T3-TE-0101 | SITAG | T3 |
| 739 | 1.4.1.7.1.9.2.8 | PP Code Deployment | milestone | 0d | 2023-12-08 A | 2023-12-08 A | 738 | 100% | 2023-12-08 | 2023-12-08 | 0d |  |  | start no earlier than 2023-10-20 | Simon Berry |  |  |  | PP |  | 5.10 | Systems Integration Testing (SIT) | Complete | COMPLETE |  |  |  |  |

Notes:
- 715: 28/11 - red because data was delivered 1 week late. This led to an onward impact. We expect data to be loaded and checked by 1/12. No impact on CIT Tests Start date
- 724: 5/12 - Approved at Etmag on 4/12 with work off plan
- 729: 4/12- Amber because not all received yet. No impact. No action. 19/12 - complete on 14/12
- 738: 16/01- Red because 1 has yet to complete onboarding. 30/1 - Completed on 26/1/24

| ID | WBS | Task | Type | Duration | Start | Finish | Predecessors | Complete | Baseline start | Baseline finish | Baseline duration | Baseline 1 start | Baseline 1 finish | Constraint | Resources | Work | Actual work | Baseline cost | Responsible | Involved | Update Version | MHHS Programme Phase | Sched Status | RAG | Artefact ID | Milestone ID | Text29 | Tier |
| --- | --- | --- | --- | --- | --- | --- | --- | --- | --- | --- | --- | --- | --- | --- | --- | --- | --- | --- | --- | --- | --- | --- | --- | --- | --- | --- | --- | --- |
| 740 | 1.4.1.7.1.9.3 | **Test Data (SIT A) Interval 5** |  | 33d | 2023-11-01 A | 2023-12-15 A |  | 100% | 2023-10-30 | 2023-12-08 | 30d | 2023-10-30 | 2023-12-08 |  | N/A | 528h | 528h |  | N/A | N/A | 5.0 | Systems Integration Testing (SIT) |  |  |  |  |  |  |
| 741 | 1.4.1.7.1.9.3.1 | Run data allocation |  | 5d | 2023-11-01 A | 2023-11-07 A | 711SS | 100% | 2023-10-30 | 2023-11-10 | 10d | 2023-10-30 | 2023-11-10 |  | Cesar Lopes | 40h | 40h |  | SI Test |  | 5.0 | Systems Integration Testing (SIT) | Complete | COMPLETE |  |  |  |  |
| 742 | 1.4.1.7.1.9.3.2 | Cleanse and populate data post cut |  | 8d | 2023-11-08 A | 2023-11-17 A | 741 | 100% | 2023-11-13 | 2023-11-17 | 5d | 2023-11-13 | 2023-11-17 |  | Cesar Lopes | 64h | 64h |  | SI Test |  | 5.0 | Systems Integration Testing (SIT) | Complete | COMPLETE |  |  |  |  |
| 743 | 1.4.1.7.1.9.3.3 | Transmit data sets to PPs |  | 2d | 2023-11-20 A | 2023-11-21 A | 742 | 100% | 2023-11-20 | 2023-11-21 | 2d | 2023-11-20 | 2023-11-21 |  | Cesar Lopes | 16h | 16h |  | SI Test |  | 5.0 | Systems Integration Testing (SIT) | Complete | COMPLETE |  |  |  |  |
| 744 | 1.4.1.7.1.9.3.4 | PP - Load test data to test environments |  | 8d | 2023-11-22 A | 2023-12-01 A | 743 | 100% | 2023-11-22 | 2023-12-01 | 8d | 2023-11-22 | 2023-12-01 |  | Richard Puddephatt | 64h | 64h |  | PP |  | 5.0 | Systems Integration Testing (SIT) | Complete | COMPLETE |  |  |  |  |
| 745 | 1.4.1.7.1.9.3.5 | PP Check data integrity on test environment |  | 10d | 2023-12-04 A | 2023-12-15 A | 744 | 100% | 2023-12-04 | 2023-12-08 | 5d | 2023-12-04 | 2023-12-08 |  | Richard Puddephatt | 80h | 80h |  | PP |  | 5.0 | Systems Integration Testing (SIT) | Complete | COMPLETE |  |  |  |  |
| 746 | 1.4.1.7.1.9.3.6 | PP submit self-declaration to Programme to confirm loading & verification of test data | milestone | 0d | 2023-12-15 A | 2023-12-15 A | 745FF | 100% | 2023-12-08 | 2023-12-08 | 0d | 2023-12-08 | 2023-12-08 |  | Richard Puddephatt |  |  |  | PP | SI Test | 5.0 | Systems Integration Testing (SIT) | Complete | COMPLETE |  |  |  |  |
| 747 | 1.4.1.7.1.9.3.7 | Test Data (SIT A) Interval 5 Complete | milestone | 0d | 2023-12-15 A | 2023-12-15 A | 746 | 100% | 2023-12-08 | 2023-12-08 | 0d |  |  |  | Richard Puddephatt |  |  |  | SI Test | PP | 5.14 | Systems Integration Testing (SIT) | Complete | COMPLETE | MHHS-ART148/169 | T3-TE-0077 | SITAG | T3 |
| 748 | 1.4.1.7.1.9.4 | **Other Preparation** |  | 40d | 2023-11-20 A | 2024-01-12 A |  | 100% | 2023-11-20 | 2024-01-12 | 40d | 2023-08-21 | 2023-11-10 |  | N/A | 928h | 928h | -0 | N/A | N/A | 5.0 | Systems Integration Testing (SIT) |  |  |  |  |  |  |
| 749 | 1.4.1.7.1.9.4.1 | Onboarding of Test Participants to Test Management Tool (Azure DevOps) |  | 40d | 2023-11-20 A | 2024-01-12 A |  | 100% | 2023-11-20 | 2024-01-12 | 40d | 2023-08-21 | 2023-11-10 | start no earlier than 2023-11-20 | Simon Berry | 320h | 320h |  | SI Test | PP | 5.0 | Systems Integration Testing (SIT) | Complete | COMPLETE |  |  |  |  |
| 750 | 1.4.1.7.1.9.4.2 | Test Management Tool onboarding |  | 36d | 2023-11-20 A | 2024-01-08 A |  | 100% | 2023-11-20 | 2024-01-08 | 36d | 2023-08-21 | 2023-11-10 | start no earlier than 2023-11-20 | Simon Berry | 288h | 288h |  | PP | SI Test | 5.0 | Systems Integration Testing (SIT) | Complete | COMPLETE |  |  |  |  |
| 751 | 1.4.1.7.1.9.5 | **SIT Component Integration Test Readiness Report** |  | 35d | 2023-11-20 A | 2024-01-05 A |  | 100% | 2023-11-20 | 2024-01-05 | 35d | 2023-11-20 | 2024-01-05 |  | N/A | 600h | 600h |  | N/A | N/A | 5.0 | Systems Integration Testing (SIT) |  |  |  |  |  |  |
| 752 | 1.4.1.7.1.9.5.1 | PP submit Test Readiness Report to Programme for assurance | milestone | 0d | 2023-12-08 A | 2023-12-08 A | 576 | 100% | 2023-12-08 | 2023-12-08 | 0d | 2023-12-08 | 2023-12-08 |  | Lee Cox |  |  |  | PP | SI Test | 5.0 | Systems Integration Testing (SIT) | Complete | COMPLETE |  |  |  |  |
| 753 | 1.4.1.7.1.9.5.2 | SI assure Test Participants' Test Readiness Reports |  | 5d | 2023-12-11 A | 2023-12-15 A | 752FF+5d | 100% | 2023-12-11 | 2023-12-15 | 5d | 2023-12-11 | 2023-12-15 |  | Lee Cox | 40h | 40h |  | SI Test | PP,IPA | 5.0 | Systems Integration Testing (SIT) | Complete | COMPLETE |  |  |  |  |
| 754 | 1.4.1.7.1.9.5.3 | SI develop Overarching SIT Component Integration Test Readiness Report |  | 20d | 2023-11-20 A | 2023-12-15 A | 753FF | 100% | 2023-11-20 | 2023-12-15 | 20d | 2023-11-20 | 2023-12-15 |  | Lee Cox | 160h | 160h |  | SI Test |  | 5.0 | Systems Integration Testing (SIT) | Complete | COMPLETE |  |  |  |  |
| 755 | 1.4.1.7.1.9.5.4 | Artefact review (via SITAG) and updates |  | 15d | 2023-12-18 A | 2024-01-05 A | 754 | 100% | 2023-12-18 | 2024-01-05 | 15d | 2023-12-18 | 2024-01-05 |  | Lee Cox | 120h | 120h |  | SI Test | PP,IPA | 5.0 | Systems Integration Testing (SIT) | Complete | COMPLETE |  |  |  |  |
| 756 | 1.4.1.7.1.9.6 | SIT Component Integration Testing 5 Preparation Complete (incl. approval of SI SIT Component Integration Test Readiness Report) | milestone | 0d | 2024-01-08 A | 2024-01-08 A | 755FS+1d, 729, 733, 750, 752, 747, 398, 381 | 100% | 2024-01-08 | 2024-01-08 | 0d | 2024-01-08 | 2024-01-08 |  | Lee Cox |  |  |  | SI Test | PP,IPA | 5.15 | Systems Integration Testing (SIT) | Complete | COMPLETE | MHHS-ART071 | T2-TE-0450 | SITAG | T2 |
| 757 | 1.4.1.7.1.10 | **CIT Interval 6 Preparation** |  | 45d | 2023-11-20 A | 2024-01-19 A |  | 100% | 2023-11-20 | 2024-01-22 | 46d | 2022-11-16 | 2024-01-22 |  | N/A | 2344h | 2344h | -0 | N/A | N/A | 5.0 | Systems Integration Testing (SIT) |  |  |  |  |  |  |
| 758 | 1.4.1.7.1.10.1 | **PIT Test Completion Report (incl. evidence)** |  | 31d | 2023-12-01 A | 2024-01-12 A |  | 100% | 2023-12-01 | 2024-01-12 | 31d | 2023-12-01 | 2024-01-12 |  | N/A | 496h | 496h |  | N/A | N/A | 5.0 | Systems Integration Testing (SIT) |  |  |  |  |  |  |
| 759 | 1.4.1.7.1.10.1.1 | Submit draft PIT Test Completion Report (incl. evidence) and submit to Programme for assurance |  | 1d | 2023-12-01 A | 2023-12-01 A |  | 100% | 2023-12-01 | 2023-12-01 | 1d | 2023-12-01 | 2023-12-01 | must start on 2023-12-01 | Lee Cox | 8h | 8h |  | PP | SI Test | 5.0 | Systems Integration Testing (SIT) | Complete | COMPLETE |  |  |  |  |
| 760 | 1.4.1.7.1.10.1.2 | Finalise PIT Test Completion Report (incl. evidence) |  | 25d | 2023-12-04 A | 2024-01-05 A | 759 | 100% | 2023-12-04 | 2024-01-05 | 25d | 2023-12-04 | 2024-01-05 |  | Lee Cox | 200h | 200h |  | PP | SI Test | 5.0 | Systems Integration Testing (SIT) | Complete | COMPLETE |  |  |  |  |
| 761 | 1.4.1.7.1.10.1.3 | PP PIT Completion Report (excl. Migration/Reverse Migration) submitted to Programme for assurance CIT Interval 6 | milestone | 0d | 2024-01-05 A | 2024-01-05 A | 760, 80, 96, 218, 223, 226 | 100% | 2024-01-05 | 2024-01-05 | 0d | 2024-01-05 | 2024-01-05 |  | Lee Cox |  |  |  | PP | SI Test | 5.19 | Systems Integration Testing (SIT) | Complete | COMPLETE |  | T3-DB-0023 | SITAG | T3 |
| 762 | 1.4.1.7.1.10.1.4 | PP Final PIT Completion Reports assured by SI |  | 5d | 2024-01-08 A | 2024-01-12 A | 761 | 100% | 2024-01-08 | 2024-01-12 | 5d | 2024-01-08 | 2024-01-12 |  | Lee Cox | 40h | 40h |  | SI Test | PP | 5.19 | Systems Integration Testing (SIT) | Complete | COMPLETE |  |  |  |  |
| 763 | 1.4.1.7.1.10.2 | **Environments (SIT A)** |  | 30d | 2023-11-24 A | 2024-01-05 A |  | 100% | 2023-11-24 | 2024-01-05 | 30d | 2022-11-16 | 2024-01-05 |  | N/A | 264h | 264h | -0 | N/A | N/A | 5.0 | Systems Integration Testing (SIT) |  |  |  |  |  |  |
| 764 | 1.4.1.7.1.10.2.1 | Programme Participants Ready to Start Connectivity Proving | milestone | 0d | 2023-11-24 A | 2023-11-24 A |  | 100% | 2023-11-24 | 2023-11-24 | 0d |  |  | start no earlier than 2023-11-24 | Simon Berry |  |  |  | PP |  | 5.10 | Systems Integration Testing (SIT) | Complete | COMPLETE |  |  |  |  |
| 765 | 1.4.1.7.1.10.2.2 | SIT Participants' SIT A environments ready to start connectivity proving CIT Interval 6 | milestone | 0d | 2023-11-24 A | 2023-11-24 A | 764 | 100% | 2023-11-24 | 2023-11-24 | 0d | 2023-11-24 | 2023-11-24 |  | Simon Berry |  |  |  | PP | PP,IPA | 5.6 | Systems Integration Testing (SIT) | Complete | COMPLETE | MHHS-ART139 | T3-TE-0024 | SITAG | T3 |
| 766 | 1.4.1.7.1.10.2.3 | Internal Connectivity Proving Phase |  | 10d | 2023-11-27 A | 2023-12-08 A | 765FS+1d | 100% | 2023-11-27 | 2023-12-08 | 10d |  |  |  | Simon Berry | 80h | 80h |  | PP |  | 5.10 | Systems Integration Testing (SIT) | Complete | COMPLETE |  |  |  |  |
| 767 | 1.4.1.7.1.10.2.4 | Internal Connectivity Proving Phase Complete | milestone | 0d | 2023-12-08 A | 2023-12-08 A | 766 | 100% | 2023-12-08 | 2023-12-08 | 0d |  |  |  | Simon Berry |  |  |  | PP |  | 5.10 | Systems Integration Testing (SIT) | Complete | COMPLETE |  |  |  |  |
| 768 | 1.4.1.7.1.10.2.5 | DIP Onboarding Activity (1. PKI Officers and Certificates, 2. Set-up Validation, 3. End Point Creation, 4. Controlled Smoke Test ) |  | 5d | 2023-12-04 A | 2023-12-08 A | 765FS+6d | 100% | 2023-12-04 | 2023-12-08 | 5d |  |  |  | Simon Berry | 40h | 40h |  | PP |  | 5.10 | Systems Integration Testing (SIT) | Complete | COMPLETE |  |  |  |  |
| 769 | 1.4.1.7.1.10.2.6 | DIP Onboarding Complete | milestone | 0d | 2023-12-08 A | 2023-12-08 A | 768 | 100% | 2023-12-08 | 2023-12-08 | 0d |  |  |  | Simon Berry |  |  |  | PP |  | 5.10 | Systems Integration Testing (SIT) | Complete | COMPLETE |  |  |  |  |
| 770 | 1.4.1.7.1.10.2.7 | PPs register PKI Officers and Request PKI Certificates Complete - Interval 6 | milestone | 0d | 2023-12-08 A | 2023-12-08 A | 769 | 100% | 2023-12-08 | 2023-12-08 | 0d | 2023-11-20 | 2023-11-24 | start no earlier than 2023-12-08 | Simon Berry |  |  |  | PP | DIP Provider | 5.17 | Systems Integration Testing (SIT) | Complete | COMPLETE |  | T3-TE-0102 | SITAG | T3 |
| 771 | 1.4.1.7.1.10.2.8 | PP Code Deployment | milestone | 0d | 2024-01-05 A | 2024-01-05 A |  | 100% | 2024-01-05 | 2024-01-05 | 0d |  |  | start no earlier than 2024-01-05 | Simon Berry |  |  |  | PP |  | 5.10 | Systems Integration Testing (SIT) | Complete | COMPLETE |  |  |  |  |

Notes:
- 747: 28/7: CH: added in to be aT3 milestone. 12/12 - Red because PPs required additional time due to some data changes required. No impact. Action to follow-up with PPs for latest progress / Action: 28/7: CH: Needs to be set-up as a reporting milestone. 31/7: Check with Cesar if has been approved so can be baselined
- 756: 2/1/24 - Approved at Dec TMAG following change in CIT governance
- 761: 9/1 - Not all completion reports yet received. Completed 22/2/24
- 765: 29/11 - Red because forecast date missed. Participants status to be determined by 4th December. No risk to future milestones
- 768: 5/12 -
- 770: 12/12 - Red because 1 Participant still to complete. 30/1 - Completed 29/1/24

| ID | WBS | Task | Type | Duration | Start | Finish | Predecessors | Complete | Remaining | Baseline start | Baseline finish | Baseline duration | Baseline 1 start | Baseline 1 finish | Total slack | Constraint | Resources | Work | Actual work | Baseline cost | Responsible | Involved | Update Version | MHHS Programme Phase | Sched Status | RAG | Artefact ID | Milestone ID | Text29 | Tier |
| --- | --- | --- | --- | --- | --- | --- | --- | --- | --- | --- | --- | --- | --- | --- | --- | --- | --- | --- | --- | --- | --- | --- | --- | --- | --- | --- | --- | --- | --- | --- |
| 772 | 1.4.1.7.1.10.3 | **Test Data (SIT A) Interval 6** |  | 25d | 2023-11-20 A | 2023-12-22 A |  | 100% |  | 2023-11-20 | 2023-12-22 | 25d | 2023-11-20 | 2023-12-22 |  |  | N/A | 400h | 400h |  | N/A | N/A | 5.0 | Systems Integration Testing (SIT) |  |  |  |  |  |  |
| 773 | 1.4.1.7.1.10.3.1 | Run data allocation |  | 10d | 2023-11-20 A | 2023-12-01 A | 743SS | 100% |  | 2023-11-20 | 2023-11-24 | 5d | 2023-11-20 | 2023-11-24 |  |  | Richard Puddephatt | 80h | 80h |  | SI Test |  | 5.0 | Systems Integration Testing (SIT) | Complete | COMPLETE |  |  |  |  |
| 774 | 1.4.1.7.1.10.3.2 | Cleanse and populate data post cut |  | 1d | 2023-12-04 A | 2023-12-04 A | 773 | 100% |  | 2023-11-27 | 2023-12-01 | 5d | 2023-11-27 | 2023-12-01 |  |  | Richard Puddephatt | 8h | 8h |  | SI Test |  | 5.0 | Systems Integration Testing (SIT) | Complete | COMPLETE |  |  |  |  |
| 775 | 1.4.1.7.1.10.3.3 | Transmit data sets to PPs |  | 1d | 2023-12-05 A | 2023-12-05 A | 774 | 100% |  | 2023-12-04 | 2023-12-05 | 2d | 2023-12-04 | 2023-12-05 |  |  | Richard Puddephatt | 8h | 8h |  | SI Test |  | 5.0 | Systems Integration Testing (SIT) | Complete | COMPLETE |  |  |  |  |
| 776 | 1.4.1.7.1.10.3.4 | PP - Load test data to test environments |  | 8d | 2023-12-06 A | 2023-12-15 A | 775 | 100% |  | 2023-12-06 | 2023-12-15 | 8d | 2023-12-06 | 2023-12-15 |  |  | Richard Puddephatt | 64h | 64h |  | PP |  | 5.0 | Systems Integration Testing (SIT) | Complete | COMPLETE |  |  |  |  |
| 777 | 1.4.1.7.1.10.3.5 | PP Check data integrity on test environment |  | 5d | 2023-12-18 A | 2023-12-22 A | 776 | 100% |  | 2023-12-18 | 2023-12-22 | 5d | 2023-12-18 | 2023-12-22 |  |  | Richard Puddephatt | 40h | 40h |  | PP |  | 5.0 | Systems Integration Testing (SIT) | Complete | COMPLETE |  |  |  |  |
| 778 | 1.4.1.7.1.10.3.6 | PP submit self-declaration to Programme to confirm loading & verification of test data | milestone | 0d | 2023-12-22 A | 2023-12-22 A | 777FF | 100% |  | 2023-12-22 | 2023-12-22 | 0d | 2023-12-22 | 2023-12-22 |  |  | Richard Puddephatt |  |  |  | PP | SI Test | 5.0 | Systems Integration Testing (SIT) | Complete | COMPLETE |  |  |  |  |
| 779 | 1.4.1.7.1.10.3.7 | Test Data (SIT A) Interval 6 Complete | milestone | 0d | 2023-12-22 A | 2023-12-22 A | 778 | 100% |  | 2023-12-22 | 2023-12-22 | 0d |  |  |  |  | Richard Puddephatt |  |  |  | SI Test | PP | 5.5 | Systems Integration Testing (SIT) | Complete | COMPLETE | MHHS-ART148/169 | T3-TE-0078 | SITAG | T3 |
| 780 | 1.4.1.7.1.10.4 | **Other Preparation** |  | 31d | 2023-12-04 A | 2024-01-15 A |  | 100% |  | 2023-12-04 | 2024-01-15 | 31d | 2023-09-04 | 2023-11-24 |  |  | N/A | 744h | 744h | -0 | N/A | N/A | 5.0 | Systems Integration Testing (SIT) |  |  |  |  |  |  |
| 781 | 1.4.1.7.1.10.4.1 | Onboarding of Test Participants to Test Management Tool (Azure DevOps) |  | 31d | 2023-12-04 A | 2024-01-15 A |  | 100% |  | 2023-12-04 | 2024-01-15 | 31d | 2023-09-04 | 2023-11-24 |  | start no earlier than 2023-12-04 | Simon Berry | 248h | 248h |  | SI Test | PP | 5.0 | Systems Integration Testing (SIT) | Complete | COMPLETE |  |  |  |  |
| 782 | 1.4.1.7.1.10.4.2 | Test Management Tool onboarding |  | 31d | 2023-12-04 A | 2024-01-15 A |  | 100% |  | 2023-12-04 | 2024-01-15 | 31d | 2023-09-04 | 2023-11-24 |  | start no earlier than 2023-12-04 | Simon Berry | 248h | 248h |  | PP | SI Test | 5.0 | Systems Integration Testing (SIT) | Complete | COMPLETE |  |  |  |  |
| 783 | 1.4.1.7.1.10.5 | **SIT Component Integration Test Readiness Report** |  | 25d | 2023-11-20 A | 2023-12-22 A |  | 100% |  | 2023-12-18 | 2024-01-19 | 25d | 2023-12-18 | 2024-01-19 |  |  | N/A | 440h | 440h |  | N/A | N/A | 5.0 | Systems Integration Testing (SIT) |  |  |  |  |  |  |
| 784 | 1.4.1.7.1.10.5.1 | PP submit Test Readiness Report to Programme for assurance | milestone | 0d | 2023-12-08 A | 2023-12-08 A | 576 | 100% |  | 2024-01-05 | 2024-01-05 | 0d | 2024-01-05 | 2024-01-05 |  |  | Lee Cox |  |  |  | PP | SI Test | 5.0 | Systems Integration Testing (SIT) | Complete | COMPLETE |  |  |  |  |
| 785 | 1.4.1.7.1.10.5.2 | SI assure Test Participants' Test Readiness Reports |  | 5d | 2023-12-11 A | 2023-12-15 A | 784FF+5d | 100% |  | 2024-01-08 | 2024-01-12 | 5d | 2024-01-08 | 2024-01-12 |  |  | Lee Cox | 40h | 40h |  | SI Test | PP,IPA | 5.0 | Systems Integration Testing (SIT) | Complete | COMPLETE |  |  |  |  |
| 786 | 1.4.1.7.1.10.5.3 | SI develop Overarching SIT Component Integration Test Readiness Report |  | 20d | 2023-11-20 A | 2023-12-15 A | 785FF | 100% |  | 2023-12-18 | 2024-01-12 | 20d | 2023-12-18 | 2024-01-12 |  |  | Lee Cox | 160h | 160h |  | SI Test |  | 5.0 | Systems Integration Testing (SIT) | Complete | COMPLETE |  |  |  |  |
| 787 | 1.4.1.7.1.10.5.4 | Artefact review (via TMAG) and updates |  | 5d | 2023-12-18 A | 2023-12-22 A | 786 | 100% |  | 2024-01-15 | 2024-01-19 | 5d | 2024-01-15 | 2024-01-19 |  |  | Lee Cox | 40h | 40h |  | SI Test | PP,IPA | 5.0 | Systems Integration Testing (SIT) | Complete | COMPLETE |  |  |  |  |
| 788 | 1.4.1.7.1.10.6 | SIT Component Integration Testing 6 Preparation Complete (incl. approval of SI SIT Component Integration Test Readiness Report) | milestone | 0d | 2024-01-19 A | 2024-01-19 A | 787FS+1d, 761, 765, 782, 784, 779, 244, 415 | 100% |  | 2024-01-22 | 2024-01-22 | 0d | 2024-01-22 | 2024-01-22 |  |  | Lee Cox |  |  |  | SI Test | PP,IPA | 5.15 | Systems Integration Testing (SIT) | Complete | COMPLETE | MHHS-ART071 | T2-TE-0500 | SITAG | T2 |
| 789 | 1.4.1.7.2 | **SIT Functional Preparation** |  | 520d | 2022-10-31 A | 2024-10-25 |  | 92% | 42.69d | 2022-10-31 | 2024-10-25 | 520d | 2022-10-31 | 2024-03-01 | 17d |  | N/A | 25306.1h | 17843.1h | -0 | N/A | N/A | 5.0 | Systems Integration Testing (SIT) |  |  |  |  |  |  |
| 790 | 1.4.1.7.2.1 | **Test Approach & Plan** |  | 208d | 2022-10-31 A | 2023-08-16 A |  | 100% |  | 2022-10-31 | 2023-08-16 | 208d | 2022-10-31 | 2023-08-16 |  |  | N/A | 3248h | 3248h |  | N/A | N/A | 5.0 | Systems Integration Testing (SIT) |  |  |  |  |  |  |
| 791 | 1.4.1.7.2.1.1 | Develop document with SITWG |  | 179d | 2022-10-31 A | 2023-07-06 A |  | 100% |  | 2022-10-31 | 2023-07-06 | 179d | 2022-10-31 | 2023-07-06 |  | finish no earlier than 2023-07-06 | Lee Cox | 1432h | 1432h |  | SI Test |  | 5.0 | Systems Integration Testing (SIT) | Complete | COMPLETE |  |  |  |  |
| 792 | 1.4.1.7.2.1.2 | Industry Consultation |  | 10d | 2023-07-07 A | 2023-07-20 A | 791 | 100% |  | 2023-07-07 | 2023-07-20 | 10d |  |  |  |  |  |  |  |  | PP |  | 5.1 | Systems Integration Testing (SIT) | Complete | COMPLETE |  |  |  |  |
| 793 | 1.4.1.7.2.1.3 | Artefact review (via TMAG) and updates |  | 19d | 2023-07-21 A | 2023-08-16 A | 792 | 100% |  | 2023-07-21 | 2023-08-16 | 19d | 2023-07-07 | 2023-08-03 |  | finish no earlier than 2023-08-03 | Lee Cox | 152h | 152h |  | SI Test | PP,IPA,Code Bodies | 5.5 | Systems Integration Testing (SIT) | Complete | COMPLETE |  |  |  |  |
| 794 | 1.4.1.7.2.1.4 | SIT Functional Testing Test Approach & Plan approved | milestone | 0d | 2023-08-16 A | 2023-08-16 A |  | 100% |  | 2023-08-16 | 2023-08-16 | 0d | 2023-08-16 | 2023-08-16 |  | finish no earlier than 2023-08-16 | Lee Cox |  |  |  | SI Test | PP | 5.0 | Systems Integration Testing (SIT) | Complete | COMPLETE | MHHS-ART073 | T3-TE-0013 | SITAG | T3 |
| 795 | 1.4.1.7.2.2 | **Test Data Approach & Plan** |  | 29d | 2023-07-07 A | 2023-08-16 A |  | 100% |  | 2023-07-07 | 2023-08-16 | 29d | 2023-07-07 | 2023-08-16 |  |  | N/A | 464h | 464h |  | N/A | N/A | 5.0 | Systems Integration Testing (SIT) |  |  |  |  |  |  |
| 796 | 1.4.1.7.2.2.1 | Industry Consultation |  | 10d | 2023-07-07 A | 2023-07-20 A | 792SS | 100% |  | 2023-07-07 | 2023-07-20 | 10d |  |  |  |  | Cesar Lopes | 80h | 80h |  | PP |  | 5.1 | Systems Integration Testing (SIT) | Complete | COMPLETE |  |  |  |  |
| 797 | 1.4.1.7.2.2.2 | Artefact review (via TMAG) and updates |  | 19d | 2023-07-21 A | 2023-08-16 A | 796 | 100% |  | 2023-07-21 | 2023-08-16 | 19d | 2023-07-07 | 2023-08-03 |  |  | Cesar Lopes | 152h | 152h |  | SI Test |  | 5.5 | Systems Integration Testing (SIT) | Complete | COMPLETE |  |  |  |  |
| 798 | 1.4.1.7.2.2.3 | SIT Functional Testing Test Data Approach & Plan approved | milestone | 0d | 2023-08-16 A | 2023-08-16 A | 797 | 100% |  | 2023-08-16 | 2023-08-16 | 0d | 2023-08-16 | 2023-08-16 |  |  | Cesar Lopes |  |  |  | SI Test | PP,IPA | 5.5 | Systems Integration Testing (SIT) | Complete | COMPLETE |  |  |  |  |

Notes:
- 779: 28/7: CH: added in to be aT3 milestone / Action: 28/7: CH: Needs to be set-up as a reporting milestone. 31/7: Check with Cesar if has been approved so can be baselined
- 788: 2/1/24 - Approved at Dec TMAG following change in CIT governance

| ID | WBS | Task | Type | Duration | Start | Finish | Predecessors | Complete | Remaining | Baseline start | Baseline finish | Baseline duration | Baseline 1 start | Baseline 1 finish | Total slack | Constraint | Resources | Work | Actual work | Baseline cost | Responsible | Involved | Update Version | MHHS Programme Phase | Sched Status | RAG | Artefact ID | Milestone ID | Text29 | Tier | Action | Guidance | Task Status |
| --- | --- | --- | --- | --- | --- | --- | --- | --- | --- | --- | --- | --- | --- | --- | --- | --- | --- | --- | --- | --- | --- | --- | --- | --- | --- | --- | --- | --- | --- | --- | --- | --- | --- |
| 799 | 1.4.1.7.2.3 | **Test scenarios** |  | 298d | 2023-01-02 A | 2024-02-21 A |  | 100% |  | 2023-01-02 | 2024-02-21 | 298d | 2023-01-02 | 2023-06-02 |  |  | N/A | 3584h | 3584h | -0 | N/A | N/A | 5.0 | Systems Integration Testing (SIT) |  |  |  |  |  |  |  |  |  |
| 800 | 1.4.1.7.2.3.1 | Development of test scenarios |  | 85d | 2023-01-02 A | 2023-04-28 A | 791SS+45d | 100% |  | 2023-01-02 | 2023-04-28 | 85d | 2023-01-02 | 2023-04-28 |  |  | Lee Cox | 680h | 680h |  | SI Test | PP, Code Bodies | 5.0 | Systems Integration Testing (SIT) | Complete | COMPLETE |  |  |  |  |  |  |  |
| 801 | 1.4.1.7.2.3.2 | Review test scenarios with SIT Working Group |  | 65d | 2023-08-17 A | 2023-11-15 A | 800FS+78d | 100% |  | 2023-08-17 | 2023-11-15 | 65d | 2023-02-01 | 2023-05-26 |  |  | Lee Cox | 520h | 520h |  | SI Test | PP, Code Bodies, IPA | 5.0 | Systems Integration Testing (SIT) | Complete | COMPLETE |  |  |  |  |  |  |  |
| 802 | 1.4.1.7.2.3.3 | SIT Functional Testing Test scenarios (themes 1-5) approved | milestone | 0d | 2023-12-08 A | 2023-12-08 A | 801FS+17d | 100% |  | 2023-12-08 | 2023-12-08 | 0d | 2023-06-02 | 2023-06-02 |  |  | Lee Cox |  |  |  | SI Test | PP | 5.14 | Systems Integration Testing (SIT) | Complete | COMPLETE | MMHS-ART073 | T3-TE-0015 | SITAG | T3 |  |  |  |
| 803 | 1.4.1.7.2.3.4 | SIT Functional Testing Test scenarios (themes 6,7,9) approved | milestone | 0d | 2024-01-17 A | 2024-01-17 A | 802FS+28d | 100% |  | 2024-01-17 | 2024-01-17 | 0d | 2023-06-02 | 2023-06-02 |  |  | Lee Cox |  |  |  | SI Test | PP | 5.16 | Systems Integration Testing (SIT) | Complete | COMPLETE | MMHS-ART073 | T3-TE-0106 | SITAG | T3 |  |  |  |
| 804 | 1.4.1.7.2.3.5 | SIT Functional Testing Test scenarios (theme 8) approved | milestone | 0d | 2024-02-21 A | 2024-02-21 A | 803FS+25d | 100% |  | 2024-02-21 | 2024-02-21 | 0d | 2023-06-02 | 2023-06-02 |  |  | Lee Cox |  |  |  | SI Test | PP | 5.14 | Systems Integration Testing (SIT) | Complete | COMPLETE | MMHS-ART073 | T3-TE-0107 | SITAG | T3 |  |  |  |
| 805 | 1.4.1.7.2.4 | **Test cases** |  | 213d | 2023-05-01 A | 2024-02-21 A |  | 100% |  | 2023-05-01 | 2024-02-21 | 213d | 2023-05-01 | 2023-09-01 |  |  | N/A | 5178.08h | 5178.08h |  | N/A | N/A | 5.0 | Systems Integration Testing (SIT) |  |  |  |  |  |  | 25/7 - needs to be replanned |  |  |
| 806 | 1.4.1.7.2.4.1 | **SI Test cases** |  | 213d | 2023-05-01 A | 2024-02-21 A |  | 100% |  | 2023-05-01 | 2024-02-21 | 213d | 2023-05-01 | 2023-09-01 |  |  | N/A | 3501.04h | 3501.04h |  | N/A | N/A | 5.0 | Systems Integration Testing (SIT) |  |  |  |  |  |  | 25/7 - needs to be replanned |  |  |
| 807 | 1.4.1.7.2.4.1.1 | Development of Test cases |  | 150d | 2023-05-01 A | 2023-11-24 A | 800 | 100% |  | 2023-05-01 | 2023-11-24 | 150d | 2023-05-01 | 2023-07-28 |  |  | Lee Cox | 1200h | 1200h |  | SI Test |  | 5.0 | Systems Integration Testing (SIT) | Complete | COMPLETE |  |  |  |  | 25/7 - needs to be replanned |  |  |
| 808 | 1.4.1.7.2.4.1.2 | Review Test cases with SIT Working Group |  | 78d | 2023-09-25 A | 2024-01-10 A | 807SS+105d | 100% |  | 2023-09-25 | 2024-01-10 | 78d | 2023-05-26 | 2023-08-25 |  |  | Lee Cox | 624h | 624h |  | SI Test | PP,IPA | 5.0 | Systems Integration Testing (SIT) | Complete | COMPLETE |  |  |  |  | 25/7 - needs to be replanned |  |  |
| 809 | 1.4.1.7.2.4.1.3 | SIT Functional Testing Test Cases (themes 1-5) approved | milestone | 0d | 2024-01-17 A | 2024-01-17 A | 808FS+5d | 100% |  | 2024-01-17 | 2024-01-17 | 0d | 2023-09-01 | 2023-09-01 |  |  | Lee Cox |  |  |  | SI Test | PP | 5.14 | Systems Integration Testing (SIT) | Complete | COMPLETE | MHHS-ART140 | T3-TE-0070 | SITAG | T3 |  | 2/1/24 - Approved at Dec TMAG |  |
| 810 | 1.4.1.7.2.4.1.4 | SIT Functional Testing Test cases (themes 6,7,9) approved | milestone | 0d | 2024-01-17 A | 2024-01-17 A | 809 | 100% |  | 2024-01-17 | 2024-01-17 | 0d | 2023-09-01 | 2023-09-01 |  |  | Lee Cox |  |  |  | SI Test | PP | 5.14 | Systems Integration Testing (SIT) | Complete | COMPLETE | MHHS-ART140 | T3-TE-0108 | SITAG | T3 |  |  |  |
| 811 | 1.4.1.7.2.4.1.5 | SIT Functional Testing Test cases (theme 8) approved | milestone | 0d | 2024-02-21 A | 2024-02-21 A | 810FS+25d | 100% |  | 2024-02-21 | 2024-02-21 | 0d | 2023-09-01 | 2023-09-01 |  |  | Lee Cox |  |  |  | SI Test | PP | 5.14 | Systems Integration Testing (SIT) | Complete | COMPLETE | MHHS-ART140 | T3-TE-0109 | SITAG | T3 |  |  |  |
| 812 | 1.4.1.7.2.5 | **Environments (SIT-Staging)** |  | 10d | 2023-12-04 A | 2023-12-15 A |  | 100% |  | 2022-11-16 | 2024-02-09 | 323d | 2022-11-16 | 2024-02-09 |  |  | N/A | 560h | 560h |  | N/A | N/A | 5.0 | Systems Integration Testing (SIT) |  |  |  |  |  |  |  |  |  |
| 813 | 1.4.1.7.2.5.1 | **SIT Functional pre-requisites** |  | 10d | 2023-12-04 A | 2023-12-15 A |  | 100% |  | 2023-12-04 | 2023-12-15 | 10d |  |  |  |  | N/A | 480h | 480h |  | N/A | N/A | 5.3 | Systems Integration Testing (SIT) |  |  |  |  |  |  |  |  |  |
| 814 | 1.4.1.7.2.5.1.1 | **DCC** |  | 10d | 2023-12-04 A | 2023-12-15 A |  | 100% |  | 2023-12-04 | 2023-12-15 | 10d |  |  |  |  | N/A | 400h | 400h |  | N/A | N/A | 5.3 | Systems Integration Testing (SIT) |  |  |  |  |  |  |  |  | -254.67 |
| 815 | 1.4.1.7.2.5.1.1.1 | **CSS** |  | 10d | 2023-12-04 A | 2023-12-15 A |  | 100% |  | 2023-12-04 | 2023-12-15 | 10d |  |  |  |  | N/A | 160h | 160h |  | N/A | N/A | 5.3 | Systems Integration Testing (SIT) |  |  |  |  |  |  |  |  | -254.67 |
| 816 | 1.4.1.7.2.5.1.1.1.1 | SIT participants have requested DCC CSS PKI certificates for access to UIT-B environment |  | 10d | 2023-12-04 A | 2023-12-15 A |  | 100% |  | 2023-12-04 | 2023-12-15 | 10d |  |  |  | start no earlier than 2023-12-04 | Simon Berry | 80h | 80h |  | SIT Participants (Suppliers & Third Parties) | PP | 5.3 | Systems Integration Testing (SIT) | Complete | COMPLETE |  |  |  |  |  |  |  |
| 817 | 1.4.1.7.2.5.1.1.1.2 | SIT participants have received DCC CSS PKI certificates for UIT-B environment | milestone | 0d | 2023-12-15 A | 2023-12-15 A | 816 | 100% |  | 2023-12-15 | 2023-12-15 | 0d |  |  |  |  | Simon Berry |  |  |  | SIT Participants (Suppliers & Third Parties) | PP | 5.5 | Systems Integration Testing (SIT) | Complete | COMPLETE |  | T3-TE-0088 | SITAG | T3 | 7/8 - added as a T3 milestone. Awaiting approval at TMAG |  |  |
| 818 | 1.4.1.7.2.5.1.1.2 | **DSP** |  | 10d | 2023-12-04 A | 2023-12-15 A |  | 100% |  | 2023-12-04 | 2023-12-15 | 10d |  |  |  |  | N/A | 160h | 160h |  | N/A | N/A | 5.3 | Systems Integration Testing (SIT) |  |  |  |  |  |  |  |  | -254.67 |
| 819 | 1.4.1.7.2.5.1.1.2.1 | SIT participants have requested DCC DSP PKI certificates for access to UIT-B environment |  | 10d | 2023-12-04 A | 2023-12-15 A |  | 100% |  | 2023-12-04 | 2023-12-15 | 10d |  |  |  | start no earlier than 2023-12-04 | Simon Berry | 80h | 80h |  | PPs in SDS Market Role | PP | 5.3 | Systems Integration Testing (SIT) | Complete | COMPLETE |  |  |  |  |  |  |  |
| 820 | 1.4.1.7.2.5.1.1.2.2 | SIT participants have received DCC DSP PKI certificates for UIT-B environment | milestone | 0d | 2023-12-15 A | 2023-12-15 A | 819 | 100% |  | 2023-12-15 | 2023-12-15 | 0d |  |  |  |  | Simon Berry |  |  |  | PPs in SDS Market Role | PP | 5.5 | Systems Integration Testing (SIT) | Complete | COMPLETE |  | T3-TE-0089 | SITAG | T3 | 7/8 - added as a T3 milestone. Awaiting approval at TMAG |  |  |
| 821 | 1.4.1.7.2.6 | **Environments (SIT A)** |  | 25d | 2024-02-05 A | 2024-03-08 |  | 99% | 0d | 2024-01-08 | 2024-02-09 | 25d | 2024-02-05 | 2024-02-09 | 0d |  | N/A | 1232h | 1080h |  | N/A | N/A | 5.0 | Systems Integration Testing (SIT) |  |  |  |  |  |  |  |  |  |
| 822 | 1.4.1.7.2.6.1 | **SIT Functional Connectivity Proving** |  | 15d | 2024-02-12 A | 2024-03-01 A |  | 100% |  | 2024-01-08 | 2024-02-02 | 20d |  |  |  |  | N/A | 232h | 232h |  | N/A | N/A | 5.5 | Systems Integration Testing (SIT) |  |  |  |  |  |  |  |  | -288.67 |
| 823 | 1.4.1.7.2.6.1.1 | SIT Functional Connectivity Proving Period |  | 15d | 2024-02-12 A | 2024-03-01 A |  | 100% |  | 2024-02-12 | 2024-03-01 | 20d |  |  |  | start no earlier than 2024-01-08 | Simon Berry | 120h | 120h |  | SI Test | PP | 5.19 | Systems Integration Testing (SIT) | Complete | COMPLETE |  |  |  |  |  |  |  |
| 824 | 1.4.1.7.2.6.1.2 | SIT Functional Connectivity Proving Complete | milestone | 0d | 2024-03-01 A | 2024-03-01 A | 823 | 100% |  | 2024-03-01 | 2024-03-01 | 0d |  |  |  | start no earlier than 2024-03-01 | Simon Berry |  |  |  | SI Test | PP | 5.19 | Systems Integration Testing (SIT) | Complete | COMPLETE |  | T3-TE-0103 | SITAG | T3 |  |  |  |

Notes:
- 802: Red because 8/12 TMAG moved to 20/12 due to reduction of Dec TMAGS. 5/12 Name change to SIT Functional Testing Test scenarios (themes 1-5) approved 20/12 - Approved at TMAG on 20/12
- 803: 5/12 - New milestone to go to 20/12 TMAG for approval. Added because of new delivery approach for SIT functional artifacts 20/12 - Approved at TMAG on 20/12
- 804: 5/12 - New milestone to go to 20/12 TMAG for approval. Added because of new delivery approach for SIT functional artifacts 20/12 - Approved at TMAG on 20/12
- 807: 15/9 - Potentially add in additional lines to track against progress
- 809: 5/12 Name change to SIT Functional Testing Test Cases (themes 1-5) approved 20/12 - Approved at TMAG on 20/12
- 810: 5/12- New milestone added because revised delivery approach for SIT Functional 20/12 - Approved at TMAG on 20/12
- 811: 5/12- New milestone added because revised delivery approach for SIT Functional
- 817: To be proposed as a T3 Milestone at next TMAG
- 820: 19/12 - MHHS PPs who require DCC, DSP, PKI certificates will request them in order to participate in DCC UEPT
- 823: 16/8 - Needs to start 8 weeks before SIT Functional Testing starts
- 824: 21/2/24 - Date change approved at SITAG on 21/2/24. 4/3 - PPs in the process of completing the activity, two thirds complete, the remain under in various stages of completeness

| ID | WBS | Task | Type | Duration | Start | Finish | Predecessors | Complete | Remaining | Baseline start | Baseline finish | Baseline duration | Baseline 1 start | Baseline 1 finish | Total slack | Free slack | Constraint | Resources | Work | Actual work | Baseline cost | Responsible | Involved | Update Version | MHHS Programme Phase | Sched Status | RAG | Task Status | Artefact ID | Action | Milestone ID | Text29 | Tier |
| --- | --- | --- | --- | --- | --- | --- | --- | --- | --- | --- | --- | --- | --- | --- | --- | --- | --- | --- | --- | --- | --- | --- | --- | --- | --- | --- | --- | --- | --- | --- | --- | --- | --- |
| 825 | 1.4.1.7.2.6.2 | **PP Environments (SIT A)** |  | 25d | 2024-02-05 A | 2024-03-08 A |  | 100% |  | 2024-02-05 | 2024-02-09 | 5d | 2024-02-05 | 2024-02-09 |  |  |  | N/A | 400h | 400h |  | N/A | N/A | 5.0 | Systems Integration Testing (SIT) |  |  |  |  |  |  |  |  |
| 826 | 1.4.1.7.2.6.2.1 | Deployment of MHHS solution code to SIT A environments |  | 25d | 2024-02-05 A | 2024-03-08 A |  | 100% |  | 2024-02-05 | 2024-02-09 | 5d | 2024-02-05 | 2024-02-09 |  |  | start no earlier than 2024-02-05 | Simon Berry | 200h | 200h |  | PP | SI Test | 5.0 | Systems Integration Testing (SIT) | Complete | COMPLETE |  |  |  |  |  |  |
| 827 | 1.4.1.7.2.6.3 | **SI Environments (SIT A)** |  | 25d | 2024-02-05 A | 2024-03-08 A |  | 100% |  | 2024-02-05 | 2024-02-09 | 5d | 2024-02-05 | 2024-02-09 |  |  |  | N/A | 400h | 400h |  | N/A | N/A | 5.0 | Systems Integration Testing (SIT) |  |  |  |  |  |  |  |  |
| 828 | 1.4.1.7.2.6.3.1 | Coordinate deployment of MHHS solution code to SIT Participants' SIT A environments |  | 25d | 2024-02-05 A | 2024-03-08 A | 826SS | 100% |  | 2024-02-05 | 2024-02-09 | 5d | 2024-02-05 | 2024-02-09 |  |  |  | Simon Berry | 200h | 200h |  | SI Test | PP | 5.0 | Systems Integration Testing (SIT) | Complete | COMPLETE |  |  |  |  |  |  |
| 829 | 1.4.1.7.2.7 | **Test data (SIT A)** |  | 225d | 2023-12-18 A | 2024-10-25 |  | 56% | 99.87d | 2023-12-18 | 2024-10-25 | 225d |  |  | 17d |  |  | N/A | 4864h | 1617.02h | -0 | N/A | N/A | 5.4 | Systems Integration Testing (SIT) |  |  | -269.67 |  |  |  |  |  |
| 830 | 1.4.1.7.2.7.1 | **Cycle 1 Test data (SIT A)** |  | 55d | 2023-12-18 A | 2024-03-01 A |  | 100% |  | 2023-12-18 | 2024-03-01 | 55d |  |  |  |  |  | N/A | 872h | 872h | -0 | N/A | N/A | 5.4 | Systems Integration Testing (SIT) |  |  | -269.67 |  |  |  |  |  |
| 831 | 1.4.1.7.2.7.1.1 | Prepare, Generate and Allocate Test Data |  | 28d | 2023-12-18 A | 2024-01-24 A | 608, 616 | 100% |  | 2023-12-18 | 2024-01-24 | 28d |  |  |  |  | start no earlier than 2023-12-11 | Richard Puddephatt | 224h | 224h |  | SI Test Data |  | 5.14 | Systems Integration Testing (SIT) | Complete | COMPLETE |  |  |  |  |  |  |
| 832 | 1.4.1.7.2.7.1.2 | Transmit Data Sets to PPs |  | 4d | 2024-01-26 A | 2024-01-31 A | 831FS+1d | 100% |  | 2024-01-25 | 2024-01-26 | 2d |  |  |  |  |  | Richard Puddephatt | 32h | 32h |  | SI Test Data |  | 5.14 | Systems Integration Testing (SIT) | Complete | COMPLETE |  |  |  |  |  |  |
| 833 | 1.4.1.7.2.7.1.3 | PP's Iterative load and data integrity check |  | 22d | 2024-02-01 A | 2024-03-01 A | 832 | 100% |  | 2024-01-29 | 2024-02-09 | 10d |  |  |  |  |  | Richard Puddephatt | 176h | 176h |  | PP |  | 5.14 | Systems Integration Testing (SIT) | Complete | COMPLETE |  |  |  |  |  |  |
| 834 | 1.4.1.7.2.7.1.4 | Cycle 1 - PP's confirmation that test data is ready for SIT Functional | milestone | 0d | 2024-03-01 A | 2024-03-01 A | 833 | 100% |  | 2024-03-01 | 2024-03-01 | 0d |  |  |  |  |  | Richard Puddephatt |  |  |  | SI Test Data |  | 5.18 | Systems Integration Testing (SIT) | Complete | COMPLETE |  | MHHS-ART140 MHHS-ART169 | 2/8 - added as a T3 milestone. Awaiting approval at TMAG | T3-TE-0079 | SITAG | T3 |
| 835 | 1.4.1.7.2.7.2 | **Cycle 2 Test data (SIT A)** |  | 57d | 2024-03-28 A | 2024-06-14 |  | 99% | 0d | 2024-03-28 | 2024-05-31 | 47d |  |  | 0d |  |  | N/A | 816h | 400h | -0 | N/A | N/A | 5.4 | Systems Integration Testing (SIT) |  |  |  |  |  |  |  |  |
| 836 | 1.4.1.7.2.7.2.1 | Prepare, Generate and Allocate Test Data |  | 31d | 2024-03-28 A | 2024-05-09 A | 834FS+18d | 100% |  | 2024-03-28 | 2024-05-09 | 31d |  |  |  |  |  | Richard Puddephatt | 248h | 248h |  | SI Test Data |  | 5.14 | Systems Integration Testing (SIT) | Complete | COMPLETE |  |  |  |  |  |  |
| 837 | 1.4.1.7.2.7.2.2 | Transmit Data Sets to PPs |  | 3d | 2024-05-10 A | 2024-05-14 A | 836 | 100% |  | 2024-05-10 | 2024-05-14 | 3d |  |  |  |  |  | Richard Puddephatt | 24h | 24h |  | SI Test Data |  | 5.14 | Systems Integration Testing (SIT) | Complete | COMPLETE |  |  |  |  |  |  |
| 838 | 1.4.1.7.2.7.2.3 | PP's Iterative load and data integrity check |  | 13d | 2024-05-15 A | 2024-05-31 A | 837 | 100% |  | 2024-05-15 | 2024-05-31 | 13d |  |  |  |  |  | Richard Puddephatt | 104h | 104h |  | PP |  | 5.14 | Systems Integration Testing (SIT) | Complete | COMPLETE |  |  |  |  |  |  |
| 839 | 1.4.1.7.2.7.2.4 | Cycle 2 - PP's confirmation that test data is ready for SIT Functional | milestone | 0d | 2024-06-14 A | 2024-06-14 A | 838FS+10d | 100% |  | 2024-05-31 | 2024-05-31 | 0d |  |  |  |  |  | Richard Puddephatt |  |  |  | SI Test Data |  | 5.27 | Systems Integration Testing (SIT) | Complete | COMPLETE |  | MHHS-ART140 MHHS-ART169 | 2/8 - added as a T3 milestone. Awaiting approval at TMAG | T3-TE-0080 | SITAG | T3 |
| 840 | 1.4.1.7.2.7.3 | **Cycle 3 Test data (SIT A)** |  | 41d | 2024-06-24 A | 2024-08-19 |  | 7% | 38d | 2024-06-24 | 2024-08-19 | 41d |  |  | 17d |  |  | N/A | 656h | 48h | -0 | N/A | N/A | 5.4 | Systems Integration Testing (SIT) |  |  |  |  |  |  |  |  |
| 841 | 1.4.1.7.2.7.3.1 | Prepare, Generate and Allocate Test Data |  | 18d | 2024-06-24 A | 2024-07-17 | 839FS+5d | 17% | 15d | 2024-06-24 | 2024-07-17 | 18d |  |  | 17d | 0d |  | Richard Puddephatt | 144h | 24h |  | SI Test Data |  | 5.14 | Systems Integration Testing (SIT) | Green | GREEN |  |  |  |  |  |  |
| 842 | 1.4.1.7.2.7.3.2 | Transmit Data Sets to PPs |  | 2d | 2024-07-18 | 2024-07-19 | 841 |  |  | 2024-07-18 | 2024-07-19 | 2d |  |  | 17d | 0d |  | Richard Puddephatt | 16h |  |  | SI Test Data |  | 5.14 | Systems Integration Testing (SIT) | Green | GREEN | 21.33 |  |  |  |  |  |
| 843 | 1.4.1.7.2.7.3.3 | PP's Iterative load and data integrity check |  | 21d | 2024-07-22 | 2024-08-19 | 842 |  |  | 2024-07-22 | 2024-08-19 | 21d |  |  | 17d | 0d |  | Richard Puddephatt | 168h |  |  | PP |  | 5.14 | Systems Integration Testing (SIT) | Green | GREEN | 25.33 |  |  |  |  |  |
| 844 | 1.4.1.7.2.7.3.4 | Cycle 3 - PP's confirmation that test data is ready for SIT Functional | milestone | 0d | 2024-08-19 | 2024-08-19 | 843 |  |  | 2024-08-19 | 2024-08-19 | 0d |  |  | 17d | 0d |  | Richard Puddephatt |  |  |  | SI Test Data |  | 5.14 | Systems Integration Testing (SIT) | Green | GREEN | 53.71 | MHHS-ART140 MHHS-ART169 | 2/8 - added as a T3 milestone. Awaiting approval at TMAG | T3-TE-0081 | SITAG | T3 |
| 845 | 1.4.1.7.2.7.4 | **Regression Test data (SIT A)** |  | 45d | 2024-08-26 | 2024-10-25 |  |  |  | 2024-08-26 | 2024-10-25 | 45d |  |  | 17d |  |  | N/A | 720h |  | -0 | N/A | N/A | 5.4 | Systems Integration Testing (SIT) |  |  |  |  |  |  |  |  |
| 846 | 1.4.1.7.2.7.4.1 | Prepare, Generate and Allocate Test Data |  | 23d | 2024-08-26 | 2024-09-25 | 844FS+4d |  |  | 2024-08-26 | 2024-09-25 | 23d |  |  | 17d | 0d |  | Richard Puddephatt | 184h |  |  | SI Test Data |  | 5.14 | Systems Integration Testing (SIT) | Green | GREEN | 60.33 |  |  |  |  |  |
| 847 | 1.4.1.7.2.7.4.2 | Transmit Data Sets to PPs |  | 2d | 2024-09-26 | 2024-09-27 | 846 |  |  | 2024-09-23 | 2024-10-04 | 10d |  |  | 17d | 0d |  | Richard Puddephatt | 16h |  |  | SI Test Data |  | 5.14 | Systems Integration Testing (SIT) | Green | GREEN | 91.33 |  |  |  |  |  |
| 848 | 1.4.1.7.2.7.4.3 | PP's Iterative load and data integrity check |  | 20d | 2024-09-30 | 2024-10-25 | 847 |  |  | 2024-10-21 | 2024-10-25 | 5d |  |  | 17d | 0d |  | Richard Puddephatt | 160h |  |  | PP |  | 5.14 | Systems Integration Testing (SIT) | Green | GREEN | 95.33 |  |  |  |  |  |
| 849 | 1.4.1.7.2.7.4.4 | Regression - PP's confirmation that test data is ready for SIT Functional | milestone | 0d | 2024-10-25 | 2024-10-25 | 848 |  |  | 2024-10-25 | 2024-10-25 | 0d |  |  | 17d | 5d |  | Richard Puddephatt |  |  |  | SI Test Data |  | 5.14 | Systems Integration Testing (SIT) | Green | GREEN | 120.71 | MHHS-ART140 MHHS-ART169 | 2/8 - added as a T3 milestone. Awaiting approval at TMAG | T3-TE-0082 | SITAG | T3 |

Notes:
- 834: 21/2/24 - Date change approved at SITAG on 21/2/24. 5/3 - Red because 20% of PPs differed the data load to 6/3. These PPs have an action plan to complete this.
- 839: 4/6: Date missed because there are 3 separate data loads for each PP to complete. This is proving time consuming but is expected to complete by 14/6
- 844: 7/12 - Re name milestone to 'Cycle 3 - PP's confirmation that test data is ready for SIT Functional'
- 849: 7/12 - Re name milestone to 'Regression - PP's confirmation that test data is ready for SIT Functional' 20/12 - Approved at TMAG on 20/12

| ID | WBS | Task | Type | Duration | Start | Finish | Predecessors | Complete | Remaining | Baseline start | Baseline finish | Baseline duration | Baseline 1 start | Baseline 1 finish | Total slack | Constraint | Resources | Work | Actual work | Baseline cost | Responsible | Involved | Update Version | MHHS Programme Phase | Sched Status | RAG | Milestone ID | Text29 | Tier | Artefact ID | Task Status |
| --- | --- | --- | --- | --- | --- | --- | --- | --- | --- | --- | --- | --- | --- | --- | --- | --- | --- | --- | --- | --- | --- | --- | --- | --- | --- | --- | --- | --- | --- | --- | --- |
| 850 | 1.4.1.7.2.8 | **SIT Functional Test Readiness Report** |  | 44d | 2024-01-01 A | 2024-02-29 A |  | 100% |  | 2024-01-01 | 2024-02-29 | 44d | 2024-01-01 | 2024-02-23 |  |  | N/A | 2016h | 2016h | -0 | N/A | N/A | 5.0 | Systems Integration Testing (SIT) |  |  |  |  |  |  |  |
| 851 | 1.4.1.7.2.8.1 | **PP SIT Functional Test Readiness Report** |  | 44d | 2024-01-01 A | 2024-02-29 A |  | 100% |  | 2024-01-01 | 2024-02-29 | 44d | 2024-01-01 | 2024-02-09 |  |  | N/A | 864h | 864h | -0 | N/A | N/A | 5.0 | Systems Integration Testing (SIT) |  |  |  |  |  |  |  |
| 852 | 1.4.1.7.2.8.1.1 | Develop draft Test Readiness Report and submit to Programme for assurance |  | 21d | 2024-01-01 A | 2024-01-29 A |  | 100% |  | 2024-01-01 | 2024-01-29 | 20d | 2024-01-01 | 2024-01-29 |  | start no earlier than 2024-01-01 | Lee Cox | 168h | 168h |  | PP | SI Test | 5.0 | Systems Integration Testing (SIT) | Complete | COMPLETE |  |  |  |  |  |
| 853 | 1.4.1.7.2.8.1.2 | Placing Reliance Stage 2 Review |  | 34d | 2024-01-15 A | 2024-02-29 A | 852SS+10d | 100% |  | 2024-01-15 | 2024-02-29 | 34d |  |  |  |  | Lee Cox | 272h | 272h |  | SI Test | PP | 5.12 | Systems Integration Testing (SIT) | Complete | COMPLETE |  |  |  |  |  |
| 854 | 1.4.1.7.2.8.1.3 | Finalise Test Readiness Report and submit to Programme for assurance |  | 9d | 2024-01-30 A | 2024-02-09 A | 852 | 100% |  | 2024-01-29 | 2024-02-09 | 10d | 2024-01-29 | 2024-02-09 |  |  | Lee Cox | 72h | 72h |  | PP | SI Test | 5.0 | Systems Integration Testing (SIT) | Complete | COMPLETE |  |  |  |  |  |
| 855 | 1.4.1.7.2.8.2 | **SI SIT Functional Test Readiness Report** |  | 40d | 2024-01-01 A | 2024-02-23 A |  | 100% |  | 2024-01-01 | 2024-02-23 | 40d | 2024-01-01 | 2024-02-23 |  |  | N/A | 800h | 800h |  | N/A | N/A | 5.0 | Systems Integration Testing (SIT) |  |  |  |  |  |  |  |
| 856 | 1.4.1.7.2.8.2.1 | Assure Test Participants' Test Readiness Reports |  | 35d | 2024-01-01 A | 2024-02-16 A | 852SS, 854FF+5d | 100% |  | 2024-01-01 | 2024-02-16 | 35d | 2024-01-01 | 2024-02-16 |  |  | Lee Cox | 280h | 280h |  | SI Test | PP,IPA | 5.0 | Systems Integration Testing (SIT) | Complete | COMPLETE |  |  |  |  |  |
| 857 | 1.4.1.7.2.8.2.2 | Develop Overarching SIT Functional Test Readiness Report |  | 20d | 2024-01-22 A | 2024-02-16 A | 856FF | 100% |  | 2024-01-22 | 2024-02-16 | 20d | 2024-01-22 | 2024-02-16 |  |  | Lee Cox | 160h | 160h |  | SI Test |  | 5.0 | Systems Integration Testing (SIT) | Complete | COMPLETE |  |  |  |  |  |
| 858 | 1.4.1.7.2.8.2.3 | Artefact review (via TMAG) and updates |  | 5d | 2024-02-19 A | 2024-02-23 A | 857 | 100% |  | 2024-02-19 | 2024-02-23 | 5d | 2024-02-19 | 2024-02-23 |  |  | Lee Cox | 40h | 40h |  | SI Test | PP,IPA | 5.0 | Systems Integration Testing (SIT) | Complete | COMPLETE |  |  |  |  |  |
| 859 | 1.4.1.7.2.9 | SIT Functional Testing Preparation Complete | milestone | 0d | 2024-03-01 A | 2024-03-01 A | 858FF+5d, 794, 313, 853, 802, 809, 834 | 100% |  | 2024-03-01 | 2024-03-01 | 0d | 2024-03-01 | 2024-03-01 |  |  | Lee Cox |  |  |  | SI Test | PP,IPA | 5.0 | Systems Integration Testing (SIT) | Complete | COMPLETE | T2-TE-0550 | SITAG | T2 |  |  |
| 860 | 1.4.1.7.3 | **SIT Migration Testing Preparation** |  | 435d | 2022-10-31 A | 2024-06-28 |  | 99% | 2.04d | 2022-10-31 | 2024-06-07 | 420d | 2022-11-16 | 2024-06-03 | 760d |  | N/A | 19511.7h | 17216.8h | -0 | N/A | N/A | 5.21 | Systems Integration Testing (SIT) |  |  |  |  |  |  |  |
| 861 | 1.4.1.7.3.1 | **Test Approach & Plan** |  | 75d | 2023-09-07 A | 2023-12-20 A |  | 100% |  | 2023-09-07 | 2023-12-20 | 75d | 2023-09-07 | 2023-12-20 |  |  | N/A | 1199.74h | 1199.74h | -0 | N/A | N/A | 5.0 | Systems Integration Testing (SIT) |  |  |  |  |  |  |  |
| 862 | 1.4.1.7.3.1.1 | Develop document with SITWG |  | 32d | 2023-09-07 A | 2023-10-20 A | 1834 | 100% |  | 2023-09-07 | 2023-10-11 | 25d | 2023-09-07 | 2023-10-11 |  | finish no earlier than 2023-10-11 | Lee Cox | 256h | 256h |  | SI Test |  | 5.0 | Systems Integration Testing (SIT) | Complete | COMPLETE |  |  |  |  |  |
| 863 | 1.4.1.7.3.1.2 | Draft document review with Code Bodies |  | 8d | 2023-10-23 A | 2023-11-01 A | 862 | 100% |  | 2023-10-12 | 2023-10-25 | 10d | 2023-10-12 | 2023-10-25 |  |  | Lee Cox | 64h | 64h |  | SI Test | Code Bodies | 5.0 | Systems Integration Testing (SIT) | Complete | COMPLETE |  |  |  |  |  |
| 864 | 1.4.1.7.3.1.3 | Industry Consultation |  | 10d | 2023-11-02 A | 2023-11-15 A | 863 | 100% |  | 2023-11-02 | 2023-11-15 | 10d |  |  |  |  | Lee Cox | 80h | 80h |  | PP |  | 5.1 | Systems Integration Testing (SIT) | Complete | COMPLETE |  |  |  |  |  |
| 865 | 1.4.1.7.3.1.4 | Artefact review (via TMAG) and updates |  | 25d | 2023-11-16 A | 2023-12-20 A | 864 | 100% |  | 2023-11-09 | 2023-12-20 | 30d | 2023-10-26 | 2023-12-20 |  |  | Lee Cox | 200h | 200h |  | SI Test | PP,IPA,Code Bodies | 5.0 | Systems Integration Testing (SIT) | Complete | COMPLETE |  |  |  |  |  |
| 866 | 1.4.1.7.3.1.5 | SIT Migration Testing Test Approach & Plan approved | milestone | 0d | 2023-12-20 A | 2023-12-20 A | 865 | 100% |  | 2023-12-20 | 2023-12-20 | 1d | 2023-12-20 | 2023-12-20 |  | finish no earlier than 2023-12-20 | Lee Cox |  |  |  | SI Test | PP | 5.14 | Systems Integration Testing (SIT) | Complete | COMPLETE | T3-TE-0018 | SITAG | T3 | MHHS-ART073 |  |
| 867 | 1.4.1.7.3.2 | **Test Data Approach & Plan** |  | 35d | 2023-11-02 A | 2023-12-20 A |  | 100% |  | 2023-11-02 | 2023-12-20 | 35d | 2023-10-26 | 2023-12-20 |  |  | N/A | 560h | 560h | -0 | N/A | N/A | 5.0 | Systems Integration Testing (SIT) |  |  |  |  |  |  |  |
| 868 | 1.4.1.7.3.2.1 | Industry Consultation |  | 10d | 2023-11-02 A | 2023-11-15 A | 864SS | 100% |  | 2023-11-02 | 2023-11-15 | 10d |  |  |  |  | PP | 80h | 80h |  | PP |  | 5.1 | Systems Integration Testing (SIT) | Complete | COMPLETE |  |  |  |  |  |
| 869 | 1.4.1.7.3.2.2 | Artefact review (via TMAG) and updates |  | 25d | 2023-11-16 A | 2023-12-20 A | 868 | 100% |  | 2023-11-09 | 2023-12-20 | 30d | 2023-10-26 | 2023-12-20 |  |  | Richard Puddephatt | 200h | 200h |  | SI Test Data |  | 5.0 | Systems Integration Testing (SIT) | Complete | COMPLETE |  |  |  |  |  |
| 870 | 1.4.1.7.3.2.3 | SIT Migration Test Data Test Approach & Plan approved | milestone | 0d | 2023-12-20 A | 2023-12-20 A | 869 | 100% |  | 2023-12-20 | 2023-12-20 | 0d | 2023-12-20 | 2023-12-20 |  |  | Richard Puddephatt |  |  |  | SI Test Data | PP,IPA | 5.14 | Systems Integration Testing (SIT) | Complete | COMPLETE |  |  |  |  |  |
| 871 | 1.4.1.7.3.3 | **Test scenarios & Test Cases** |  | 85d | 2023-12-21 A | 2024-04-17 |  | 99% | 0d | 2023-12-21 | 2024-03-20 | 65d | 2023-07-24 | 2024-01-17 | 0d |  | N/A | 3128h | 2168h | -0 | N/A | N/A | 5.16 | Systems Integration Testing (SIT) |  |  |  |  |  |  |  |
| 872 | 1.4.1.7.3.3.1 | **Theme 1** |  | 65d | 2023-12-21 A | 2024-03-20 A |  | 100% |  | 2023-12-21 | 2024-03-20 | 65d |  |  |  |  | N/A | 816h | 816h | -0 | N/A | N/A | 5.16 | Systems Integration Testing (SIT) |  |  |  |  |  |  | -448.67 |
| 873 | 1.4.1.7.3.3.1.1 | Develop Test Scenarios & Test Cases |  | 25d | 2023-12-21 A | 2024-01-24 A | 866 | 100% |  | 2023-12-21 | 2024-01-24 | 25d |  |  |  |  | Lee Cox | 200h | 200h |  | SI Test | SI Test, PP | 5.16 |  | Complete | COMPLETE |  |  |  |  |  |
| 874 | 1.4.1.7.3.3.1.2 | Industry Review Workshop |  | 1d | 2024-01-25 A | 2024-01-25 A | 873 | 100% |  | 2024-01-25 | 2024-01-25 | 1d |  |  |  |  | Lee Cox | 8h | 8h |  | SI Test, PP | SI Test, PP | 5.16 |  | Complete | COMPLETE |  |  |  |  |  |
| 875 | 1.4.1.7.3.3.1.3 | Industry Consultation Review |  | 6d | 2024-02-05 A | 2024-02-12 A | 874FS+6d | 100% |  | 2024-02-05 | 2024-02-12 | 6d |  |  |  |  | Lee Cox | 48h | 48h |  | SI Test, PP | SI Test, PP | 5.16 |  | Complete | COMPLETE |  |  |  |  |  |
| 876 | 1.4.1.7.3.3.1.4 | Review with SIT Working Group |  | 5d | 2024-02-29 A | 2024-03-06 A | 875FS+12d | 100% |  | 2024-02-29 | 2024-03-06 | 5d |  |  |  |  | Lee Cox | 40h | 40h |  | SI Test, PP | SI Test, PP | 5.19 |  | Complete | COMPLETE |  |  |  |  |  |
| 877 | 1.4.1.7.3.3.1.5 | SIT Migration Test scenarios & Test Cases Approved - Theme 1 | milestone | 0d | 2024-03-20 A | 2024-03-20 A | 876FS+10d | 100% |  | 2024-03-20 | 2024-03-20 | 0d |  |  |  |  | Lee Cox |  |  |  | SI Test | SI Test, PP | 5.21 | Systems Integration Testing (SIT) | Complete | COMPLETE | T3-TE-0110 | SITAG |  |  |  |

Notes:
- 859: 28/11 - At risk because of challenges with CCP and PP readiness & dependent on successful Secondary Routing Testing. Approved at 1/3 eSITAG
- 866: 24/10 - Amber because consultation window delayed by 5 days. 20/12 - Approved to complete at TMAG on 20/12
- 870: 20/12 - approved at TMAG on 20/12
- 877: 23/1 - New milestones added because of new themed delivery approach. To go to Feb SITAG for approval

| ID | WBS | Task | Type | Duration | Start | Finish | Predecessors | Complete | Remaining | Baseline start | Baseline finish | Baseline duration | Baseline 1 start | Baseline 1 finish | Total slack | Constraint | Resources | Work | Actual work | Baseline cost | Responsible | Involved | Task Status | Update Version | MHHS Programme Phase | Sched Status | RAG | Milestone ID | Text29 | Tier |
| --- | --- | --- | --- | --- | --- | --- | --- | --- | --- | --- | --- | --- | --- | --- | --- | --- | --- | --- | --- | --- | --- | --- | --- | --- | --- | --- | --- | --- | --- | --- |
| 878 | 1.4.1.7.3.3.2 | **Theme 2** |  | 85d | 2023-12-21 A | 2024-04-17 |  | 99% | 0d | 2023-12-21 | 2024-04-17 | 85d |  |  | 0d |  | N/A | 1096h | 616h | -0 | N/A | N/A | -448.67 | 5.16 | Systems Integration Testing (SIT) |  |  |  |  |  |
| 879 | 1.4.1.7.3.3.2.1 | Develop Test Scenarios & Test Cases |  | 40d | 2023-12-21 A | 2024-02-14 A | 866 | 100% |  | 2023-12-21 | 2024-02-14 | 40d |  |  |  |  | Lee Cox | 320h | 320h |  | SI Test | SI Test, PP |  | 5.16 |  | Complete | COMPLETE |  |  |  |
| 880 | 1.4.1.7.3.3.2.2 | Industry Review Workshop |  | 1d | 2024-02-15 A | 2024-02-15 A | 879 | 100% |  | 2024-02-15 | 2024-02-15 | 1d |  |  |  |  | Lee Cox | 8h | 8h |  | SI Test, PP | SI Test, PP |  | 5.16 |  | Complete | COMPLETE |  |  |  |
| 881 | 1.4.1.7.3.3.2.3 | Industry Consultation Review |  | 6d | 2024-02-26 A | 2024-03-04 A | 880FS+6d | 100% |  | 2024-02-26 | 2024-03-04 | 6d |  |  |  |  | Lee Cox | 48h | 48h |  | SI Test, PP | SI Test, PP |  | 5.19 |  | Complete | COMPLETE |  |  |  |
| 882 | 1.4.1.7.3.3.2.4 | Review with SIT Working Group |  | 5d | 2024-03-28 A | 2024-04-03 A | 881FS+17d | 100% |  | 2024-03-28 | 2024-04-03 | 5d |  |  |  |  | Lee Cox | 40h | 40h |  | SI Test, PP | SI Test, PP |  | 5.16 |  | Complete | COMPLETE |  |  |  |
| 883 | 1.4.1.7.3.3.2.5 | SIT Migration Test scenarios & Test Cases Approved - Theme 2 | milestone | 0d | 2024-04-17 A | 2024-04-17 A | 882FS+10d | 100% |  | 2024-04-17 | 2024-04-17 | 0d |  |  |  |  | Lee Cox |  |  |  | SI Test | SI Test, PP |  | 5.22 | Systems Integration Testing (SIT) | Complete | COMPLETE | T3-TE-0111 | SITAG |  |
| 884 | 1.4.1.7.3.3.3 | **Theme 3** |  | 85d | 2023-12-21 A | 2024-04-17 |  | 99% | 0d | 2023-12-21 | 2024-04-17 | 85d |  |  | 0d |  | N/A | 1216h | 736h | -0 | N/A | N/A | -448.67 | 5.16 | Systems Integration Testing (SIT) |  |  |  |  |  |
| 885 | 1.4.1.7.3.3.3.1 | Develop Test Scenarios & Test Cases |  | 55d | 2023-12-21 A | 2024-03-06 A | 866 | 100% |  | 2023-12-21 | 2024-03-06 | 55d |  |  |  |  | Lee Cox | 440h | 440h |  | SI Test | SI Test, PP |  | 5.19 |  | Complete | COMPLETE |  |  |  |
| 886 | 1.4.1.7.3.3.3.2 | Industry Review Workshop |  | 1d | 2024-03-07 A | 2024-03-07 A | 885 | 100% |  | 2024-03-07 | 2024-03-07 | 1d |  |  |  |  | Lee Cox | 8h | 8h |  | SI Test, PP | SI Test, PP |  | 5.16 |  | Complete | COMPLETE |  |  |  |
| 887 | 1.4.1.7.3.3.3.3 | Industry Consultation Review |  | 6d | 2024-03-13 A | 2024-03-20 A | 886FS+3d | 100% |  | 2024-03-13 | 2024-03-20 | 6d |  |  |  |  | Lee Cox | 48h | 48h |  | SI Test, PP | SI Test, PP |  | 5.16 |  | Complete | COMPLETE |  |  |  |
| 888 | 1.4.1.7.3.3.3.4 | Review with SIT Working Group |  | 5d | 2024-03-28 A | 2024-04-03 A | 887FS+5d | 100% |  | 2024-03-28 | 2024-04-03 | 5d |  |  |  |  | Lee Cox | 40h | 40h |  | SI Test, PP | SI Test, PP |  | 5.16 |  | Complete | COMPLETE |  |  |  |
| 889 | 1.4.1.7.3.3.3.5 | SIT Migration Test scenarios & Test Cases Approved - Theme 3 | milestone | 0d | 2024-04-17 A | 2024-04-17 A | 888FS+10d | 100% |  | 2024-04-17 | 2024-04-17 | 0d |  |  |  |  | Lee Cox |  |  |  | SI Test | SI Test, PP |  | 5.22 | Systems Integration Testing (SIT) | Complete | COMPLETE | T3-TE-0112 | SITAG |  |
| 890 | 1.4.1.7.3.4 | **Environments (SIT B)** |  | 435d | 2022-10-31 A | 2024-06-28 |  | 99% | 3.77d | 2022-10-31 | 2024-06-07 | 420d | 2022-11-16 | 2024-05-13 | 760d |  | N/A | 10904h | 10725.5h | -0 | N/A | N/A |  | 5.0 | Systems Integration Testing (SIT) |  |  |  |  |  |
| 891 | 1.4.1.7.3.4.1 | **PP Environments (SIT B)** |  | 41d | 2024-05-03 A | 2024-06-28 |  | 95% | 2.05d | 2024-05-03 | 2024-06-07 | 26d | 2022-11-16 | 2024-05-13 | 760d |  | N/A | 648h | 615.6h | -0 | N/A | N/A |  | 5.0 | Systems Integration Testing (SIT) |  |  |  |  |  |
| 892 | 1.4.1.7.3.4.1.1 | PP Environments available | milestone | 0d | 2024-05-03 A | 2024-05-03 A | 466 | 100% |  | 2024-05-03 | 2024-05-03 | 0d | 2022-11-16 | 2024-04-01 |  | start no earlier than 2024-05-03 | Simon Berry |  |  |  | PP | SI Test |  | 5.21 | Systems Integration Testing (SIT) | Complete | COMPLETE |  |  |  |
| 893 | 1.4.1.7.3.4.1.2 | PP Onboarding / Smoke test |  | 35d | 2024-05-13 A | 2024-06-28 | 892FS+6d | 94% | 2d | 2024-05-13 | 2024-06-07 | 20d | 2022-11-16 | 2024-04-01 | 760d |  | Simon Berry | 280h | 264h |  | PP | SI Test |  | 5.21 | Systems Integration Testing (SIT) | Red | RED |  |  |  |
| 894 | 1.4.1.7.3.4.1.3 | DTN Connectivity Proving Complete |  | 5d | 2024-06-10 A | 2024-06-14 A | 892FS+26d | 100% |  | 2024-05-31 | 2024-05-31 | 0d | 2024-04-15 | 2024-04-26 |  |  | Simon Berry | 40h | 40h |  | PP | SI Test |  | 5.21 | Systems Integration Testing (SIT) | Complete | COMPLETE |  |  |  |
| 895 | 1.4.1.7.3.4.1.4 | PP Code Deployment | milestone | 0d | 2024-06-14 A | 2024-06-14 A | 894 | 100% |  | 2024-06-03 | 2024-06-03 | 0d | 2024-04-29 | 2024-05-13 |  |  | Simon Berry |  |  |  | PP | SI Test |  | 5.21 | Systems Integration Testing (SIT) | Complete | COMPLETE |  |  |  |
| 896 | 1.4.1.7.3.4.2 | **SI Environments (SIT B)** |  | 425d | 2022-10-31 A | 2024-06-14 |  | 99% | 2.01d | 2022-10-31 | 2024-06-07 | 420d | 2022-11-16 | 2024-05-10 | 770d |  | N/A | 6776h | 6660.04h | -0 | N/A | N/A |  | 5.0 | Systems Integration Testing (SIT) |  |  |  |  |  |
| 897 | 1.4.1.7.3.4.2.1 | Coordinate SIT Participants' SIT B environment preparation |  | 420d | 2022-10-31 A | 2024-06-07 A |  | 100% |  | 2022-10-31 | 2024-06-07 | 420d | 2022-11-16 | 2024-04-01 |  |  | Simon Berry | 3360h | 3360h |  | SI Test | PP |  | 5.21 | Systems Integration Testing (SIT) | Complete | COMPLETE |  |  |  |
| 898 | 1.4.1.7.3.4.2.2 | Assure PPs' self-declaration of environment preparation complete (incl. security certificates and security compliance) | milestone | 0d | 2024-06-07 A | 2024-06-07 A | 897 | 100% |  | 2024-06-07 | 2024-06-07 | 0d | 2022-11-16 | 2024-03-29 |  |  | Simon Berry |  |  |  | SI Test | PP |  | 5.21 | Systems Integration Testing (SIT) | Complete | COMPLETE |  |  |  |
| 899 | 1.4.1.7.3.4.2.3 | SIT Participants' SIT B environments ready to start connectivity proving (incl. certificates and security compliance) | milestone | 0d | 2024-06-05 A | 2024-06-05 A | 892FS+24d | 100% |  | 2024-05-03 | 2024-05-03 | 0d | 2024-04-01 | 2024-04-01 |  |  | Simon Berry |  |  |  | SI Test | PP,IPA |  | 5.26 | Systems Integration Testing (SIT) | Complete | COMPLETE | T3-TE-0033 | SITAG | T3 |
| 900 | 1.4.1.7.3.4.2.4 | Coordinate SIT Participants' SIT B environment connectivity proving |  | 2d | 2024-06-06 | 2024-06-07 | 899 |  |  | 2024-05-14 | 2024-06-07 | 19d | 2024-04-01 | 2024-04-26 | 775d |  | Simon Berry | 16h |  |  | SI Test | PP | -20.67 | 5.21 | Systems Integration Testing (SIT) | Overdue Start | RED |  |  |  |
| 901 | 1.4.1.7.3.4.2.5 | Coordinate deployment of MHHS solution code to SIT Participants' SIT B environments | milestone | 0d | 2024-06-14 A | 2024-06-14 A | 895 | 100% |  | 2024-06-04 | 2024-06-07 | 4d | 2024-04-15 | 2024-04-26 |  |  | Simon Berry |  |  |  | SI Test | PP |  | 5.21 | Systems Integration Testing (SIT) | Complete | COMPLETE |  |  |  |

Notes:
- 883: 23/1 - New milestones added because of new themed delivery approach
- 889: 23/1 - New milestones added because of new themed delivery approach
- 899: 3/6: SI coordinated smoke test will run from 5th - 7th June

| ID | WBS | Task | Type | Duration | Start | Finish | Predecessors | Complete | Remaining | Baseline start | Baseline finish | Baseline duration | Baseline 1 start | Baseline 1 finish | Total slack | Free slack | Constraint | Resources | Work | Actual work | Baseline cost | Responsible | Involved | Update Version | MHHS Programme Phase | Sched Status | RAG | Milestone ID | Text29 | Tier | Artefact ID | Impact | Task Status |
| --- | --- | --- | --- | --- | --- | --- | --- | --- | --- | --- | --- | --- | --- | --- | --- | --- | --- | --- | --- | --- | --- | --- | --- | --- | --- | --- | --- | --- | --- | --- | --- | --- | --- |
| 902 | 1.4.1.7.3.5 | **SIT Migration Test Readiness Report** |  | 44d | 2024-04-02 A | 2024-05-31 A |  | 100% |  | 2024-04-02 | 2024-05-31 | 44d | 2024-04-02 | 2024-05-27 |  |  |  | N/A | 2024h | 2024h | -0 | N/A | N/A | 5.0 | Systems Integration Testing (SIT) |  |  |  |  |  |  |  |  |
| 903 | 1.4.1.7.3.5.1 | **PP SIT Migration Test Readiness Report** |  | 44d | 2024-04-02 A | 2024-05-31 A |  | 100% |  | 2024-04-02 | 2024-05-31 | 44d | 2024-04-02 | 2024-05-13 |  |  |  | N/A | 872h | 872h | -0 | N/A | N/A | 5.0 | Systems Integration Testing (SIT) |  |  |  |  |  |  |  |  |
| 904 | 1.4.1.7.3.5.1.1 | Develop draft Test Readiness Report and submit to Programme for assurance |  | 20d | 2024-04-02 A | 2024-04-29 A |  | 100% |  | 2024-04-02 | 2024-04-30 | 20d | 2024-04-02 | 2024-04-30 |  |  | start no earlier than 2024-04-02 | Lee Cox | 160h | 160h |  | PP | SI Test | 5.0 | Systems Integration Testing (SIT) | Complete | COMPLETE |  |  |  |  |  |  |
| 905 | 1.4.1.7.3.5.1.2 | Placing Reliance Stage 2 Review |  | 35d | 2024-04-15 A | 2024-05-31 A | 904SS+9d | 100% |  | 2024-04-15 | 2024-05-31 | 35d |  |  |  |  |  | Lee Cox | 280h | 280h |  | SI Test | PP | 5.12 | Systems Integration Testing (SIT) | Complete | COMPLETE |  |  |  |  |  |  |
| 906 | 1.4.1.7.3.5.1.3 | Finalise Test Readiness Report and submit to Programme for assurance |  | 10d | 2024-04-30 A | 2024-05-13 A | 904 | 100% |  | 2024-04-30 | 2024-05-13 | 10d | 2024-04-30 | 2024-05-13 |  |  |  | Lee Cox | 80h | 80h |  | PP | SI Test | 5.0 | Systems Integration Testing (SIT) | Complete | COMPLETE |  |  |  |  |  |  |
| 907 | 1.4.1.7.3.5.2 | **SI SIT Migration Test Readiness Report** |  | 40d | 2024-04-02 A | 2024-05-27 A |  | 100% |  | 2024-04-02 | 2024-05-27 | 40d | 2024-04-02 | 2024-05-27 |  |  |  | N/A | 800h | 800h |  | N/A | N/A | 5.0 | Systems Integration Testing (SIT) |  |  |  |  |  |  |  |  |
| 908 | 1.4.1.7.3.5.2.1 | Assure Test Participants' Test Readiness Reports |  | 35d | 2024-04-02 A | 2024-05-20 A | 904SS, 906FF+5d | 100% |  | 2024-04-02 | 2024-05-20 | 35d | 2024-04-02 | 2024-05-20 |  |  |  | Lee Cox | 280h | 280h |  | SI Test | PP,IPA | 5.0 | Systems Integration Testing (SIT) | Complete | COMPLETE |  |  |  |  |  |  |
| 909 | 1.4.1.7.3.5.2.2 | Develop Overarching SIT Migration Test Readiness Report |  | 20d | 2024-04-23 A | 2024-05-20 A | 908FF | 100% |  | 2024-04-23 | 2024-05-20 | 20d | 2024-04-23 | 2024-05-20 |  |  |  | Lee Cox | 160h | 160h |  | SI Test |  | 5.0 | Systems Integration Testing (SIT) | Complete | COMPLETE |  |  |  |  |  |  |
| 910 | 1.4.1.7.3.5.2.3 | Artefact review (via SITAG) and updates |  | 5d | 2024-05-21 A | 2024-05-27 A | 909 | 100% |  | 2024-05-21 | 2024-05-27 | 5d | 2024-05-21 | 2024-05-27 |  |  |  | Lee Cox | 40h | 40h |  | SI Test | PP,IPA | 5.0 | Systems Integration Testing (SIT) | Complete | COMPLETE |  |  |  |  |  |  |
| 911 | 1.4.1.7.3.6 | SIT Migration Testing Preparation Complete | milestone | 0d | 2024-06-03 A | 2024-06-03 A | 910FF+5d, 866, 330, 905, 877, 883, 889 | 100% |  | 2024-06-03 | 2024-06-03 | 0d | 2024-06-03 | 2024-06-03 |  |  |  | Lee Cox |  |  |  | SI Test | PP,IPA | 5.0 | Systems Integration Testing (SIT) | Complete | COMPLETE | T2-TE-0650 | SITAG | T2 |  |  |  |
| 912 | 1.4.1.7.4 | **SIT Non-Functional Preparation** |  | 193d | 2023-11-30 A | 2024-08-27 |  | 70% | 58.33d | 2023-11-30 | 2024-08-27 | 193d | 2023-07-03 | 2024-08-26 | 719d |  |  | N/A | 9864h | 5507.74h | -0 | N/A | N/A | 5.0 | Systems Integration Testing (SIT) |  |  |  |  |  |  |  |  |
| 913 | 1.4.1.7.4.1 | **Test Approach & Plan** |  | 120d | 2023-11-30 A | 2024-05-15 |  | 99% | 0d | 2023-11-30 | 2024-05-15 | 120d | 2023-11-30 | 2024-03-20 | 83d |  |  | N/A | 1696h | 1041.96h | -0 | N/A | N/A | 5.0 | Systems Integration Testing (SIT) |  |  |  |  |  |  |  |  |
| 914 | 1.4.1.7.4.1.1 | Develop document with SITWG |  | 67d | 2023-11-30 A | 2024-03-01 A |  | 100% |  | 2023-11-30 | 2024-03-01 | 67d | 2023-11-30 | 2024-01-10 |  |  | must start on 2023-11-30 | Lee Cox | 536h | 536h |  | SI Test |  | 5.0 | Systems Integration Testing (SIT) | Complete | COMPLETE |  |  |  |  |  |  |
| 915 | 1.4.1.7.4.1.2 | Draft document review with Code Bodies |  | 10d | 2024-03-04 A | 2024-03-15 A | 914 | 100% |  | 2024-03-04 | 2024-03-15 | 10d | 2024-01-11 | 2024-01-24 |  |  |  | Lee Cox | 80h | 80h |  | SI Test | Code Bodies | 5.0 | Systems Integration Testing (SIT) | Complete | COMPLETE |  |  |  |  |  |  |
| 916 | 1.4.1.7.4.1.3 | Industry Consultation |  | 10d | 2024-03-18 A | 2024-03-29 A | 915 | 100% |  | 2024-03-18 | 2024-03-29 | 10d |  |  |  |  |  | Lee Cox | 80h | 80h |  | PP |  | 5.1 | Systems Integration Testing (SIT) | Complete | COMPLETE |  |  |  |  |  |  |
| 917 | 1.4.1.7.4.1.4 | Industry Assurance Review |  | 5d | 2024-04-11 A | 2024-04-17 A | 916FS+8d | 100% |  | 2024-04-11 | 2024-04-17 | 5d |  |  |  |  |  | Lee Cox | 40h | 40h |  |  |  | 5.16 |  | Complete | COMPLETE |  |  |  |  |  |  |
| 918 | 1.4.1.7.4.1.5 | SIT Non-Functional Testing Test Approach & Plan approved | milestone | 0d | 2024-05-15 | 2024-05-15 | 917FS+20d |  |  | 2024-05-15 | 2024-05-15 | 0d | 2024-03-20 | 2024-03-20 | 83d | 71d |  | Lee Cox |  |  |  | SI Test | PP | 5.18 | Systems Integration Testing (SIT) | Overdue Start | RED | T3-TE-0026 | SITAG | T3 | MHHS-ART073 | 26/6: Risks the start of SIT non-functional testing | -42.29 |
| 919 | 1.4.1.7.4.2 | **Test Data Approach & Plan** |  | 41d | 2024-03-20 A | 2024-05-15 A |  | 100% |  | 2024-03-20 | 2024-05-15 | 41d | 2024-01-25 | 2024-03-20 |  |  |  | N/A | 656h | 656h | -0 | N/A | N/A | 5.0 | Systems Integration Testing (SIT) |  |  |  |  |  |  |  |  |
| 920 | 1.4.1.7.4.2.1 | Industry Consultation |  | 14d | 2024-03-20 A | 2024-04-08 A | 916SS+2d | 100% |  | 2024-03-20 | 2024-04-08 | 14d |  |  |  |  |  | Richard Puddephatt | 112h | 112h |  | PP |  | 5.1 | Systems Integration Testing (SIT) | Complete | COMPLETE |  |  |  |  |  |  |
| 921 | 1.4.1.7.4.2.2 | Artefact review (via SITAG) and updates |  | 27d | 2024-04-09 A | 2024-05-15 A | 920 | 100% |  | 2024-04-09 | 2024-05-15 | 27d | 2024-01-25 | 2024-03-13 |  |  |  | Richard Puddephatt | 216h | 216h |  | SI Test |  | 5.0 | Systems Integration Testing (SIT) | Complete | COMPLETE |  |  |  |  |  |  |
| 922 | 1.4.1.7.4.2.3 | SIT Non-Functional Testing Test Data Approach & Plan approved | milestone | 0d | 2024-05-15 A | 2024-05-15 A | 918FF, 921 | 100% |  | 2024-05-15 | 2024-05-15 | 0d | 2024-03-20 | 2024-03-20 |  |  |  | Richard Puddephatt |  |  |  | SI Test | PP,IPA | 5.24 | Systems Integration Testing (SIT) | Complete | COMPLETE | T3-TE-0113 | SITAG |  |  |  |  |
| 923 | 1.4.1.7.4.3 | **Test scenarios & Test Cases** |  | 98d | 2024-03-04 A | 2024-07-17 |  | 95% | 5.24d | 2024-03-04 | 2024-07-17 | 98d | 2023-07-24 | 2024-01-17 | 33d |  |  | N/A | 3952h | 3746.22h | -0 | N/A | N/A | 5.21 | Systems Integration Testing (SIT) |  |  |  |  |  |  |  |  |
| 924 | 1.4.1.7.4.3.1 | **Theme 1** |  | 78d | 2024-03-04 A | 2024-06-19 |  | 99% | 0d | 2024-03-04 | 2024-06-19 | 78d |  |  | 53d |  |  | N/A | 992h | 992h | -0 | N/A | N/A | 5.21 | Systems Integration Testing (SIT) |  |  |  |  |  |  |  | -448.67 |
| 925 | 1.4.1.7.4.3.1.1 | Develop Test Scenarios & Test Cases |  | 33d | 2024-03-04 A | 2024-04-17 A | 914 | 100% |  | 2024-03-04 | 2024-04-17 | 33d |  |  |  |  |  | Lee Cox | 264h | 264h |  | SI Test | SI Test, PP | 5.21 |  | Complete | COMPLETE |  |  |  |  |  |  |
| 926 | 1.4.1.7.4.3.1.2 | Industry Review Workshop |  | 1d | 2024-04-18 A | 2024-04-18 A | 925 | 100% |  | 2024-04-18 | 2024-04-18 | 1d |  |  |  |  |  | Lee Cox | 8h | 8h |  | SI Test, PP | SI Test, PP | 5.21 |  | Complete | COMPLETE |  |  |  |  |  |  |
| 927 | 1.4.1.7.4.3.1.3 | Industry Consultation Review |  | 7d | 2024-05-02 A | 2024-05-10 A | 926FS+9d | 100% |  | 2024-05-02 | 2024-05-10 | 7d |  |  |  |  |  | Lee Cox | 56h | 56h |  | SI Test, PP | SI Test, PP | 5.21 |  | Complete | COMPLETE |  |  |  |  |  |  |
| 928 | 1.4.1.7.4.3.1.4 | Review with NFT Working Group |  | 5d | 2024-05-31 A | 2024-06-06 A | 927FS+14d | 100% |  | 2024-05-31 | 2024-06-06 | 5d |  |  |  |  |  | Lee Cox | 40h | 40h |  | SI Test, PP | SI Test, PP | 5.21 |  | Complete | COMPLETE |  |  |  |  |  |  |
| 929 | 1.4.1.7.4.3.1.5 | SIT NFT Scenarios & Test Cases Approved - Theme 1 | milestone | 0d | 2024-06-19 | 2024-06-19 | 928FS+9d |  |  | 2024-06-19 | 2024-06-19 | 0d |  |  | 53d | 48d |  | Lee Cox |  |  |  | SI Test | SI Test, PP | 5.22 | Systems Integration Testing (SIT) | Overdue Start | RED | T3-TE-0114 | SITAG |  |  | 26/6: Risks the start of SIT non-functional testing | -7.29 |

Notes:
- 911: 28/5: Amber because subject to SITAG agreement on work-off items. 4/6 eSITAG approved milestone completion subject to work-off items
- 918: 21/2/24 - Date change approved at SITAG on 21/2/24. 27/2 At risk because of tight delivery schedule. 11/6: Deferred from May SITAG Approval. Phase 1 tooling under investigation / Action: 26/6: Conclude phase 1 SIT NFT assumption verification. Re-issue for SITAG approval. Forecast SITAG TBC / Issue: 26/8: Deferred from May SITAG Approval because tooling assumptions needed verifying
- 922: 13/2 - To go to Feb SITAG as a new milestone. 21/2/24 - Approved at SITAG on 21/2/24 as a new milestone. 3/4 At risk because of tight delivery schedule (added as amber to align with Lee's status)
- 929: 23/1 - New milestone added because of NFT themed delivery approach. To go to April SITAG for approval 17/4: Approved new milestone at SITAG on 17/4/24. 19/6: Date missed as deferred whilst NF SIT Phase 1 Assumptions are validated / Action: 26/6: Conclude phase 1 SIT NFT assumption verification. Re-issue for SITAG approval. Forecast SITAG TBC / Issue: 26/8: Deferred from June SITAG Approval because Phase 1 tooling assumptions needed verifying

| ID | WBS | Task | Type | Duration | Start | Finish | Predecessors | Complete | Remaining | Baseline start | Baseline finish | Baseline duration | Baseline 1 start | Baseline 1 finish | Total slack | Free slack | Constraint | Resources | Work | Actual work | Baseline cost | Responsible | Involved | Task Status | Update Version | MHHS Programme Phase | Sched Status | RAG | Action | Milestone ID | Text29 | Tier |
| --- | --- | --- | --- | --- | --- | --- | --- | --- | --- | --- | --- | --- | --- | --- | --- | --- | --- | --- | --- | --- | --- | --- | --- | --- | --- | --- | --- | --- | --- | --- | --- | --- |
| 930 | 1.4.1.7.4.3.2 | **Theme 2** |  | 98d | 2024-03-04 A | 2024-07-17 |  | 92% | 7.42d | 2024-03-04 | 2024-07-17 | 98d |  |  | 33d |  |  | N/A | 1312h | 1212.61h |  | N/A | N/A | -448.67 | 5.21 | Systems Integration Testing (SIT) |  |  |  |  |  |  |
| 931 | 1.4.1.7.4.3.2.1 | Develop Test Scenarios & Test Cases |  | 53d | 2024-03-04 A | 2024-05-15 A | 914 | 100% |  | 2024-03-04 | 2024-05-15 | 53d |  |  |  |  |  | Lee Cox | 424h | 424h |  | SI Test | SI Test, PP |  | 5.21 |  | Complete | COMPLETE |  |  |  |  |
| 932 | 1.4.1.7.4.3.2.2 | Industry Review Workshop |  | 1d | 2024-05-16 A | 2024-05-16 A | 931 | 100% |  | 2024-05-16 | 2024-05-16 | 1d |  |  |  |  |  | Lee Cox | 8h | 8h |  | SI Test, PP | SI Test, PP |  | 5.21 |  | Complete | COMPLETE |  |  |  |  |
| 933 | 1.4.1.7.4.3.2.3 | Industry Consultation Review |  | 7d | 2024-05-20 A | 2024-05-28 A | 932FS+1d | 100% |  | 2024-05-20 | 2024-05-28 | 7d |  |  |  |  |  | Lee Cox | 56h | 56h |  | SI Test, PP | SI Test, PP |  | 5.21 |  | Complete | COMPLETE |  |  |  |  |
| 934 | 1.4.1.7.4.3.2.4 | Review with NFT Working Group |  | 5d | 2024-06-28 | 2024-07-04 | 933FS+22d |  |  | 2024-06-28 | 2024-07-04 | 5d |  |  | 33d | 0d |  | Lee Cox | 40h |  |  | SI Test, PP | SI Test, PP | 1.33 | 5.21 |  | Green | GREEN |  |  |  |  |
| 935 | 1.4.1.7.4.3.2.5 | SIT NFT Scenarios & Test Cases Approved - Theme 2 | milestone | 0d | 2024-07-17 | 2024-07-17 | 934FS+9d |  |  | 2024-07-17 | 2024-07-17 | 0d |  |  | 33d | 0d |  | Lee Cox |  |  |  | SI Test | SI Test, PP | 20.71 | 5.22 | Systems Integration Testing (SIT) | Green | AMBER | 26/6: Obtain approval for test approach and plan | T3-TE-0115 | SITAG |  |
| 936 | 1.4.1.7.4.3.3 | **Theme 3** |  | 98d | 2024-03-04 A | 2024-07-17 |  | 93% | 6.53d | 2024-03-04 | 2024-07-17 | 98d |  |  | 33d |  |  | N/A | 1384h | 1291.73h | -0 | N/A | N/A | -448.67 | 5.21 | Systems Integration Testing (SIT) |  |  |  |  |  |  |
| 937 | 1.4.1.7.4.3.3.1 | Develop Test Scenarios & Test Cases |  | 63d | 2024-03-04 A | 2024-05-29 A | 914 | 100% |  | 2024-03-04 | 2024-05-29 | 63d |  |  |  |  |  | Lee Cox | 504h | 504h |  | SI Test | SI Test, PP |  | 5.21 |  | Complete | COMPLETE |  |  |  |  |
| 938 | 1.4.1.7.4.3.3.2 | Industry Review Workshop |  | 1d | 2024-05-30 A | 2024-05-30 A | 937 | 100% |  | 2024-05-30 | 2024-05-30 | 1d |  |  |  |  |  | Lee Cox | 8h | 8h |  | SI Test, PP | SI Test, PP |  | 5.21 |  | Complete | COMPLETE |  |  |  |  |
| 939 | 1.4.1.7.4.3.3.3 | Industry Consultation Review |  | 6d | 2024-06-10 A | 2024-06-17 A | 938FS+6d | 100% |  | 2024-06-10 | 2024-06-17 | 6d |  |  |  |  |  | Lee Cox | 48h | 48h |  | SI Test, PP | SI Test, PP |  | 5.21 |  | Complete | COMPLETE |  |  |  |  |
| 940 | 1.4.1.7.4.3.3.4 | Review with NFT Working Group |  | 5d | 2024-06-28 | 2024-07-04 | 939FS+8d |  |  | 2024-06-28 | 2024-07-04 | 5d |  |  | 33d | 0d |  | Lee Cox | 40h |  |  | SI Test, PP | SI Test, PP | 1.33 | 5.21 |  | Green | GREEN |  |  |  |  |
| 941 | 1.4.1.7.4.3.3.5 | SIT NFT Scenarios & Test Cases Approved - Theme 3 | milestone | 0d | 2024-07-17 | 2024-07-17 | 940FS+9d |  |  | 2024-07-17 | 2024-07-17 | 0d |  |  | 33d | 0d |  | Lee Cox |  |  |  | SI Test | SI Test, PP | 20.71 | 5.22 | Systems Integration Testing (SIT) | Green | AMBER | 26/6: Obtain approval for test approach and plan | T3-TE-0114 | SITAG |  |
| 942 | 1.4.1.7.4.4 | **Environments (SIT B)** |  | 0d | 2024-08-27 | 2024-08-27 |  |  |  | 2024-08-27 | 2024-08-27 | 0d | 2024-07-30 | 2024-08-05 | 719d |  |  | N/A |  |  | -0 | N/A | N/A |  | 5.0 | Systems Integration Testing (SIT) |  |  |  |  |  |  |
| 943 | 1.4.1.7.4.4.1 | **PP Environments (SIT B)** |  | 0d | 2024-08-27 | 2024-08-27 |  |  |  | 2024-08-27 | 2024-08-27 | 0d | 2024-07-30 | 2024-08-05 | 719d |  |  | N/A |  |  | -0 | N/A | N/A |  | 5.0 | Systems Integration Testing (SIT) |  |  |  |  |  |  |
| 944 | 1.4.1.7.4.4.1.1 | Deployment of MHHS solution code to SIT B environments | milestone | 0d | 2024-08-27 | 2024-08-27 |  |  |  | 2024-08-27 | 2024-08-27 | 0d | 2024-07-30 | 2024-08-05 | 719d | 0d | start no earlier than 2024-08-27 | Simon Berry |  |  |  | PP | SI Test | 61.33 | 5.21 | Systems Integration Testing (SIT) | Green | GREEN | 26/3/24: Lee said change to SB and align to IR7 |  |  |  |
| 945 | 1.4.1.7.4.4.2 | **SI Environments (SIT B)** |  | 0d | 2024-08-27 | 2024-08-27 |  |  |  | 2024-08-27 | 2024-08-27 | 0d | 2024-07-30 | 2024-08-05 | 719d |  |  | N/A |  |  | -0 | N/A | N/A |  | 5.0 | Systems Integration Testing (SIT) |  |  |  |  |  |  |
| 946 | 1.4.1.7.4.4.2.1 | Coordinate deployment of MHHS solution code to SIT Participants' SIT B environments | milestone | 0d | 2024-08-27 | 2024-08-27 | 944SS |  |  | 2024-08-27 | 2024-08-27 | 0d | 2024-07-30 | 2024-08-05 | 719d |  |  | Simon Berry |  |  |  | SI Test | PP | 61.33 | 5.21 | Systems Integration Testing (SIT) | Green | GREEN |  |  |  |  |
| 947 | 1.4.1.7.4.5 | **SIT Non-Functional Test Readiness Report** |  | 44d | 2024-06-25 A | 2024-08-23 |  | 3% | 42.65d | 2024-06-25 | 2024-08-23 | 44d | 2024-06-25 | 2024-08-19 | 6d |  |  | N/A | 2064h | 63.55h | -0 | N/A | N/A |  | 5.0 | Systems Integration Testing (SIT) |  |  |  |  |  |  |
| 948 | 1.4.1.7.4.5.1 | **PP SIT Non-Functional Test Readiness Report** |  | 44d | 2024-06-25 A | 2024-08-23 |  | 3% | 42.74d | 2024-06-25 | 2024-08-23 | 44d | 2024-06-25 | 2024-08-05 | 6d |  |  | N/A | 912h | 26.06h | -0 | N/A | N/A |  | 5.0 | Systems Integration Testing (SIT) |  |  |  |  |  |  |
| 949 | 1.4.1.7.4.5.1.1 | Develop draft Test Readiness Report and submit to Programme for assurance |  | 20d | 2024-06-25 A | 2024-07-22 |  | 10% | 18d | 2024-06-25 | 2024-07-22 | 20d | 2024-06-25 | 2024-07-22 | 5d | 0d | start no earlier than 2024-06-25 | Lee Cox | 160h | 16h |  | PP | SI Test |  | 5.0 | Systems Integration Testing (SIT) | Green | GREEN |  |  |  |  |
| 950 | 1.4.1.7.4.5.1.2 | Placing Reliance Stage 2 Review |  | 40d | 2024-07-01 | 2024-08-23 | 949SS+4d |  |  | 2024-07-01 | 2024-08-23 | 40d |  |  | 6d | 1d |  | Lee Cox | 320h |  |  | SI Test | PP | 4.33 | 5.12 | Systems Integration Testing (SIT) | Green | GREEN |  |  |  |  |
| 951 | 1.4.1.7.4.5.1.3 | Finalise Test Readiness Report and submit to Programme for assurance |  | 10d | 2024-07-23 | 2024-08-05 | 949 |  |  | 2024-07-23 | 2024-08-05 | 10d | 2024-07-23 | 2024-08-05 | 5d | 0d |  | Lee Cox | 80h |  |  | PP | SI Test | 26.33 | 5.0 | Systems Integration Testing (SIT) | Green | GREEN |  |  |  |  |
| 952 | 1.4.1.7.4.5.2 | **SI SIT Non-Functional Test Readiness Report** |  | 40d | 2024-06-25 A | 2024-08-19 |  | 3% | 38.67d | 2024-06-25 | 2024-08-19 | 40d | 2024-06-25 | 2024-08-19 | 5d |  |  | N/A | 800h | 26.67h |  | N/A | N/A |  | 5.0 | Systems Integration Testing (SIT) |  |  |  |  |  |  |
| 953 | 1.4.1.7.4.5.2.1 | Assure Test Participants' Test Readiness Reports |  | 35d | 2024-06-25 A | 2024-08-12 | 949SS, 951FF+5d | 6% | 33d | 2024-06-25 | 2024-08-12 | 35d | 2024-06-25 | 2024-08-12 | 5d | 0d |  | Lee Cox | 280h | 16h |  | SI Test | PP,IPA |  | 5.0 | Systems Integration Testing (SIT) | Green | GREEN |  |  |  |  |
| 954 | 1.4.1.7.4.5.2.2 | Develop Overarching SIT Non-Functional Test Readiness Report |  | 20d | 2024-07-16 | 2024-08-12 | 953FF |  |  | 2024-07-16 | 2024-08-12 | 20d | 2024-07-16 | 2024-08-12 | 5d | 0d |  | Lee Cox | 160h |  |  | SI Test |  | 19.33 | 5.0 | Systems Integration Testing (SIT) | Green | GREEN |  |  |  |  |
| 955 | 1.4.1.7.4.5.2.3 | Artefact review (via SITAG) and updates |  | 5d | 2024-08-13 | 2024-08-19 | 954 |  |  | 2024-08-13 | 2024-08-19 | 5d | 2024-08-13 | 2024-08-19 | 5d | 0d |  | Lee Cox | 40h |  |  | SI Test | PP,IPA | 47.33 | 5.0 | Systems Integration Testing (SIT) | Green | GREEN |  |  |  |  |
| 956 | 1.4.1.7.4.6 | SIT Non-Functional Testing Preparation Complete | milestone | 0d | 2024-08-26 | 2024-08-26 | 955FF+5d, 794, 347, 950, 929, 935, 941 |  |  | 2024-08-26 | 2024-08-26 | 0d | 2024-08-26 | 2024-08-26 | 5d | 0d |  | Lee Cox |  |  |  | SI Test | PP,IPA | 60.71 | 5.0 | Systems Integration Testing (SIT) | Green | AMBER | 26/6: Obtain approval for test approach and plan | T2-TE-0700 | SITAG | T2 |

Notes:
- 935: 23/1 - New milestone added because of NFT themed delivery approach. To go to April SITAG for approval 17/4: Approved new milestone at SITAG on 17/4/24 21/5: At risk because deferment of NF test approach and plan / Impact: 26/6: Risks the start of SIT non-functional testing / Issue: 26/8: At risk because test approach and plan not yet approved
- 941: 23/1 - New milestone added because of NFT themed delivery approach. To go to April SITAG for approval 17/4: Approved new milestone at SITAG on 17/4/24 21/5: At risk because deferment of NF test approach and plan / Impact: 26/6: Risks the start of SIT non-functional testing / Issue: 26/8: At risk because test approach and plan not yet approved
- 944: 25/3: SB - Date aligns to IR8 code delivery for SIT B
- 946: 25/3: SB - Date aligns to IR8 code delivery for SIT B
- 956: 21/5: At risk because deferment of NF test approach and plan / Impact: 26/6: Risks the ability to achieve preparation complete for SIT non-functional testing / Issue: 26/8: At risk because test approach and plan not yet approved

| ID | WBS | Task | Type | Duration | Start | Finish | Predecessors | Complete | Remaining | Baseline start | Baseline finish | Baseline duration | Baseline 1 start | Baseline 1 finish | Total slack | Free slack | Constraint | Resources | Work | Actual work | Baseline cost | Responsible | Involved | Update Version | MHHS Programme Phase | Sched Status | RAG | Artefact ID | Milestone ID | Text29 | Tier | Task Status |
| --- | --- | --- | --- | --- | --- | --- | --- | --- | --- | --- | --- | --- | --- | --- | --- | --- | --- | --- | --- | --- | --- | --- | --- | --- | --- | --- | --- | --- | --- | --- | --- | --- |
| 957 | 1.4.1.7.5 | **SIT Operational Preparation** |  | 170d | 2024-02-01 A | 2024-09-25 |  | 86% | 23.79d | 2024-02-01 | 2025-03-03 | 283d | 2023-08-03 | 2025-03-10 | 697d |  |  | N/A | 6648h | 5173.25h | -0 | N/A | N/A | 5.0 | Systems Integration Testing (SIT) |  |  |  |  |  |  |  |
| 958 | 1.4.1.7.5.1 | **Test Approach & Plan** |  | 75d | 2024-02-01 A | 2024-05-15 A |  | 100% |  | 2024-02-01 | 2024-05-15 | 75d | 2024-02-01 | 2024-05-15 |  |  |  | N/A | 1120h | 1120h | -0 | N/A | N/A | 5.0 | Systems Integration Testing (SIT) |  |  |  |  |  |  |  |
| 959 | 1.4.1.7.5.1.1 | Develop document with SITWG |  | 25d | 2024-02-01 A | 2024-03-06 A |  | 100% |  | 2024-02-01 | 2024-03-06 | 25d | 2024-02-01 | 2024-03-06 |  |  | must start on 2024-02-01 | Lee Cox | 200h | 200h |  | SI Test |  | 5.0 | Systems Integration Testing (SIT) | Complete | COMPLETE |  |  |  |  |  |
| 960 | 1.4.1.7.5.1.2 | Draft document review with Code Bodies |  | 4d | 2024-03-21 A | 2024-03-26 A | 959FS+10d | 100% |  | 2024-03-07 | 2024-03-20 | 10d | 2024-03-07 | 2024-03-20 |  |  |  | Lee Cox | 32h | 32h |  | SI Test | Code Bodies | 5.0 | Systems Integration Testing (SIT) | Complete | COMPLETE |  |  |  |  |  |
| 961 | 1.4.1.7.5.1.3 | Industry Consultation |  | 10d | 2024-03-27 A | 2024-04-09 A | 960 | 100% |  | 2024-03-27 | 2024-04-09 | 10d |  |  |  |  |  | Lee Cox | 80h | 80h |  | PP |  | 5.1 | Systems Integration Testing (SIT) | Complete | COMPLETE |  |  |  |  |  |
| 962 | 1.4.1.7.5.1.4 | Artefact review (via SITAG) and updates |  | 26d | 2024-04-10 A | 2024-05-15 A | 961 | 100% |  | 2024-04-04 | 2024-05-15 | 30d | 2024-03-21 | 2024-05-15 |  |  |  | Lee Cox | 208h | 208h |  | SI Test | PP,IPA,Code Bodies | 5.0 | Systems Integration Testing (SIT) | Complete | COMPLETE |  |  |  |  |  |
| 963 | 1.4.1.7.5.1.5 | SIT Operational Testing Test Approach & Plan approved | milestone | 0d | 2024-05-15 A | 2024-05-15 A | 962 | 100% |  | 2024-05-15 | 2024-05-15 | 0d | 2024-05-15 | 2024-05-15 |  |  |  | Lee Cox |  |  |  | SI Test | PP | 5.24 | Systems Integration Testing (SIT) | Complete | COMPLETE | MHHS-ART073 | T3-TE-0029 | SITAG | T3 |  |
| 964 | 1.4.1.7.5.2 | **Test Data Approach & Plan** |  | 36d | 2024-03-27 A | 2024-05-15 A |  | 100% |  | 2024-03-27 | 2024-05-15 | 36d | 2024-03-21 | 2024-05-15 |  |  |  | N/A | 576h | 576h | -0 | N/A | N/A | 5.0 | Systems Integration Testing (SIT) |  |  |  |  |  |  |  |
| 965 | 1.4.1.7.5.2.1 | Industry Consultation |  | 10d | 2024-03-27 A | 2024-04-09 A | 961SS | 100% |  | 2024-03-27 | 2024-04-09 | 10d |  |  |  |  |  | Richard Puddephatt | 80h | 80h |  | PP |  | 5.1 | Systems Integration Testing (SIT) | Complete | COMPLETE |  |  |  |  |  |
| 966 | 1.4.1.7.5.2.2 | Artefact review (via SITAG) and updates |  | 26d | 2024-04-10 A | 2024-05-15 A | 965 | 100% |  | 2024-04-10 | 2024-05-15 | 26d | 2024-03-21 | 2024-05-15 |  |  |  | Richard Puddephatt | 208h | 208h |  | SI Test |  | 5.0 | Systems Integration Testing (SIT) | Complete | COMPLETE |  |  |  |  |  |
| 967 | 1.4.1.7.5.2.3 | SIT Operational Testing Test Data Approach & Plan approved | milestone | 0d | 2024-05-15 A | 2024-05-15 A | 966 | 100% |  | 2024-05-15 | 2024-05-15 | 0d | 2024-05-15 | 2024-05-15 |  |  |  | Richard Puddephatt |  |  |  | SI Test | PP,IPA | 5.0 | Systems Integration Testing (SIT) | Complete | COMPLETE |  |  |  |  |  |
| 968 | 1.4.1.7.5.3 | **Test scenarios & Test Cases** |  | 96d | 2024-04-10 A | 2024-08-21 |  | 84% | 15d | 2024-04-10 | 2024-08-21 | 96d | 2023-07-24 | 2024-01-17 | 25d |  |  | N/A | 3176h | 2484.16h | -0 | N/A | N/A | 5.21 | Systems Integration Testing (SIT) |  |  |  |  |  |  |  |
| 969 | 1.4.1.7.5.3.1 | **Theme 1** |  | 71d | 2024-04-10 A | 2024-07-17 |  | 82% | 12.68d | 2024-04-10 | 2024-07-17 | 71d |  |  | 50d |  |  | N/A | 792h | 424h | -0 | N/A | N/A | 5.21 | Systems Integration Testing (SIT) |  |  |  |  |  |  | -448.67 |
| 970 | 1.4.1.7.5.3.1.1 | Develop Test Scenarios & Test Cases |  | 16d | 2024-04-10 A | 2024-05-01 A | 961 | 100% |  | 2024-04-10 | 2024-05-01 | 16d |  |  |  |  |  | Lee Cox | 128h | 128h |  | SI Test | SI Test, PP | 5.21 |  | Complete | COMPLETE |  |  |  |  |  |
| 971 | 1.4.1.7.5.3.1.2 | Industry Review Workshop |  | 1d | 2024-05-02 A | 2024-05-02 A | 970 | 100% |  | 2024-05-02 | 2024-05-02 | 1d |  |  |  |  |  | Lee Cox | 8h | 8h |  | SI Test, PP | SI Test, PP | 5.21 |  | Complete | COMPLETE |  |  |  |  |  |
| 972 | 1.4.1.7.5.3.1.3 | Industry Consultation Review |  | 6d | 2024-05-28 A | 2024-06-04 A | 971FS+17d | 100% |  | 2024-05-28 | 2024-06-04 | 6d |  |  |  |  |  | Lee Cox | 48h | 48h |  | SI Test, PP | SI Test, PP | 5.21 |  | Complete | COMPLETE |  |  |  |  |  |
| 973 | 1.4.1.7.5.3.1.4 | Review with SIT Working Group |  | 5d | 2024-06-27 | 2024-07-03 | 972FS+16d |  |  | 2024-06-27 | 2024-07-03 | 5d |  |  | 50d | 0d |  | Lee Cox | 40h |  |  | SI Test, PP | SI Test, PP | 5.21 |  | Green | GREEN |  |  |  |  | 0.33 |
| 974 | 1.4.1.7.5.3.1.5 | SIT Operational Scenarios & Test Cases Approved - Theme 1 | milestone | 0d | 2024-07-17 | 2024-07-17 | 973FS+10d |  |  | 2024-07-17 | 2024-07-17 | 0d |  |  | 50d | 0d |  | Lee Cox |  |  |  | SI Test | SI Test, PP | 5.22 | Systems Integration Testing (SIT) | Green | GREEN |  | T3-TE-0117 | SITAG |  | 20.71 |
| 975 | 1.4.1.7.5.3.2 | **Theme 2** |  | 71d | 2024-04-10 A | 2024-07-17 |  | 88% | 8.26d | 2024-04-10 | 2024-07-17 | 71d |  |  | 50d |  |  | N/A | 912h | 805.95h |  | N/A | N/A | 5.21 | Systems Integration Testing (SIT) |  |  |  |  |  |  | -448.67 |
| 976 | 1.4.1.7.5.3.2.1 | Develop Test Scenarios & Test Cases |  | 31d | 2024-04-10 A | 2024-05-22 A | 961 | 100% |  | 2024-04-10 | 2024-05-22 | 31d |  |  |  |  |  | Lee Cox | 248h | 248h |  | SI Test | SI Test, PP | 5.21 |  | Complete | COMPLETE |  |  |  |  |  |
| 977 | 1.4.1.7.5.3.2.2 | Industry Review Workshop |  | 1d | 2024-05-23 A | 2024-05-23 A | 976 | 100% |  | 2024-05-23 | 2024-05-23 | 1d |  |  |  |  |  | Lee Cox | 8h | 8h |  | SI Test, PP | SI Test, PP | 5.21 |  | Complete | COMPLETE |  |  |  |  |  |
| 978 | 1.4.1.7.5.3.2.3 | Industry Consultation Review |  | 6d | 2024-06-04 A | 2024-06-11 A | 977FS+7d | 100% |  | 2024-06-04 | 2024-06-11 | 6d |  |  |  |  |  | Lee Cox | 48h | 48h |  | SI Test, PP | SI Test, PP | 5.21 |  | Complete | COMPLETE |  |  |  |  |  |
| 979 | 1.4.1.7.5.3.2.4 | Review with SIT Working Group |  | 5d | 2024-06-27 | 2024-07-03 | 978FS+11d |  |  | 2024-06-27 | 2024-07-03 | 5d |  |  | 50d | 0d |  | Lee Cox | 40h |  |  | SI Test, PP | SI Test, PP | 5.21 |  | Green | GREEN |  |  |  |  | 0.33 |
| 980 | 1.4.1.7.5.3.2.5 | SIT Operational Scenarios & Test Cases Approved - Theme 2 | milestone | 0d | 2024-07-17 | 2024-07-17 | 979FS+10d |  |  | 2024-07-17 | 2024-07-17 | 0d |  |  | 50d | 0d |  | Lee Cox |  |  |  | SI Test | SI Test, PP | 5.22 | Systems Integration Testing (SIT) | Green | GREEN |  | T3-TE-0118 | SITAG |  | 20.71 |

Notes:
- 963: 26/3 - At risk because of tight delivery schedule
- 974: 23/1 - New milestone added because of NFT themed delivery approach. To go to April SITAG for approval. 17/4: Approved as new milestone at SITAG on 17/4/24
- 980: 23/1 - New milestone added because of Operational themed delivery approach. To go to April SITAG for approval. 17/4: Approved as new milestone at SITAG on 17/4/24

| ID | WBS | Task | Type | Duration | Start | Finish | Predecessors | Complete | Remaining | Baseline start | Baseline finish | Baseline duration | Baseline 1 start | Baseline 1 finish | Total slack | Free slack | Constraint | Resources | Work | Actual work | Baseline cost | Responsible | Involved | Task Status | Update Version | MHHS Programme Phase | Sched Status | RAG | Milestone ID | Text29 | Tier | Artefact ID | Text3 |
| --- | --- | --- | --- | --- | --- | --- | --- | --- | --- | --- | --- | --- | --- | --- | --- | --- | --- | --- | --- | --- | --- | --- | --- | --- | --- | --- | --- | --- | --- | --- | --- | --- | --- |
| 981 | 1.4.1.7.5.3.3 | **Theme 3** |  | 96d | 2024-04-10 A | 2024-08-21 |  | 82% | 16.84d | 2024-04-10 | 2024-08-21 | 96d |  |  | 25d |  |  | N/A | 1224h | 1040.81h |  | N/A | N/A | -448.67 | 5.21 | Systems Integration Testing (SIT) |  |  |  |  |  |  |  |
| 982 | 1.4.1.7.5.3.3.1 | Develop Test Scenarios & Test Cases |  | 46d | 2024-04-10 A | 2024-06-12 A | 961 | 100% |  | 2024-04-10 | 2024-06-12 | 46d |  |  |  |  |  | Lee Cox | 368h | 368h |  | SI Test | SI Test, PP |  | 5.21 |  | Complete | COMPLETE |  |  |  |  |  |
| 983 | 1.4.1.7.5.3.3.2 | Industry Review Workshop |  | 1d | 2024-06-13 A | 2024-06-13 A | 982 | 100% |  | 2024-06-13 | 2024-06-13 | 1d |  |  |  |  |  | Lee Cox | 8h | 8h |  | SI Test, PP | SI Test, PP |  | 5.21 |  | Complete | COMPLETE |  |  |  |  |  |
| 984 | 1.4.1.7.5.3.3.3 | Industry Consultation Review |  | 5d | 2024-07-15 | 2024-07-19 | 983FS+21d |  |  | 2024-06-24 | 2024-07-01 | 6d |  |  | 25d | 0d |  | Lee Cox | 40h |  |  | SI Test, PP | SI Test, PP | 18.33 | 5.21 |  | Red | RED |  |  |  |  |  |
| 985 | 1.4.1.7.5.3.3.4 | Review with SIT Working Group |  | 5d | 2024-07-25 | 2024-07-31 | 984FS+3d |  |  | 2024-07-25 | 2024-07-31 | 5d |  |  | 25d | 0d |  | Lee Cox | 40h |  |  | SI Test, PP | SI Test, PP | 28.33 | 5.21 |  | Green | GREEN |  |  |  |  |  |
| 986 | 1.4.1.7.5.3.3.5 | SIT Operational Scenarios & Test Cases Approved - Theme 3 | milestone | 0d | 2024-08-21 | 2024-08-21 | 985FS+15d |  |  | 2024-08-21 | 2024-08-21 | 0d |  |  | 25d | 0d |  | Lee Cox |  |  |  | SI Test | SI Test, PP | 55.71 | 5.22 | Systems Integration Testing (SIT) | Green | GREEN | T3-TE-0114 | SITAG |  |  |  |
| 987 | 1.4.1.7.5.4 | **Environments (SIT B)** |  | 0d | 2024-08-27 | 2024-08-27 |  |  |  | 2024-08-27 | 2024-08-27 | 0d | 2024-09-03 | 2024-09-09 | 719d |  |  | N/A |  |  | -0 | N/A | N/A |  | 5.0 | Systems Integration Testing (SIT) |  |  |  |  |  |  |  |
| 988 | 1.4.1.7.5.4.1 | **PP Environments (SIT B)** |  | 0d | 2024-08-27 | 2024-08-27 |  |  |  | 2024-08-27 | 2024-08-27 | 0d | 2024-09-03 | 2024-09-09 | 719d |  |  | N/A |  |  | -0 | N/A | N/A |  | 5.0 | Systems Integration Testing (SIT) |  |  |  |  |  |  |  |
| 989 | 1.4.1.7.5.4.1.1 | Deployment of MHHS solution code to SIT B environments | milestone | 0d | 2024-08-27 | 2024-08-27 |  |  |  | 2024-08-27 | 2024-08-27 | 0d | 2024-09-03 | 2024-09-09 | 719d | 0d | start no earlier than 2024-08-27 | Simon Berry |  |  |  | PP | SI Test | 61.33 | 5.21 | Systems Integration Testing (SIT) | Green | GREEN |  |  |  |  |  |
| 990 | 1.4.1.7.5.4.2 | **SI Environments (SIT B)** |  | 0d | 2024-08-27 | 2024-08-27 |  |  |  | 2024-08-27 | 2024-08-27 | 0d | 2024-09-03 | 2024-09-09 | 719d |  |  | N/A |  |  | -0 | N/A | N/A |  | 5.0 | Systems Integration Testing (SIT) |  |  |  |  |  |  |  |
| 991 | 1.4.1.7.5.4.2.1 | Coordinate deployment of MHHS solution code to SIT Participants' SIT B environments | milestone | 0d | 2024-08-27 | 2024-08-27 | 989SS |  |  | 2024-08-27 | 2024-08-27 | 0d | 2024-09-03 | 2024-09-09 | 719d |  |  | Simon Berry |  |  |  | SI Test | PP | 61.33 | 5.21 | Systems Integration Testing (SIT) | Green | GREEN |  |  |  |  |  |
| 992 | 1.4.1.7.5.5 | **SIT Operational Test Readiness Report** |  | 19d | 2024-08-30 | 2024-09-25 |  |  |  | 2024-08-05 | 2025-03-03 | 151d | 2025-01-07 | 2025-03-03 | 0d |  |  | N/A | 416h |  | -0 | N/A | N/A |  | 5.0 | Systems Integration Testing (SIT) |  |  |  |  |  |  |  |
| 993 | 1.4.1.7.5.5.1 | **PP SIT Operational Test Readiness Report** |  | 0d | 2024-08-30 | 2024-08-30 |  |  |  | 2024-08-05 | 2025-02-03 | 131d | 2025-01-07 | 2025-02-17 | 0d |  |  | N/A |  |  | -0 | N/A | N/A |  | 5.0 | Systems Integration Testing (SIT) |  |  |  |  |  |  |  |
| 994 | 1.4.1.7.5.5.1.1 | Test Readiness Report submitted to Programme for assurance | milestone | 0d | 2024-08-30 | 2024-08-30 |  |  |  | 2025-01-07 | 2025-02-03 | 20d | 2025-01-07 | 2025-02-03 | 0d |  | start no earlier than 2024-08-30 | Lee Cox |  |  |  | PP | SI Test | 64.33 | 5.0 | Systems Integration Testing (SIT) | Green | GREEN |  |  |  |  |  |
| 995 | 1.4.1.7.5.5.2 | **SI SIT Operational Test Readiness Report** |  | 19d | 2024-08-30 | 2024-09-25 |  |  |  | 2025-01-07 | 2025-03-03 | 40d | 2025-01-07 | 2025-03-03 | 0d |  |  | N/A | 264h |  |  | N/A | N/A |  | 5.0 | Systems Integration Testing (SIT) |  |  |  |  |  |  |  |
| 996 | 1.4.1.7.5.5.2.1 | Assure Test Participants' Test Readiness Reports |  | 5d | 2024-08-30 | 2024-09-05 | 994 |  |  | 2025-01-07 | 2025-02-24 | 35d | 2025-01-07 | 2025-02-24 | 0d |  |  | Lee Cox | 40h |  |  | SI Test | PP,IPA | 64.33 | 5.0 | Systems Integration Testing (SIT) | Green | GREEN |  |  |  |  |  |
| 997 | 1.4.1.7.5.5.2.2 | Develop Overarching SIT Operational Test Readiness Report |  | 4d | 2024-09-13 | 2024-09-18 | 996SS+10d |  |  | 2025-01-28 | 2025-02-24 | 20d | 2025-01-28 | 2025-02-24 | 0d |  |  | Lee Cox | 32h |  |  | SI Test |  | 78.33 | 5.0 | Systems Integration Testing (SIT) | Green | GREEN |  |  |  |  |  |
| 998 | 1.4.1.7.5.5.2.3 | Artefact review (via SITAG) and updates |  | 5d | 2024-09-19 | 2024-09-25 | 997 |  |  | 2025-02-25 | 2025-03-03 | 5d | 2025-02-25 | 2025-03-03 | 0d |  |  | Lee Cox | 40h |  |  | SI Test | PP,IPA | 84.33 | 5.0 | Systems Integration Testing (SIT) | Green | GREEN |  |  |  |  |  |
| 999 | 1.4.1.7.5.6 | SIT Operational Testing Preparation Complete | milestone | 0d | 2024-09-25 | 2024-09-25 | 998, 364, 974, 980, 986 |  |  | 2024-09-25 | 2024-09-25 | 0d | 2025-03-10 | 2025-03-10 | 0d |  |  | Lee Cox |  |  |  | SI Test | PP,IPA | 90.71 | 5.10 | Systems Integration Testing (SIT) | Green | GREEN | T2-TE-0750 | SITAG | T2 |  |  |
| 1000 | 1.4.2 | **SIT Execution** |  | 390d | 2023-10-30 A | 2025-04-25 |  | 16% | 326.23d | 2023-10-30 | 2025-04-25 | 390d | 2023-10-30 | 2025-04-25 | 545d |  |  | N/A | 42280h | 7365.33h | -0 | N/A | N/A |  | 5.0 | Systems Integration Testing (SIT) |  |  |  |  |  |  |  |
| 1001 | 1.4.2.1 | System Integration Testing Start (M9) | milestone | 0d | 2023-10-30 A | 2023-10-30 A | 633FS+5d, 524, 547 | 100% |  | 2023-10-30 | 2023-10-30 | 0d | 2023-10-30 | 2023-10-30 |  |  | must start on 2023-10-30 | Lee Cox |  |  |  | CPT | PMO |  | 5.11 | Systems Integration Testing (SIT) | Complete | COMPLETE | T1-TE-1000 | PSG | T1 | MHHS-ART071 |  |
| 1002 | 1.4.2.2 | **SIT Component Integration Testing** |  | 96d | 2023-10-30 A | 2024-03-11 |  | 99% | 0d | 2023-10-30 | 2024-03-08 | 95d | 2023-10-30 | 2024-03-08 | 0d |  |  | N/A | 1976h | 1733.71h |  | N/A | N/A |  | 5.0 | Systems Integration Testing (SIT) |  |  |  |  |  |  | D24A - Industry Integration Test Completion Report |
| 1003 | 1.4.2.2.1 | SIT Component Integration Testing Start | milestone | 0d | 2023-10-30 A | 2023-10-30 A | 1001 | 100% |  | 2023-10-30 | 2023-10-30 | 0d | 2023-10-30 | 2023-10-30 |  |  |  | Lee Cox |  |  |  | SI Test | PP |  | 5.11 | Systems Integration Testing (SIT) | Complete | COMPLETE |  |  |  |  |  |
| 1004 | 1.4.2.2.2 | Component Integration Testing Interval 1 Start | milestone | 0d | 2023-10-30 A | 2023-10-30 A | 633SS+1d, 554, 558, 562, 115 | 100% |  | 2023-10-30 | 2023-10-30 | 0d | 2023-10-30 | 2023-10-30 |  |  |  | Lee Cox |  |  |  | SI Test | PP |  | 5.11 | Systems Integration Testing (SIT) | Complete | COMPLETE | T3-TE-0060 | SITAG | T3 | MHHS-ART071 |  |
| 1005 | 1.4.2.2.3 | Component Integration Testing Interval 2 Start | milestone | 0d | 2023-11-13 A | 2023-11-13 A | 660SS+5d, 554, 562, 558, 115 | 100% |  | 2023-11-13 | 2023-11-13 | 0d | 2023-11-13 | 2023-11-13 |  |  |  | Lee Cox |  |  |  | SI Test | PP |  | 5.12 | Systems Integration Testing (SIT) | Complete | COMPLETE | T3-TE-0061 | SITAG | T3 |  |  |
| 1006 | 1.4.2.2.4 | Component Integration Testing Interval 3 Start | milestone | 0d | 2023-11-27 A | 2023-11-27 A | 692SS+5d, 554, 558, 562, 115 | 100% |  | 2023-11-27 | 2023-11-27 | 0d | 2023-11-27 | 2023-11-27 |  |  |  | Lee Cox |  |  |  | SI Test | PP |  | 5.0 | Systems Integration Testing (SIT) | Complete | COMPLETE | T3-TE-0062 | SITAG | T3 |  |  |
| 1007 | 1.4.2.2.5 | Component Integration Testing Interval 4 Start | milestone | 0d | 2023-12-11 A | 2023-12-11 A | 724SS+5d, 554, 558, 562, 115 | 100% |  | 2023-12-11 | 2023-12-11 | 0d | 2023-12-11 | 2023-12-11 |  |  |  | Lee Cox |  |  |  | SI Test | PP |  | 5.0 | Systems Integration Testing (SIT) | Complete | COMPLETE | T3-TE-0063 | SITAG | T3 |  |  |
| 1008 | 1.4.2.2.6 | Component Integration Testing Interval 5 Start | milestone | 0d | 2024-01-15 A | 2024-01-15 A | 756SS+5d, 554, 558, 562, 115 | 100% |  | 2024-01-15 | 2024-01-15 | 0d | 2024-01-15 | 2024-01-15 |  |  |  | Lee Cox |  |  |  | SI Test | PP |  | 5.0 | Systems Integration Testing (SIT) | Complete | COMPLETE | T3-TE-0064 |  | T3 |  |  |
| 1009 | 1.4.2.2.7 | Component Integration Testing Interval 6 Start | milestone | 0d | 2024-01-29 A | 2024-01-29 A | 554, 558, 562, 788, 115, 600 | 100% |  | 2024-01-29 | 2024-01-29 | 0d | 2024-01-29 | 2024-01-29 |  |  | must start on 2024-01-29 | Lee Cox |  |  |  | SI Test | PP |  | 5.0 | Systems Integration Testing (SIT) | Complete | COMPLETE | T3-TE-0065 | SITAG | T3 |  |  |
| 1010 | 1.4.2.2.8 | SIT Component Integration Testing Execution |  | 85d | 2023-10-30 A | 2024-02-23 A | 1004SS | 100% |  | 2023-10-30 | 2024-02-23 | 85d | 2023-10-30 | 2024-02-23 |  |  | must start on 2023-10-30 | Lee Cox | 680h | 680h |  | SI Test | PP |  | 5.0 | Systems Integration Testing (SIT) | Complete | COMPLETE |  |  |  |  | D24A - Industry Integration Test Completion Report |
| 1011 | 1.4.2.2.9 | SIT Component Integration Testing End (incl. confirmation that PPs have submitted their Test Completion Reports to Programme for assurance) | milestone | 0d | 2024-02-23 A | 2024-02-23 A | 1010FF | 100% |  | 2024-02-23 | 2024-02-23 | 0d | 2024-02-23 | 2024-02-23 |  |  |  | Lee Cox |  |  |  | SI Test | PP |  | 5.19 | Systems Integration Testing (SIT) | Complete | COMPLETE | T3-TE-0032 | SITAG | T3 | MHHS-ART074 |  |
| 1012 | 1.4.2.2.10 | Assurance of PPs Test Completion Reports |  | 30d | 2024-01-22 A | 2024-03-01 A | 1011FF+5d | 100% |  | 2024-01-22 | 2024-03-01 | 30d | 2024-01-22 | 2024-03-01 |  |  |  | Lee Cox | 240h | 240h |  | SI Test | PP |  | 5.19 | Systems Integration Testing (SIT) | Complete | COMPLETE |  |  |  |  |  |

Notes:
- 986: 23/1 - New milestone added because of Operational themed delivery approach. To go to April SITAG for approval. 17/4: Approved as new milestone at SITAG on 17/4/24
- 999: 6/10 - Needs to go to TMAG for date change. Date needs changing because error on the baseline. Approved for date change at TMAG on 23/10/23
- 1001: On track, however there are a number of associated risks that are being mitigated by the Programme
- 1004: On track, however there are a number of associated risks that are being mitigated by the Programme
- 1007: 13/12 - Complete noting a work-off plan and revised CIT Approach being taken to Dec TMAG
- 1008: 2/1//24 - Approved at 20/12 TMAG based on CIT Gov approach change
- 1009: 2/1//24 - Approved at 20/12 TMAG based on CIT Gov approach change
- 1011: All PPs are expected to complete their CIT by the target date on 09-Feb

| ID | WBS | Task | Type | Duration | Start | Finish | Predecessors | Complete | Remaining | Baseline start | Baseline finish | Baseline duration | Baseline 1 start | Baseline 1 finish | Total slack | Free slack | Resources | Work | Actual work | Baseline cost | Responsible | Involved | Update Version | MHHS Programme Phase | Sched Status | RAG | Artefact ID | Milestone ID | Text29 | Tier | Text3 | Task Status |
| --- | --- | --- | --- | --- | --- | --- | --- | --- | --- | --- | --- | --- | --- | --- | --- | --- | --- | --- | --- | --- | --- | --- | --- | --- | --- | --- | --- | --- | --- | --- | --- | --- |
| 1013 | 1.4.2.2.11 | **SIT CI Test Completion Report** |  | 18d | 2024-02-07 A | 2024-03-01 A |  | 100% |  | 2024-02-07 | 2024-03-01 | 18d | 2024-02-07 | 2024-03-01 |  |  | N/A | 288h | 288h |  | N/A | N/A | 5.0 | Systems Integration Testing (SIT) |  |  |  |  |  |  |  |  |
| 1014 | 1.4.2.2.11.1 | Develop document |  | 13d | 2024-02-07 A | 2024-02-23 A | 1011FF | 100% |  | 2024-02-07 | 2024-02-23 | 13d | 2024-02-07 | 2024-02-23 |  |  | Lee Cox | 104h | 104h |  | SI Test |  | 5.19 | Systems Integration Testing (SIT) | Complete | COMPLETE |  |  |  |  |  |  |
| 1015 | 1.4.2.2.11.2 | Review & agree document |  | 5d | 2024-02-26 A | 2024-03-01 A | 1014, 1012FF | 100% |  | 2024-02-26 | 2024-03-01 | 5d | 2024-02-26 | 2024-03-01 |  |  | Lee Cox | 40h | 40h |  | SI Test | PP,IPA | 5.19 | Systems Integration Testing (SIT) | Complete | COMPLETE |  |  |  |  |  |  |
| 1016 | 1.4.2.2.12 | SIT Component Integration Testing Test Completion Report Approved | milestone | 0d | 2024-03-11 A | 2024-03-11 A | 1015FS+6d | 100% |  | 2024-03-08 | 2024-03-08 | 0d | 2024-03-08 | 2024-03-08 |  |  | Lee Cox |  |  |  | SI Test | PP | 5.18 | Systems Integration Testing (SIT) | Complete | COMPLETE | MHHS-ART074 | T2-TE-0600 | SITAG | T2 |  |  |
| 1017 | 1.4.2.3 | **SIT - Minimum Viable Cohort (MVC)** |  | 240d | 2024-03-11 A | 2025-02-07 |  | 10% | 214.8d | 2024-03-11 | 2025-02-07 | 240d | 2024-03-11 | 2025-02-07 | 600d |  | N/A | 16432h | 2404.14h | -0 | N/A | N/A | 5.0 | Systems Integration Testing (SIT) |  |  |  |  |  |  |  |  |
| 1018 | 1.4.2.3.1 | **SIT Functional Testing (MVC)** |  | 225d | 2024-03-11 A | 2025-01-17 |  | 26% | 166.34d | 2024-03-11 | 2025-01-17 | 225d | 2024-03-11 | 2025-01-17 | 615d |  | N/A | 7640h | 2106.57h |  | N/A | N/A | 5.0 | Systems Integration Testing (SIT) |  |  |  |  |  |  |  |  |
| 1019 | 1.4.2.3.1.1 | SIT Functional Testing Start | milestone | 0d | 2024-03-11 A | 2024-03-11 A | 1016, 859FS+5d, 794, 802, 803, 804, 811 | 100% |  | 2024-03-11 | 2024-03-11 | 0d | 2024-03-11 | 2024-03-11 |  |  | Lee Cox |  |  |  | SI Test | PP | 5.0 | Systems Integration Testing (SIT) | Complete | COMPLETE | MHHS-ART073 | T3-TE-0034 | SITAG | T3 |  |  |
| 1020 | 1.4.2.3.1.2 | **SIT Functional Testing Execution (Minimum Viable Cohort)** |  | 225d | 2024-03-11 A | 2025-01-17 |  | 26% | 166.34d | 2024-03-11 | 2025-01-17 | 225d | 2024-03-11 | 2025-01-17 | 615d |  | N/A | 5840h | 1637.29h |  | N/A | N/A | 5.0 | Systems Integration Testing (SIT) |  |  |  |  |  |  | D24C - E2E Test Completion Report | M10 |
| 1021 | 1.4.2.3.1.2.1 | **Cycle 1 (Full Cycle)** |  | 70d | 2024-03-11 A | 2024-06-14 A |  | 100% |  | 2024-03-11 | 2024-07-12 | 90d | 2024-03-11 | 2024-07-12 |  |  | N/A | 1120h | 1120h |  | N/A | N/A | 5.0 | Systems Integration Testing (SIT) |  |  |  |  |  |  |  |  |
| 1022 | 1.4.2.3.1.2.1.1 | Test Execution |  | 55d | 2024-03-11 A | 2024-05-24 A | 1019SS-1d, 834 | 100% |  | 2024-03-11 | 2024-06-28 | 80d | 2024-03-11 | 2024-06-28 |  |  | Lee Cox | 440h | 440h |  | PP | SI Test | 5.0 | Systems Integration Testing (SIT) | Complete | COMPLETE |  |  |  |  |  |  |
| 1023 | 1.4.2.3.1.2.1.2 | Defect resolution, assurance, review, data & environments maintenance |  | 15d | 2024-05-27 A | 2024-06-14 A | 1022 | 100% |  | 2024-07-01 | 2024-07-12 | 10d | 2024-07-01 | 2024-07-12 |  |  | Lee Cox | 120h | 120h |  | SI Test | PP | 5.0 | Systems Integration Testing (SIT) | Complete | COMPLETE |  |  |  |  |  |  |
| 1024 | 1.4.2.3.1.2.2 | **Cycle 2 (Defect retests and targeted regression testing)** |  | 55d | 2024-06-17 A | 2024-08-30 |  | 5% | 52d | 2024-07-15 | 2024-09-20 | 50d | 2024-07-15 | 2024-09-20 | 12d |  | N/A | 880h | 48h |  | N/A | N/A | 5.0 | Systems Integration Testing (SIT) |  |  |  |  |  |  |  |  |
| 1025 | 1.4.2.3.1.2.2.1 | Test Execution |  | 45d | 2024-06-17 A | 2024-08-16 | 1023, 839 | 7% | 42d | 2024-07-15 | 2024-09-06 | 40d | 2024-07-15 | 2024-09-06 | 11d | 0d | Lee Cox | 360h | 24h |  | PP | SI Test | 5.0 | Systems Integration Testing (SIT) | Green | GREEN |  |  |  |  |  |  |
| 1026 | 1.4.2.3.1.2.2.2 | Defect resolution, assurance, review, data & environments maintenance |  | 10d | 2024-08-19 | 2024-08-30 | 1025 |  |  | 2024-09-09 | 2024-09-20 | 10d | 2024-09-09 | 2024-09-20 | 12d | 0d | Lee Cox | 80h |  |  | SI Test | PP | 5.0 | Systems Integration Testing (SIT) | Green | GREEN |  |  |  |  |  | 53.33 |
| 1027 | 1.4.2.3.1.2.3 | **SIT Functional Testing back-up progress risk-assessment** |  | 20d | 2024-09-02 | 2024-09-27 |  |  |  | 2024-09-23 | 2024-10-18 | 20d | 2024-09-23 | 2024-10-18 | 695d |  | N/A | 400h |  |  | N/A | N/A | 5.0 | Systems Integration Testing (SIT) |  |  |  |  |  |  |  |  |
| 1028 | 1.4.2.3.1.2.3.1 | Back-up risk-assessment of SIT Functional progress to assess whether Qualification Execution can start early |  | 15d | 2024-09-02 | 2024-09-20 | 1026 |  |  | 2024-09-23 | 2024-10-11 | 15d | 2024-09-23 | 2024-10-11 | 695d | 0d | Nicola Farley; Lee Cox | 240h |  |  | SI Test | Code Bodies,PP,IPA | 5.0 | Systems Integration Testing (SIT) | Green | GREEN |  |  |  |  |  | 67.33 |
| 1029 | 1.4.2.3.1.2.3.2 | Back-up SITAG decision on early Qualification Testing Execution start | milestone | 0d | 2024-09-27 | 2024-09-27 | 1028FS+5d |  |  | 2024-10-18 | 2024-10-18 | 0d | 2024-10-18 | 2024-10-18 | 695d |  | Nicola Farley; Lee Cox |  |  |  | SI Test | Code Bodies,PP,IPA | 5.0 | Systems Integration Testing (SIT) | Green | GREEN |  | T3-TE-0041 | QAG | T3 |  | 92.71 |
| 1030 | 1.4.2.3.1.2.4 | **Cycle 3 (Defect retests and targeted regression testing)** |  | 45d | 2024-09-02 | 2024-11-01 |  |  |  | 2024-09-23 | 2024-11-01 | 30d | 2024-09-23 | 2024-11-01 | 12d |  | N/A | 720h |  |  | N/A | N/A | 5.0 | Systems Integration Testing (SIT) |  |  |  |  |  |  |  |  |
| 1031 | 1.4.2.3.1.2.4.1 | Test Execution |  | 35d | 2024-09-02 | 2024-10-18 | 1026, 844 |  |  | 2024-09-23 | 2024-10-18 | 20d | 2024-09-23 | 2024-10-18 | 12d | 0d | Lee Cox | 280h |  |  | PP | SI Test | 5.0 | Systems Integration Testing (SIT) | Green | GREEN |  |  |  |  |  | 67.33 |
| 1032 | 1.4.2.3.1.2.4.2 | Defect resolution, assurance, review, data & environments maintenance |  | 10d | 2024-10-21 | 2024-11-01 | 1031 |  |  | 2024-10-21 | 2024-11-01 | 10d | 2024-10-21 | 2024-11-01 | 12d | 0d | Lee Cox | 80h |  |  | SI Test | PP | 5.0 | Systems Integration Testing (SIT) | Green | GREEN |  |  |  |  |  | 116.33 |
| 1033 | 1.4.2.3.1.2.5 | Core Systems Code Freeze | milestone | 0d | 2024-11-01 | 2024-11-01 | 1032FF |  |  | 2024-11-01 | 2024-11-01 | 0d | 2024-11-01 | 2024-11-01 | 669d | 4d | Lee Cox |  |  |  | SI Test | PP | 5.0 | Systems Integration Testing (SIT) | Green | GREEN |  | T3-TE-0045 | SITAG | T3 |  | 127.71 |
| 1034 | 1.4.2.3.1.2.6 | Regression Testing (code freeze) |  | 45d | 2024-11-04 | 2025-01-03 | 1032, 849 |  |  | 2024-11-04 | 2025-01-03 | 45d | 2024-11-04 | 2025-01-03 | 12d | 0d | Lee Cox | 360h |  |  | PP | SI Test | 5.0 | Systems Integration Testing (SIT) | Green | GREEN |  |  |  |  |  | 130.33 |
| 1035 | 1.4.2.3.1.2.7 | SIT Functional Testing End (Minimum Viable Cohort) (incl. confirmation that PPs have submitted their Test Completion Reports to Programme for assurance) | milestone | 0d | 2025-01-03 | 2025-01-03 | 1034FF |  |  | 2025-01-03 | 2025-01-03 | 0d | 2025-01-03 | 2025-01-03 | 12d | 0d | Lee Cox |  |  |  | SI Test | PP | 5.0 | Systems Integration Testing (SIT) | Green | GREEN | MHHS-ART072 | T3-TE-0046 | SITAG | T3 |  | 190.71 |
| 1036 | 1.4.2.3.1.2.8 | Assurance of PPs Test Completion Reports |  | 30d | 2024-12-02 | 2025-01-10 | 1035FF+5d |  |  | 2024-12-02 | 2025-01-10 | 30d | 2024-12-02 | 2025-01-10 | 12d | 0d | Lee Cox | 240h |  |  | SI Test | PP | 5.0 | Systems Integration Testing (SIT) | Green | GREEN |  |  |  |  |  | 158.33 |

Notes:
- 1016: 20/2 - Date changed to align with SITAG meeting. On track for approval 11/3
- 1019: 28/11 - At risk because of challenges with CCP and PP readiness & dependent on successful Secondary Routing Testing
- 1025: Action: Lee
- 1028: Action: 5/12 - LC said change name from his to nicola and check dates based on new start date for non sit ldso testing
- 1029: Action: 5/12 - LC said change name from his to nicola and check dates based on new start date for non sit ldso testing

| ID | WBS | Task | Type | Duration | Start | Finish | Predecessors | Complete | Remaining | Baseline start | Baseline finish | Baseline duration | Baseline 1 start | Baseline 1 finish | Total slack | Free slack | Resources | Work | Actual work | Baseline cost | Responsible | Involved | Update Version | MHHS Programme Phase | Task Status | Sched Status | RAG | Artefact ID | Milestone ID | Text29 | Tier | Text3 | Action | Issue |
| --- | --- | --- | --- | --- | --- | --- | --- | --- | --- | --- | --- | --- | --- | --- | --- | --- | --- | --- | --- | --- | --- | --- | --- | --- | --- | --- | --- | --- | --- | --- | --- | --- | --- | --- |
| 1037 | 1.4.2.3.1.2.9 | **SIT Functional Test Completion Report (Minimum Viable Cohort)** |  | 20d | 2024-12-16 | 2025-01-10 |  |  |  | 2024-12-16 | 2025-01-10 | 20d | 2024-12-16 | 2025-01-10 | 12d |  | N/A | 320h |  |  | N/A | N/A | 5.0 | Systems Integration Testing (SIT) |  |  |  |  |  |  |  |  |  |  |
| 1038 | 1.4.2.3.1.2.9.1 | Develop document |  | 15d | 2024-12-16 | 2025-01-03 | 1035FF |  |  | 2024-12-16 | 2025-01-03 | 15d | 2024-12-16 | 2025-01-03 | 12d | 0d | Lee Cox | 120h |  |  | SI Test |  | 5.0 | Systems Integration Testing (SIT) | 172.33 | Green | GREEN |  |  |  |  |  |  |  |
| 1039 | 1.4.2.3.1.2.9.2 | Review & agree document |  | 5d | 2025-01-06 | 2025-01-10 | 1038, 1036FF |  |  | 2025-01-06 | 2025-01-10 | 5d | 2025-01-06 | 2025-01-10 | 12d | 0d | Lee Cox | 40h |  |  | SI Test | PP,IPA | 5.0 | Systems Integration Testing (SIT) | 193.33 | Green | GREEN |  |  |  |  |  |  |  |
| 1040 | 1.4.2.3.1.2.10 | SIT Functional Testing Test Completion Report (Minimum Viable Cohort) Approved | milestone | 0d | 2025-01-17 | 2025-01-17 | 1039FF+5d |  |  | 2025-01-17 | 2025-01-17 | 0d | 2025-01-17 | 2025-01-17 | 12d | 11d | Lee Cox |  |  |  | SI Test | PP | 5.0 | Systems Integration Testing (SIT) | 204.71 | Green | GREEN | MHHS-ART072 | T2-TE-0850 | SITAG | T2 |  |  |  |
| 1041 | 1.4.2.3.2 | **SIT Migration Testing (MVC)** |  | 154d | 2024-06-17 A | 2025-01-17 |  | 4% | 148.44d | 2024-06-10 | 2025-01-03 | 150d | 2024-06-10 | 2024-10-18 | 15d |  | N/A | 2584h | 96h | -0 | N/A | N/A | 5.0 | Systems Integration Testing (SIT) |  |  |  |  |  |  |  |  |  |  |
| 1042 | 1.4.2.3.2.1 | SIT Migration Testing Start | milestone | 0d | 2024-06-17 A | 2024-06-17 A | 911FS+10d, 866, 870, 877, 883, 889 | 100% |  | 2024-06-10 | 2024-06-10 | 0d | 2024-06-10 | 2024-06-10 |  |  | Lee Cox |  |  |  | SI Test | PP | 5.27 | Systems Integration Testing (SIT) |  | Complete | COMPLETE | MHHS-ART076 | T3-TE-0038 | SITAG | T3 |  |  |  |
| 1043 | 1.4.2.3.2.2 | SIT Migration Testing Execution (Minimum Viable Cohort) |  | 89d | 2024-06-18 A | 2024-10-18 | 1042SS | 8% | 82d | 2024-06-10 | 2024-10-04 | 85d | 2024-06-10 | 2024-10-04 | 15d | 0d | Lee Cox | 712h | 56h |  | SI Test | PP | 5.0 | Systems Integration Testing (SIT) |  | Red | RED |  |  |  |  | D24E - Migration Test Completion Report |  |  |
| 1044 | 1.4.2.3.2.3 | Defect resolution, assurance, review, data & environments maintenance |  | 10d | 2024-10-21 | 2024-11-01 | 1043 |  |  | 2024-10-21 | 2024-11-01 | 10d | 2024-10-21 | 2024-11-01 | 15d | 0d | Lee Cox | 80h |  |  | SI Test | PP | 5.27 | Systems Integration Testing (SIT) | 116.33 | Green | GREEN |  |  |  |  |  |  |  |
| 1045 | 1.4.2.3.2.4 | Regression Testing (code freeze) |  | 45d | 2024-11-04 | 2025-01-03 | 1044 |  |  | 2024-11-04 | 2025-01-03 | 45d |  |  | 15d | 0d |  |  |  |  |  |  | 5.27 |  | 130.33 | Green | GREEN |  |  |  |  |  |  |  |
| 1046 | 1.4.2.3.2.5 | SIT Migration Testing End (Minimum Viable Cohort) (incl. confirmation that PPs have submitted their Test Completion Reports to Programme for assurance) | milestone | 0d | 2025-01-03 | 2025-01-03 | 1043FF, 1045 |  |  | 2024-10-04 | 2024-10-04 | 0d | 2024-10-04 | 2024-10-04 | 15d | 0d | Lee Cox |  |  |  | SI Test | PP | 5.0 | Systems Integration Testing (SIT) | 190.71 | Red | RED | MHHS-ART076 | T3-TE-0043 | SITAG | T3 |  | 26/6: Revise plan to align to 3/1/25 MVC Test Complete | 26/6: Plan did not consider SIT Migration regression testing |
| 1047 | 1.4.2.3.2.6 | Assurance of PPs Test Completion Reports |  | 30d | 2024-12-02 | 2025-01-10 | 1046FF+5d |  |  | 2024-09-02 | 2024-10-11 | 30d | 2024-09-02 | 2024-10-11 | 15d | 0d | Lee Cox | 240h |  |  | SI Test | PP | 5.0 | Systems Integration Testing (SIT) | 158.33 | Red | RED |  |  |  |  |  |  |  |
| 1048 | 1.4.2.3.2.7 | **SIT Migration Testing Test Completion Report (Minimum Viable Cohort)** |  | 20d | 2024-12-16 | 2025-01-10 |  |  |  | 2024-09-16 | 2024-10-11 | 20d | 2024-09-16 | 2024-10-11 | 15d |  | N/A | 320h |  |  | N/A | N/A | 5.0 | Systems Integration Testing (SIT) |  |  |  |  |  |  |  |  |  |  |
| 1049 | 1.4.2.3.2.7.1 | Develop document |  | 15d | 2024-12-16 | 2025-01-03 | 1046FF |  |  | 2024-09-16 | 2024-10-04 | 15d | 2024-09-16 | 2024-10-04 | 15d | 0d | Lee Cox | 120h |  |  | SI Test |  | 5.0 | Systems Integration Testing (SIT) | 172.33 | Red | RED |  |  |  |  |  |  |  |
| 1050 | 1.4.2.3.2.7.2 | Review & agree document |  | 5d | 2025-01-06 | 2025-01-10 | 1049, 1047FF |  |  | 2024-10-07 | 2024-10-11 | 5d | 2024-10-07 | 2024-10-11 | 15d | 0d | Lee Cox | 40h |  |  | SI Test | PP,IPA | 5.0 | Systems Integration Testing (SIT) | 193.33 | Red | RED |  |  |  |  |  |  |  |
| 1051 | 1.4.2.3.2.8 | SIT Migration Testing Test Completion Report (Minimum Viable Cohort) Approved | milestone | 0d | 2025-01-17 | 2025-01-17 | 1050FF+5d |  |  | 2024-10-18 | 2024-10-18 | 0d | 2024-10-18 | 2024-10-18 | 15d |  | Lee Cox |  |  |  | SI Test | PP | 5.0 | Systems Integration Testing (SIT) | 204.71 | Red | RED | MHHS-ART076 | T2-TE-0800 | SITAG | T2 |  | 26/6: Revise plan to align to Jan 25 SITAG approval | 26/6: Plan did not consider SIT Migration regression testing |
| 1052 | 1.4.2.3.3 | **SIT Non-Functional Testing (MVC)** |  | 99d | 2024-09-02 | 2025-01-17 |  |  |  | 2024-09-02 | 2025-01-17 | 100d | 2024-09-02 | 2025-01-17 | 5d |  | N/A | 2064h |  |  | N/A | N/A | 5.0 | Systems Integration Testing (SIT) |  |  |  |  |  |  |  |  |  |  |
| 1053 | 1.4.2.3.3.1 | SIT Non-Functional Testing Start | milestone | 0d | 2024-09-02 | 2024-09-02 | 956FS+5d, 1025FS+5d, 918, 922, 929, 935, 941 |  |  | 2024-09-02 | 2024-09-02 | 0d | 2024-09-02 | 2024-09-02 | 5d | 0d | Lee Cox |  |  |  | SI Test | PP | 5.0 | Systems Integration Testing (SIT) | 67.71 | yellow | GREEN | MHHS-ART079 | T3-TE-0040 | SITAG | T3 |  |  |  |
| 1054 | 1.4.2.3.3.2 | SIT Non-Functional Testing Execution (Minimum Viable Cohort) |  | 89d | 2024-09-03 | 2025-01-03 | 1053SS |  |  | 2024-09-02 | 2025-01-03 | 90d | 2024-09-02 | 2025-01-03 | 15d | 0d | Lee Cox | 712h |  |  | SI Test | PP | 5.0 | Systems Integration Testing (SIT) | 68.33 | Green | GREEN |  |  |  |  | D24D - NF Test Completion Report |  |  |
| 1055 | 1.4.2.3.3.3 | SIT Non-Functional Testing End (Minimum Viable Cohort) (incl. confirmation that PPs have submitted their Test Completion Reports to Programme for assurance) | milestone | 0d | 2025-01-03 | 2025-01-03 | 1054FF |  |  | 2025-01-03 | 2025-01-03 | 0d | 2025-01-03 | 2025-01-03 | 15d | 0d | Lee Cox |  |  |  | SI Test | PP | 5.0 | Systems Integration Testing (SIT) | 190.71 | Green | GREEN | MHHS-ART079 | T3-TE-0047 | SITAG | T3 |  |  |  |
| 1056 | 1.4.2.3.3.4 | Assurance of PPs Test Completion Reports |  | 30d | 2024-12-02 | 2025-01-10 | 1055FF+5d |  |  | 2024-12-02 | 2025-01-10 | 30d | 2024-12-02 | 2025-01-10 | 15d | 0d | Lee Cox | 240h |  |  | SI Test | PP | 5.0 | Systems Integration Testing (SIT) | 158.33 | Green | GREEN |  |  |  |  |  |  |  |
| 1057 | 1.4.2.3.3.5 | **SIT Non-Functional Testing Test Completion Report (Minimum Viable Cohort)** |  | 20d | 2024-12-16 | 2025-01-10 |  |  |  | 2024-12-16 | 2025-01-10 | 20d | 2024-12-16 | 2025-01-10 | 15d |  | N/A | 320h |  |  | N/A | N/A | 5.0 | Systems Integration Testing (SIT) |  |  |  |  |  |  |  |  |  |  |
| 1058 | 1.4.2.3.3.5.1 | Develop document |  | 15d | 2024-12-16 | 2025-01-03 | 1055FF |  |  | 2024-12-16 | 2025-01-03 | 15d | 2024-12-16 | 2025-01-03 | 15d | 0d | Lee Cox | 120h |  |  | SI Test |  | 5.0 | Systems Integration Testing (SIT) | 172.33 | Green | GREEN |  |  |  |  |  |  |  |
| 1059 | 1.4.2.3.3.5.2 | Review & agree document |  | 5d | 2025-01-06 | 2025-01-10 | 1058, 1056FF |  |  | 2025-01-06 | 2025-01-10 | 5d | 2025-01-06 | 2025-01-10 | 15d | 0d | Lee Cox | 40h |  |  | SI Test | PP,IPA | 5.0 | Systems Integration Testing (SIT) | 193.33 | Green | GREEN |  |  |  |  |  |  |  |
| 1060 | 1.4.2.3.3.6 | SIT Non-Functional Testing Test Completion Report (Minimum Viable Cohort) Approved | milestone | 0d | 2025-01-17 | 2025-01-17 | 1059FF+5d |  |  | 2025-01-17 | 2025-01-17 | 0d | 2025-01-17 | 2025-01-17 | 15d |  | Lee Cox |  |  |  | SI Test | PP | 5.0 | Systems Integration Testing (SIT) | 204.71 | Green | GREEN | MHHS-ART079 | T2-TE-0900 | SITAG | T2 |  |  |  |

Notes:
- 1042: 21/5: at risk because dependant on prioritised SIT F CoA tests. Subject to approval at eSITAG on 10/6. 11/6: Missed date because MPRS data and code not ready. Decision deferred to 17/6
- 1046: 18/6: To go to July SITAG for date change approval. Baseline date incorrect. SIT Migration Test Completion equals 18/10 / Impact: 26/6: SIT Migration Test Compltion Report date was incorrect
- 1051: 18/6: To go to PSG for date change approval. Baseline date incorrect. SIT Migration Test execution completes 18/10, overall report approval 2 weeks later / Impact: 26/6: SIT Migration Test Compltion Report date was incorrect

| ID | WBS | Task | Type | Duration | Start | Finish | Predecessors | Complete | Remaining | Baseline start | Baseline finish | Baseline duration | Baseline 1 start | Baseline 1 finish | Total slack | Free slack | Resources | Work | Actual work | Baseline cost | Responsible | Involved | Update Version | MHHS Programme Phase | Artefact ID | Task Status | Sched Status | RAG | Milestone ID | Text29 | Tier | Text3 |
| --- | --- | --- | --- | --- | --- | --- | --- | --- | --- | --- | --- | --- | --- | --- | --- | --- | --- | --- | --- | --- | --- | --- | --- | --- | --- | --- | --- | --- | --- | --- | --- | --- |
| 1061 | 1.4.2.3.4 | **SIT Operational Testing (MVC)** |  | 89d | 2024-10-07 | 2025-02-07 |  |  |  | 2024-10-07 | 2025-02-07 | 90d | 2024-10-07 | 2025-02-07 | 0d |  | N/A | 1904h |  |  | N/A | N/A | 5.0 | Systems Integration Testing (SIT) |  |  |  |  |  |  |  |  |
| 1062 | 1.4.2.3.4.1 | SIT Operational Testing Start | milestone | 0d | 2024-10-07 | 2024-10-07 | 999FS+8d, 963, 967, 974, 980, 986 |  |  | 2024-10-07 | 2024-10-07 | 0d | 2024-10-07 | 2024-10-07 | 0d |  | Lee Cox |  |  |  | SI Test | PP | 5.0 | Systems Integration Testing (SIT) | MHHS-ART073 MHHS-ART143 | 102.71 | yellow | GREEN | T3-TE-0042 | SITAG | T3 |  |
| 1063 | 1.4.2.3.4.2 | SIT Operational Testing Execution (Minimum Viable Cohort) |  | 79d | 2024-10-08 | 2025-01-24 | 1062SS |  |  | 2024-10-07 | 2025-01-24 | 80d | 2024-10-07 | 2025-01-24 | 0d |  | Lee Cox | 632h |  |  | SI Test | PP | 5.0 | Systems Integration Testing (SIT) |  | 103.33 | Green | GREEN |  |  |  | D24D - NF Test Completion Report |
| 1064 | 1.4.2.3.4.3 | SIT Operational Testing End (Minimum Viable Cohort) (incl. confirmation that PPs have submitted their Test Completion Reports to Programme for assurance) | milestone | 0d | 2025-01-24 | 2025-01-24 | 1063FF |  |  | 2025-01-24 | 2025-01-24 | 0d | 2025-01-24 | 2025-01-24 | 0d |  | Lee Cox |  |  |  | SI Test | PP | 5.0 | Systems Integration Testing (SIT) | MHHS-ART081 | 211.71 | Green | GREEN | T3-TE-0050 | SITAG | T3 |  |
| 1065 | 1.4.2.3.4.4 | Assurance of PPs Test Completion Reports |  | 30d | 2024-12-23 | 2025-01-31 | 1064FF+5d |  |  | 2024-12-23 | 2025-01-31 | 30d | 2024-12-23 | 2025-01-31 | 0d |  | Lee Cox | 240h |  |  | SI Test | PP | 5.0 | Systems Integration Testing (SIT) |  | 179.33 | Green | GREEN |  |  |  |  |
| 1066 | 1.4.2.3.4.5 | **SIT Operational Testing Test Completion Report (Minimum Viable Cohort)** |  | 20d | 2025-01-06 | 2025-01-31 |  |  |  | 2025-01-06 | 2025-01-31 | 20d | 2025-01-06 | 2025-01-31 | 0d |  | N/A | 320h |  |  | N/A | N/A | 5.0 | Systems Integration Testing (SIT) |  |  |  |  |  |  |  |  |
| 1067 | 1.4.2.3.4.5.1 | Develop document |  | 15d | 2025-01-06 | 2025-01-24 | 1064FF |  |  | 2025-01-06 | 2025-01-24 | 15d | 2025-01-06 | 2025-01-24 | 0d |  | Lee Cox | 120h |  |  | SI Test |  | 5.0 | Systems Integration Testing (SIT) |  | 193.33 | Green | GREEN |  |  |  |  |
| 1068 | 1.4.2.3.4.5.2 | Review & agree document |  | 5d | 2025-01-27 | 2025-01-31 | 1067, 1065FF |  |  | 2025-01-27 | 2025-01-31 | 5d | 2025-01-27 | 2025-01-31 | 0d |  | Lee Cox | 40h |  |  | SI Test | PP,IPA | 5.0 | Systems Integration Testing (SIT) |  | 214.33 | Green | GREEN |  |  |  |  |
| 1069 | 1.4.2.3.4.6 | SIT Operational Testing Test Completion Report (Minimum Viable Cohort) Approved | milestone | 0d | 2025-02-07 | 2025-02-07 | 1068FF+5d |  |  | 2025-02-07 | 2025-02-07 | 0d | 2025-02-07 | 2025-02-07 | 0d |  | Lee Cox |  |  |  | SI Test | PP | 5.0 | Systems Integration Testing (SIT) | MHHS-ART081 | 225.71 | Green | GREEN | T2-TE-0950 | SITAG | T2 |  |
| 1070 | 1.4.2.3.5 | **SIT MVC Test Exit Report** |  | 20d | 2025-01-06 | 2025-01-31 |  |  |  | 2025-01-06 | 2025-01-31 | 20d | 2025-01-06 | 2025-01-31 | 0d |  | N/A | 320h |  |  | N/A | N/A | 5.0 | Systems Integration Testing (SIT) |  |  |  |  |  |  |  |  |
| 1071 | 1.4.2.3.5.1 | Develop document |  | 15d | 2025-01-06 | 2025-01-24 | 1067FF |  |  | 2025-01-06 | 2025-01-24 | 15d | 2025-01-06 | 2025-01-24 | 0d |  | Lee Cox | 120h |  |  | SI Test |  | 5.0 | Systems Integration Testing (SIT) |  | 193.33 | Green | GREEN |  |  |  |  |
| 1072 | 1.4.2.3.5.2 | Review & agree document |  | 5d | 2025-01-27 | 2025-01-31 | 1071 |  |  | 2025-01-27 | 2025-01-31 | 5d | 2025-01-27 | 2025-01-31 | 0d |  | Lee Cox | 40h |  |  | SI Test | PP,IPA | 5.0 | Systems Integration Testing (SIT) |  | 214.33 | Green | GREEN |  |  |  |  |
| 1073 | 1.4.2.3.6 | SIT Minimum Viable Cohort Complete (SIT Minimum Viable Cohort Test Exit Report Approved) | milestone | 0d | 2025-02-07 | 2025-02-07 | 1072FS+5d, 1016, 1040, 1051, 1060, 1069 |  |  | 2025-02-07 | 2025-02-07 | 0d | 2025-02-07 | 2025-02-07 | 0d |  | Lee Cox |  |  |  | CPT | PP,IPA | 5.0 | Systems Integration Testing (SIT) | MHHS-ART081 | 225.71 | yellow | GREEN | T1-TE-2000 | PSG | T1 |  |
| 1074 | 1.4.2.4 | **SIT - Other Participants** |  | 295d | 2024-03-11 A | 2025-04-25 |  | 9% | 268.69d | 2024-03-11 | 2025-04-25 | 295d | 2024-03-11 | 2025-04-25 | 5d |  | N/A | 20752h | 2717.34h | -0 | N/A | N/A | 5.0 | Systems Integration Testing (SIT) |  | M10,M11 |  |  |  |  |  | D24D - NF Test Completion Report |
| 1075 | 1.4.2.4.1 | **SIT Functional Testing (Other Participants)** |  | 295d | 2024-03-11 A | 2025-04-25 |  | 26% | 219.56d | 2024-03-11 | 2025-04-25 | 295d | 2024-03-11 | 2025-04-25 | 5d |  | N/A | 8600h | 2475.54h |  | N/A | N/A | 5.0 | Systems Integration Testing (SIT) |  |  |  |  |  |  |  |  |
| 1076 | 1.4.2.4.1.1 | **SIT Functional Testing Execution (Other Participants)** |  | 280d | 2024-03-11 A | 2025-04-04 |  | 28% | 202d | 2024-03-11 | 2025-04-04 | 280d | 2024-03-11 | 2025-04-04 | 5d |  | N/A | 5840h | 1872h |  | N/A | N/A | 5.0 | Systems Integration Testing (SIT) |  | M10 |  |  |  |  |  | D24C - E2E Test Completion Report |
| 1077 | 1.4.2.4.1.1.1 | **Cycle 1 (Full Cycle)** |  | 70d | 2024-03-11 A | 2024-06-14 A |  | 100% |  | 2024-03-11 | 2024-07-12 | 90d | 2024-03-11 | 2024-07-12 |  |  | N/A | 1120h | 1120h |  | N/A | N/A | 5.0 | Systems Integration Testing (SIT) |  |  |  |  |  |  |  |  |
| 1078 | 1.4.2.4.1.1.1.1 | Test Execution |  | 55d | 2024-03-11 A | 2024-05-24 A | 1022SS, 128 | 100% |  | 2024-03-11 | 2024-06-28 | 80d | 2024-03-11 | 2024-06-28 |  |  | Lee Cox | 440h | 440h |  | PP | SI Test | 5.0 | Systems Integration Testing (SIT) |  |  | Complete | COMPLETE |  |  |  |  |
| 1079 | 1.4.2.4.1.1.1.2 | Defect resolution, assurance, review, data & environments maintenance |  | 15d | 2024-05-27 A | 2024-06-14 A | 1078 | 100% |  | 2024-07-01 | 2024-07-12 | 10d | 2024-07-01 | 2024-07-12 |  |  | Lee Cox | 120h | 120h |  | SI Test | PP | 5.0 | Systems Integration Testing (SIT) |  |  | Complete | COMPLETE |  |  |  |  |
| 1080 | 1.4.2.4.1.1.2 | **Cycle 2 (Defect retests and targeted regression testing)** |  | 55d | 2024-06-17 A | 2024-08-30 |  | 15% | 47d | 2024-07-15 | 2024-09-20 | 50d | 2024-07-15 | 2024-09-20 | 5d |  | N/A | 880h | 128h |  | N/A | N/A | 5.0 | Systems Integration Testing (SIT) |  |  |  |  |  |  |  |  |
| 1081 | 1.4.2.4.1.1.2.1 | Test Execution |  | 45d | 2024-06-17 A | 2024-08-16 | 1079, 132, 136 | 18% | 37d | 2024-07-15 | 2024-09-06 | 40d | 2024-07-15 | 2024-09-06 | 5d | 0d | Lee Cox | 360h | 64h |  | PP | SI Test | 5.0 | Systems Integration Testing (SIT) |  |  | Green | GREEN |  |  |  |  |
| 1082 | 1.4.2.4.1.1.2.2 | Defect resolution, assurance, review, data & environments maintenance |  | 10d | 2024-08-19 | 2024-08-30 | 1081 |  |  | 2024-09-09 | 2024-09-20 | 10d | 2024-09-09 | 2024-09-20 | 5d | 0d | Lee Cox | 80h |  |  | SI Test | PP | 5.0 | Systems Integration Testing (SIT) |  | 53.33 | Green | GREEN |  |  |  |  |
| 1083 | 1.4.2.4.1.1.3 | **Cycle 3 (Defect retests and targeted regression testing)** |  | 45d | 2024-09-02 | 2024-11-01 |  |  |  | 2024-09-23 | 2024-11-01 | 30d | 2024-09-23 | 2024-11-01 | 5d |  | N/A | 720h |  |  | N/A | N/A | 5.0 | Systems Integration Testing (SIT) |  |  |  |  |  |  |  |  |
| 1084 | 1.4.2.4.1.1.3.1 | Test Execution |  | 35d | 2024-09-02 | 2024-10-18 | 1082, 140 |  |  | 2024-09-23 | 2024-10-18 | 20d | 2024-09-23 | 2024-10-18 | 5d | 0d | Lee Cox | 280h |  |  | PP | SI Test | 5.0 | Systems Integration Testing (SIT) |  | 67.33 | Green | GREEN |  |  |  |  |
| 1085 | 1.4.2.4.1.1.3.2 | Defect resolution, assurance, review, data & environments maintenance |  | 10d | 2024-10-21 | 2024-11-01 | 1084 |  |  | 2024-10-21 | 2024-11-01 | 10d | 2024-10-21 | 2024-11-01 | 5d | 0d | Lee Cox | 80h |  |  | SI Test | PP | 5.0 | Systems Integration Testing (SIT) |  | 116.33 | Green | GREEN |  |  |  |  |
| 1086 | 1.4.2.4.1.1.4 | Regression Testing (code freeze) |  | 45d | 2024-11-04 | 2025-01-03 | 1085 |  |  | 2024-11-04 | 2025-01-03 | 45d | 2024-11-04 | 2025-01-03 | 5d | 0d | Lee Cox | 360h |  |  | PP | SI Test | 5.0 | Systems Integration Testing (SIT) |  | 130.33 | Green | GREEN |  |  |  |  |
| 1087 | 1.4.2.4.1.1.5 | SIT Other PPs continued support |  | 65d | 2025-01-06 | 2025-04-04 | 1086 |  |  | 2025-01-06 | 2025-04-04 | 65d | 2025-01-06 | 2025-04-04 | 5d | 0d | Lee Cox | 520h |  |  | PP | SI Test | 5.0 | Systems Integration Testing (SIT) |  | 193.33 | Green | GREEN |  |  |  |  |
| 1088 | 1.4.2.4.1.2 | SIT Functional Testing End (Other Participants) (incl. confirmation that PPs have submitted their Test Completion Reports to Programme for assurance) | milestone | 0d | 2025-04-04 | 2025-04-04 | 1087FF |  |  | 2025-04-04 | 2025-04-04 | 0d | 2025-04-04 | 2025-04-04 | 5d | 0d | Lee Cox |  |  |  | SI Test | PP | 5.0 | Systems Integration Testing (SIT) | MHHS-ART072 | 281.71 | Green | GREEN | T3-TE-0052 | SITAG | T3 |  |
| 1089 | 1.4.2.4.1.3 | Assurance of PPs Test Completion Reports |  | 5d | 2025-04-14 | 2025-04-18 | 1088FS+5d |  |  | 2025-04-14 | 2025-04-18 | 5d | 2025-04-14 | 2025-04-18 | 5d | 0d | Lee Cox | 40h |  |  | SI Test | PP | 5.0 | Systems Integration Testing (SIT) |  | 291.33 | Green | GREEN |  |  |  |  |

| ID | WBS | Task | Type | Duration | Start | Finish | Predecessors | Complete | Remaining | Baseline start | Baseline finish | Baseline duration | Baseline 1 start | Baseline 1 finish | Total slack | Free slack | Resources | Work | Actual work | Responsible | Involved | Update Version | MHHS Programme Phase | Task Status | Sched Status | RAG | Artefact ID | Milestone ID | Text29 | Tier | Text3 |
| --- | --- | --- | --- | --- | --- | --- | --- | --- | --- | --- | --- | --- | --- | --- | --- | --- | --- | --- | --- | --- | --- | --- | --- | --- | --- | --- | --- | --- | --- | --- | --- |
| 1090 | 1.4.2.4.1.4 | **SIT Functional Testing Test Completion Report (Other Participants)** |  | 25d | 2025-03-17 | 2025-04-18 |  |  |  | 2025-03-17 | 2025-04-18 | 25d | 2025-03-17 | 2025-04-18 | 5d |  | N/A | 360h |  | N/A | N/A | 5.0 | Systems Integration Testing (SIT) |  |  |  |  |  |  |  |  |
| 1091 | 1.4.2.4.1.4.1 | Develop document |  | 15d | 2025-03-17 | 2025-04-04 | 1088FF |  |  | 2025-03-17 | 2025-04-04 | 15d | 2025-03-17 | 2025-04-04 | 10d | 5d | Lee Cox | 120h |  | SI Test |  | 5.0 | Systems Integration Testing (SIT) | 263.33 | Green | GREEN |  |  |  |  |  |
| 1092 | 1.4.2.4.1.4.2 | Review & agree document |  | 5d | 2025-04-14 | 2025-04-18 | 1091, 1089FF |  |  | 2025-04-14 | 2025-04-18 | 5d | 2025-04-14 | 2025-04-18 | 5d | 0d | Lee Cox | 40h |  | SI Test | PP,IPA | 5.0 | Systems Integration Testing (SIT) | 291.33 | Green | GREEN |  |  |  |  |  |
| 1093 | 1.4.2.4.1.5 | SIT Functional Testing Test Completion Report (Other Participants) Approved | milestone | 0d | 2025-04-25 | 2025-04-25 | 1092FF+5d |  |  | 2025-04-25 | 2025-04-25 | 0d | 2025-04-25 | 2025-04-25 | 5d | 0d | Lee Cox |  |  | SI Test | PP | 5.0 | Systems Integration Testing (SIT) | 302.71 | Green | GREEN | MHHS-ART072 | T3-TE-0055 | SITAG | T3 |  |
| 1094 | 1.4.2.4.2 | **SIT Migration Testing (Other Participants)** |  | 224d | 2024-06-18 A | 2025-04-25 |  | 1% | 222.09d | 2024-06-10 | 2025-04-25 | 230d | 2024-06-10 | 2025-04-25 | 5d |  | N/A | 3864h | 31.32h | N/A | N/A | 5.0 | Systems Integration Testing (SIT) |  |  |  |  |  |  |  |  |
| 1095 | 1.4.2.4.2.1 | SIT Migration Testing Execution (Other Participants) |  | 209d | 2024-06-18 A | 2025-04-04 | 1042SS | 1% | 207d | 2024-06-10 | 2025-04-04 | 215d | 2024-06-10 | 2025-04-04 | 5d | 0d | Lee Cox | 1672h | 16h | SI Test | PP | 5.0 | Systems Integration Testing (SIT) | -8.67 | Green | GREEN |  |  |  |  | D24E - Migration Test Completion Report |
| 1096 | 1.4.2.4.2.2 | SIT Migration Testing End (Other Participants) (incl. confirmation that PPs have submitted their Test Completion Reports to Programme for assurance) | milestone | 0d | 2025-04-04 | 2025-04-04 | 1095FF |  |  | 2025-04-04 | 2025-04-04 | 0d | 2025-04-04 | 2025-04-04 | 5d | 0d | Lee Cox |  |  | SI Test | PP | 5.0 | Systems Integration Testing (SIT) | 281.71 | Green | GREEN | MHHS-ART076 | T3-TE-0051 | SITAG | T3 |  |
| 1097 | 1.4.2.4.2.3 | Assurance of PPs Test Completion Reports |  | 5d | 2025-04-14 | 2025-04-18 | 1096FS+5d |  |  | 2025-04-14 | 2025-04-18 | 5d | 2025-04-14 | 2025-04-18 | 5d | 0d | Lee Cox | 40h |  | SI Test | PP | 5.0 | Systems Integration Testing (SIT) | 291.33 | Green | GREEN |  |  |  |  |  |
| 1098 | 1.4.2.4.2.4 | **SIT Migration Testing Test Completion Report (Other Participants)** |  | 25d | 2025-03-17 | 2025-04-18 |  |  |  | 2025-03-17 | 2025-04-18 | 25d | 2025-03-17 | 2025-04-18 | 5d |  | N/A | 360h |  | N/A | N/A | 5.0 | Systems Integration Testing (SIT) |  |  |  |  |  |  |  |  |
| 1099 | 1.4.2.4.2.4.1 | Develop document |  | 15d | 2025-03-17 | 2025-04-04 | 1096FF |  |  | 2025-03-17 | 2025-04-04 | 15d | 2025-03-17 | 2025-04-04 | 10d | 5d | Lee Cox | 120h |  | SI Test |  | 5.0 | Systems Integration Testing (SIT) | 263.33 | Green | GREEN |  |  |  |  |  |
| 1100 | 1.4.2.4.2.4.2 | Review & agree document |  | 5d | 2025-04-14 | 2025-04-18 | 1099, 1097FF |  |  | 2025-04-14 | 2025-04-18 | 5d | 2025-04-14 | 2025-04-18 | 5d | 0d | Lee Cox | 40h |  | SI Test | PP,IPA | 5.0 | Systems Integration Testing (SIT) | 291.33 | Green | GREEN |  |  |  |  |  |
| 1101 | 1.4.2.4.2.5 | SIT Migration Testing Test Completion Report (Other Participants) Approved | milestone | 0d | 2025-04-25 | 2025-04-25 | 1100FF+5d |  |  | 2025-04-25 | 2025-04-25 | 0d | 2025-04-25 | 2025-04-25 | 5d | 0d | Lee Cox |  |  | SI Test | PP | 5.0 | Systems Integration Testing (SIT) | 302.71 | Green | GREEN | MHHS-ART076 | T3-TE-0056 | SITAG | T3 |  |
| 1102 | 1.4.2.4.3 | **SIT Non-Functional Testing (Other Participants)** |  | 169d | 2024-09-03 | 2025-04-25 |  |  |  | 2024-09-02 | 2025-04-25 | 170d | 2024-09-02 | 2025-04-25 | 5d |  | N/A | 2984h |  | N/A | N/A | 5.0 | Systems Integration Testing (SIT) |  |  |  |  |  |  |  |  |
| 1103 | 1.4.2.4.3.1 | SIT Non-Functional Testing Execution (Other Participants) |  | 154d | 2024-09-03 | 2025-04-04 | 1053SS |  |  | 2024-09-02 | 2025-04-04 | 155d | 2024-09-02 | 2025-04-04 | 5d | 0d | Lee Cox | 1232h |  | SI Test | PP | 5.0 | Systems Integration Testing (SIT) | 68.33 | Green | GREEN |  |  |  |  | D24D - NF Test Completion Report |
| 1104 | 1.4.2.4.3.2 | SIT Non-Functional Testing End (Other Participants) (incl. confirmation that PPs have submitted their Test Completion Reports to Programme for assurance) | milestone | 0d | 2025-04-04 | 2025-04-04 | 1103FF |  |  | 2025-04-04 | 2025-04-04 | 0d | 2025-04-04 | 2025-04-04 | 5d | 0d | Lee Cox |  |  | SI Test | PP | 5.0 | Systems Integration Testing (SIT) | 281.71 | Green | GREEN | MHHS-ART079 | T3-TE-0053 | SITAG | T3 |  |
| 1105 | 1.4.2.4.3.3 | Assurance of PPs Test Completion Reports |  | 5d | 2025-04-14 | 2025-04-18 | 1104FS+5d |  |  | 2025-04-14 | 2025-04-18 | 5d | 2025-04-14 | 2025-04-18 | 5d | 0d | Lee Cox | 40h |  | SI Test | PP | 5.0 | Systems Integration Testing (SIT) | 291.33 | Green | GREEN |  |  |  |  |  |
| 1106 | 1.4.2.4.3.4 | **SIT Non-Functional Testing Test Completion Report (Other Participants)** |  | 25d | 2025-03-17 | 2025-04-18 |  |  |  | 2025-03-17 | 2025-04-18 | 25d | 2025-03-17 | 2025-04-18 | 5d |  | N/A | 360h |  | N/A | N/A | 5.0 | Systems Integration Testing (SIT) |  |  |  |  |  |  |  |  |
| 1107 | 1.4.2.4.3.4.1 | Develop document |  | 15d | 2025-03-17 | 2025-04-04 | 1104FF |  |  | 2025-03-17 | 2025-04-04 | 15d | 2025-03-17 | 2025-04-04 | 10d | 5d | Lee Cox | 120h |  | SI Test |  | 5.0 | Systems Integration Testing (SIT) | 263.33 | Green | GREEN |  |  |  |  |  |
| 1108 | 1.4.2.4.3.4.2 | Review & agree document |  | 5d | 2025-04-14 | 2025-04-18 | 1107, 1105FF |  |  | 2025-04-14 | 2025-04-18 | 5d | 2025-04-14 | 2025-04-18 | 5d | 0d | Lee Cox | 40h |  | SI Test | PP,IPA | 5.0 | Systems Integration Testing (SIT) | 291.33 | Green | GREEN |  |  |  |  |  |
| 1109 | 1.4.2.4.3.5 | SIT Non-Functional Testing Test Completion Report (Other Participants) Approved | milestone | 0d | 2025-04-25 | 2025-04-25 | 1108FF+5d |  |  | 2025-04-25 | 2025-04-25 | 0d | 2025-04-25 | 2025-04-25 | 5d | 0d | Lee Cox |  |  | SI Test | PP | 5.0 | Systems Integration Testing (SIT) | 302.71 | Green | GREEN | MHHS-ART079 | T3-TE-0057 | SITAG | T3 |  |
| 1110 | 1.4.2.4.4 | **SIT Operational Testing (Other Participants)** |  | 144d | 2024-10-08 | 2025-04-25 |  |  |  | 2024-10-07 | 2025-04-25 | 145d | 2024-10-07 | 2025-04-25 | 5d |  | N/A | 2624h |  | N/A | N/A | 5.0 | Systems Integration Testing (SIT) |  |  |  |  |  |  |  |  |
| 1111 | 1.4.2.4.4.1 | SIT Operational Testing Execution (Other Participants) |  | 129d | 2024-10-08 | 2025-04-04 | 1062SS |  |  | 2024-10-07 | 2025-04-04 | 130d | 2024-10-07 | 2025-04-04 | 5d | 0d | Lee Cox | 1032h |  | SI Test | PP | 5.0 | Systems Integration Testing (SIT) | 103.33 | Green | GREEN |  |  |  |  | D24D - NF Test Completion Report |
| 1112 | 1.4.2.4.4.2 | SIT Operational Testing End (Other Participants) (incl. confirmation that PPs have submitted their Test Completion Reports to Programme for assurance) | milestone | 0d | 2025-04-04 | 2025-04-04 | 1111FF |  |  | 2025-04-04 | 2025-04-04 | 0d | 2025-04-04 | 2025-04-04 | 5d | 0d | Lee Cox |  |  | SI Test | PP | 5.0 | Systems Integration Testing (SIT) | 281.71 | Green | GREEN | MHHS-ART081 | T3-TE-0054 | SITAG | T3 |  |
| 1113 | 1.4.2.4.4.3 | Assurance of PPs Test Completion Reports |  | 10d | 2025-04-07 | 2025-04-18 | 1112 |  |  | 2025-04-14 | 2025-04-18 | 5d | 2025-04-14 | 2025-04-18 | 5d | 0d | Lee Cox | 80h |  | SI Test | PP | 5.0 | Systems Integration Testing (SIT) | 284.33 | Green | GREEN |  |  |  |  |  |

| ID | WBS | Task | Type | Duration | Start | Finish | Predecessors | Complete | Remaining | Baseline start | Baseline finish | Baseline duration | Baseline 1 start | Baseline 1 finish | Total slack | Free slack | Constraint | Resources | Work | Actual work | Baseline cost | Responsible | Involved | Update Version | MHHS Programme Phase | Task Status | Sched Status | RAG | Artefact ID | Milestone ID | Text29 | Tier |
| --- | --- | --- | --- | --- | --- | --- | --- | --- | --- | --- | --- | --- | --- | --- | --- | --- | --- | --- | --- | --- | --- | --- | --- | --- | --- | --- | --- | --- | --- | --- | --- | --- |
| 1114 | 1.4.2.4.4.4 | **SIT Operational Testing Test Completion Report (Other Participants)** |  | 25d | 2025-03-17 | 2025-04-18 |  |  |  | 2025-03-17 | 2025-04-18 | 25d | 2025-03-17 | 2025-04-18 | 5d |  |  | N/A | 360h |  |  | N/A | N/A | 5.0 | Systems Integration Testing (SIT) |  |  |  |  |  |  |  |
| 1115 | 1.4.2.4.4.4.1 | Develop document |  | 15d | 2025-03-17 | 2025-04-04 | 1112FF |  |  | 2025-03-17 | 2025-04-04 | 15d | 2025-03-17 | 2025-04-04 | 10d | 0d |  | Lee Cox | 120h |  |  | SI Test |  | 5.0 | Systems Integration Testing (SIT) | 263.33 | Green | GREEN |  |  |  |  |
| 1116 | 1.4.2.4.4.4.2 | Review & agree document |  | 5d | 2025-04-14 | 2025-04-18 | 1115, 1113FF |  |  | 2025-04-14 | 2025-04-18 | 5d | 2025-04-14 | 2025-04-18 | 5d | 0d |  | Lee Cox | 40h |  |  | SI Test | PP,IPA | 5.0 | Systems Integration Testing (SIT) | 291.33 | Green | GREEN |  |  |  |  |
| 1117 | 1.4.2.4.4.5 | SIT Operational Testing Test Completion Report (Other Participants) Approved | milestone | 0d | 2025-04-25 | 2025-04-25 | 1116FF+5d |  |  | 2025-04-25 | 2025-04-25 | 0d | 2025-04-25 | 2025-04-25 | 5d | 0d |  | Lee Cox |  |  |  | SI Test | PP | 5.0 | Systems Integration Testing (SIT) | 302.71 | Green | GREEN | MHHS-ART081 | T3-TE-0058 | SITAG | T3 |
| 1118 | 1.4.2.4.5 | **SIT Other Participants Test Exit Report** |  | 20d | 2025-03-17 | 2025-04-11 |  |  |  | 2025-03-17 | 2025-04-11 | 20d | 2025-03-17 | 2025-04-11 | 11d |  |  | N/A | 320h |  |  | N/A | N/A | 5.0 | Systems Integration Testing (SIT) |  |  |  |  |  |  |  |
| 1119 | 1.4.2.4.5.1 | Develop document |  | 15d | 2025-03-17 | 2025-04-04 | 1115FF |  |  | 2025-03-17 | 2025-04-04 | 15d | 2025-03-17 | 2025-04-04 | 11d | 0d |  | Lee Cox | 120h |  |  | SI Test |  | 5.0 | Systems Integration Testing (SIT) | 263.33 | Green | GREEN |  |  |  |  |
| 1120 | 1.4.2.4.5.2 | Review & agree document |  | 5d | 2025-04-07 | 2025-04-11 | 1119 |  |  | 2025-04-07 | 2025-04-11 | 5d | 2025-04-07 | 2025-04-11 | 11d | 6d |  | Lee Cox | 40h |  |  | SI Test | PP,IPA | 5.0 | Systems Integration Testing (SIT) | 284.33 | Green | GREEN |  |  |  |  |
| 1121 | 1.4.2.4.6 | SIT - Other Participants Complete | milestone | 0d | 2025-04-25 | 2025-04-25 | 1120FS+4d, 1093, 1101, 1109, 1117 |  |  | 2025-04-25 | 2025-04-25 | 0d | 2025-04-21 | 2025-04-21 | 5d | 4d |  | Lee Cox |  |  |  | SI Test | PP | 5.27 | Systems Integration Testing (SIT) | 302.71 | Green | GREEN | MHHS-ART081 | T3-TE-0059 | SITAG | T3 |
| 1122 | 1.4.3 | **UIT Environment Preparation** |  | 680d | 2022-10-31 A | 2025-06-06 |  | 10% | 612.72d | 2022-10-31 | 2025-06-06 | 680d | 2022-10-31 | 2025-06-06 | 515d |  |  | N/A | 87936h | 11895.5h | -0 | N/A | N/A | 5.0 | Systems Integration Testing (SIT) |  |  |  |  |  |  |  |
| 1123 | 1.4.3.1 | **Test Artefact Development** |  | 361d | 2023-03-01 | 2024-07-18 |  |  |  | 2023-03-01 | 2024-07-18 | 361d | 2023-03-01 | 2023-08-04 | 747d |  |  | N/A | 8128h |  | -0 | N/A | N/A | 5.0 | Systems Integration Testing (SIT) |  |  |  |  |  |  |  |
| 1124 | 1.4.3.1.1 | **E2E Sandbox Guidance** |  | 361d | 2023-03-01 | 2024-07-18 |  |  |  | 2023-03-01 | 2024-07-18 | 361d | 2023-03-01 | 2023-08-04 | 747d |  |  | N/A | 3752h |  | -0 | N/A | N/A | 5.0 | Systems Integration Testing (SIT) |  |  |  |  |  |  |  |
| 1125 | 1.4.3.1.1.1 | Develop document |  | 83d | 2023-03-01 | 2023-06-23 |  |  |  | 2023-03-01 | 2023-06-23 | 83d | 2023-03-01 | 2023-06-23 | 995d | 0d | start no earlier than 2023-03-01 | Stuart Scott | 664h |  |  | SI Test |  | 5.0 | Systems Integration Testing (SIT) | -483.67 | Overdue Start | RED |  |  |  |  |
| 1126 | 1.4.3.1.1.2 | Artefact review (via SITAG) and updates |  | 25d | 2023-06-26 | 2023-07-28 | 1125 |  |  | 2023-06-26 | 2023-07-28 | 25d | 2023-06-26 | 2023-07-28 | 995d | 248d |  | Stuart Scott | 200h |  |  | SI Test | PP,IPA | 5.0 | Systems Integration Testing (SIT) | -366.67 | Overdue Start | RED |  |  |  |  |
| 1127 | 1.4.3.1.1.3 | E2E Sandbox Guidance approved | milestone | 0d | 2024-07-18 | 2024-07-18 | 1126FF+5d |  |  | 2024-07-18 | 2024-07-18 | 0d | 2023-08-04 | 2023-08-04 | 747d |  | start no earlier than 2024-07-18 | Stuart Scott |  |  |  | SI Test | PP | 5.27 | Systems Integration Testing (SIT) | 21.33 | Green | GREEN | MHHS-ART154 | T3-TE-0067 | QAG | T3 |
| 1128 | 1.4.3.1.2 | **E2E Sandbox Test Data Approach & Plan** |  | 93d | 2023-03-29 | 2023-08-04 |  |  |  | 2023-03-29 | 2023-08-04 | 93d | 2023-03-29 | 2023-08-04 | 995d |  |  | N/A | 1488h |  |  | N/A | N/A | 5.0 | Systems Integration Testing (SIT) |  |  |  |  |  |  |  |
| 1129 | 1.4.3.1.2.1 | Develop document |  | 68d | 2023-03-29 | 2023-06-30 | 1125SS+20d |  |  | 2023-03-29 | 2023-06-30 | 68d | 2023-03-29 | 2023-06-30 | 995d | 0d |  | Stuart Scott | 544h |  |  | SI Test |  | 5.0 | Systems Integration Testing (SIT) | -455.67 | Overdue Start | RED |  |  |  |  |
| 1130 | 1.4.3.1.2.2 | Review, update & agree document internally |  | 25d | 2023-07-03 | 2023-08-04 | 1129 |  |  | 2023-07-03 | 2023-08-04 | 25d | 2023-07-03 | 2023-08-04 | 995d |  |  | Stuart Scott | 200h |  |  | SI Test | PP,IPA | 5.0 | Systems Integration Testing (SIT) | -359.67 | Overdue Start | RED |  |  |  |  |
| 1131 | 1.4.3.2 | **UIT Stub Specification and Delivery** |  | 190d | 2023-12-04 A | 2024-08-23 |  | 78% | 42d | 2023-12-04 | 2024-08-23 | 190d | 2023-10-27 | 2024-08-23 | 665d |  |  | N/A | 4560h | 3552h | -0 | N/A | N/A | 5.0 | Systems Integration Testing (SIT) |  |  |  |  |  |  |  |
| 1132 | 1.4.3.2.1 | **Qualification Test Stubs** |  | 190d | 2023-12-04 A | 2024-08-23 |  | 78% | 42d | 2023-12-04 | 2024-08-23 | 190d | 2023-10-27 | 2024-08-23 | 665d |  |  | N/A | 3040h | 2368h | -0 | N/A | N/A | 5.16 | Systems Integration Testing (SIT) |  |  |  |  |  |  |  |
| 1133 | 1.4.3.2.1.1 | Specify |  | 44d | 2023-12-04 A | 2024-02-01 A | 470FS+13d | 100% |  | 2023-12-04 | 2024-02-01 | 44d | 2023-10-27 | 2023-12-29 |  |  |  | Matthew Bray | 352h | 352h |  | SI DevOps | Qualification,SRO | 5.0 | Systems Integration Testing (SIT) |  | Complete | COMPLETE |  |  |  |  |
| 1134 | 1.4.3.2.1.2 | Build & Test |  | 141d | 2024-02-02 A | 2024-08-16 | 1133 | 74% | 37d | 2024-02-02 | 2024-08-16 | 141d | 2023-12-29 | 2024-05-24 | 665d | 0d |  | Matthew Bray | 1128h | 832h |  | SI DevOps | Qualification,SRO | 5.23 | Systems Integration Testing (SIT) |  | Green | GREEN |  |  |  |  |
| 1135 | 1.4.3.2.1.3 | Prepare for release |  | 5d | 2024-08-19 | 2024-08-23 | 1134 |  |  | 2024-08-19 | 2024-08-23 | 5d | 2024-07-29 | 2024-08-23 | 665d | 0d |  | Matthew Bray | 40h |  |  | SI DevOps | Qualification,SRO | 5.0 | Systems Integration Testing (SIT) | 53.33 | Green | GREEN |  |  |  |  |
| 1136 | 1.4.3.2.1.4 | Non-SIT LDSO Test Harness Released | milestone | 0d | 2024-08-23 | 2024-08-23 | 1135 |  |  | 2024-08-23 | 2024-08-23 | 0d | 2024-08-23 | 2024-08-23 | 665d | 0d |  | Matthew Bray |  |  |  | SI DevOps | Qualification,SRO | 5.27 | Systems Integration Testing (SIT) | 57.71 | Green | GREEN | MHHS-ART080 | T3-TE-0035 | QAG | T3 |
| 1137 | 1.4.3.3 | **Environments (UIT)** |  | 680d | 2022-10-31 | 2025-06-06 |  |  |  | 2022-10-31 | 2025-06-06 | 680d | 2022-10-31 | 2025-06-06 | 0d |  |  | N/A | 52568h |  |  | N/A | N/A | 5.0 | Systems Integration Testing (SIT) |  |  |  |  |  |  |  |
| 1138 | 1.4.3.3.1 | **Central Party Environments (UIT)** |  | 498d | 2022-11-16 | 2024-10-11 |  |  |  | 2022-11-16 | 2024-10-04 | 493d | 2022-11-16 | 2024-10-04 | 366d |  |  | N/A | 12144h |  |  | N/A | N/A | 5.0 | Systems Integration Testing (SIT) |  |  |  |  |  |  |  |
| 1139 | 1.4.3.3.1.1 | Central Parties' environment preparation (incl. security certificates and security compliance) |  | 488d | 2022-11-16 | 2024-09-27 | 466 |  |  | 2022-11-16 | 2024-08-23 | 463d | 2022-11-16 | 2024-08-23 | 366d | 0d |  | Simon Berry | 3904h |  |  | PP | SI Test | 5.0 | Systems Integration Testing (SIT) | -588.67 | Overdue Start | RED |  |  |  |  |
| 1140 | 1.4.3.3.1.2 | Submit self-declaration of environment preparation complete (incl. security certificates and security compliance) to Programme for assurance |  | 488d | 2022-11-16 | 2024-09-27 | 1139SS |  |  | 2022-11-16 | 2024-08-23 | 463d | 2022-11-16 | 2024-08-23 | 665d | 0d |  | Simon Berry | 3904h |  |  | PP | SI Test | 5.0 | Systems Integration Testing (SIT) | -588.67 | Overdue Start | RED |  |  |  |  |
| 1141 | 1.4.3.3.1.3 | Central Parties' UIT environment connectivity proving |  | 24d | 2024-08-27 | 2024-09-27 | 1153FS+1d |  |  | 2024-08-27 | 2024-09-20 | 19d | 2024-08-27 | 2024-09-20 | 665d | 0d |  | Simon Berry | 192h |  |  | PP | SI Test | 5.0 | Systems Integration Testing (SIT) | 61.33 | yellow | RED |  |  |  |  |
| 1142 | 1.4.3.3.1.4 | Deployment of MHHS solution code to UIT environments |  | 10d | 2024-09-16 | 2024-09-27 | 1141FF |  |  | 2024-09-09 | 2024-09-20 | 10d | 2024-09-09 | 2024-09-20 | 665d | 0d |  | Simon Berry | 80h |  |  | PP | SI Test | 5.0 | Systems Integration Testing (SIT) | 81.33 | yellow | RED |  |  |  |  |
| 1143 | 1.4.3.3.1.5 | Central Parties' UIT environment Regression Testing |  | 10d | 2024-09-30 | 2024-10-11 | 1142 |  |  | 2024-09-23 | 2024-10-04 | 10d | 2024-09-23 | 2024-10-04 | 665d | 0d |  | Simon Berry | 80h |  |  | PP | SI Test | 5.0 | Systems Integration Testing (SIT) | 95.33 | yellow | RED |  |  |  |  |

Notes:
- 1117: Action: 4/6 - sort out link. Remove fixed date from line 1119
- 1121: 4/6 - To go to June SITAG for baseline date change as previous date was incorrect. 19/6: Date change approved at SITAG on 19/6
- 1127: 26/6: Baseline date change approved at QAG on 20/6/24
- 1134: 30/4: Removed previous testing phases as were no longer relevant and extended task to push out to align with existing dates
- 1136: 22/1- Change name from CSS & SMRS Simulators Released to Non-SIT LDSO Test Harness Released because original naming is no longer applicable and refreshed scope determined in Dec from Code Bodies via Qualification team. 24/6: Approved at QAG on 20/6 / Action: 11/12- MB - Might not be delivering css awaiting confirmation from requirements done by SRO and code bodies - tbc in Jan 24

| ID | WBS | Task | Type | Duration | Start | Finish | Predecessors | Baseline start | Baseline finish | Baseline duration | Baseline 1 start | Baseline 1 finish | Total slack | Free slack | Constraint | Resources | Work | Responsible | Involved | Update Version | MHHS Programme Phase | Task Status | Sched Status | RAG | Milestone ID | Text29 | Tier | Action | Artefact ID |
| --- | --- | --- | --- | --- | --- | --- | --- | --- | --- | --- | --- | --- | --- | --- | --- | --- | --- | --- | --- | --- | --- | --- | --- | --- | --- | --- | --- | --- | --- |
| 1144 | 1.4.3.3.2 | **E2E Sandbox Participants (UIT)** |  | 680d | 2022-10-31 | 2025-06-06 |  | 2022-10-31 | 2025-06-06 | 680d | 2022-10-31 | 2025-06-06 | 0d |  |  | N/A | 16240h | N/A | N/A | 5.0 | Systems Integration Testing (SIT) |  |  |  |  |  |  |  |  |
| 1145 | 1.4.3.3.2.1 | E2E Sandbox Participants environment preparation (incl. security certificates and security compliance) |  | 660d | 2022-10-31 | 2025-05-09 |  | 2022-10-31 | 2025-05-09 | 660d | 2022-10-31 | 2025-05-09 | 0d |  | must finish on 2025-05-09 | Simon Berry | 5280h | PP | SI Test | 5.0 | Systems Integration Testing (SIT) | -604.67 | Overdue Start | GREEN |  |  |  |  |  |
| 1146 | 1.4.3.3.2.2 | Submit self-declaration of environment preparation complete (incl. security certificates and security compliance) to Programme for assurance |  | 660d | 2022-10-31 | 2025-05-09 |  | 2022-10-31 | 2025-05-09 | 660d | 2022-10-31 | 2025-05-09 | 515d | 0d |  | Simon Berry | 5280h | PP | SI Test | 5.0 | Systems Integration Testing (SIT) | -604.67 | Overdue Start | GREEN |  |  |  |  |  |
| 1147 | 1.4.3.3.2.3 | E2E Sandbox Participants UIT environment connectivity proving |  | 20d | 2025-05-12 | 2025-06-06 | 1146 | 2025-05-12 | 2025-06-06 | 20d | 2025-05-12 | 2025-06-06 | 515d | 0d |  | Simon Berry | 160h | PP | SI Test | 5.0 | Systems Integration Testing (SIT) | 319.33 | Green | GREEN |  |  |  |  |  |
| 1148 | 1.4.3.3.2.4 | Deployment of MHHS solution code to UIT environments |  | 10d | 2025-05-26 | 2025-06-06 | 1147FF | 2025-05-26 | 2025-06-06 | 10d | 2025-05-26 | 2025-06-06 | 515d | 0d |  | Simon Berry | 80h | PP | SI Test | 5.0 | Systems Integration Testing (SIT) | 333.33 | Green | GREEN |  |  |  |  |  |
| 1149 | 1.4.3.3.3 | **SI Environments (UIT)** |  | 680d | 2022-10-31 | 2025-06-06 |  | 2022-10-31 | 2025-06-06 | 680d | 2022-10-31 | 2025-06-06 | 461d |  |  | N/A | 18744h | N/A | N/A | 5.0 | Systems Integration Testing (SIT) |  |  |  |  |  |  |  |  |
| 1150 | 1.4.3.3.3.1 | Coordinate Central Parties' UIT environment preparation |  | 463d | 2022-11-16 | 2024-08-23 | 1139SS | 2022-11-16 | 2024-08-23 | 463d | 2022-11-16 | 2024-08-23 | 720d |  |  | Simon Berry | 3704h | SI Test | PP | 5.0 | Systems Integration Testing (SIT) | -588.67 | Overdue Start | GREEN |  |  |  |  |  |
| 1151 | 1.4.3.3.3.2 | Coordinate E2E Sandbox Participants' UIT environment preparation (for E2E Sandbox Testing Start) |  | 463d | 2022-10-31 | 2024-08-07 | 1145SS | 2022-10-31 | 2024-08-07 | 463d | 2022-10-31 | 2024-08-07 | 732d |  |  | Simon Berry | 3704h | SI Test | PP | 5.0 | Systems Integration Testing (SIT) | -604.67 | Overdue Start | GREEN |  |  |  |  |  |
| 1152 | 1.4.3.3.3.3 | Assure Central Parties' self-declaration of environment preparation complete (incl. security certificates and security compliance) |  | 463d | 2022-11-16 | 2024-08-23 | 1140SS, 1146SS | 2022-11-16 | 2024-08-23 | 463d | 2022-11-16 | 2024-08-23 | 665d | 0d |  | Simon Berry | 3704h | SI Test | PP | 5.0 | Systems Integration Testing (SIT) | -588.67 | Overdue Start | GREEN |  |  |  |  |  |
| 1153 | 1.4.3.3.3.4 | Central Parties' UIT environments ready to start connectivity proving (incl. certificates and security compliance) | milestone | 0d | 2024-08-23 | 2024-08-23 | 1152, 1136 | 2024-08-23 | 2024-08-23 | 0d | 2024-08-23 | 2024-08-23 | 665d | 0d |  | Simon Berry |  | SI Test | PP | 5.0 | Systems Integration Testing (SIT) | 57.71 | Green | GREEN | T3-TE-0044 | QAG | T3 |  |  |
| 1154 | 1.4.3.3.3.5 | Coordinate Central Parties' UIT environment connectivity proving |  | 19d | 2025-05-12 | 2025-06-05 | 1141SS, 1147SS | 2025-05-12 | 2025-06-05 | 19d | 2025-05-12 | 2025-06-05 | 516d |  |  | Simon Berry | 152h | SI Test | PP | 5.0 | Systems Integration Testing (SIT) | 319.33 | Green | GREEN |  |  |  |  |  |
| 1155 | 1.4.3.3.3.6 | Coordinate deployment of MHHS solution code to Central Parties' UIT environments |  | 10d | 2025-05-26 | 2025-06-06 | 1142SS, 1148SS | 2025-05-26 | 2025-06-06 | 10d | 2025-05-26 | 2025-06-06 | 515d |  |  | Simon Berry | 80h | SI Test | PP | 5.0 | Systems Integration Testing (SIT) | 333.33 | Green | GREEN |  |  |  |  |  |
| 1156 | 1.4.3.3.3.7 | Coordinate Central Parties' UIT environment Regression Testing |  | 10d | 2024-09-30 | 2024-10-11 | 1143SS | 2024-09-23 | 2024-10-04 | 10d | 2024-09-23 | 2024-10-04 | 685d |  |  | Simon Berry | 80h | SI Test | PP | 5.0 | Systems Integration Testing (SIT) | 95.33 | yellow | RED |  |  |  |  |  |
| 1157 | 1.4.3.3.3.8 | **Environments** |  | 115d | 2024-08-06 | 2025-01-13 |  | 2024-08-06 | 2025-01-13 | 115d | 2024-08-06 | 2025-01-13 | 0d |  |  | N/A | 1880h | N/A | N/A | 5.0 | Qualification |  |  |  |  |  |  | review |  |
| 1158 | 1.4.3.3.3.8.1 | Coordinate Qualification Participants' environment preparation |  | 60d | 2024-08-06 | 2024-10-28 |  | 2024-08-06 | 2024-10-28 | 60d | 2024-08-06 | 2024-10-28 | 0d |  | must start on 2024-08-06 | Simon Berry | 480h | SI Test | Code Bodies, PP | 5.0 | Qualification | 40.33 | Green | GREEN |  |  |  | review |  |
| 1159 | 1.4.3.3.3.8.2 | Coordinate deployment of MHHS solution code to Qualification Participants' UIT environments |  | 10d | 2024-10-15 | 2024-10-28 | 1158FF | 2024-10-15 | 2024-10-28 | 10d | 2024-10-15 | 2024-10-28 | 619d | 0d |  | Simon Berry | 80h | SI Test | Code Bodies, PP | 5.0 | Qualification | 110.33 | Green | GREEN |  |  |  | review |  |
| 1160 | 1.4.3.3.3.8.3 | Qualification Testing Tranche 1 Participants' UIT environments ready to start connectivity proving (incl. certificates and security compliance) | milestone | 0d | 2024-11-04 | 2024-11-04 | 1159FS+5d | 2024-11-04 | 2024-11-04 | 0d | 2024-11-04 | 2024-11-04 | 619d | 0d |  | Simon Berry |  | SI Test | Code Bodies, PP, IPA | 5.0 | Qualification | 130.71 | Green | GREEN | T3-QU-0017 | QAG | T3 | review | MHHS-ART073 |
| 1161 | 1.4.3.3.3.8.4 | **Coordinate Qualification Participants' connectivity proving** |  | 50d | 2024-11-05 | 2025-01-13 |  | 2024-11-05 | 2025-01-13 | 50d | 2024-11-05 | 2025-01-13 | 619d |  |  | N/A | 400h | N/A | N/A | 5.0 | Qualification |  |  |  |  |  |  |  |  |
| 1162 | 1.4.3.3.3.8.4.1 | Assurance of Qualification Participants' connectivity proving |  | 50d | 2024-11-05 | 2025-01-13 | 1160 | 2024-11-05 | 2025-01-13 | 50d | 2024-11-05 | 2025-01-13 | 619d |  |  |  |  | SI Test | Code Bodies, PP | 5.0 | Qualification | 131.33 | Green | GREEN |  |  |  |  |  |
| 1163 | 1.4.3.4 | **Test Data** |  | 30d | 2024-09-02 | 2024-10-11 |  | 2024-08-26 | 2024-10-04 | 30d | 2024-08-26 | 2024-10-04 | 665d |  |  | N/A | 2400h | N/A | N/A | 5.0 | Systems Integration Testing (SIT) |  |  |  |  |  |  |  |  |
| 1164 | 1.4.3.4.1 | **Central Parties (for E2E Sandbox & Qualification)** |  | 30d | 2024-09-02 | 2024-10-11 |  | 2024-08-26 | 2024-10-04 | 30d | 2024-08-26 | 2024-10-04 | 665d |  |  | N/A | 720h | N/A | N/A | 5.0 | Systems Integration Testing (SIT) |  |  |  |  |  |  |  |  |
| 1165 | 1.4.3.4.1.1 | Central Parties' UIT environment test data loading & verification (& data cleansing, if required) |  | 30d | 2024-09-02 | 2024-10-11 | 1143FF | 2024-08-26 | 2024-10-04 | 30d | 2024-08-26 | 2024-10-04 | 665d | 0d |  | Richard Puddephatt | 240h | PP | SI Test | 5.0 | Systems Integration Testing (SIT) | 67.33 | yellow | RED |  |  |  |  |  |
| 1166 | 1.4.3.4.1.2 | Submit self-declaration to Programme to confirm loading & verification of test data |  | 30d | 2024-09-02 | 2024-10-11 | 1165SS | 2024-08-26 | 2024-10-04 | 30d | 2024-08-26 | 2024-10-04 | 665d | 0d |  | Richard Puddephatt | 240h | PP | SI Test | 5.0 | Systems Integration Testing (SIT) | 67.33 | yellow | RED |  |  |  |  |  |
| 1167 | 1.4.3.4.2 | **E2E Sandbox Participants** |  | 30d | 2024-09-02 | 2024-10-11 |  | 2024-08-26 | 2024-10-04 | 30d | 2024-08-26 | 2024-10-04 | 685d |  |  | N/A | 480h | N/A | N/A | 5.0 | Systems Integration Testing (SIT) |  |  |  |  |  |  |  |  |
| 1168 | 1.4.3.4.2.1 | UIT environment test data loading and verification (and data cleansing, if required) (for E2E Sandbox Testing Start) |  | 30d | 2024-09-02 | 2024-10-11 | 1165FF | 2024-08-26 | 2024-10-04 | 30d | 2024-08-26 | 2024-10-04 | 685d | 0d |  | Richard Puddephatt | 240h | PP | SI Test | 5.0 | Systems Integration Testing (SIT) | 67.33 | yellow | RED |  |  |  |  |  |

Notes:
- 1165: 1/5: changed from Simon berry to richard puddephatt
- 1166: 1/5: changed from Simon berry to richard puddephatt
- 1168: 1/5: changed from Simon berry to richard puddephatt

| ID | WBS | Task | Type | Duration | Start | Finish | Predecessors | Complete | Remaining | Baseline start | Baseline finish | Baseline duration | Baseline 1 start | Baseline 1 finish | Total slack | Free slack | Constraint | Resources | Work | Actual work | Responsible | Involved | Update Version | MHHS Programme Phase | Task Status | Sched Status | RAG | Artefact ID | Milestone ID | Text29 | Tier |
| --- | --- | --- | --- | --- | --- | --- | --- | --- | --- | --- | --- | --- | --- | --- | --- | --- | --- | --- | --- | --- | --- | --- | --- | --- | --- | --- | --- | --- | --- | --- | --- |
| 1169 | 1.4.3.4.3 | **SI Test Data** |  | 30d | 2024-09-02 | 2024-10-11 |  |  |  | 2024-08-26 | 2024-10-04 | 30d | 2024-08-26 | 2024-10-04 | 685d |  |  | N/A | 960h |  | N/A | N/A | 5.0 | Systems Integration Testing (SIT) |  |  |  |  |  |  |  |
| 1170 | 1.4.3.4.3.1 | Coordinate Central Parties' UIT environment test data loading and verification (and data cleansing, if required) |  | 30d | 2024-09-02 | 2024-10-11 | 1165SS |  |  | 2024-08-26 | 2024-10-04 | 30d | 2024-08-26 | 2024-10-04 | 685d |  |  | Richard Puddephatt | 240h |  | SI Test | PP | 5.0 | Systems Integration Testing (SIT) | 67.33 | yellow | RED |  |  |  |  |
| 1171 | 1.4.3.4.3.2 | Assure evidence of Central Parties' UIT environment test data load and verification |  | 30d | 2024-09-02 | 2024-10-11 | 1166SS |  |  | 2024-08-26 | 2024-10-04 | 30d | 2024-08-26 | 2024-10-04 | 685d |  |  | Richard Puddephatt | 240h |  | SI Test | PP | 5.0 | Systems Integration Testing (SIT) | 67.33 | yellow | RED |  |  |  |  |
| 1172 | 1.4.3.4.3.3 | Coordinate E2E Sandbox Participants' UIT environment test data loading and verification (and data cleansing, if required) (for E2E Sandbox Testing Start) |  | 30d | 2024-09-02 | 2024-10-11 | 1168SS |  |  | 2024-08-26 | 2024-10-04 | 30d | 2024-08-26 | 2024-10-04 | 685d |  |  | Richard Puddephatt | 240h |  | SI Test | PP | 5.0 | Systems Integration Testing (SIT) | 67.33 | yellow | RED |  |  |  |  |
| 1173 | 1.4.3.5 | **Other Preparation** |  | 484d | 2022-11-16 A | 2024-09-23 |  | 59% | 196.43d | 2022-11-16 | 2024-09-23 | 484d | 2022-11-16 | 2024-09-23 | 699d |  |  | N/A | 13200h | 7805.21h | N/A | N/A | 5.0 | Systems Integration Testing (SIT) |  |  |  |  |  |  |  |
| 1174 | 1.4.3.5.1 | **SI Other Preparation** |  | 66d | 2024-05-08 | 2024-08-07 |  |  |  | 2024-05-02 | 2024-08-01 | 66d | 2024-05-02 | 2024-08-01 | 732d |  |  | N/A | 1056h |  | N/A | N/A | 5.0 | Systems Integration Testing (SIT) |  |  |  |  |  |  |  |
| 1175 | 1.4.3.5.1.1 | Onboarding of UIT E2E Sandbox Participants to Test Management Tool for E2E Sandbox Testing Start (onboarding of participants will be ongoing hereafter) |  | 66d | 2024-05-08 | 2024-08-07 | 1190SS-132d |  |  | 2024-05-02 | 2024-08-01 | 66d | 2024-05-02 | 2024-08-01 | 732d | 0d |  | Stuart Scott | 528h |  | SI Test | PP | 5.0 | Systems Integration Testing (SIT) | -49.67 | Overdue Start | RED |  |  |  |  |
| 1176 | 1.4.3.5.2 | **Other Preparation (for Central Parties & E2E Sandbox Participants)** |  | 484d | 2022-11-16 A | 2024-09-23 |  | 67% | 161.92d | 2022-11-16 | 2024-09-23 | 484d | 2022-11-16 | 2024-09-23 | 699d |  |  | N/A | 8272h | 5504.64h | N/A | N/A | 5.0 | Systems Integration Testing (SIT) |  |  |  |  |  |  |  |
| 1177 | 1.4.3.5.2.1 | Test Management Tool onboarding for E2E Sandbox Testing Start (onboarding will be ongoing hereafter) |  | 66d | 2024-05-08 | 2024-08-07 | 1175SS |  |  | 2024-05-02 | 2024-08-01 | 66d | 2024-05-02 | 2024-08-01 | 732d |  |  | Stuart Scott | 528h |  | PP | SI Test | 5.0 | Systems Integration Testing (SIT) | -49.67 | Overdue Start | RED |  |  |  |  |
| 1178 | 1.4.3.5.2.2 | Other Preparation (incl. test execution planning) |  | 484d | 2022-11-16 A | 2024-09-23 | 1139SS, 1145SS | 76% | 118d | 2022-11-16 | 2024-09-23 | 484d | 2022-11-16 | 2024-09-23 | 699d |  |  | Stuart Scott | 3872h | 2928h | PP | SI Test | 5.0 | Systems Integration Testing (SIT) |  | Green | GREEN |  |  |  |  |
| 1179 | 1.4.3.6 | **UIT E2E Sandbox Test Readiness Report** |  | 45d | 2024-09-02 | 2024-11-01 |  |  |  | 2024-08-26 | 2024-10-25 | 45d | 2024-08-26 | 2024-10-25 | 665d |  |  | N/A | 1640h |  | N/A | N/A | 5.0 | Systems Integration Testing (SIT) |  |  |  |  |  |  |  |
| 1180 | 1.4.3.6.1 | **Central Parties E2E Sandbox Test Readiness Report** |  | 30d | 2024-09-02 | 2024-10-11 |  |  |  | 2024-08-26 | 2024-10-04 | 30d | 2024-08-26 | 2024-10-04 | 665d |  |  | N/A | 480h |  | N/A | N/A | 5.0 | Systems Integration Testing (SIT) |  |  |  |  |  |  |  |
| 1181 | 1.4.3.6.1.1 | Develop draft Test Readiness Report and submit to Programme for assurance |  | 20d | 2024-09-02 | 2024-09-27 | 1166FF-10d |  |  | 2024-08-26 | 2024-09-20 | 20d | 2024-08-26 | 2024-09-20 | 665d | 0d |  | Stuart Scott | 160h |  | PP | SI Test | 5.0 | Systems Integration Testing (SIT) | 67.33 | yellow | RED |  |  |  |  |
| 1182 | 1.4.3.6.1.2 | Finalise Test Readiness Report and submit to Programme for assurance |  | 10d | 2024-09-30 | 2024-10-11 | 1166FF |  |  | 2024-09-23 | 2024-10-04 | 10d | 2024-09-23 | 2024-10-04 | 665d | 0d |  | Stuart Scott | 80h |  | PP | SI Test | 5.0 | Systems Integration Testing (SIT) | 95.33 | yellow | RED |  |  |  |  |
| 1183 | 1.4.3.6.2 | **SI E2E Sandbox Test Readiness Report** |  | 40d | 2024-09-02 | 2024-10-25 |  |  |  | 2024-08-26 | 2024-10-18 | 40d | 2024-08-26 | 2024-10-18 | 665d |  |  | N/A | 800h |  | N/A | N/A | 5.0 | Systems Integration Testing (SIT) |  |  |  |  |  |  |  |
| 1184 | 1.4.3.6.2.1 | Assure Central Parties' E2E Sandbox Test Readiness Reports |  | 35d | 2024-09-02 | 2024-10-18 | 1181SS, 1182FF+5d |  |  | 2024-08-26 | 2024-10-11 | 35d | 2024-08-26 | 2024-10-11 | 665d | 0d |  | Stuart Scott | 280h |  | SI Test | PP | 5.0 | Systems Integration Testing (SIT) | 67.33 | yellow | RED |  |  |  |  |
| 1185 | 1.4.3.6.2.2 | Develop Overarching E2E Sandbox Test Readiness Report |  | 20d | 2024-09-23 | 2024-10-18 | 1184FF |  |  | 2024-09-16 | 2024-10-11 | 20d | 2024-09-16 | 2024-10-11 | 665d | 0d |  | Stuart Scott | 160h |  | SI Test |  | 5.0 | Systems Integration Testing (SIT) | 88.33 | yellow | RED |  |  |  |  |
| 1186 | 1.4.3.6.2.3 | Artefact review (via SITAG) and updates |  | 5d | 2024-10-21 | 2024-10-25 | 1185 |  |  | 2024-10-14 | 2024-10-18 | 5d | 2024-10-14 | 2024-10-18 | 665d | 0d |  | Stuart Scott | 40h |  | SI Test | PP,IPA | 5.0 | Systems Integration Testing (SIT) | 116.33 | yellow | RED |  |  |  |  |
| 1187 | 1.4.3.6.3 | UIT E2E Sandbox Preparation Complete | milestone | 0d | 2024-11-01 | 2024-11-01 | 1186FS+5d |  |  | 2024-10-25 | 2024-10-25 | 0d | 2024-10-25 | 2024-10-25 | 665d | 0d |  | Stuart Scott |  |  | SI Test | PP | 5.0 | Systems Integration Testing (SIT) | 127.71 | yellow | RED | MHHS-ART154 MHHS-ART147 | T3-TE-0048 | QAG | T3 |
| 1188 | 1.4.4 | **SIT PPs E2E Sandbox Testing Execution** |  | 316d | 2024-11-08 | 2026-01-23 |  |  |  | 2024-11-04 | 2026-01-19 | 316d | 2024-11-04 | 2026-01-19 | 350d |  |  | N/A | 5056h |  | N/A | N/A | 5.0 | Systems Integration Testing (SIT) |  |  |  |  |  |  |  |
| 1189 | 1.4.4.1 | SIT PPs E2E Sandbox Testing Start | milestone | 0d | 2024-11-08 | 2024-11-08 | 1033FS+1d, 1187FS+5d |  |  | 2024-11-04 | 2024-11-04 | 0d | 2024-11-04 | 2024-11-04 | 665d | 0d |  | Stuart Scott |  |  | SI Test | PP | 5.0 | Systems Integration Testing (SIT) | 134.71 | yellow | RED | MHHS-ART018 MHHS-ART154 MHHS-ART147 | T3-TE-0049 | QAG | T3 |
| 1190 | 1.4.4.2 | SIT PPs E2E Sandbox Testing Execution |  | 316d | 2024-11-08 | 2026-01-23 | 1189SS-1d |  |  | 2024-11-04 | 2026-01-19 | 316d | 2024-11-04 | 2026-01-19 | 350d | 0d | start no earlier than 2024-11-04 | Stuart Scott | 2528h |  | PP | SI Test | 5.0 | Systems Integration Testing (SIT) | 134.33 | yellow | RED |  |  |  |  |
| 1191 | 1.4.5 | **External Programme Dependency Management** |  | 174d | 2022-10-31 A | 2023-06-30 A |  | 100% |  | 2022-10-31 | 2023-06-30 | 174d | 2022-10-31 | 2023-06-30 |  |  |  | N/A | 9712h | 9712h | N/A | N/A | 5.0 | Systems Integration Testing (SIT) |  |  |  |  |  |  |  |
| 1192 | 1.4.5.1 | **BSC CP1558** |  | 173d | 2022-10-31 A | 2023-06-29 A |  | 100% |  | 2022-10-31 | 2023-06-29 | 173d | 2022-10-31 | 2023-06-29 |  |  |  | N/A | 2768h | 2768h | N/A | N/A | 5.0 | Systems Integration Testing (SIT) |  |  |  |  |  |  |  |
| 1193 | 1.4.5.1.1 | Monitor progress to implementation date |  | 173d | 2022-10-31 A | 2023-06-28 A |  | 100% |  | 2022-10-31 | 2023-06-28 | 173d | 2022-10-31 | 2023-06-28 |  |  |  | Andrew Margan | 1384h | 1384h | CPT | Code Bodies | 5.0 | Systems Integration Testing (SIT) |  | Complete | COMPLETE |  |  |  |  |
| 1194 | 1.4.5.1.2 | BSC CP1558 Implementation Date | milestone | 0d | 2023-06-29 A | 2023-06-29 A | 1193 | 100% |  | 2023-06-29 | 2023-06-29 | 0d | 2023-06-29 | 2023-06-29 |  |  | must start on 2023-06-29 | Andrew Margan |  |  | Code Bodies |  | 5.0 | Systems Integration Testing (SIT) |  | Complete | COMPLETE |  |  |  |  |

| ID | WBS | Task | Type | Duration | Start | Finish | Predecessors | Complete | Remaining | Baseline start | Baseline finish | Baseline duration | Baseline 1 start | Baseline 1 finish | Total slack | Free slack | Constraint | Resources | Work | Actual work | Baseline cost | Responsible | Involved | Update Version | MHHS Programme Phase | Sched Status | RAG | Task Status | Milestone ID | Text29 | Tier | Guidance |
| --- | --- | --- | --- | --- | --- | --- | --- | --- | --- | --- | --- | --- | --- | --- | --- | --- | --- | --- | --- | --- | --- | --- | --- | --- | --- | --- | --- | --- | --- | --- | --- | --- |
| 1195 | 1.4.5.2 | **REC CP R0032** |  | 174d | 2022-10-31 A | 2023-06-30 A |  | 100% |  | 2022-10-31 | 2023-06-30 | 174d | 2022-10-31 | 2023-06-30 |  |  |  | N/A | 2784h | 2784h |  | N/A | N/A | 5.0 | Systems Integration Testing (SIT) |  |  |  |  |  |  |  |
| 1196 | 1.4.5.2.1 | Monitor progress to implementation date |  | 174d | 2022-10-31 A | 2023-06-29 A |  | 100% |  | 2022-10-31 | 2023-06-29 | 174d | 2022-10-31 | 2023-06-29 |  |  |  | Andrew Margan | 1392h | 1392h |  | CPT | Code Bodies | 5.0 | Systems Integration Testing (SIT) | Complete | COMPLETE |  |  |  |  |  |
| 1197 | 1.4.5.2.2 | REC CP R0032 Implementation Date | milestone | 0d | 2023-06-30 A | 2023-06-30 A | 1196 | 100% |  | 2023-06-30 | 2023-06-30 | 0d | 2023-06-30 | 2023-06-30 |  |  | must start on 2023-06-30 | Andrew Margan |  |  |  | Code Bodies |  | 5.0 | Systems Integration Testing (SIT) | Complete | COMPLETE |  |  |  |  |  |
| 1198 | 1.4.5.3 | **REC CP R0044** |  | 173d | 2022-10-31 A | 2023-06-29 A |  | 100% |  | 2022-10-31 | 2023-06-29 | 173d | 2022-10-31 | 2023-06-29 |  |  |  | N/A | 2768h | 2768h |  | N/A | N/A | 5.0 | Systems Integration Testing (SIT) |  |  |  |  |  |  |  |
| 1199 | 1.4.5.3.1 | Monitor progress to implementation date |  | 173d | 2022-10-31 A | 2023-06-28 A |  | 100% |  | 2022-10-31 | 2023-06-28 | 173d | 2022-10-31 | 2023-06-28 |  |  |  | Andrew Margan | 1384h | 1384h |  | CPT | Code Bodies | 5.0 | Systems Integration Testing (SIT) | Complete | COMPLETE |  |  |  |  |  |
| 1200 | 1.4.5.3.2 | REC CP R0044 Implementation Date | milestone | 0d | 2023-06-29 A | 2023-06-29 A | 1199 | 100% |  | 2023-06-29 | 2023-06-29 | 0d | 2023-06-29 | 2023-06-29 |  |  | must start on 2023-06-29 | Andrew Margan |  |  |  | Code Bodies |  | 5.0 | Systems Integration Testing (SIT) | Complete | COMPLETE |  |  |  |  |  |
| 1201 | 1.5 | **NON SIT LDSO QUALIFICATION** |  | 339d | 2023-11-07 A | 2025-02-21 |  | 55% | 151.32d | 2023-11-07 | 2025-02-28 | 343d | 2024-01-29 | 2024-07-05 | 590d |  |  | N/A | 28096h | 11697.4h | -0 | N/A | N/A |  | Systems Integration Testing (SIT) |  |  |  |  |  |  |  |
| 1202 | 1.5.1 | **Approach Planning** |  | 208d | 2023-11-07 A | 2024-08-22 |  | 82% | 37.33d | 2023-11-07 | 2024-07-18 | 183d |  |  | 721d |  |  | N/A | 3224h | 1768h | -0 | N/A | N/A | 5.24 |  |  |  | -386.67 |  |  |  |  |
| 1203 | 1.5.1.1 | Develop Draft Testing Approach & Plan |  | 61d | 2023-11-07 A | 2024-01-30 A |  | 100% |  | 2023-11-07 | 2024-01-30 | 61d |  |  |  |  | start no earlier than 2023-11-07 | Ben Wickins | 488h | 488h |  | Non-SIT LDSO | Non-SIT LDSO | 5.24 |  | Complete | COMPLETE |  |  |  |  |  |
| 1204 | 1.5.1.2 | Draft Testing Approach & Plan Issued to LDSO for Review |  | 1d | 2024-01-31 A | 2024-01-31 A | 1203 | 100% |  | 2024-01-31 | 2024-01-31 | 1d |  |  |  |  |  | Ben Wickins | 8h | 8h |  | Non-SIT LDSO | Non-SIT LDSO | 5.24 |  | Complete | COMPLETE |  |  |  |  |  |
| 1205 | 1.5.1.3 | LDSO Review Complete |  | 10d | 2024-02-01 A | 2024-02-14 A | 1204 | 100% |  | 2024-02-01 | 2024-02-14 | 10d |  |  |  |  |  | Ben Wickins | 80h | 80h |  | LDSOs | Non-SIT LDSO | 5.24 |  | Complete | COMPLETE |  |  |  |  |  |
| 1206 | 1.5.1.4 | Update Following LDSO Review |  | 14d | 2024-02-15 A | 2024-03-05 A | 1205 | 100% |  | 2024-02-15 | 2024-03-05 | 14d |  |  |  |  |  | Ben Wickins | 112h | 112h |  | Non-SIT LDSO | Non-SIT LDSO, Code Bodies | 5.24 |  | Complete | COMPLETE |  |  |  |  |  |
| 1207 | 1.5.1.5 | QWG Review of Approach & Plan |  | 1d | 2024-03-12 A | 2024-03-12 A | 1206FS+4d | 100% |  | 2024-03-12 | 2024-03-12 | 1d |  |  |  |  |  | Ben Wickins | 8h | 8h |  | Non-SIT LDSO, PP | Non-SIT LDSO, Code Bodies | 5.24 |  | Complete | COMPLETE |  |  |  |  |  |
| 1208 | 1.5.1.6 | QAG Approval for Approach & Plan | milestone | 0d | 2024-03-21 A | 2024-03-21 A | 1207FS+7d | 100% |  | 2024-03-21 | 2024-03-21 | 0d |  |  |  |  |  | Ben Wickins |  |  |  | Code Bodies | Non-SIT LDSO,Code Bodies | 5.24 |  | Complete | COMPLETE |  |  |  |  |  |
| 1209 | 1.5.1.7 | Confirmation of Participants for Non-SIT LDSO Qualification Testing | milestone | 0d | 2024-03-21 A | 2024-03-21 A | 1208 | 100% |  | 2024-03-21 | 2024-03-21 | 0d | 2024-01-29 | 2024-01-29 |  |  |  | Ben Wickins |  |  |  | Non-SIT LDSO | SI Test, PP, IPA | 5.24 | Systems Integration Testing (SIT) | Complete | COMPLETE |  | T3-QU-0011 | QAG (Non-SIT LDSO) | T3 |  |
| 1210 | 1.5.1.8 | Update to Annex 1 for internal review (NF, Not Operational) |  | 15d | 2024-03-18 A | 2024-04-05 A | 915 | 100% |  | 2024-03-18 | 2024-04-05 | 15d |  |  |  |  |  | Ben Wickins | 120h | 120h |  | Non-SIT LDSO | PP, Code Bodies | 5.24 |  | Complete | COMPLETE |  |  |  |  | 26/3: Linked to the development of SIT non functional plan |
| 1211 | 1.5.1.9 | Non-Functional, Operational & Migration Approaches Socialised with Code Bodies & LDSO & Feedback Actioned |  | 86d | 2024-04-08 A | 2024-08-05 | 1210 | 67% | 28d | 2024-04-08 | 2024-07-01 | 61d |  |  | 721d | 0d |  | Ben Wickins | 688h | 464h |  | Non-SIT LDSO | PP, Code Bodies | 5.27 |  | Red | RED |  |  |  |  |  |
| 1212 | 1.5.1.10 | QWG Review Operational, Non-Functional & Migration Annexes of Approach & Plan |  | 1d | 2024-08-13 | 2024-08-13 | 1211FS+5d |  |  | 2024-07-09 | 2024-07-09 | 1d |  |  | 721d | 0d |  | Ben Wickins | 8h |  |  | Non-SIT LDSO, PP | Non-SIT LDSO, PP, Code Bodies | 5.27 |  | Red | RED | 47.33 |  |  |  |  |
| 1213 | 1.5.1.11 | Update Following QWG Review |  | 6d | 2024-08-14 | 2024-08-21 | 1212 |  |  | 2024-07-10 | 2024-07-17 | 6d |  |  | 721d | 0d |  | Ben Wickins | 48h |  |  | Non-SIT LDSO, PP | Non-SIT LDSO, Code Bodies | 5.27 |  | Red | RED | 48.33 |  |  |  |  |
| 1214 | 1.5.1.12 | QAG Approval for Operational, Non-Functional & Migration Annexes of Approach & Plan | milestone | 0d | 2024-08-22 | 2024-08-22 | 1213FS+1d, 1209, 918 |  |  | 2024-07-18 | 2024-07-18 | 0d |  |  | 721d | 0d |  | Ben Wickins |  |  |  | Code Bodies | Non-SIT LDSO, Code Bodies | 5.27 |  | Red | RED | 56.71 | T3-QU-0110 | QAG (Non-SIT LDSO) |  |  |
| 1215 | 1.5.2 | **Functional Test Cases & Scenarios** |  | 58d | 2024-01-30 A | 2024-04-18 |  | 99% | 0d | 2024-01-30 | 2024-04-18 | 58d |  |  | 0d |  |  | N/A | 928h | 395.43h | -0 | N/A | N/A | 5.24 |  |  |  | -385.67 |  |  |  |  |
| 1216 | 1.5.2.1 | **Functional Test Cases & Scenarios Batch 1** |  | 8d | 2024-01-30 A | 2024-02-08 A |  | 100% |  | 2024-01-30 | 2024-02-08 | 8d |  |  |  |  |  | N/A | 104h | 104h | -0 | N/A | N/A | 5.24 |  |  |  |  |  |  |  |  |
| 1217 | 1.5.2.1.1 | Walkthrough Test Cases & Scenarios Batch 1 with Code Bodies |  | 1d | 2024-01-30 A | 2024-01-30 A | 1203SS+60d | 100% |  | 2024-01-30 | 2024-01-30 | 1d |  |  |  |  |  | Ben Wickins | 8h | 8h |  | Non-SIT LDSO | Non-SIT LDSO, Code Bodies | 5.24 |  | Complete | COMPLETE |  |  |  |  |  |
| 1218 | 1.5.2.1.2 | Walkthrough Test Cases & Scenarios Batch 1 with LDSO |  | 1d | 2024-02-01 A | 2024-02-01 A | 1217 | 100% |  | 2024-02-01 | 2024-02-01 | 1d |  |  |  |  |  | Ben Wickins | 8h | 8h |  | LDSO, Non-SIT LDSO | LDSO, Non-SIT LDSO | 5.24 |  | Complete | COMPLETE |  |  |  |  |  |
| 1219 | 1.5.2.1.3 | Action Feedback on Test Cases & Scenarios Batch 1 |  | 5d | 2024-02-02 A | 2024-02-08 A | 1218 | 100% |  | 2024-02-02 | 2024-02-08 | 5d |  |  |  |  |  | Ben Wickins | 40h | 40h |  | Non-SIT LDSO | Non-SIT LDSO, LDSO , Code Bodies | 5.24 |  | Complete | COMPLETE |  |  |  |  |  |

Notes:
- 1209: Have confirmed LDSOs going through SIT. We should receive notifications on non-SIT through January. Milestone holds to baseline. 13/5: date on cr47 was 18/4 but completed before CR approved
- 1210: Includes time to update Approach & Plan with updates
- 1214: 25/6: To go to July QAG for baseline date change from 18/7/24 to 22/8/24 / Action: 25/6: Project to engage with Code Bodies and industry in sufficient time to review all required materials. / Impact: 25/6: A significant amount of material is being presented for approval at the August QAG. No impact on deliverability of project / Issue: 25/6: Date missed because non-functional test materials are not available for the July QAG and therefore to maintain our approach of approving plans in parallel with materials all have slipped to the August QAG

| ID | WBS | Task | Type | Duration | Start | Finish | Predecessors | Complete | Remaining | Baseline start | Baseline finish | Baseline duration | Baseline 1 start | Baseline 1 finish | Total slack | Free slack | Constraint | Resources | Work | Actual work | Baseline cost | Responsible | Involved | Update Version | Sched Status | RAG | Milestone ID | Text29 | MHHS Programme Phase | Task Status | Tier |
| --- | --- | --- | --- | --- | --- | --- | --- | --- | --- | --- | --- | --- | --- | --- | --- | --- | --- | --- | --- | --- | --- | --- | --- | --- | --- | --- | --- | --- | --- | --- | --- |
| 1220 | 1.5.2.2 | **Functional Test Cases & Scenarios Batch 2** |  | 14d | 2024-02-20 A | 2024-03-08 A |  | 100% |  | 2024-02-20 | 2024-03-08 | 14d |  |  |  |  |  | N/A | 168h | 168h | -0 | N/A | N/A | 5.24 |  |  |  |  |  |  |  |
| 1221 | 1.5.2.2.1 | Walkthrough Test Cases & Scenarios Batch 2 with Code Bodies |  | 1d | 2024-02-20 A | 2024-02-20 A | 1203SS+75d | 100% |  | 2024-02-20 | 2024-02-20 | 1d |  |  |  |  |  | Ben Wickins | 8h | 8h |  | Non-SIT LDSO | Non-SIT LDSO, Code Bodies | 5.24 | Complete | COMPLETE |  |  |  |  |  |
| 1222 | 1.5.2.2.2 | Walkthrough Test Cases & Scenarios Batch 2 with LDSO |  | 1d | 2024-03-01 A | 2024-03-01 A | 1221FS+7d | 100% |  | 2024-03-01 | 2024-03-01 | 1d |  |  |  |  |  | Ben Wickins | 8h | 8h |  | LDSO, Non-SIT LDSO | LDSO, Non-SIT LDSO | 5.24 | Complete | COMPLETE |  |  |  |  |  |
| 1223 | 1.5.2.2.3 | Action Feedback on Test Cases & Scenarios Batch 2 |  | 5d | 2024-03-04 A | 2024-03-08 A | 1222 | 100% |  | 2024-03-04 | 2024-03-08 | 5d |  |  |  |  |  | Ben Wickins | 40h | 40h |  | Non-SIT LDSO | Non-SIT LDSO, LDSO , Code Bodies | 5.24 | Complete | COMPLETE |  |  |  |  |  |
| 1224 | 1.5.2.3 | **Functional Test Cases & Scenarios Batch 3** |  | 13d | 2024-03-20 A | 2024-04-05 |  | 99% | 0d | 2024-03-20 | 2024-04-05 | 13d |  |  | 0d |  |  | N/A | 168h | 91.43h | -0 | N/A | N/A | 5.24 |  |  |  |  |  |  |  |
| 1225 | 1.5.2.3.1 | Walkthrough Test Cases & Scenarios Batch 3 with Code Bodies |  | 1d | 2024-03-20 A | 2024-03-20 A | 1203SS+96d | 100% |  | 2024-03-20 | 2024-03-20 | 1d |  |  |  |  |  | Ben Wickins | 8h | 8h |  | Non-SIT LDSO | Non-SIT LDSO, Code Bodies | 5.24 | Complete | COMPLETE |  |  |  |  |  |
| 1226 | 1.5.2.3.2 | Walkthrough Test Cases & Scenarios Batch 3 with LDSO |  | 1d | 2024-03-28 A | 2024-03-28 A | 1225FS+5d | 100% |  | 2024-03-28 | 2024-03-28 | 1d |  |  |  |  |  | Ben Wickins | 8h | 8h |  | LDSO, Non-SIT LDSO | LDSO, Non-SIT LDSO | 5.24 | Complete | COMPLETE |  |  |  |  |  |
| 1227 | 1.5.2.3.3 | Action Feedback on Test Cases & Scenarios Batch 3 |  | 6d | 2024-03-29 A | 2024-04-05 A | 1226 | 100% |  | 2024-03-29 | 2024-04-05 | 6d |  |  |  |  |  | Ben Wickins | 48h | 48h |  | Non-SIT LDSO | Non-SIT LDSO, LDSO , Code Bodies | 5.24 | Complete | COMPLETE |  |  |  |  |  |
| 1228 | 1.5.2.4 | Test Cases & Scenarios Batch 1-3 Discussion at QWG |  | 1d | 2024-04-09 A | 2024-04-09 A | 1219, 1223, 1227FS+1d | 100% |  | 2024-04-09 | 2024-04-09 | 1d |  |  |  |  |  | Ben Wickins | 8h | 8h |  | Non-SIT LDSO, PP | Non-SIT LDSO, Code Bodies | 5.24 | Complete | COMPLETE |  |  |  |  |  |
| 1229 | 1.5.2.5 | Action QWG Feedback on Test Cases & Scenarios Batch 1-3 |  | 2d | 2024-04-10 A | 2024-04-11 A | 1228 | 100% |  | 2024-04-10 | 2024-04-11 | 2d |  |  |  |  |  | Ben Wickins | 16h | 16h |  | Non-SIT LDSO | Non-SIT LDSO, Code Bodies | 5.24 | Complete | COMPLETE |  |  |  |  |  |
| 1230 | 1.5.2.6 | Batch 1-3 Non-SIT LDSO QT Functional Test Scenarios and Test Cases approved | milestone | 0d | 2024-04-18 A | 2024-04-18 A | 1229FS+5d | 100% |  | 2024-04-18 | 2024-04-18 | 0d |  |  |  |  |  | Ben Wickins |  |  |  | Code Bodies | Non-SIT LDSO, Code Bodies | 5.24 | Complete | COMPLETE | T3-QU-0069 | QAG (Non-SIT LDSO) |  |  |  |
| 1231 | 1.5.3 | **Test Execution Schedule** |  | 84d | 2024-04-19 A | 2024-08-15 |  | 80% | 16.52d | 2024-04-19 | 2024-08-15 | 84d | 2024-01-29 | 2024-04-26 | 34d |  |  | N/A | 1144h | 918.95h | -0 | N/A | N/A | 5.24 |  |  |  |  | Systems Integration Testing (SIT) |  |  |
| 1232 | 1.5.3.1 | Draft Test Delivery Schedule for Functional and Operational Testing |  | 20d | 2024-04-19 A | 2024-05-16 A | 1230 | 100% |  | 2024-04-19 | 2024-05-16 | 20d | 2024-01-29 | 2024-03-22 |  |  |  | Ben Wickins | 160h | 160h |  | Non-SIT LDSO | SI Test, PP, Non-SIT LDSO | 5.24 | Complete | COMPLETE |  |  | Systems Integration Testing (SIT) |  |  |
| 1233 | 1.5.3.2 | Socialise Test Delivery Schedule with Code Bodies & LDSO for Review & Action Feedback |  | 37d | 2024-05-17 A | 2024-07-08 | 1232 | 78% | 8d | 2024-05-17 | 2024-07-08 | 37d |  |  | 53d | 0d |  | Ben Wickins | 296h | 232h |  | Non-SIT LDSO | LDSO, Code Bodies, Non-SIT LDSO | 5.24 | Green | GREEN |  |  |  |  |  |
| 1234 | 1.5.3.3 | Agree Test Execution Timetable Format at QWG, Including Anonymisation Requirements |  | 1d | 2024-07-09 | 2024-07-09 | 1233 |  |  | 2024-07-09 | 2024-07-09 | 1d | 2024-03-25 | 2024-04-19 | 53d | 0d |  | Ben Wickins | 8h |  |  | Non-SIT LDSO, PP | Non-SIT LDSO, Code Bodies | 5.24 | Green | GREEN |  |  | Systems Integration Testing (SIT) | 12.33 |  |
| 1235 | 1.5.3.4 | Action QWG Feedback |  | 3d | 2024-07-10 | 2024-07-12 | 1234 |  |  | 2024-07-10 | 2024-07-12 | 3d |  |  | 53d | 0d |  | Ben Wickins | 24h |  |  | Non-SIT LDSO, PP | Non-SIT LDSO, Code Bodies | 5.24 | Green | GREEN |  |  |  | 13.33 |  |
| 1236 | 1.5.3.5 | Agree Test Execution Timetable Format at QAG, Including Anonymisation Requirements | milestone | 0d | 2024-07-18 | 2024-07-18 | 1235FS+4d |  |  | 2024-07-18 | 2024-07-18 | 0d |  |  | 53d | 19d |  | Ben Wickins |  |  |  | Code Bodies | Non-SIT LDSO, Code Bodies | 5.25 | Green | GREEN | T3-QU-0111 | QAG (Non-SIT LDSO) |  | 21.71 |  |
| 1237 | 1.5.3.6 | Qualification Testing for Non-SIT LDSOs (Functional, Migration, NFT, Operational) Test Execution Schedule Approved | milestone | 0d | 2024-08-15 | 2024-08-15 | 1236 |  |  | 2024-08-15 | 2024-08-15 | 0d | 2024-04-26 | 2024-04-26 | 34d |  | start no earlier than 2024-08-15 | Ben Wickins |  |  |  | Non-SIT LDSO | Non-SIT LDSO, Code Bodies, PP | 5.24 | Green | GREEN | T3-QU-0008 | QAG (Non-SIT LDSO) | Systems Integration Testing (SIT) | 49.33 | T3 |
| 1238 | 1.5.4 | **Functional, Non-Functional, Operational & Migration Test Scenarios & Cases** |  | 110d | 2024-03-22 A | 2024-08-22 |  | 72% | 30.89d | 2024-03-22 | 2024-07-18 | 85d |  |  | 28d |  |  | N/A | 2376h | 1308.45h | -0 | N/A | N/A | 5.24 |  |  |  |  |  |  |  |
| 1239 | 1.5.4.1 | Test Scenarios & Cases - Functional - Drafted, Reviewed |  | 14d | 2024-04-01 A | 2024-04-18 A | 1208 | 100% |  | 2024-04-01 | 2024-04-18 | 14d |  |  |  |  |  | Ben Wickins | 112h | 112h |  | Non-SIT LDSO | Non-SIT LDSO, LDSO, Code Bodies | 5.24 | Complete | COMPLETE |  |  |  |  |  |
| 1240 | 1.5.4.2 | Test Scenarios & Cases- Functional - Approved at QAG | milestone | 0d | 2024-04-18 A | 2024-04-18 A | 1239 | 100% |  | 2024-04-18 | 2024-04-18 | 0d |  |  |  |  |  | Ben Wickins |  |  |  | Non-SIT LDSO | Non-SIT LDSO, LDSO, Code Bodies | 5.24 | Complete | COMPLETE | T3-QU-0070 | QAG (Non-SIT LDSO) |  |  |  |
| 1241 | 1.5.4.3 | Test Scenarios & Cases - Non-Functional - Drafted, Reviewed |  | 110d | 2024-03-22 A | 2024-08-22 | 1208, 935FF | 63% | 41d | 2024-03-22 | 2024-07-18 | 85d |  |  | 28d | 0d |  | Ben Wickins | 880h | 552h |  | Non-SIT LDSO | Non-SIT LDSO, LDSO, Code Bodies | 5.24 | Red | RED |  |  |  |  |  |
| 1242 | 1.5.4.4 | Test Scenarios & Cases - Non-Functional - Approved at QAG | milestone | 0d | 2024-08-22 | 2024-08-22 | 1241 |  |  | 2024-07-18 | 2024-07-18 | 0d |  |  | 28d | 27d | start no earlier than 2024-07-17 | Ben Wickins |  |  |  | Non-SIT LDSO | Non-SIT LDSO, LDSO, Code Bodies | 5.27 | Red | RED | T3-QU-0071 | QAG (Non-SIT LDSO) |  | 56.71 |  |
| 1243 | 1.5.4.5 | Test Scenarios & Cases - Migration - Drafted, Reviewed |  | 45d | 2024-03-22 A | 2024-05-23 A | 1208 | 100% |  | 2024-03-22 | 2024-05-23 | 45d |  |  |  |  |  | Ben Wickins | 360h | 360h |  | Non-SIT LDSO | Non-SIT LDSO, LDSO, Code Bodies | 5.24 | Complete | COMPLETE |  |  |  |  |  |
| 1244 | 1.5.4.6 | Test Scenarios & Cases - Migration - Approved at QAG | milestone | 0d | 2024-05-23 A | 2024-05-23 A | 1243 | 100% |  | 2024-05-23 | 2024-05-23 | 0d |  |  |  |  |  | Ben Wickins |  |  |  | Non-SIT LDSO | Non-SIT LDSO, LDSO, Code Bodies | 5.24 | Complete | COMPLETE | T3-QU-0072 | QAG (Non-SIT LDSO) |  |  |  |
| 1245 | 1.5.4.7 | Test Scenarios & Cases - Operational - Drafted, Reviewed |  | 34d | 2024-06-03 A | 2024-07-18 | 1208FS+51d | 53% | 16d | 2024-06-03 | 2024-07-18 | 34d |  |  | 48d | 0d |  | Ben Wickins | 272h | 144h |  | Non-SIT LDSO | Non-SIT LDSO, LDSO, Code Bodies | 5.24 | Green | GREEN |  |  |  |  |  |
| 1246 | 1.5.4.8 | Test Scenarios & Cases - Operational - Approved at QAG | milestone | 0d | 2024-07-18 | 2024-07-18 | 1245, 935FF |  |  | 2024-07-18 | 2024-07-18 | 0d |  |  | 48d | 18d |  | Ben Wickins |  |  |  | Non-SIT LDSO | Non-SIT LDSO, LDSO, Code Bodies | 5.24 | Green | GREEN | T3-QU-0073 | QAG (Non-SIT LDSO) |  | 21.71 |  |

Notes:
- 1230: 13/5: New milestone approved as part of cr47.
- 1237: 13/5: Date rebaselined as part of cr47 / Action: 29/4: BW to confirm date and if needs approval and link into an ado load and other prep activity
- 1240: 13/5: New milestone approved as part of cr47.
- 1242: 13/5: New milestone approved as part of cr47. 20/5: At risk because Non-functional Testing still subject to discussion at approach level / Impact: 25/6There is no impact the QT window and it will be approved at the August QAG / Issue: 25/6: Non functional test materials are not ready in time for July QAG
- 1244: 13/5: New milestone approved as part of cr47.
- 1246: 13/5: New milestone approved as part of cr47.

| ID | WBS | Task | Type | Duration | Start | Finish | Predecessors | Complete | Remaining | Baseline start | Baseline finish | Baseline duration | Total slack | Free slack | Deadline | Resources | Work | Actual work | Baseline cost | Responsible | Involved | Task Status | Update Version | Sched Status | RAG | Milestone ID | Text29 |
| --- | --- | --- | --- | --- | --- | --- | --- | --- | --- | --- | --- | --- | --- | --- | --- | --- | --- | --- | --- | --- | --- | --- | --- | --- | --- | --- | --- |
| 1247 | 1.5.5 | **Test Data** |  | 241d | 2024-01-22 A | 2024-12-23 |  | 49% | 122.9d | 2024-01-22 | 2024-12-23 | 241d | 44d |  |  | N/A | 3936h | 1149.29h | -0 | N/A | N/A | -385.67 | 5.24 |  |  |  |  |
| 1248 | 1.5.5.1 | Test Data Plan Drafted & Reviewed |  | 89d | 2024-01-22 A | 2024-05-23 A | 1203 | 100% |  | 2024-01-22 | 2024-05-23 | 89d |  |  |  | Ben Wickins | 712h | 712h |  | Code Bodies | Non-SIT LDSO, Code Bodies |  | 5.24 | Complete | COMPLETE |  |  |
| 1249 | 1.5.5.2 | Non-SIT LDSO QT Test Data Plan Approved by QAG | milestone | 0d | 2024-05-23 A | 2024-05-23 A | 1248 | 100% |  | 2024-05-16 | 2024-05-16 | 0d |  |  |  | Ben Wickins |  |  |  | Code Bodies | Non-SIT LDSO, Code Bodies |  | 5.24 | Complete | COMPLETE | T3-QU-0074 | QAG (Non-SIT LDSO) |
| 1250 | 1.5.5.3 | Develop Test Data Matrices |  | 10d | 2024-05-24 A | 2024-06-06 A | 1249 | 100% |  | 2024-05-24 | 2024-06-06 | 10d |  |  |  | Ben Wickins | 80h | 80h |  | Non-SIT LDSO | Non-SIT LDSO |  | 5.24 | Complete | COMPLETE |  |  |
| 1251 | 1.5.5.4 | Test Data Cut |  | 17d | 2024-05-24 A | 2024-06-17 A | 1249 | 100% |  | 2024-05-24 | 2024-06-17 | 17d |  |  |  | Ben Wickins | 136h | 136h |  | PP, Non-SIT LDSO | PP, Non-SIT LDSO |  | 5.24 | Complete | COMPLETE |  |  |
| 1252 | 1.5.5.5 | Test Data Cut Complete | milestone | 0d | 2024-06-17 A | 2024-06-17 A | 1251, 1250 | 100% |  | 2024-06-17 | 2024-06-17 | 0d |  |  |  | Ben Wickins |  |  |  | PP, Non-SIT LDSO | PP, Non-SIT LDSO |  | 5.27 | Complete | COMPLETE | T3-QU-0112 | QAG (Non-SIT LDSO) |
| 1253 | 1.5.5.6 | Test Data Reviewed by the Programme |  | 39d | 2024-06-18 A | 2024-08-09 | 1252 | 18% | 32d | 2024-06-18 | 2024-08-09 | 39d | 44d | 0d |  | Ben Wickins | 312h | 56h |  | Non-SIT LDSO | PP, Non-SIT LDSO |  | 5.24 | Green | GREEN |  |  |
| 1254 | 1.5.5.7 | Test Data Loaded |  | 17d | 2024-08-12 | 2024-09-03 | 1253 |  |  | 2024-08-12 | 2024-09-03 | 17d | 44d | 0d |  | Ben Wickins | 136h |  |  | Non-SIT LDSO | PP, Non-SIT LDSO | 46.33 | 5.24 | Green | GREEN |  |  |
| 1255 | 1.5.5.8 | Test Data Signed Off | milestone | 0d | 2024-09-03 | 2024-09-03 | 1254 |  |  | 2024-09-03 | 2024-09-03 | 0d | 44d | 0d |  | Ben Wickins |  |  |  | Non-SIT LDSO | PP, Non-SIT LDSO | 68.71 | 5.25 | Green | GREEN | T3-QU-0113 | QAG (Non-SIT LDSO) |
| 1256 | 1.5.5.9 | Test Execution Data Support |  | 79d | 2024-09-04 | 2024-12-23 | 1255 |  |  | 2024-09-04 | 2024-12-23 | 79d | 44d | 24d |  | Ben Wickins | 632h |  |  | Non-SIT LDSO | Non-SIT LDSO | 69.33 | 5.24 | Green | GREEN |  |  |
| 1257 | 1.5.6 | **Tooling** |  | 145d | 2024-01-31 A | 2024-08-20 |  | 73% | 39d | 2024-01-31 | 2024-08-20 | 145d | 30d |  |  | N/A | 2320h | 1696h | -0 | N/A | N/A | -385.67 | 5.24 |  |  |  |  |
| 1258 | 1.5.6.1 | Design Approach & Set-Up ADO Tool for Test & Defect Management Tool |  | 53d | 2024-01-31 A | 2024-04-12 A | 1203 | 100% |  | 2024-01-31 | 2024-04-12 | 53d |  |  |  | Ben Wickins | 424h | 424h |  | Non-SIT LDSO | Non-SIT LDSO, SI Test |  | 5.24 | Complete | COMPLETE |  |  |
| 1259 | 1.5.6.2 | Develop Training Requirements & Materials Inc. Day in the Life |  | 87d | 2024-04-15 A | 2024-08-13 | 1258 | 61% | 34d | 2024-04-15 | 2024-08-13 | 87d | 30d | 0d |  | Ben Wickins | 696h | 424h |  | Non-SIT LDSO | Non-SIT LDSO, SI Test |  | 5.24 | Green | GREEN |  |  |
| 1260 | 1.5.6.3 | ADO Launch |  | 5d | 2024-08-14 | 2024-08-20 | 1259, 1240, 1244, 1246 |  |  | 2024-08-14 | 2024-08-20 | 5d | 30d |  |  | Ben Wickins | 40h |  |  | Non-SIT LDSO | Non-SIT LDSO | 48.33 | 5.24 | Green | GREEN |  |  |
| 1261 | 1.5.7 | **Pre-Integration Testing** |  | 174d | 2024-01-31 A | 2024-09-30 |  | 56% | 75.86d | 2024-01-31 | 2024-09-30 | 174d | 694d |  |  | N/A | 5264h | 2008.99h | -0 | N/A | N/A | -385.67 | 5.24 |  |  |  |  |
| 1262 | 1.5.7.1 | PIT Guidance & Templates & Approach & Plans Developed |  | 106d | 2024-02-05 A | 2024-07-01 | 1203FS+3d | 97% | 3d | 2024-02-05 | 2024-07-01 | 106d | 0d |  |  | Ben Wickins | 848h | 824h |  | Non-SIT LDSO | Non-SIT LDSO, LDSO |  | 5.27 | Green | GREEN |  |  |
| 1263 | 1.5.7.2 | PIT Test Approach & Plan Deadline for Submission for Non-SIT LDSO​ QT | milestone | 0d | 2024-07-01 | 2024-07-01 | 1262 |  |  | 2024-07-01 | 2024-07-01 | 0d | 0d |  |  | Ben Wickins |  |  |  | Non-SIT LDSO | Non-SIT LDSO, LDSO | 4.71 | 5.27 | Green | GREEN | T3-QU-0075 | QAG (Non-SIT LDSO) |
| 1264 | 1.5.7.3 | Develop and agree PIT Test Scenarios |  | 20d | 2024-07-02 | 2024-07-29 | 1263 |  |  | 2024-06-17 | 2024-07-29 | 31d | 1d | 0d |  | Ben Wickins | 160h |  |  | Non-SIT LDSO | Non-SIT LDSO, Code Bodies, LDSO | 5.33 | 5.24 | Green | GREEN |  |  |
| 1265 | 1.5.7.4 | PIT Execution |  | 45d | 2024-07-30 | 2024-09-30 | 1264 |  |  | 2024-07-30 | 2024-09-30 | 45d | 1d | 0d |  | Ben Wickins | 360h |  |  | Non-SIT LDSO | Non-SIT LDSO, LDSO | 33.33 | 5.24 | Green | GREEN |  |  |
| 1266 | 1.5.7.5 | Non-SIT LDSO Participants have submitted PIT Test Completion Report & evidence for QT Entry​ | milestone | 0d | 2024-09-30 | 2024-09-30 | 1265 |  |  | 2024-09-30 | 2024-09-30 | 0d | 1d | 0d |  | Ben Wickins |  |  |  | Non-SIT LDSO | Non-SIT LDSO, LDSO | 95.71 | 5.24 | Green | GREEN | T3-QU-0076 | QAG (Non-SIT LDSO) |
| 1267 | 1.5.7.6 | **Placing Reliance - Code Body & LDSO Functional and Migration** |  | 147d | 2024-01-31 A | 2024-08-22 |  | 69% | 46d | 2024-01-31 | 2024-07-18 | 122d | 721d |  |  | N/A | 1992h | 1016h | -0 | N/A | N/A | -100.67 | 5.24 |  |  |  |  |
| 1268 | 1.5.7.6.1 | Placing Reliance Submitted & Reviewed |  | 21d | 2024-01-31 A | 2024-02-28 A | 1203 | 100% |  | 2024-01-31 | 2024-02-28 | 21d |  |  | 2024-01-05 | Ben Wickins | 168h | 168h |  | LDSO, Non-SIT LDSO | LDSO, Non-SIT LDSO |  | 5.24 | Complete | COMPLETE |  |  |
| 1269 | 1.5.7.6.2 | Define & Agree QT Testing for Each LDSO |  | 22d | 2024-02-29 A | 2024-03-29 A | 1268 | 100% |  | 2024-02-29 | 2024-03-29 | 22d |  |  |  | Ben Wickins | 176h | 176h |  | Non-SIT LDSO | LDSO, Non-SIT LDSO |  | 5.24 | Complete | COMPLETE |  |  |
| 1270 | 1.5.7.6.3 | Develop Test Scope & Reliance Submissions |  | 20d | 2024-04-01 A | 2024-04-26 A | 1269 | 100% |  | 2024-04-01 | 2024-04-26 | 20d |  |  |  | Ben Wickins | 160h | 160h |  | Non-SIT LDSO | LDSO, Non-SIT LDSO, Code Bodies |  | 5.24 | Complete | COMPLETE |  |  |
| 1271 | 1.5.7.6.4 | Review and Consultation |  | 84d | 2024-04-29 A | 2024-08-22 | 1270, 1214FF | 45% | 46d | 2024-04-29 | 2024-07-18 | 59d | 721d | 0d |  | Ben Wickins | 312h | 304h |  | Non-SIT LDSO | LDSO, Non-SIT LDSO |  | 5.27 | Red | RED |  |  |

Notes:
- 1249: 13/5: New milestone approved as part of cr47. 13/5: Date change to line up with QAG
- 1252: 28/5 LDSO will complete test data cut between 3rd and 17th June
- 1263: 13/5: New milestone approved as part of cr47. 11/6: Missed date because additional time requested by PPs. 24/6: Approved at QAG on 20/6
- 1266: 13/5: New milestone approved as part of cr47.

| ID | WBS | Task | Type | Duration | Start | Finish | Predecessors | Complete | Remaining | Baseline start | Baseline finish | Baseline duration | Baseline 1 start | Baseline 1 finish | Total slack | Free slack | Constraint | Resources | Work | Actual work | Baseline cost | Responsible | Involved | Task Status | Update Version | Sched Status | RAG | Milestone ID | Text29 | MHHS Programme Phase | Action | Tier |
| --- | --- | --- | --- | --- | --- | --- | --- | --- | --- | --- | --- | --- | --- | --- | --- | --- | --- | --- | --- | --- | --- | --- | --- | --- | --- | --- | --- | --- | --- | --- | --- | --- |
| 1272 | 1.5.7.7 | **Placing Reliance - Code Body & LDSO Non Functional and Operational** |  | 49d | 2024-06-17 A | 2024-08-22 |  | 6% | 46d | 2024-06-17 | 2024-07-18 | 24d |  |  | 721d |  |  | N/A | 584h | 48h | -0 | N/A | N/A | -100.67 | 5.25 |  |  |  |  |  |  |  |
| 1273 | 1.5.7.7.1 | Placing Reliance Submitted & Reviewed |  | 32d | 2024-06-17 A | 2024-07-30 | 1212FF-10d | 9% | 29d | 2024-06-17 | 2024-06-25 | 7d |  |  | 721d | 0d |  | Ben Wickins | 56h | 24h |  | LDSO, Non-SIT LDSO | LDSO, Non-SIT LDSO |  | 5.27 | Red | RED |  |  |  |  |  |
| 1274 | 1.5.7.7.2 | Review and Consultation |  | 17d | 2024-07-31 | 2024-08-22 | 1273 |  |  | 2024-06-26 | 2024-07-18 | 17d |  |  | 721d | 0d |  | Ben Wickins | 136h |  |  | Non-SIT LDSO | LDSO, Non-SIT LDSO | 34.33 | 5.27 | Red | RED |  |  |  |  |  |
| 1275 | 1.5.7.7.3 | PP Test Scope Presented at QAG | milestone | 0d | 2024-08-22 | 2024-08-22 | 1274, 1271 |  |  | 2024-07-18 | 2024-07-18 | 0d |  |  | 721d |  |  | Ben Wickins |  |  |  | Non-SIT LDSO | LDSO, Non-SIT LDSO | 56.71 | 5.27 | Red | RED | T3-QU-0077 | QAG (Non-SIT LDSO) |  |  |  |
| 1276 | 1.5.8 | **LDSO Test Reporting** |  | 118d | 2024-04-19 A | 2024-10-01 |  | 43% | 67.72d | 2024-04-19 | 2024-10-01 | 118d |  |  | 0d |  |  | N/A | 1864h | 636.11h | -0 | N/A | N/A |  | 5.24 |  |  |  |  |  |  |  |
| 1277 | 1.5.8.1 | Interim Test Report & Plan Developed & Reviewed |  | 71d | 2024-04-19 A | 2024-07-26 | 1230 | 69% | 22d | 2024-04-19 | 2024-07-26 | 71d |  |  | 0d |  |  | Ben Wickins | 568h | 392h |  | Non-SIT LDSO, LDSO | Non-SIT LDSO, LDSO |  | 5.24 | Green | GREEN |  |  |  |  |  |
| 1278 | 1.5.8.2 | Test Plan Submission to MHHS Programme For Review | milestone | 0d | 2024-07-26 | 2024-07-26 | 1277 |  |  | 2024-07-26 | 2024-07-26 | 0d |  |  | 0d |  |  | Ben Wickins |  |  |  | LDSO | Non-SIT LDSO, LDSO | 29.71 | 5.25 | Green | GREEN | T3-QU-0114 | QAG (Non-SIT LDSO) |  |  |  |
| 1279 | 1.5.8.3 | Final Test Report Developed & Submitted |  | 44d | 2024-07-29 | 2024-09-26 | 1278 |  |  | 2024-07-29 | 2024-09-26 | 44d |  |  | 0d |  |  | Ben Wickins | 352h |  |  | Non-SIT LDSO | Non-SIT LDSO, LDSO | 32.33 | 5.24 | Green | GREEN |  |  |  |  |  |
| 1280 | 1.5.8.4 | Non-SIT LDSO QT Test Execution Starts | milestone | 0d | 2024-10-01 | 2024-10-01 | 1279FS+3d, 1260, 1287, 1294, 1295, 1237 |  |  | 2024-10-01 | 2024-10-01 | 0d |  |  | 0d |  |  | Ben Wickins |  |  |  | Non-SIT LDSO | Non-SIT LDSO, LDSO, Code Bodies | 96.71 | 5.25 | Green | GREEN | T3-QU-0115 | QAG (Non-SIT LDSO) |  |  |  |
| 1281 | 1.5.9 | **Test Environment** |  | 111d | 2024-04-17 A | 2024-09-18 |  | 47% | 58.76d | 2024-04-17 | 2024-09-18 | 111d | 2024-01-29 | 2024-07-05 | 9d |  |  | N/A | 1976h | 801.88h | -0 | N/A | N/A |  | 5.24 |  |  |  |  | Systems Integration Testing (SIT) |  |  |
| 1282 | 1.5.9.1 | Define Test Harness Requirements and Sign-Off with SRO |  | 13d | 2024-04-17 A | 2024-05-03 A | 471 | 100% |  | 2024-04-17 | 2024-05-03 | 13d |  |  |  |  |  | Ben Wickins | 104h | 104h |  | Non-SIT LDSO | Non-SIT LDSO,SRO,Sims and Ems |  | 5.24 | Complete | COMPLETE |  |  |  |  |  |
| 1283 | 1.5.9.2 | Central System (DIP Env & Helix Test Harness) Test Environment DBT |  | 92d | 2024-04-17 A | 2024-08-22 | 471 | 55% | 41d | 2024-04-17 | 2024-08-22 | 92d |  |  | 28d | 0d |  | Ben Wickins | 736h | 408h |  | LDSO | Non SIT-LDSO, LDSO |  | 5.24 | Green | GREEN |  |  |  |  |  |
| 1284 | 1.5.9.3 | Coordinate LDSO Env Preparation |  | 30d | 2024-07-12 | 2024-08-22 | 1283FF |  |  | 2024-07-12 | 2024-08-22 | 30d |  |  | 28d | 19d |  | Ben Wickins | 240h |  |  | Non-SIT LDSO | Non-SIT LDSO | 15.33 | 5.24 | Green | GREEN |  |  |  |  |  |
| 1285 | 1.5.9.4 | DIP available for Onboarding |  | 1d | 2024-08-01 | 2024-08-01 |  |  |  | 2024-08-01 | 2024-08-01 | 1d |  |  | 9d | 0d | start no earlier than 2024-08-01 | Ben Wickins | 8h |  |  | Test Env | Test Env, Non-SIT LDSO | 35.33 | 5.24 | Green | GREEN |  |  |  | 11/3: Ask Simon B for the link |  |
| 1286 | 1.5.9.5 | Qualification Testing for Non-SIT LDSOs Participants' environments) Ready to start DIP onboarding (incl. certificates and security compliance) | milestone | 0d | 2024-08-05 | 2024-08-05 | 1285FS+2d |  |  | 2024-08-05 | 2024-08-05 | 0d | 2024-04-26 | 2024-04-26 | 9d | 0d |  | Ben Wickins |  |  |  | Non-SIT LDSO | Code Bodies, PP, IPA | 39.71 | 5.24 | Green | GREEN | T3-QU-0009 | QAG (Non-SIT LDSO) | Systems Integration Testing (SIT) |  | T3 |
| 1287 | 1.5.9.6 | LDSO Test Environments Connection Confirmed to UIT Environment | milestone | 0d | 2024-09-18 | 2024-09-18 | 1286FS+32d, 1284 |  |  | 2024-09-18 | 2024-09-18 | 0d |  |  | 9d |  |  | Ben Wickins |  |  |  | Non-SIT LDSO | Code Bodies, PP, IPA | 83.71 | 5.24 | Green | GREEN | T3-QU-0078 | QAG (Non-SIT LDSO) |  | 13/5: Date in cry is 18/9? |  |
| 1288 | 1.5.10 | **Test Readiness** |  | 65d | 2024-07-02 | 2024-09-30 |  |  |  | 2024-06-17 | 2024-09-30 | 76d |  |  | 0d |  |  | N/A | 1048h |  | -0 | N/A | N/A |  | 5.24 |  |  |  |  |  |  |  |
| 1289 | 1.5.10.1 | Preparation for Interim Test Readiness Report |  | 19d | 2024-07-02 | 2024-07-26 | 1263 |  |  | 2024-06-17 | 2024-07-26 | 30d |  |  | 0d |  |  | Ben Wickins | 152h |  |  | LDSO | LDSO, Non-SIT LDSO | 5.33 | 5.24 | Green | GREEN |  |  |  |  |  |
| 1290 | 1.5.10.2 | Interim Test Readiness Report Submission to MHHS Programme for Review | milestone | 0d | 2024-07-26 | 2024-07-26 | 1289 |  |  | 2024-07-26 | 2024-07-26 | 0d |  |  | 0d |  |  | Ben Wickins |  |  |  | LDSO | Non-SIT LDSO, LDSO | 29.71 | 5.25 | Green | GREEN | T3-QU-0116 | QAG (Non-SIT LDSO) |  |  |  |
| 1291 | 1.5.10.3 | LDSO Update Readiness Report & Final Assurance by Programme |  | 25d | 2024-07-29 | 2024-08-30 | 1290 |  |  | 2024-07-29 | 2024-08-30 | 25d |  |  | 0d |  |  | Ben Wickins | 200h |  |  | Non-SIT LDSO, LDSO | Non-SIT LDSO, LDSO | 32.33 | 5.24 | Green | GREEN |  |  |  |  |  |
| 1292 | 1.5.10.4 | Final Test Readiness Report Submitted to MHHS Programme |  | 1d | 2024-09-02 | 2024-09-02 | 1291 |  |  | 2024-09-02 | 2024-09-02 | 1d |  |  | 8d | 7d |  | Ben Wickins | 8h |  |  | LDSO | Non-SIT LDSO, Code Bodies | 67.33 | 5.24 | Green | GREEN |  |  |  |  |  |
| 1293 | 1.5.10.5 | Final Programme Assurance of LDSO Test Readiness |  | 21d | 2024-09-02 | 2024-09-30 | 1291 |  |  | 2024-09-02 | 2024-09-30 | 21d |  |  | 0d |  |  | Ben Wickins | 168h |  |  | Non-SIT LDSO | Non-SIT LDSO, LDSO | 67.33 | 5.24 | Green | GREEN |  |  |  |  |  |
| 1294 | 1.5.10.6 | Qualification Testing for Non-SIT LDSOs (Functional, Migration, NFT, Operational) Programme Test Readiness confirmed | milestone | 0d | 2024-09-30 | 2024-09-30 | 1292FS+13d, 1266, 1240, 1242, 1244, 1282 |  |  | 2024-09-30 | 2024-09-30 | 0d | 2024-07-05 | 2024-07-05 | 1d |  |  | Ben Wickins |  |  |  | Non-SIT LDSO | SI Test, PP, Non-SIT LDSO | 95.71 | 5.24 | Green | GREEN | T3-QU-0007 | QAG (Non-SIT LDSO) | Systems Integration Testing (SIT) |  | T3 |
| 1295 | 1.5.10.7 | Qualification Testing for Non-SIT LDSOs (Functional, Migration, NFT, Operational) Test Readiness Confirmed (Final Test Readiness Review for LDSO) | milestone | 0d | 2024-09-30 | 2024-09-30 | 1291, 1293 |  |  | 2024-09-30 | 2024-09-30 | 0d | 2024-07-05 | 2024-07-05 | 0d |  |  | Ben Wickins |  |  |  | LDSO | SI Test, PP, LDSO | 95.71 | 5.24 | Green | GREEN | T2-QU-0550 | QAG (Non-SIT LDSO) | Systems Integration Testing (SIT) |  |  |

Notes:
- 1275: To go to 20/6 QAG for date change and name change to PP Test Scope presented at QAG. 11/6: Date missed because update to S and A QA and P. 24/6: Approved at QAG on 20/6. To go to july QAG for date change approval
- 1286: 13/5: Date rebaselined as part of cr47
- 1287: 13/5: New milestone approved as part of cr47.
- 1294: 13/5: Date rebaselined as part of cr47
- 1295: 13/5: New milestone approved as part of cr47.

| ID | WBS | Task | Type | Duration | Start | Finish | Predecessors | Complete | Remaining | Baseline start | Baseline finish | Baseline duration | Baseline 1 start | Baseline 1 finish | Total slack | Free slack | Constraint | Resources | Work | Actual work | Baseline cost | Responsible | Involved | Task Status | Update Version | Sched Status | RAG | Milestone ID | Text29 | MHHS Programme Phase |
| --- | --- | --- | --- | --- | --- | --- | --- | --- | --- | --- | --- | --- | --- | --- | --- | --- | --- | --- | --- | --- | --- | --- | --- | --- | --- | --- | --- | --- | --- | --- |
| 1296 | 1.5.11 | **Test Window** |  | 59d | 2024-10-01 | 2024-12-20 |  |  |  | 2024-10-01 | 2024-12-20 | 59d |  |  | 0d |  |  | N/A | 944h |  | -0 | N/A | N/A | -527.67 | 5.24 |  |  |  |  |  |
| 1297 | 1.5.11.1 | All Non-SIT LDSOs Qualification Testing |  | 59d | 2024-10-01 | 2024-12-20 | 1295 |  |  | 2024-10-01 | 2024-12-20 | 59d |  |  | 0d |  |  | Ben Wickins | 472h |  |  | LDSO | Non-SIT LDSO,Code Bodies, LDSO | 96.33 | 5.24 | Green | GREEN |  |  |  |
| 1298 | 1.5.12 | **Test Result Assurance** |  | 60d | 2024-11-04 | 2025-01-24 |  |  |  | 2024-11-04 | 2025-01-24 | 60d |  |  | 0d |  |  | N/A | 760h |  | -0 | N/A | N/A |  | 5.24 |  |  |  |  |  |
| 1299 | 1.5.12.1 | LDSOs Develop & Submit Test Report (QT Test Completion Report) |  | 19d | 2024-11-04 | 2024-11-28 | 1280FS+23d |  |  | 2024-11-04 | 2024-11-28 | 19d |  |  | 0d |  |  | Ben Wickins | 152h |  |  | LDSO | Non-SIT LDSO, LDSO | 130.33 | 5.24 | Green | GREEN |  |  |  |
| 1300 | 1.5.12.2 | Test Reports Reviewed By MHHS & Code Bodies & Finalised |  | 16d | 2024-11-29 | 2024-12-20 | 1299 |  |  | 2024-11-29 | 2024-12-20 | 16d |  |  | 0d |  |  | Ben Wickins | 128h |  |  | Non-SIT LDSO | Non-SIT LDSO, Code Bodies | 155.33 | 5.24 | Green | GREEN |  |  |  |
| 1301 | 1.5.12.3 | Non-SIT LDSOs submission deadline for their QT Test Completion Report to MHHS Programme | milestone | 0d | 2024-12-20 | 2024-12-20 | 1300, 1297 |  |  | 2024-12-20 | 2024-12-20 | 0d |  |  | 0d |  |  | Ben Wickins |  |  |  | Non-SIT LDSO | Non-SIT LDSO | 176.71 | 5.24 | Green | GREEN | T3-QU-0079 | QAG (Non-SIT LDSO) |  |
| 1302 | 1.5.12.4 | Qualification Testing for Non-SIT LDSOs (Functional, Migration, NFT, Operational) 1 End | milestone | 0d | 2025-01-24 | 2025-01-24 | 1301FS+25d, 1256 |  |  | 2025-01-24 | 2025-01-24 | 0d |  |  | 20d |  |  | Ben Wickins |  |  |  | Non-SIT LDSO | Non-SIT LDSO | 211.71 | 5.24 | Green | GREEN | T3-QU-0010 | QAG (Non-SIT LDSO) |  |
| 1303 | 1.5.13 | **Non-SIT LDSO Qualification Closure** |  | 45d | 2024-12-23 | 2025-02-21 |  |  |  | 2024-12-23 | 2025-02-28 | 49d |  |  | 0d |  |  | N/A | 520h |  | -0 | N/A | N/A |  | 5.24 |  |  |  |  |  |
| 1304 | 1.5.13.1 | Non-SIT LDSO Qualification Learned Captured |  | 15d | 2024-12-23 | 2025-01-10 | 1301 |  |  | 2024-12-23 | 2025-01-10 | 15d |  |  | 0d |  |  | Ben Wickins | 120h |  |  | Non-SIT LDSO | Non-SIT LDSO | 179.33 | 5.24 | Green | GREEN |  |  |  |
| 1305 | 1.5.13.2 | Non-SIT LDSO Qualification Closure Down |  | 5d | 2025-01-13 | 2025-01-17 | 1304 |  |  | 2025-01-13 | 2025-01-17 | 5d |  |  | 0d |  |  | Ben Wickins | 40h |  |  | Non-SIT LDSO | Non-SIT LDSO | 200.33 | 5.24 | Green | GREEN |  |  |  |
| 1306 | 1.5.13.3 | BSC PAB & REC Manager approval of Qualification for Non-SIT LDSOs (Start of Migration for Qualification Participants) | milestone | 0d | 2025-02-21 | 2025-02-21 | 1305FS+25d, 1302, 1405, 1406 |  |  | 2025-02-28 | 2025-02-28 | 0d |  |  | 0d |  |  | Ben Wickins |  |  |  | Non-SIT LDSO | Non-SIT LDSO | 239.71 | 5.24 | Green | GREEN | T2-QU-0500 | QAG (Non-SIT LDSO) |  |
| 1307 | 1.6 | **S & A QUALIFICATION** |  | 870d | 2022-10-31 A | 2026-02-27 |  | 20% | 692.79d | 2023-11-07 | 2026-02-27 | 603d | 2024-01-29 | 2024-07-05 | 325d |  |  | N/A | 100784h | 11499.5h | -0 | N/A | N/A | -461.67 |  |  |  |  |  | Systems Integration Testing (SIT) |
| 1308 | 1.6.1 | **MHHS Qualification - Qualification Deliverables** |  | 349d | 2023-11-07 A | 2025-03-07 |  | 71% | 101.9d | 2023-11-07 | 2024-09-12 | 223d |  |  | 580d |  |  | N/A | 17648h | 4980.75h | -0 | N/A | N/A | -131.67 | 5.24 |  |  |  |  |  |
| 1309 | 1.6.1.1 | **BSC & REC Assessment Criteria** |  | 213d | 2023-11-07 A | 2024-08-29 |  | 73% | 56.8d | 2023-11-07 | 2024-08-29 | 212d |  |  | 687d |  |  | N/A | 2304h | 608h | -0 | N/A | N/A | -131.67 | 5.24 |  |  |  |  |  |
| 1310 | 1.6.1.1.1 | Draft BSC Assessment Criteria (Functional) |  | 21d | 2023-11-07 A | 2023-12-05 A |  | 100% |  | 2023-11-07 | 2023-12-05 | 21d |  |  |  |  | finish no earlier than 2023-12-05 | Laura Kennedy | 168h | 168h |  | Code Bodies |  |  | 5.24 | Complete | COMPLETE |  |  |  |
| 1311 | 1.6.1.1.2 | BSC PAB Review |  | 1d | 2023-12-14 A | 2023-12-14 A |  | 100% |  | 2023-12-14 | 2023-12-14 | 1d |  |  |  |  | start no earlier than 2023-12-14 | Laura Kennedy | 8h | 8h |  | Code Bodies |  |  | 5.24 | Complete | COMPLETE |  |  |  |
| 1312 | 1.6.1.1.3 | Update BSC Assessment Criteria (Functional, Non-Functional, Migration) |  | 30d | 2024-02-07 A | 2024-03-19 A |  | 100% |  | 2024-02-07 | 2024-03-19 | 30d |  |  |  |  | finish no earlier than 2024-03-19 | Laura Kennedy | 240h | 240h |  | Code Bodies |  |  | 5.24 | Complete | COMPLETE |  |  |  |
| 1313 | 1.6.1.1.4 | REC & BSC PAB Approval |  | 3d | 2024-03-26 A | 2024-03-28 A |  | 100% |  | 2024-03-26 | 2024-03-28 | 3d |  |  |  |  | start no earlier than 2024-03-28 | Laura Kennedy | 24h | 24h |  | Code Bodies |  |  | 5.24 | Complete | COMPLETE |  |  |  |
| 1314 | 1.6.1.1.5 | Update BSC Assessment Criteria (Functional, Non-Functional, Migration, Operational) |  | 20d | 2024-07-24 | 2024-08-20 | 983FS+28d |  |  | 2024-07-24 | 2024-08-20 | 20d |  |  | 687d | 0d |  | Laura Kennedy | 160h |  |  | Code Bodies |  | 27.33 | 5.24 | Green | GREEN |  |  |  |
| 1315 | 1.6.1.1.6 | Assessment Criteria (Functional, Non-Functional, Migration, Operational) Approved by REC PAB and BSC PAB | milestone | 0d | 2024-08-29 | 2024-08-29 | 1314FS+7d |  |  | 2024-08-29 | 2024-08-29 | 0d |  |  | 687d | 6d |  | Laura Kennedy |  |  |  | Code Bodies |  | 63.71 | 5.25 | yellow | GREEN | T3-QU-0080 | QAG |  |
| 1316 | 1.6.1.2 | **Qualification Approach and Plan** |  | 194d | 2023-12-04 A | 2024-08-29 |  | 77% | 44.55d | 2023-12-04 | 2024-08-29 | 194d |  |  | 716d |  |  | N/A | 3792h | 1580.75h | -0 | N/A | N/A | -131.67 | 5.24 |  |  |  |  |  |
| 1317 | 1.6.1.2.1 | **Qualification Approach and Plan v2** |  | 84d | 2023-12-04 A | 2024-03-28 |  | 99% | 0d | 2023-12-04 | 2024-03-28 | 84d |  |  | 0d |  |  | N/A | 1200h | 768h | -0 | N/A | N/A | -131.67 | 5.24 |  |  |  |  |  |
| 1318 | 1.6.1.2.1.1 | Draft Qualification Approach and Plan v2 |  | 30d | 2023-12-04 A | 2024-01-12 A |  | 100% |  | 2023-12-04 | 2024-01-12 | 30d |  |  |  |  | finish no earlier than 2024-01-12 | Laura Kennedy | 240h | 240h |  | Code Bodies |  |  | 5.24 | Complete | COMPLETE |  |  |  |
| 1319 | 1.6.1.2.1.2 | Internal Review (Code Bodies and MHHSP) for Qualification Approach and Plan V2 |  | 10d | 2024-01-15 A | 2024-01-26 A | 1318 | 100% |  | 2024-01-15 | 2024-01-26 | 10d |  |  |  |  | finish no earlier than 2024-01-26 | Laura Kennedy | 80h | 80h |  | Code Bodies, SI Team, SRO |  |  | 5.24 | Complete | COMPLETE |  |  |  |
| 1320 | 1.6.1.2.1.3 | Industry consultation for Qualification Approach and Plan v2 |  | 11d | 2024-01-31 A | 2024-02-14 A | 1319 | 100% |  | 2024-01-31 | 2024-02-14 | 11d |  |  |  |  | start no earlier than 2024-01-31 | Laura Kennedy | 88h | 88h |  | Participants |  |  | 5.24 | Complete | COMPLETE |  |  |  |
| 1321 | 1.6.1.2.1.4 | Update Qualification Approach and Plan v2 post industry consultation |  | 10d | 2024-02-15 A | 2024-02-28 A | 1320 | 100% |  | 2024-02-15 | 2024-02-28 | 10d |  |  |  |  |  | Laura Kennedy | 80h | 80h |  | Code Bodies |  |  | 5.24 | Complete | COMPLETE |  |  |  |
| 1322 | 1.6.1.2.1.5 | QWG Endorsement of Qualification Approach and Plan v2 |  | 1d | 2024-03-12 A | 2024-03-12 A |  | 100% |  | 2024-03-12 | 2024-03-12 | 1d |  |  |  |  | start no earlier than 2024-03-12 | Laura Kennedy | 8h | 8h |  | Code Bodies |  |  | 5.24 | Complete | COMPLETE |  |  |  |
| 1323 | 1.6.1.2.1.6 | QAG Approval of Qualification Approach and Plan v2 |  | 1d | 2024-03-21 A | 2024-03-21 A |  | 100% |  | 2024-03-21 | 2024-03-21 | 1d |  |  |  |  | start no earlier than 2024-03-21 | Laura Kennedy | 8h | 8h |  | Code Bodies |  |  | 5.24 | Complete | COMPLETE |  |  |  |
| 1324 | 1.6.1.2.1.7 | BSC and REC PAB Approval of Qualification Approach and Plan v2 |  | 3d | 2024-03-26 A | 2024-03-28 A |  | 100% |  | 2024-03-26 | 2024-03-28 | 3d |  |  |  |  | finish no earlier than 2024-03-28 | Laura Kennedy | 24h | 24h |  | Code Bodies |  |  | 5.24 | Complete | COMPLETE |  |  |  |
| 1325 | 1.6.1.2.1.8 | Functional Testing elements of Qualification Approach & Plan v2 approvement by REC PAB and BSC PAB | milestone | 0d | 2024-03-28 A | 2024-03-28 A | 1324 | 100% |  | 2024-03-28 | 2024-03-28 | 0d |  |  |  |  |  | Laura Kennedy |  |  |  | Code Bodies |  |  | 5.24 | Complete | COMPLETE | T3-QU-0063 | QAG |  |
| 1326 | 1.6.1.2.1.9 | Migration Testing elements of Qualification Approach & Plan v2 appoved by REC PAB and BSC PAB | milestone | 0d | 2024-03-28 A | 2024-03-28 A | 1324 | 100% |  | 2024-03-28 | 2024-03-28 | 0d |  |  |  |  |  | Laura Kennedy |  |  |  | Code Bodies |  |  | 5.24 | Complete | COMPLETE | T3-QU-0064 | QAG |  |

Notes:
- 1297: Action: 11/4: Detailed test schedule in development and due for 5/6 when Code Bodies test delivery schedule and will then enter in to QWG/QAG process. Once this has been agreed (end july) futher detail will be added re: test groups timelines.
- 1301: 13/5: New milestone approved as part of cr47.
- 1302: 13/5: No change as part of cr47
- 1306: 13/5: name changed as part of cr47.

| ID | WBS | Task | Type | Duration | Start | Finish | Predecessors | Complete | Remaining | Baseline start | Baseline finish | Baseline duration | Total slack | Free slack | Constraint | Resources | Work | Actual work | Baseline cost | Responsible | Involved | Task Status | Update Version | Sched Status | RAG | Milestone ID | Text29 | Impact |
| --- | --- | --- | --- | --- | --- | --- | --- | --- | --- | --- | --- | --- | --- | --- | --- | --- | --- | --- | --- | --- | --- | --- | --- | --- | --- | --- | --- | --- |
| 1327 | 1.6.1.2.2 | **Qualification Approach and Plan v3** |  | 84d | 2024-05-06 A | 2024-08-29 |  | 55% | 37.74d | 2024-05-06 | 2024-08-29 | 84d | 716d |  |  | N/A | 1040h | 572.75h | -0 | N/A | N/A | -133.67 | 5.24 |  |  |  |  |  |
| 1328 | 1.6.1.2.2.1 | Draft Qualification Approach and Plan v3 |  | 35d | 2024-05-06 A | 2024-06-21 A | 918 | 100% |  | 2024-05-06 | 2024-06-21 | 35d |  |  | finish no earlier than 2024-05-17 | Laura Kennedy | 280h | 280h |  | Code Bodies |  |  | 5.27 | Complete | COMPLETE |  |  |  |
| 1329 | 1.6.1.2.2.2 | Internal Review (Code Bodies and MHHSP) of Qualification Approach and Plan v3 |  | 10d | 2024-06-24 A | 2024-07-05 | 1328 | 30% | 7d | 2024-06-24 | 2024-07-05 | 10d | 716d | 0d |  | Laura Kennedy | 80h | 24h |  | Code Bodies, SI Team, SRO |  |  | 5.27 | Green | GREEN |  |  |  |
| 1330 | 1.6.1.2.2.3 | Industry consultation for Qualification Approach and Plan v3 |  | 10d | 2024-07-08 | 2024-07-19 | 1329 |  |  | 2024-07-08 | 2024-07-19 | 10d | 716d | 0d |  | Laura Kennedy | 80h |  |  | Participants |  | 11.33 | 5.27 | Green | GREEN |  |  |  |
| 1331 | 1.6.1.2.2.4 | Update Qualification Approach and Plan v3 Post-Consultation |  | 10d | 2024-07-22 | 2024-08-02 | 1330 |  |  | 2024-07-22 | 2024-08-02 | 10d | 716d | 0d |  | Laura Kennedy | 80h |  |  | Code Bodies |  | 25.33 | 5.27 | Green | GREEN |  |  |  |
| 1332 | 1.6.1.2.2.5 | QWG Endorsement of Qualification Approach and Plan v3 |  | 1d | 2024-08-13 | 2024-08-13 | 1331FS+6d |  |  | 2024-08-13 | 2024-08-13 | 1d | 716d | 0d |  | Laura Kennedy | 8h |  |  | Code Bodies |  | 47.33 | 5.27 | Green | GREEN |  |  |  |
| 1333 | 1.6.1.2.2.6 | QAG Approval of Qualification Approach and Plan v3 | milestone | 0d | 2024-08-22 | 2024-08-22 | 1332FS+7d |  |  | 2024-08-22 | 2024-08-22 | 0d | 716d | 0d |  | Laura Kennedy |  |  |  | Code Bodies |  | 56.71 | 5.27 | Green | GREEN | T3-QU-0081 | QAG |  |
| 1334 | 1.6.1.2.2.7 | BSC and REC PAB Approval of Qualification Approach and Plan v3 |  | 3d | 2024-08-27 | 2024-08-29 | 1333FS+2d |  |  | 2024-08-27 | 2024-08-29 | 3d | 716d | 0d |  | Laura Kennedy | 24h |  |  | Code Bodies |  | 61.33 | 5.27 | Green | GREEN |  |  |  |
| 1335 | 1.6.1.2.2.8 | Non-Functional Testing elements of Qualification Approach and Plan v3 approved by REC PAB and BSC PAB | milestone | 0d | 2024-08-29 | 2024-08-29 | 1334 |  |  | 2024-08-29 | 2024-08-29 | 0d | 716d |  |  | Laura Kennedy |  |  |  | Code Bodies |  | 63.71 | 5.27 | Green | GREEN | T3-QU-0065 | QAG |  |
| 1336 | 1.6.1.2.3 | **Qualification Approach and Plan v4 (Final)** | inactive | 55d | 2024-06-14 | 2024-08-29 |  |  |  | 2024-06-14 | 2024-08-29 | 55d | 716d |  |  | N/A | 760h |  | -0 | N/A | N/A | -133.67 | 5.27 |  |  |  |  |  |
| 1337 | 1.6.1.2.3.1 | Draft Qualification Approach and Plan v4 | inactive | 6d | 2024-06-14 | 2024-06-21 | 983 |  |  | 2024-06-14 | 2024-06-21 | 6d | 716d | 0d |  | Laura Kennedy | 48h |  |  | Code Bodies |  | -12.67 | 5.27 |  | RED |  |  |  |
| 1338 | 1.6.1.2.3.2 | Internal Review (Code Bodies and MHHSP) for Qualification Approach and Plan v4 | inactive | 10d | 2024-06-24 | 2024-07-05 | 1337 |  |  | 2024-06-24 | 2024-07-05 | 10d | 716d | 0d |  | Laura Kennedy | 80h |  |  | Code Bodies, SI Team, SRO |  | -2.67 | 5.27 |  | GREEN |  |  |  |
| 1339 | 1.6.1.2.3.3 | Industry consultation for Qualification Approach and Plan v4 | inactive | 10d | 2024-07-08 | 2024-07-19 | 1338 |  |  | 2024-07-08 | 2024-07-19 | 10d | 716d | 0d |  | Laura Kennedy | 80h |  |  | Participants |  | 11.33 | 5.27 |  | GREEN |  |  |  |
| 1340 | 1.6.1.2.3.4 | Update Qualification Approach and Plan v4 Post-Consultation | inactive | 10d | 2024-07-22 | 2024-08-02 | 1339 |  |  | 2024-07-22 | 2024-08-02 | 10d | 716d | 0d |  | Laura Kennedy | 80h |  |  | Code Bodies |  | 25.33 | 5.27 |  | GREEN |  |  |  |
| 1341 | 1.6.1.2.3.5 | QWG Endorsement of Qualification Approach and Plan v4 | inactive | 1d | 2024-08-13 | 2024-08-13 | 1340FS+6d |  |  | 2024-08-13 | 2024-08-13 | 1d | 716d | 0d |  | Laura Kennedy | 8h |  |  | Code Bodies |  | 47.33 | 5.27 |  | GREEN |  |  |  |
| 1342 | 1.6.1.2.3.6 | QAG Approval of Qualification Approach and Plan v4 | milestone, inactive | 0d | 2024-08-22 | 2024-08-22 | 1341FS+7d |  |  | 2024-08-22 | 2024-08-22 | 1d | 716d | 0d |  | Laura Kennedy |  |  |  | Code Bodies |  | 56.71 | 5.27 |  | GREEN | T3-QU-0082 | QAG | 25/6: v3 and v4 overlapped |
| 1343 | 1.6.1.2.3.7 | BSC and REC PAB Approval of Qualification Approach and Plan v4 | inactive | 3d | 2024-08-27 | 2024-08-29 | 1342FS+2d |  |  | 2024-08-27 | 2024-08-29 | 3d | 716d | 0d |  | Laura Kennedy | 24h |  |  | Code Bodies |  | 61.33 | 5.27 |  | GREEN |  |  |  |
| 1344 | 1.6.1.2.3.8 | Operational Testing elements of Qualification Approach & Plan v4 approved by REC PAB & BSC PAB | milestone, inactive | 0d | 2024-08-29 | 2024-08-29 | 1343 |  |  | 2024-08-29 | 2024-08-29 | 0d | 716d | 0d |  | Laura Kennedy |  |  |  | Code Bodies |  | 63.71 | 5.27 |  | GREEN | T3-QU-0068 | QAG | 25/6: v3 and v4 overlapped |
| 1345 | 1.6.1.2.3.9 | Final Qualification Approach & Plan v4 approved by REC PAB & BSC PAB | milestone, inactive | 0d | 2024-08-29 | 2024-08-29 | 1343, 1344 |  |  | 2024-08-29 | 2024-08-29 | 0d | 716d |  |  | Laura Kennedy |  |  |  | Code Bodies |  | 63.71 | 5.27 |  | GREEN | T3-QU-0062 | QAG | 25/6: v3 and v4 overlapped |
| 1346 | 1.6.1.3 | **Qualification Assessment Document** |  | 316d | 2023-12-22 A | 2025-03-07 |  | 68% | 102.65d | 2023-12-22 | 2024-09-12 | 190d | 2d |  |  | N/A | 8760h | 2624h | -0 | N/A | N/A | -131.67 | 5.24 |  |  |  |  |  |
| 1347 | 1.6.1.3.1 | **Qualification Assessment Document v1** |  | 70d | 2023-12-22 A | 2024-03-28 |  | 99% | 0d | 2023-12-22 | 2024-03-28 | 70d | 0d |  |  | N/A | 1072h | 752h | -0 | N/A | N/A | -131.67 | 5.24 |  |  |  |  |  |
| 1348 | 1.6.1.3.1.1 | Draft Qualification Assessment Document v1 |  | 30d | 2023-12-22 A | 2024-02-01 A |  | 100% |  | 2023-12-22 | 2024-02-01 | 30d |  |  | finish no earlier than 2024-02-01 | Laura Kennedy | 240h | 240h |  | Code Bodies |  |  | 5.24 | Complete | COMPLETE |  |  |  |
| 1349 | 1.6.1.3.1.2 | Internal Review (Code Bodies and MHHSP) of Qualification Assessment Document v1 |  | 10d | 2024-02-01 A | 2024-02-14 A |  | 100% |  | 2024-02-01 | 2024-02-14 | 10d |  |  | finish no earlier than 2024-02-14 | Laura Kennedy | 80h | 80h |  | Code Bodies, SI Team, SRO |  |  | 5.24 | Complete | COMPLETE |  |  |  |
| 1350 | 1.6.1.3.1.3 | Industry consultation for Qualification Assessment Document v1 |  | 11d | 2024-02-16 A | 2024-03-01 A |  | 100% |  | 2024-02-16 | 2024-03-01 | 11d |  |  | start no earlier than 2024-02-16 | Laura Kennedy | 88h | 88h |  | Participants |  |  | 5.24 | Complete | COMPLETE |  |  |  |
| 1351 | 1.6.1.3.1.4 | Update Post-Consultation for Qualification Assessment Document v1 |  | 10d | 2024-03-04 A | 2024-03-15 A | 1350 | 100% |  | 2024-03-04 | 2024-03-15 | 10d |  |  |  | Laura Kennedy | 80h | 80h |  | Code Bodies |  |  | 5.24 | Complete | COMPLETE |  |  |  |
| 1352 | 1.6.1.3.1.5 | BSC and REC PAB Approval of Qualification Assessment Document v1 |  | 3d | 2024-03-26 A | 2024-03-28 A |  | 100% |  | 2024-03-26 | 2024-03-28 | 3d |  |  | start no earlier than 2024-03-26 | Laura Kennedy | 24h | 24h |  | Code Bodies |  |  | 5.24 | Complete | COMPLETE |  |  |  |
| 1353 | 1.6.1.3.1.6 | Qualification Assessment Document v1 approved by REC PAB and BSC PAB | milestone | 0d | 2024-03-28 A | 2024-03-28 A | 1352 | 100% |  | 2024-03-28 | 2024-03-28 | 0d |  |  |  | Laura Kennedy |  |  |  | Code Bodies |  |  | 5.24 | Complete | COMPLETE | T3-QU-0066 | QAG |  |

Notes:
- 1333: 28/5: Late because of delay to approval of SIT Non Functional approach. Re-planned to align to v4. To go to June QAG for baseline date change. 24/6: Approved at QAG on 20/6
- 1335: 28/5: Late because of delay to approval of SIT Non Functional approach. Re-planned to align to v4. 24/6: Approved at QAG on 20/6 / Action: 31/5: To be linked into QTF breakdown when confirmed and added to plan
- 1342: Action: 25/6: Combined v3/4 and removed version 4 milestones / Issue: 25/6: Delay in confirmation of non functional scope pushed v3 timelines out
- 1344: Action: 25/6: Combined v3/4 and removed version 4 milestones / Issue: 25/6: Delay in confirmation of non functional scope pushed v3 timelines out
- 1345: Action: 25/6: Combined v3/4 and removed version 4 milestones / Issue: 25/6: Delay in confirmation of non functional scope pushed v3 timelines out

| ID | WBS | Task | Type | Duration | Start | Finish | Predecessors | Complete | Remaining | Baseline start | Baseline finish | Baseline duration | Total slack | Free slack | Constraint | Resources | Work | Actual work | Baseline cost | Responsible | Involved | Task Status | Update Version | Sched Status | RAG | Milestone ID | Text29 |
| --- | --- | --- | --- | --- | --- | --- | --- | --- | --- | --- | --- | --- | --- | --- | --- | --- | --- | --- | --- | --- | --- | --- | --- | --- | --- | --- | --- |
| 1354 | 1.6.1.3.2 | **Qualification Assessment Document v2** |  | 110d | 2024-03-29 A | 2024-08-29 |  | 59% | 44.56d | 2024-03-29 | 2024-08-29 | 110d | 62d |  |  | N/A | 1512h | 584h | -0 | N/A | N/A | -131.67 | 5.24 |  |  |  |  |
| 1355 | 1.6.1.3.2.1 | Draft Qualification Assessment Document V1.1 |  | 26d | 2024-03-29 A | 2024-05-03 A | 1353 | 100% |  | 2024-03-29 | 2024-05-03 | 26d |  |  |  | Laura Kennedy | 208h | 208h |  |  |  |  | 5.24 | Complete | COMPLETE |  |  |
| 1356 | 1.6.1.3.2.2 | Industry Consultation for Qualification Assessment Document V1.1 |  | 12d | 2024-05-06 A | 2024-05-21 A | 1355 | 100% |  | 2024-05-06 | 2024-05-21 | 12d |  |  |  | Laura Kennedy | 96h | 96h |  |  |  |  | 5.24 | Complete | COMPLETE |  |  |
| 1357 | 1.6.1.3.2.3 | Draft Qualification Assessment Document v2 |  | 6d | 2024-06-14 A | 2024-06-21 A | 977, 983, 1356 | 100% |  | 2024-06-14 | 2024-06-21 | 6d |  |  |  | Laura Kennedy | 48h | 48h |  | Code Bodies |  |  | 5.24 | Complete | COMPLETE |  |  |
| 1358 | 1.6.1.3.2.4 | Internal Review (Code Bodies and MHHSP) of Qualification Assessment Document v2 |  | 10d | 2024-06-24 A | 2024-07-05 | 1357 | 30% | 7d | 2024-06-24 | 2024-07-05 | 10d | 62d | 0d |  | Laura Kennedy | 80h | 24h |  | Code Bodies, SI Team, SRO |  |  | 5.24 | Green | GREEN |  |  |
| 1359 | 1.6.1.3.2.5 | Industry consultation for Qualification Assessment Document v2 |  | 10d | 2024-07-08 | 2024-07-19 | 1358 |  |  | 2024-07-08 | 2024-07-19 | 10d | 62d | 0d |  | Laura Kennedy | 80h |  |  | Participants |  | 11.33 | 5.24 | Green | GREEN |  |  |
| 1360 | 1.6.1.3.2.6 | Update Post-Consultation for Qualification Assessment Document v2 |  | 10d | 2024-07-22 | 2024-08-02 | 1359 |  |  | 2024-07-22 | 2024-08-02 | 10d | 62d | 0d |  | Laura Kennedy | 80h |  |  | Code Bodies |  | 25.33 | 5.24 | Green | GREEN |  |  |
| 1361 | 1.6.1.3.2.7 | QWG Endorsement of Qualification Assessment Document v2 |  | 1d | 2024-08-13 | 2024-08-13 | 1360FS+6d |  |  | 2024-08-13 | 2024-08-13 | 1d | 62d | 0d |  | Laura Kennedy | 8h |  |  | Code Bodies |  | 47.33 | 5.24 | Green | GREEN |  |  |
| 1362 | 1.6.1.3.2.8 | QAG Endorsement of Qualification Assessment Document v2 |  | 1d | 2024-08-22 | 2024-08-22 | 1361FS+6d |  |  | 2024-08-22 | 2024-08-22 | 1d | 62d | 0d |  | Laura Kennedy | 8h |  |  | Code Bodies |  | 56.33 | 5.25 | Green | GREEN | T3-QU-0083 | QAG |
| 1363 | 1.6.1.3.2.9 | BSC and REC PAB Approval of Qualification Assessment Document v2 |  | 3d | 2024-08-27 | 2024-08-29 | 1362FS+2d |  |  | 2024-08-27 | 2024-08-29 | 3d | 62d | 0d |  | Laura Kennedy | 24h |  |  | Code Bodies |  | 61.33 | 5.24 | Green | GREEN |  |  |
| 1364 | 1.6.1.3.2.10 | Qualification Assessment Document v2 approved by REC PAB and BSC PAB | milestone | 0d | 2024-08-29 | 2024-08-29 | 1363 |  |  | 2024-08-29 | 2024-08-29 | 0d | 62d | 0d |  | Laura Kennedy |  |  |  | Code Bodies |  | 63.71 | 5.24 | Green | GREEN | T3-QU-0067 | QAG |
| 1365 | 1.6.1.3.3 | **Qualification Assessment Document Portal** |  | 285d | 2024-02-05 A | 2025-03-07 |  | 59% | 116.67d | 2024-02-05 | 2024-09-12 | 159d | 2d |  |  | N/A | 3648h | 1048h | -0 | N/A | N/A | -131.67 | 5.24 |  |  |  |  |
| 1366 | 1.6.1.3.3.1 | Design Completion |  | 30d | 2024-02-05 A | 2024-03-15 A |  | 100% |  | 2024-02-05 | 2024-03-15 | 30d |  |  | finish no earlier than 2024-03-15 | Laura Kennedy | 240h | 240h |  | QAD Portal Dev Team |  |  | 5.24 | Complete | COMPLETE |  |  |
| 1367 | 1.6.1.3.3.2 | Qualification Assessment Document Portal Build |  | 30d | 2024-03-18 A | 2024-04-26 A | 1366 | 100% |  | 2024-03-18 | 2024-04-26 | 30d |  |  |  | Laura Kennedy | 240h | 240h |  | QAD Portal Dev Team |  |  | 5.24 | Complete | COMPLETE |  |  |
| 1368 | 1.6.1.3.3.3 | Qualification Assessment Document Internal Testing |  | 20d | 2024-04-29 A | 2024-05-24 A | 1367 | 100% |  | 2024-04-29 | 2024-05-24 | 20d |  |  |  | Laura Kennedy | 160h | 160h |  | QAD Portal Dev Team. Code Bodies |  |  | 5.24 | Complete | COMPLETE |  |  |
| 1369 | 1.6.1.3.3.4 | Qualification Assessment Document Portal Training and Onboarding Material Creation |  | 20d | 2024-05-27 A | 2024-06-21 A | 1368 | 100% |  | 2024-05-27 | 2024-06-21 | 20d |  |  |  | Laura Kennedy | 160h | 160h |  | QAD Portal Dev Team |  |  | 5.24 | Complete | COMPLETE |  |  |
| 1370 | 1.6.1.3.3.5 | Qualification Assessment Document Portal Webinar (Date TBC) |  | 1d | 2024-06-18 A | 2024-06-18 A |  | 100% |  | 2024-06-11 | 2024-06-11 | 1d |  |  | start no earlier than 2024-06-18 | Laura Kennedy | 8h | 8h |  | QAD Portal Dev Team |  |  | 5.24 | Complete | COMPLETE |  |  |
| 1371 | 1.6.1.3.3.6 | SIT Participant QAD Application Creation in Portal |  | 10d | 2024-08-12 | 2024-08-23 | 1369FS+35d |  |  | 2024-06-17 | 2024-07-26 | 30d | 1d | 0d |  | Laura Kennedy | 80h |  |  | Code Bodies |  | 46.33 | 5.24 | Red | RED |  |  |
| 1372 | 1.6.1.3.3.7 | Non-SIT LDSO Participant QAD Application Creation in Portal |  | 10d | 2024-08-12 | 2024-08-23 | 1369FS+35d |  |  | 2024-06-17 | 2024-07-26 | 30d | 10d | 0d |  | Laura Kennedy | 80h |  |  | Code Bodies |  | 46.33 | 5.24 | Red | RED |  |  |
| 1373 | 1.6.1.3.3.8 | QT Wave 1 Participant QAD Application Creation in Portal |  | 10d | 2024-09-23 | 2024-10-04 | 1369FS+65d |  |  | 2024-06-17 | 2024-07-26 | 30d | 1d | 0d |  | Laura Kennedy | 80h |  |  | Code Bodies |  | 88.33 | 5.24 | Red | RED |  |  |
| 1374 | 1.6.1.3.3.9 | QT Wave 2 Participant QAD Application Creation in Portal |  | 10d | 2024-10-28 | 2024-11-08 | 1369FS+90d |  |  |  |  |  | 1d | 0d |  | Laura Kennedy | 80h |  |  |  |  | 123.33 | 5.27 | No BL | GREEN |  |  |
| 1375 | 1.6.1.3.3.10 | QT Wave 3 Participant QAD Application Creation in Portal |  | 10d | 2024-12-30 | 2025-01-10 | 1369FS+135d |  |  |  |  |  | 2d | 0d |  | Laura Kennedy | 80h |  |  |  |  | 186.33 | 5.27 | No BL | GREEN |  |  |
| 1376 | 1.6.1.3.3.11 | QT Wave 4 Participant QAD Application Creation in Portal |  | 10d | 2025-02-24 | 2025-03-07 | 1369FS+175d |  |  |  |  |  | 2d | 0d |  | Laura Kennedy | 80h |  |  |  |  | 242.33 | 5.27 | No BL | GREEN |  |  |
| 1377 | 1.6.1.3.3.12 | Update to Qualification Assessment Document Portal post QAD V2 |  | 10d | 2024-08-30 | 2024-09-12 | 1364 |  |  | 2024-08-30 | 2024-09-12 | 10d | 62d | 0d |  | Laura Kennedy | 80h |  |  | QAD Portal Dev Team |  | 64.33 | 5.24 | Green | GREEN |  |  |
| 1378 | 1.6.1.3.3.13 | Update to Qualification Assessment Document Portal post QAD V2 Complete | milestone | 0d | 2024-09-12 | 2024-09-12 | 1377 |  |  | 2024-09-12 | 2024-09-12 | 0d | 62d | 56d |  | Laura Kennedy |  |  |  |  |  | 77.71 | 5.25 | Green | GREEN | T3-QU-0084 | QAG |

| ID | WBS | Task | Type | Duration | Start | Finish | Predecessors | Baseline start | Baseline finish | Baseline duration | Baseline 1 start | Baseline 1 finish | Total slack | Free slack | Resources | Work | Baseline cost | Responsible | Involved | Task Status | Update Version | MHHS Programme Phase | Sched Status | RAG | Milestone ID | Text29 |
| --- | --- | --- | --- | --- | --- | --- | --- | --- | --- | --- | --- | --- | --- | --- | --- | --- | --- | --- | --- | --- | --- | --- | --- | --- | --- | --- |
| 1379 | 1.6.2 | **MHHS Qualification - SIT Participants** |  | 194d | 2024-09-02 | 2025-05-30 |  | 2024-09-02 | 2025-05-30 | 194d | 2024-01-29 | 2024-07-05 | 1d |  | N/A | 3264h | -0 | N/A | N/A | -133.67 | 5.24 | Systems Integration Testing (SIT) |  |  |  |  |
| 1380 | 1.6.2.1 | Initial QAD Submission Window opens | milestone | 0d | 2024-09-02 | 2024-09-02 | 1371FS+6d | 2024-09-02 | 2024-09-02 | 0d |  |  | 1d | 0d | Laura Kennedy |  |  | Participants |  | 67.71 | 5.24 |  | yellow | GREEN |  |  |
| 1381 | 1.6.2.2 | SIT Participants submit Initial QAD |  | 28d | 2024-09-03 | 2024-10-10 | 1380 | 2024-09-02 | 2024-10-10 | 29d |  |  | 1d | 0d | Laura Kennedy | 224h |  | Participants |  | 68.33 | 5.24 |  | Green | GREEN |  |  |
| 1382 | 1.6.2.3 | Code Bodies review Initial QAD |  | 36d | 2024-10-11 | 2024-11-29 | 1381 | 2024-10-11 | 2024-11-29 | 36d |  |  | 1d | 0d | Laura Kennedy | 288h |  | Code Bodies |  | 106.33 | 5.24 |  | Green | GREEN |  |  |
| 1383 | 1.6.2.4 | Completion of Code Bodies review of Initial QAD | milestone | 0d | 2024-11-29 | 2024-11-29 | 1382 | 2024-11-29 | 2024-11-29 | 0d |  |  | 1d | 0d | Laura Kennedy |  |  | Code Bodies |  | 155.71 | 5.24 |  | Green | GREEN |  |  |
| 1384 | 1.6.2.5 | **MHHS Qualification - SIT MVC Participants** |  | 65d | 2024-11-29 | 2025-02-28 |  | 2024-11-29 | 2025-02-28 | 64d |  |  | 1d |  | N/A | 880h |  | N/A | N/A | -154.67 | 5.24 |  |  |  |  |  |
| 1385 | 1.6.2.5.1 | Final QAD Submission Window (MVC) opens | milestone | 0d | 2024-11-29 | 2024-11-29 | 1382, 1378, 1383 | 2024-11-29 | 2024-11-29 | 0d |  |  | 6d | 0d | Laura Kennedy |  |  | Participants |  | 155.71 | 5.24 |  | Green | GREEN |  |  |
| 1386 | 1.6.2.5.2 | SIT MVC Participants submit Final QAD |  | 26d | 2024-12-02 | 2025-01-06 | 1385 | 2024-12-02 | 2025-01-06 | 26d |  |  | 6d | 0d | Laura Kennedy | 208h |  | Participants |  | 158.33 | 5.24 |  | Green | GREEN |  |  |
| 1387 | 1.6.2.5.3 | Completion of Code Bodies review of Final QAD (MVC) |  | 19d | 2025-01-07 | 2025-01-31 | 1386, 1064FF | 2025-01-07 | 2025-01-31 | 19d |  |  | 6d | 5d | Laura Kennedy | 152h |  | Code Bodies |  | 194.33 | 5.24 |  | Green | GREEN |  |  |
| 1388 | 1.6.2.5.4 | QAD Sign Off Deadline (MVC) | milestone | 0d | 2025-02-07 | 2025-02-07 | 1073, 1387 | 2025-02-07 | 2025-02-07 | 1d |  |  | 1d | 0d | Laura Kennedy |  |  | Participants |  | 225.71 | 5.24 |  | Green | GREEN |  |  |
| 1389 | 1.6.2.5.5 | REC Code Manager / BSC PAB Approval of Qualification (MVC) | milestone | 0d | 2025-02-28 | 2025-02-28 | 1388FS+15d | 2025-02-28 | 2025-02-28 | 0d |  |  | 1d | 0d | Laura Kennedy |  |  | Code Bodies |  | 246.71 | 5.25 |  | yellow | GREEN | T3-QU-0085 | QAG |
| 1390 | 1.6.2.6 | **MHHS Qualification - SIT Non-MVC Participants** |  | 129d | 2024-12-02 | 2025-05-30 |  | 2024-12-02 | 2025-05-30 | 129d |  |  | 1d |  | N/A | 1872h |  | N/A | N/A | -154.67 | 5.24 |  |  |  |  |  |
| 1391 | 1.6.2.6.1 | Final QAD Submission Window (Non-MVC) opens | milestone | 0d | 2024-12-02 | 2024-12-02 | 1383FS+1d | 2024-12-02 | 2024-12-02 | 0d |  |  | 1d | 0d | Laura Kennedy |  |  | Participants |  | 158.71 | 5.24 |  | yellow | GREEN |  |  |
| 1392 | 1.6.2.6.2 | SIT Non-MVC Participants submit Final QAD |  | 85d | 2024-12-03 | 2025-03-31 | 1391SS | 2024-12-02 | 2025-03-31 | 86d |  |  | 1d | 0d | Laura Kennedy | 680h |  | Participants |  | 159.33 | 5.24 |  | Green | GREEN |  |  |
| 1393 | 1.6.2.6.3 | Completion of Code Bodies review of Final QAD (Non-MVC) |  | 19d | 2025-04-01 | 2025-04-25 | 1392 | 2025-04-01 | 2025-04-25 | 19d |  |  | 1d | 0d | Laura Kennedy | 152h |  | Code Bodies |  | 278.33 | 5.24 |  | Green | GREEN |  |  |
| 1394 | 1.6.2.6.4 | QAD Sign Off Deadline (Non-MVC) |  | 1d | 2025-05-02 | 2025-05-02 | 1393FS+4d, 1121 | 2025-05-02 | 2025-05-02 | 1d |  |  | 1d | 0d | Laura Kennedy | 8h |  | Participants |  | 309.33 | 5.24 |  | Green | GREEN |  |  |
| 1395 | 1.6.2.6.5 | REC Code Manager / BSC PAB Approval of Qualification (Non-MVC) | milestone | 0d | 2025-05-30 | 2025-05-30 | 1394FS+20d | 2025-05-30 | 2025-05-30 | 0d |  |  | 1d | 0d | Laura Kennedy |  |  | Code Bodies |  | 337.71 | 5.25 |  | yellow | GREEN | T3-QU-0086 | QAG |
| 1396 | 1.6.3 | **MHHS Qualification - Non-SIT LDSO** |  | 114d | 2024-09-02 | 2025-02-07 |  | 2024-09-02 | 2025-02-07 | 115d |  |  | 10d |  | N/A | 1776h | -0 | N/A | N/A | -133.67 | 5.24 |  |  |  |  |  |
| 1397 | 1.6.3.1 | Initial QAD Submission window opens | milestone | 0d | 2024-09-02 | 2024-09-02 | 1372FS+6d | 2024-09-02 | 2024-09-02 | 0d |  |  | 10d | 0d | Laura Kennedy |  |  | Participants |  | 67.71 | 5.24 |  | yellow | GREEN |  |  |
| 1398 | 1.6.3.2 | Non-SIT LDSO Participants submit initial QAD |  | 28d | 2024-09-03 | 2024-10-10 | 1397 | 2024-09-02 | 2024-10-10 | 29d |  |  | 10d | 0d | Laura Kennedy | 224h |  | Participants |  | 68.33 | 5.24 |  | Green | GREEN |  |  |
| 1399 | 1.6.3.3 | Non-SIT LDSO QT Participants have submitted their initial QAD | milestone | 0d | 2024-10-10 | 2024-10-10 | 1398 | 2024-10-10 | 2024-10-10 | 0d |  |  | 10d | 0d | Laura Kennedy |  |  | Participants |  | 105.71 | 5.25 |  | Green | GREEN | T3-QU-0087 | QAG |
| 1400 | 1.6.3.4 | Code Bodies review of Non-SIT LDSO participants Initial QAD |  | 36d | 2024-10-11 | 2024-11-29 | 1399 | 2024-10-11 | 2024-11-29 | 36d |  |  | 10d | 0d | Laura Kennedy | 288h |  | Code Bodies |  | 106.33 | 5.24 |  | Green | GREEN |  |  |
| 1401 | 1.6.3.5 | Completion of Code Bodies review of Initial QAD | milestone | 0d | 2024-11-29 | 2024-11-29 | 1400 | 2024-11-29 | 2024-11-29 | 0d |  |  | 10d | 0d | Laura Kennedy |  |  | Code Bodies |  | 155.71 | 5.24 |  | Green | GREEN |  |  |
| 1402 | 1.6.3.6 | Final QAD Submission window opens | milestone | 0d | 2024-12-02 | 2024-12-02 | 1401FS+1d | 2024-12-02 | 2024-12-02 | 0d |  |  | 10d | 0d | Laura Kennedy |  |  | Participants |  | 158.71 | 5.24 |  | yellow | GREEN |  |  |
| 1403 | 1.6.3.7 | Non-SIT LDSO Participants submit Final QAD |  | 25d | 2024-12-03 | 2025-01-06 | 1299SS, 1402SS | 2024-12-02 | 2025-01-06 | 26d |  |  | 10d | 0d | Laura Kennedy | 200h |  | Participants |  | 159.33 | 5.24 |  | Green | GREEN |  |  |
| 1404 | 1.6.3.8 | Non-SIT LDSO QT Participants have submitted their final QAD | milestone | 0d | 2025-01-06 | 2025-01-06 | 1403 | 2025-01-06 | 2025-01-06 | 0d |  |  | 10d | 0d | Laura Kennedy |  |  | Participants |  | 193.71 | 5.25 |  | Green | GREEN | T3-QU-0088 | QAG |
| 1405 | 1.6.3.9 | Completion of Code Bodies review of the Final QAD |  | 19d | 2025-01-07 | 2025-01-31 | 1404 | 2025-01-07 | 2025-01-31 | 19d |  |  | 10d | 0d | Laura Kennedy | 152h |  | Code Bodies |  | 194.33 | 5.24 |  | Green | GREEN |  |  |
| 1406 | 1.6.3.10 | QAD Sign Off Deadline | milestone | 0d | 2025-02-07 | 2025-02-07 | 1405FS+5d | 2025-02-07 | 2025-02-07 | 1d |  |  | 10d |  | Laura Kennedy |  |  | Participants |  | 225.71 | 5.24 |  | Green | GREEN |  |  |

Notes:
- 1399: 14/5: Was in non-sit ldso CR 47
- 1404: 14/5: Was in non-sit ldso CR 47

| ID | WBS | Task | Type | Duration | Start | Finish | Predecessors | Complete | Remaining | Baseline start | Baseline finish | Baseline duration | Total slack | Free slack | Constraint | Resources | Work | Actual work | Baseline cost | Responsible | Involved | Task Status | Update Version | Sched Status | RAG | Milestone ID | Text29 |
| --- | --- | --- | --- | --- | --- | --- | --- | --- | --- | --- | --- | --- | --- | --- | --- | --- | --- | --- | --- | --- | --- | --- | --- | --- | --- | --- | --- |
| 1407 | 1.6.4 | **MHHS Qualification - Qualification Waves** |  | 870d | 2022-10-31 A | 2026-02-27 |  | 15% | 742.4d | 2023-12-18 | 2026-02-27 | 574d | 325d |  |  | N/A | 74184h | 5721.85h | -0 | N/A | N/A | -131.67 | 5.24 |  |  |  |  |
| 1408 | 1.6.4.1 | **Qualification Wave Prep** |  | 584d | 2022-10-31 A | 2025-01-23 |  | 28% | 417.65d | 2023-12-18 | 2025-01-23 | 289d | 611d |  |  | N/A | 33080h | 5721.85h | -0 | N/A | N/A | -131.67 | 5.24 |  |  |  |  |
| 1409 | 1.6.4.1.1 | **Non-SIT Supplier and Agent Test Approach and Plan** |  | 119d | 2023-12-18 A | 2024-05-30 |  | 99% | 0d | 2023-12-18 | 2024-05-30 | 118d | 0d |  |  | N/A | 1640h | 1088h | -0 | N/A | N/A | -133.67 | 5.24 |  |  |  |  |
| 1410 | 1.6.4.1.1.1 | Draft Non-SIT S&A Test Approach and Plan |  | 50d | 2023-12-18 A | 2024-02-23 A |  | 100% |  | 2023-12-18 | 2024-02-23 | 50d |  |  | finish no earlier than 2024-02-23 | Laura Kennedy | 400h | 400h |  | Non-SIT S&A QT Test Team |  |  | 5.24 | Complete | COMPLETE |  |  |
| 1411 | 1.6.4.1.1.2 | Internal Review of Non-SIT S&A Test Approach and Plan (Code Bodies and MHHSP) |  | 10d | 2024-02-26 A | 2024-03-08 A | 1410 | 100% |  | 2024-02-26 | 2024-03-08 | 10d |  |  |  | Laura Kennedy | 80h | 80h |  | Code Bodies, SI Team, SRO |  |  | 5.24 | Complete | COMPLETE |  |  |
| 1412 | 1.6.4.1.1.3 | Issue Non-SIT S&A Test Approach and Plan for Consultation |  | 15d | 2024-03-18 A | 2024-04-05 A | 1411 | 100% |  | 2024-03-18 | 2024-04-05 | 15d |  |  | start no earlier than 2024-03-18 | Laura Kennedy | 120h | 120h |  | Participants |  |  | 5.24 | Complete | COMPLETE |  |  |
| 1413 | 1.6.4.1.1.4 | Update Non-SIT S&A Test Approach and Plan Post-Consultation |  | 10d | 2024-04-08 A | 2024-04-19 A | 1412 | 100% |  | 2024-04-08 | 2024-04-19 | 10d |  |  |  | Laura Kennedy | 80h | 80h |  | Non-SIT S&A QT Test Team |  |  | 5.24 | Complete | COMPLETE |  |  |
| 1414 | 1.6.4.1.1.5 | QWG Endorsement of Non-SIT S&A Test Approach and Plan |  | 1d | 2024-05-14 A | 2024-05-14 A |  | 100% |  | 2024-05-14 | 2024-05-14 | 1d |  |  | finish no earlier than 2024-05-14 | Laura Kennedy | 8h | 8h |  | Non-SIT S&A QT Test Team |  |  | 5.24 | Complete | COMPLETE |  |  |
| 1415 | 1.6.4.1.1.6 | QAG Approval of Non-SIT S&A Test Approach and Plan | milestone | 0d | 2024-05-23 A | 2024-05-23 A | 1414FS+7d | 100% |  | 2024-05-23 | 2024-05-23 | 0d |  |  |  | Laura Kennedy |  |  |  | Non-SIT S&A QT Test Team |  |  | 5.25 | Complete | COMPLETE | T3-QU-0089 | QAG |
| 1416 | 1.6.4.1.1.7 | BSC & REC PAB Approval of Non-SIT S&A Test Approach and Plan | milestone | 0d | 2024-05-30 A | 2024-05-30 A | 1415FS+5d | 100% |  | 2024-05-30 | 2024-05-30 | 0d |  |  |  | Laura Kennedy |  |  |  | Code Bodies |  |  | 5.25 | Complete | COMPLETE | T3-QU-0090 | QAG |
| 1417 | 1.6.4.1.2 | **QT Test Data Approach and Plan** |  | 64d | 2024-04-19 A | 2024-07-18 |  | 93% | 4.68d | 2024-04-19 | 2024-07-18 | 64d | 746d |  |  | N/A | 840h | 304h | -0 | N/A | N/A | -133.67 | 5.24 |  |  |  |  |
| 1418 | 1.6.4.1.2.1 | QT Test Data Approach agreed as part of the Non-SIT Supplier and Agent Test Approach and Plan | milestone | 0d | 2024-04-19 A | 2024-04-19 A | 1413 | 100% |  | 2024-04-19 | 2024-04-19 | 0d |  |  |  | Laura Kennedy |  |  |  | Non-SIT S&A QT Test Team, Participants |  |  | 5.24 | Complete | COMPLETE |  |  |
| 1419 | 1.6.4.1.2.2 | Draft Test Data Approach and Plan for QT |  | 10d | 2024-05-06 A | 2024-05-17 A | 1418 | 100% |  | 2024-05-06 | 2024-05-17 | 10d |  |  |  | Laura Kennedy | 80h | 80h |  | Non-SIT S&A QT Test Team |  |  | 5.24 | Complete | COMPLETE |  |  |
| 1420 | 1.6.4.1.2.3 | Internal Review (Code Bodies and MHHSP) of QT Test Data Approach and Plan |  | 15d | 2024-05-20 A | 2024-06-07 A | 1419 | 100% |  | 2024-05-20 | 2024-05-31 | 10d |  |  |  | Laura Kennedy | 120h | 120h |  | Code Bodies, SI Team, SRO |  |  | 5.24 | Complete | COMPLETE |  |  |
| 1421 | 1.6.4.1.2.4 | Issue QT Test Data Approach and Plan for Industry Consultation |  | 10d | 2024-06-10 A | 2024-06-21 A | 1420 | 100% |  | 2024-06-03 | 2024-06-14 | 10d |  |  |  | Laura Kennedy | 80h | 80h |  | Participants |  |  | 5.24 | Complete | COMPLETE |  |  |
| 1422 | 1.6.4.1.2.5 | Update QT Test Approach and Plan Post Industry Consultation |  | 5d | 2024-06-24 A | 2024-06-28 | 1421 | 60% | 2d | 2024-06-17 | 2024-06-28 | 10d | 746d | 0d |  | Laura Kennedy | 40h | 24h |  | Non-SIT S&A QT Team |  |  | 5.24 | Green | GREEN |  |  |
| 1423 | 1.6.4.1.2.6 | QWG Endorsement of Test Data Approach and Plan |  | 1d | 2024-07-09 | 2024-07-09 | 1422FS+6d |  |  | 2024-07-09 | 2024-07-09 | 1d | 746d | 0d |  | Laura Kennedy | 8h |  |  | Non-SIT S&A QT Test Team |  | 12.33 | 5.24 | Green | GREEN |  |  |
| 1424 | 1.6.4.1.2.7 | QAG Approval of QT Test Data Approach and Plan | milestone | 0d | 2024-07-18 | 2024-07-18 | 1423FS+7d |  |  | 2024-07-18 | 2024-07-18 | 0d | 746d |  |  | Laura Kennedy |  |  |  | Non-SIT S&A QT Test Team |  | 21.71 | 5.25 | Green | GREEN | T3-QU-0091 | QAG |
| 1425 | 1.6.4.1.3 | **QT Functional Test Scenarios and Test Cases** |  | 59d | 2024-03-04 A | 2024-05-23 |  | 99% | 0d | 2024-03-04 | 2024-05-23 | 59d | 0d |  |  | N/A | 952h | 560h | -0 | N/A | N/A | -133.67 | 5.24 |  |  |  |  |
| 1426 | 1.6.4.1.3.1 | Draft Test Scenarios and Test Case list - Batch 1 |  | 10d | 2024-03-04 A | 2024-03-15 A |  | 100% |  | 2024-03-04 | 2024-03-15 | 10d |  |  | finish no earlier than 2024-03-15 | Laura Kennedy | 80h | 80h |  | Non-SIT S&A QT Test Team, Code Bodies |  |  | 5.24 | Complete | COMPLETE |  |  |
| 1427 | 1.6.4.1.3.2 | Issue Batch 1 for Consultation |  | 15d | 2024-03-18 A | 2024-04-05 A | 1426 | 100% |  | 2024-03-18 | 2024-04-05 | 15d |  |  | start no earlier than 2024-03-18 | Laura Kennedy | 120h | 120h |  | Participants |  |  | 5.24 | Complete | COMPLETE |  |  |
| 1428 | 1.6.4.1.3.3 | Gap analysis against QT Requirements |  | 8d | 2024-03-18 A | 2024-03-27 A | 1426 | 100% |  | 2024-03-18 | 2024-03-27 | 8d |  |  |  | Laura Kennedy | 64h | 64h |  | Non-SIT S&A QT Test Team |  |  | 5.24 | Complete | COMPLETE |  |  |
| 1429 | 1.6.4.1.3.4 | Update Test Scenarios and Test Case list - Batch 2 |  | 6d | 2024-03-28 A | 2024-04-04 A | 1428 | 100% |  | 2024-03-28 | 2024-04-04 | 6d |  |  |  | Laura Kennedy | 48h | 48h |  | Non-SIT S&A QT Test Team, Code Bodies |  |  | 5.24 | Complete | COMPLETE |  |  |
| 1430 | 1.6.4.1.3.5 | Issue Batch 2 for consultation |  | 10d | 2024-04-05 A | 2024-04-18 A | 1429 | 100% |  | 2024-04-05 | 2024-04-18 | 10d |  |  |  | Laura Kennedy | 80h | 80h |  | Participants |  |  | 5.24 | Complete | COMPLETE |  |  |
| 1431 | 1.6.4.1.3.6 | Update Batch 2 post consultation |  | 10d | 2024-04-19 A | 2024-05-02 A | 1430 | 100% |  | 2024-04-19 | 2024-05-02 | 10d |  |  |  | Laura Kennedy | 80h | 80h |  | Non-SIT S&A QT Test Team, Code Bodies |  |  | 5.24 | Complete | COMPLETE |  |  |
| 1432 | 1.6.4.1.3.7 | QWG Endorsement of Batch 1 and 2 |  | 1d | 2024-05-14 A | 2024-05-14 A |  | 100% |  | 2024-05-14 | 2024-05-14 | 1d |  |  | finish no earlier than 2024-05-14 | Laura Kennedy | 8h | 8h |  | Non-SIT S&A QT Test Team |  |  | 5.24 | Complete | COMPLETE |  |  |
| 1433 | 1.6.4.1.3.8 | QAG Approval of QT Functional Test Scenarios and Test Cases Batches 1 and 2 | milestone | 0d | 2024-05-23 A | 2024-05-23 A | 1432FS+7d | 100% |  | 2024-05-23 | 2024-05-23 | 0d |  |  |  | Laura Kennedy |  |  |  | Non-SIT S&A QT Test Team |  |  | 5.25 | Complete | COMPLETE | T3-QU-0092 | QAG |

Notes:
- 1424: Action: 31/5: To be linked into QTF breakdown when confirmed and added to plan

| ID | WBS | Task | Type | Duration | Start | Finish | Predecessors | Complete | Remaining | Baseline start | Baseline finish | Baseline duration | Total slack | Free slack | Resources | Work | Actual work | Responsible | Involved | Update Version | Sched Status | RAG | Task Status | Milestone ID | Text29 |
| --- | --- | --- | --- | --- | --- | --- | --- | --- | --- | --- | --- | --- | --- | --- | --- | --- | --- | --- | --- | --- | --- | --- | --- | --- | --- |
| 1434 | 1.6.4.1.4 | **QT Migration Test Scenarios and Test Cases** |  | 54d | 2024-05-06 A | 2024-07-18 |  | 95% | 2.7d | 2024-05-06 | 2024-07-18 | 54d | 746d |  | N/A | 752h | 552.4h | N/A | N/A | 5.25 |  |  |  |  |  |
| 1435 | 1.6.4.1.4.1 | Draft Test Scenarios and Test Case list - Batch 1 |  | 20d | 2024-05-06 A | 2024-05-31 A | 889FS+12d | 100% |  | 2024-05-06 | 2024-05-31 | 20d |  |  | Laura Kennedy | 160h | 160h |  |  | 5.25 | Complete | COMPLETE |  |  |  |
| 1436 | 1.6.4.1.4.2 | Issue Batch 1 for Consultation |  | 10d | 2024-06-03 A | 2024-06-14 A | 1435 | 100% |  | 2024-06-03 | 2024-06-14 | 10d |  |  | Laura Kennedy | 80h | 80h |  |  | 5.25 | Complete | COMPLETE |  |  |  |
| 1437 | 1.6.4.1.4.3 | Update Batch 1 Post Consultation |  | 10d | 2024-06-17 A | 2024-06-28 | 1436 | 80% | 2d | 2024-06-17 | 2024-06-28 | 10d | 746d | 0d | Laura Kennedy | 80h | 64h |  |  | 5.25 | Green | GREEN |  |  |  |
| 1438 | 1.6.4.1.4.4 | QWG Endorsement of Batch 1 | milestone | 0d | 2024-07-09 | 2024-07-09 | 1437FS+7d |  |  | 2024-07-09 | 2024-07-09 | 0d | 746d | 0d | Laura Kennedy |  |  |  |  | 5.25 | yellow | GREEN | 12.71 |  |  |
| 1439 | 1.6.4.1.4.5 | QAG Approval of QT Migration Test Scenarios and Test Cases Batches 1 | milestone | 0d | 2024-07-18 | 2024-07-18 | 1438FS+7d |  |  | 2024-07-18 | 2024-07-18 | 0d | 746d |  | Laura Kennedy |  |  |  |  | 5.27 | Green | GREEN | 21.71 | T3-QU-0119 | QAG |
| 1440 | 1.6.4.1.5 | **QT Non-Functional Test Scenarios and Test Cases** |  | 44d | 2024-07-22 | 2024-09-19 |  |  |  | 2024-07-22 | 2024-09-19 | 43d | 701d |  | N/A | 592h |  | N/A | N/A | 5.25 |  |  |  |  |  |
| 1441 | 1.6.4.1.5.1 | Draft Test Scenarios and Test Case list - Batch 2 |  | 10d | 2024-07-22 | 2024-08-02 | 941FS+2d, 935FS+2d |  |  | 2024-07-22 | 2024-08-02 | 10d | 701d | 0d | Laura Kennedy | 80h |  |  |  | 5.25 | Green | GREEN | 25.33 |  |  |
| 1442 | 1.6.4.1.5.2 | Issue Batch 2 for Consultation |  | 10d | 2024-08-05 | 2024-08-16 | 1441 |  |  | 2024-08-05 | 2024-08-16 | 10d | 701d | 0d | Laura Kennedy | 80h |  |  |  | 5.25 | Green | GREEN | 39.33 |  |  |
| 1443 | 1.6.4.1.5.3 | Update Batch 2 Post Consultation |  | 10d | 2024-08-19 | 2024-08-30 | 1442 |  |  | 2024-08-19 | 2024-08-30 | 10d | 701d | 0d | Laura Kennedy | 80h |  |  |  | 5.25 | Green | GREEN | 53.33 |  |  |
| 1444 | 1.6.4.1.5.4 | QWG Endorsement of Batch 2 | milestone | 0d | 2024-09-10 | 2024-09-10 | 1443FS+7d |  |  | 2024-09-10 | 2024-09-10 | 0d | 701d | 0d | Laura Kennedy |  |  |  |  | 5.25 | yellow | GREEN | 75.71 |  |  |
| 1445 | 1.6.4.1.5.5 | QAG Approval of QT Non-Functional Test Scenarios and Test Cases Batch 2 | milestone | 0d | 2024-09-19 | 2024-09-19 | 1444FS+7d |  |  | 2024-09-19 | 2024-09-19 | 0d | 701d |  | Laura Kennedy |  |  |  |  | 5.27 | yellow | GREEN | 84.71 | T3-QU-0120 | QAG |
| 1446 | 1.6.4.1.6 | **QT Operational Test Scenarios and Test Cases** |  | 64d | 2024-07-22 | 2024-10-17 |  |  |  | 2024-07-22 | 2024-10-17 | 63d | 681d |  | N/A | 1192h |  | N/A | N/A | 5.25 |  |  |  |  |  |
| 1447 | 1.6.4.1.6.1 | Draft QT Operational Test Cases - Batch 1 |  | 10d | 2024-07-22 | 2024-08-02 | 974FS+2d |  |  | 2024-07-22 | 2024-08-02 | 10d | 701d | 0d | Laura Kennedy | 80h |  |  |  | 5.25 | Green | GREEN | 25.33 |  |  |
| 1448 | 1.6.4.1.6.2 | Issue Batch 1 for Consultation |  | 10d | 2024-08-05 | 2024-08-16 | 1447 |  |  | 2024-08-05 | 2024-08-16 | 10d | 701d | 0d | Laura Kennedy | 80h |  |  |  | 5.25 | Green | GREEN | 39.33 |  |  |
| 1449 | 1.6.4.1.6.3 | Update Batch 1 Post Consultation |  | 10d | 2024-08-19 | 2024-08-30 | 1448 |  |  | 2024-08-19 | 2024-08-30 | 10d | 701d | 0d | Laura Kennedy | 80h |  |  |  | 5.25 | Green | GREEN | 53.33 |  |  |
| 1450 | 1.6.4.1.6.4 | QWG Endorsement of Batch 1 | milestone | 0d | 2024-09-10 | 2024-09-10 | 1449FS+7d |  |  | 2024-09-10 | 2024-09-10 | 0d | 701d | 0d | Laura Kennedy |  |  |  |  | 5.25 | yellow | GREEN | 75.71 |  |  |
| 1451 | 1.6.4.1.6.5 | QAG Approval of QT Operational Test Scenarios and Test Cases Batch 1 | milestone | 0d | 2024-09-19 | 2024-09-19 | 1450FS+7d |  |  | 2024-09-19 | 2024-09-19 | 0d | 701d |  | Laura Kennedy |  |  |  |  | 5.27 | yellow | GREEN | 84.71 | T3-QU-0121 | QAG |
| 1452 | 1.6.4.1.6.6 | Draft QT Operational Test Cases - Batch 2 |  | 10d | 2024-07-22 | 2024-08-02 | 980FS+2d |  |  | 2024-07-22 | 2024-08-02 | 10d | 701d | 0d | Laura Kennedy | 80h |  |  |  | 5.25 | Green | GREEN | 25.33 |  |  |
| 1453 | 1.6.4.1.6.7 | Issue Batch 2 for Consultation |  | 10d | 2024-08-05 | 2024-08-16 | 1452 |  |  | 2024-08-05 | 2024-08-16 | 10d | 701d | 0d | Laura Kennedy | 80h |  |  |  | 5.25 | Green | GREEN | 39.33 |  |  |
| 1454 | 1.6.4.1.6.8 | Update Batch 2 Post Consultation |  | 10d | 2024-08-19 | 2024-08-30 | 1453 |  |  | 2024-08-19 | 2024-08-30 | 10d | 701d | 0d | Laura Kennedy | 80h |  |  |  | 5.25 | Green | GREEN | 53.33 |  |  |
| 1455 | 1.6.4.1.6.9 | QWG Endorsement of Batch 2 | milestone | 0d | 2024-09-10 | 2024-09-10 | 1454FS+7d |  |  | 2024-09-10 | 2024-09-10 | 0d | 701d | 0d | Laura Kennedy |  |  |  |  | 5.25 | yellow | GREEN | 75.71 |  |  |
| 1456 | 1.6.4.1.6.10 | QAG Approval of QT Operational Test Scenarios and Test Cases Batch 2 | milestone | 0d | 2024-09-19 | 2024-09-19 | 1455FS+7d |  |  | 2024-09-19 | 2024-09-19 | 0d | 701d |  | Laura Kennedy |  |  |  |  | 5.27 | yellow | GREEN | 84.71 | T3-QU-0122 | QAG |
| 1457 | 1.6.4.1.6.11 | Draft QT Operational Test Cases - Batch 3 |  | 10d | 2024-08-26 | 2024-09-06 | 986FS+2d |  |  | 2024-08-26 | 2024-09-06 | 10d | 681d | 0d | Laura Kennedy | 80h |  |  |  | 5.25 | Green | GREEN | 60.33 |  |  |
| 1458 | 1.6.4.1.6.12 | Issue Batch 3 for Consultation |  | 10d | 2024-09-09 | 2024-09-20 | 1457, 1315 |  |  | 2024-09-09 | 2024-09-20 | 10d | 681d | 0d | Laura Kennedy | 80h |  |  |  | 5.25 | Green | GREEN | 74.33 |  |  |
| 1459 | 1.6.4.1.6.13 | Update Batch 3 Post Consultation |  | 5d | 2024-09-23 | 2024-09-27 | 1458 |  |  | 2024-09-23 | 2024-09-27 | 5d | 681d | 0d | Laura Kennedy | 40h |  |  |  | 5.25 | Green | GREEN | 88.33 |  |  |
| 1460 | 1.6.4.1.6.14 | QWG Endorsement of Batch 3 | milestone | 0d | 2024-10-08 | 2024-10-08 | 1459FS+7d |  |  | 2024-10-08 | 2024-10-08 | 0d | 681d | 0d | Laura Kennedy |  |  |  |  | 5.25 | yellow | GREEN | 103.71 |  |  |
| 1461 | 1.6.4.1.6.15 | QAG Approval of QT Operational Test Scenarios and Test Cases Batch 3 | milestone | 0d | 2024-10-17 | 2024-10-17 | 1460FS+7d |  |  | 2024-10-17 | 2024-10-17 | 0d | 681d |  | Laura Kennedy |  |  |  |  | 5.27 | yellow | GREEN | 112.71 | T3-QU-0123 | QAG |

Notes:
- 1439: Action: 31/5: To be linked into QTF breakdown when confirmed and added to plan. 24/6: New milestone approved at QAG on 20/6
- 1445: Action: 31/5: To be linked into QTF breakdown when confirmed and added to plan. 24/6: New milestone approved at QAG on 20/6
- 1451: Action: 31/5: To be linked into QTF breakdown when confirmed and added to plan. 24/6: New milestone approved at QAG on 20/6
- 1456: Action: 31/5: To be linked into QTF breakdown when confirmed and added to plan. 24/6: New milestone approved at QAG on 20/6
- 1461: Action: 31/5: To be linked into QTF breakdown when confirmed and added to plan. 24/6: New milestone approved at QAG on 20/6

| ID | WBS | Task | Type | Duration | Start | Finish | Predecessors | Complete | Remaining | Baseline start | Baseline finish | Baseline duration | Total slack | Free slack | Constraint | Resources | Work | Actual work | Baseline cost | Responsible | Task Status | Update Version | Sched Status | RAG |
| --- | --- | --- | --- | --- | --- | --- | --- | --- | --- | --- | --- | --- | --- | --- | --- | --- | --- | --- | --- | --- | --- | --- | --- | --- |
| 1462 | 1.6.4.1.7 | **Qualification Testing Framework (Test Stubs and Supporting UI)** |  | 584d | 2022-10-31 A | 2025-01-23 |  | 13% | 510.29d |  |  |  | 611d |  |  | Laura Kennedy | 22800h | 1841.45h |  | Non-SIT S&A QT Test Team | -594.67 | 5.27 |  |  |
| 1463 | 1.6.4.1.7.1 | Proof of Concept for QTF Completion |  | 45d | 2024-01-29 A | 2024-03-29 A |  | 100% |  | 2024-01-22 | 2024-03-29 | 50d |  |  | start no earlier than 2024-01-22 | Laura Kennedy | 360h | 360h |  | Non-SIT S&A QT Test Team |  | 5.27 | Complete | COMPLETE |
| 1464 | 1.6.4.1.7.2 | Discovery and Mobilisation |  | 25d | 2024-04-01 A | 2024-05-03 A | 1463 | 100% |  | 2024-04-01 | 2024-04-22 | 15d |  |  |  | Laura Kennedy | 200h | 200h |  | Non-SIT S&A QT Test Team |  | 5.27 | Complete | COMPLETE |
| 1465 | 1.6.4.1.7.3 | **Agile DBT of Qualification Testing Framework** |  | 470d | 2022-10-31 A | 2024-08-16 |  | 15% | 401.01d | 2024-04-22 | 2024-11-01 | 140d | 725d |  |  | Laura Kennedy | 4216h | 585.45h |  | Non-SIT S&A QT Test Team |  | 5.27 |  |  |
| 1466 | 1.6.4.1.7.3.1 | **User Interface (UI)** |  | 48d | 2024-04-24 A | 2024-06-28 |  | 56% | 20.89d |  |  |  | 760d |  |  | Laura Kennedy | 1064h | 481.16h |  | Non-SIT S&A QT Test Team | -594.67 | 5.27 |  |  |
| 1467 | 1.6.4.1.7.3.1.1 | UI Wireframe |  | 48d | 2024-04-24 A | 2024-06-28 | 1413FS+2d | 96% | 2d |  |  |  | 760d | 0d |  | Laura Kennedy | 384h | 368h |  | Non-SIT S&A QT Test Team |  | 5.27 | No BL | GREEN |
| 1468 | 1.6.4.1.7.3.1.2 | UI Standards |  | 35d | 2024-05-13 | 2024-06-28 | 1467SS+13d |  |  |  |  |  | 735d | 0d |  | Laura Kennedy | 280h |  |  | Non-SIT S&A QT Test Team | -44.67 | 5.27 | Overdue Start | GREEN |
| 1469 | 1.6.4.1.7.3.1.3 | Elexon Branding Sylesheet |  | 1d | 2024-05-17 A | 2024-05-20 A | 1464FS+10d | 100% |  |  |  |  |  |  |  | Laura Kennedy | 8h | 8h |  | Non-SIT S&A QT Test Team |  | 5.27 | Complete | COMPLETE |
| 1470 | 1.6.4.1.7.3.1.4 | Elexon Branding QTF Logo |  | 1d | 2024-05-31 A | 2024-06-03 A | 1464FS+20d | 100% |  |  |  |  |  |  |  | Laura Kennedy | 8h | 8h |  | Non-SIT S&A QT Test Team |  | 5.27 | Complete | COMPLETE |
| 1471 | 1.6.4.1.7.3.2 | **Design, Build, Test** |  | 470d | 2022-10-31 A | 2024-08-16 |  |  | 470d |  |  |  | 725d |  |  | Laura Kennedy | 2496h | 8h |  | Non-SIT S&A QT Test Team | -594.67 | 5.27 |  |  |
| 1472 | 1.6.4.1.7.3.2.1 | UI Screens |  | 60d | 2024-05-13 | 2024-08-02 | 1468SS |  |  |  |  |  | 735d |  |  | Laura Kennedy | 480h |  |  | Non-SIT S&A QT Test Team | -44.67 | 5.27 | Overdue Start | GREEN |
| 1473 | 1.6.4.1.7.3.2.2 | Tooling (Trigger Files / Template Generators) |  | 70d | 2024-05-13 | 2024-08-16 | 1467SS+13d |  |  | 2024-01-31 | 2024-08-20 | 145d | 695d | 0d |  | Laura Kennedy | 560h |  | -0 | Non-SIT S&A QT Test Team | -44.67 | 5.27 | Overdue Start | GREEN |
| 1474 | 1.6.4.1.7.3.2.3 | Database Schema |  | 50d | 2024-05-13 | 2024-07-19 | 1467SS+13d |  |  |  |  |  | 745d |  |  | Laura Kennedy | 400h |  |  | Non-SIT S&A QT Test Team | -44.67 | 5.27 | Overdue Start | GREEN |
| 1475 | 1.6.4.1.7.3.2.4 | API's |  | 60d | 2024-05-13 | 2024-08-02 | 1467SS+13d |  |  |  |  |  | 735d |  |  | Laura Kennedy | 480h |  |  | Non-SIT S&A QT Test Team | -44.67 | 5.27 | Overdue Start | GREEN |
| 1476 | 1.6.4.1.7.3.2.5 | DIP (SIT-A) Onboarding for Development inc. Test Stubs |  | 1d | 2024-07-12 | 2024-07-12 | 1464 |  |  |  |  |  | 750d |  | start no earlier than 2024-07-12 | Laura Kennedy | 8h |  |  | Non-SIT S&A QT Test Team, Electralink | 15.33 | 5.27 | No BL | GREEN |
| 1477 | 1.6.4.1.7.3.2.6 | DTN Onboarding for Development inc. Test Stubs |  | 1d | 2022-10-31 | 2022-10-31 |  |  |  |  |  |  | 1194d |  |  | Laura Kennedy | 8h |  |  | Non-SIT S&A QT Test Team, MHHSP, Avanade | -604.67 | 5.27 | Overdue Start | RED |
| 1478 | 1.6.4.1.7.4 | QTF Test Cases DBT Refinement, Execution and Results Validation, Defect Management, Error Handling |  | 79d | 2022-10-31 | 2023-02-16 |  |  |  |  |  |  | 1102d | 0d |  | Laura Kennedy | 632h |  |  | Non-SIT S&A QT Test Team | -604.67 | 5.27 | Overdue Start | RED |
| 1479 | 1.6.4.1.7.5 | Qualification Testing Framework (Test Stubs and Supporting UI) Complete | milestone | 0d | 2023-02-16 | 2023-02-16 | 1478 |  |  | 2025-01-17 | 2025-01-17 | 0d | 1116d |  |  | Laura Kennedy |  |  |  | Non-SIT S&A QT Test Team | -496.29 | 5.27 | Overdue Start | GREEN |
| 1480 | 1.6.4.1.7.6 | **Environments** |  | 500d | 2022-10-31 A | 2024-09-27 |  | 17% | 415.82d |  |  |  | 695d |  |  | Laura Kennedy | 5664h | 688h |  | Non-SIT S&A QT Test Team | -594.67 | 5.27 |  |  |
| 1481 | 1.6.4.1.7.6.1 | **Azure Devops** |  | 120d | 2024-04-15 A | 2024-09-27 |  | 23% | 92.31d |  |  |  | 695d |  |  | Laura Kennedy | 2000h | 280h |  | Non-SIT S&A QT Test Team | -594.67 | 5.27 |  |  |
| 1482 | 1.6.4.1.7.6.1.1 | **QFT ADO Development Instance** |  | 15d | 2024-04-15 A | 2024-05-03 |  | 99% | 0d |  |  |  | 0d |  |  | Laura Kennedy | 240h | 160h |  | Non-SIT S&A QT Test Team | -594.67 | 5.27 |  |  |
| 1483 | 1.6.4.1.7.6.1.1.1 | Elexon Instance Setup for QTF Build |  | 5d | 2024-04-15 A | 2024-04-19 A | 1464SS+10d | 100% |  |  |  |  |  |  |  | Laura Kennedy | 40h | 40h |  | Non-SIT S&A QT Test Team |  | 5.27 | Complete | COMPLETE |
| 1484 | 1.6.4.1.7.6.1.1.2 | Configuration and User Access |  | 10d | 2024-04-22 A | 2024-05-03 A | 1483 | 100% |  |  |  |  |  |  |  | Laura Kennedy | 80h | 80h |  | Non-SIT S&A QT Test Team |  | 5.27 | Complete | COMPLETE |
| 1485 | 1.6.4.1.7.6.1.2 | **MHHSP ADO Instance** |  | 50d | 2024-07-22 | 2024-09-27 |  |  |  |  |  |  | 695d |  |  | Laura Kennedy | 800h |  |  | Non-SIT S&A QT Test Team | -594.67 | 5.27 | Complete |  |
| 1486 | 1.6.4.1.7.6.1.2.1 | MHHSP Instance Setup for QTF Production |  | 30d | 2024-07-22 | 2024-08-30 | 1492 |  |  |  |  |  | 695d | 0d | start no earlier than 2024-07-22 | Laura Kennedy | 240h |  |  | MHHSP | 25.33 | 5.27 | No BL | GREEN |
| 1487 | 1.6.4.1.7.6.1.2.2 | Configuration and User Access |  | 20d | 2024-09-02 | 2024-09-27 | 1486 |  |  |  |  |  | 695d |  |  | Laura Kennedy | 160h |  |  | Non-SIT S&A QT Test Team | 67.33 | 5.27 | No BL | GREEN |

| ID | WBS | Task | Duration | Start | Finish | Predecessors | Complete | Remaining | Baseline start | Baseline finish | Baseline duration | Total slack | Free slack | Constraint | Resources | Work | Actual work | Baseline cost | Responsible | Task Status | Update Version | Sched Status | RAG |
| --- | --- | --- | --- | --- | --- | --- | --- | --- | --- | --- | --- | --- | --- | --- | --- | --- | --- | --- | --- | --- | --- | --- | --- |
| 1488 | 1.6.4.1.7.6.2 | **Temporary Development Environment** | 35d | 2024-04-15 A | 2024-05-31 |  | 99% | 0d |  |  |  | 0d |  |  | Laura Kennedy | 560h | 400h |  | Non-SIT S&A QT Test Team | -594.67 | 5.27 |  |  |
| 1489 | 1.6.4.1.7.6.2.1 | Design | 15d | 2024-04-15 A | 2024-05-03 A | 1464SS+10d | 100% |  |  |  |  |  |  |  | Laura Kennedy | 120h | 120h |  | Non-SIT S&A QT Test Team |  | 5.27 | Complete | COMPLETE |
| 1490 | 1.6.4.1.7.6.2.2 | Build and Deployment | 20d | 2024-05-06 A | 2024-05-31 A | 1484, 1489 | 100% |  |  |  |  |  |  |  | Laura Kennedy | 160h | 160h |  | Non-SIT S&A QT Test Team |  | 5.27 | Complete | COMPLETE |
| 1491 | 1.6.4.1.7.6.3 | **Dev, Test & Prod Environment Requirements + Design** | 105d | 2022-10-31 | 2023-03-24 |  |  |  |  |  |  | 1076d |  |  | Laura Kennedy | 840h |  |  | Non-SIT S&A QT Test Team | -594.67 | 5.27 | Complete |  |
| 1492 | 1.6.4.1.7.6.3.1 | Design (including Security Review) | 40d | 2022-10-31 | 2022-12-23 |  |  |  |  |  |  | 1076d | 0d |  | Laura Kennedy | 320h |  |  | Non-SIT S&A QT Test Team | -604.67 | 5.27 | Overdue Start | RED |
| 1493 | 1.6.4.1.7.6.3.2 | Hub Deployment | 20d | 2022-12-26 | 2023-01-20 | 1492 |  |  |  |  |  | 1076d | 0d |  | Laura Kennedy | 160h |  |  | Non-SIT S&A QT Test Team | -548.67 | 5.27 | Overdue Start | RED |
| 1494 | 1.6.4.1.7.6.3.3 | Development Envn. Deployment | 15d | 2023-01-23 | 2023-02-10 | 1493 |  |  |  |  |  | 1076d | 0d |  | Laura Kennedy | 120h |  |  | Non-SIT S&A QT Test Team | -520.67 | 5.27 | Overdue Start | RED |
| 1495 | 1.6.4.1.7.6.3.4 | Test Envn. Deployment | 15d | 2023-02-13 | 2023-03-03 | 1494 |  |  |  |  |  | 1076d | 0d |  | Laura Kennedy | 120h |  |  | Non-SIT S&A QT Test Team | -499.67 | 5.27 | Overdue Start | RED |
| 1496 | 1.6.4.1.7.6.3.5 | Production Envn. Deployment | 15d | 2023-03-06 | 2023-03-24 | 1495 |  |  |  |  |  | 1076d | 0d |  | Laura Kennedy | 120h |  |  | Non-SIT S&A QT Test Team | -478.67 | 5.27 | Overdue Start | RED |
| 1497 | 1.6.4.1.7.6.4 | **QTF Deployment into Production** | 14d | 2023-03-27 | 2023-04-13 |  |  |  |  |  |  | 1076d |  |  | Laura Kennedy | 232h |  |  | Non-SIT S&A QT Test Team | -594.67 | 5.27 | No BL |  |
| 1498 | 1.6.4.1.7.6.4.1 | App Deployment | 1d | 2023-03-27 | 2023-03-27 | 1478, 1496 |  |  |  |  |  | 1076d | 0d |  | Laura Kennedy | 8h |  |  | Non-SIT S&A QT Test Team | -457.67 | 5.27 | Overdue Start | RED |
| 1499 | 1.6.4.1.7.6.4.2 | Smoke Test | 2d | 2023-03-27 | 2023-03-28 | 1498SS |  |  |  |  |  | 1076d | 0d |  | Laura Kennedy | 16h |  |  | Non-SIT S&A QT Test Team | -457.67 | 5.27 | Overdue Start | RED |
| 1500 | 1.6.4.1.7.6.4.3 | PEN Test | 2d | 2023-03-29 | 2023-03-30 | 1499 |  |  |  |  |  | 1076d | 0d |  | Laura Kennedy | 16h |  |  | Non-SIT S&A QT Test Team | -455.67 | 5.27 | Overdue Start | RED |
| 1501 | 1.6.4.1.7.6.4.4 | Regresssion Test | 10d | 2023-03-31 | 2023-04-13 | 1500 |  |  |  |  |  | 1076d |  |  | Laura Kennedy | 80h |  |  | Non-SIT S&A QT Test Team | -453.67 | 5.27 | Overdue Start | RED |
| 1502 | 1.6.4.1.7.6.5 | **DIP Onboarding (UIT)** | 37d | 2024-08-05 | 2024-09-24 |  |  |  |  |  |  | 698d |  |  | Laura Kennedy | 432h |  |  | Non-SIT S&A QT Test Team | -594.67 | 5.27 |  |  |
| 1503 | 1.6.4.1.7.6.5.1 | DIP available for Onboarding | 1d | 2024-08-05 | 2024-08-05 | 1489 |  |  | 2024-08-01 | 2024-08-01 | 0d | 698d | 0d | start no earlier than 2024-08-05 | Laura Kennedy | 8h |  |  | MHHSP, Avanade | 39.33 | 5.27 | yellow | RED |
| 1504 | 1.6.4.1.7.6.5.2 | Qualification Testing for Non-SIT S&A Participants' environments) Ready to start DIP onboarding (incl. certificates and security compliance) | 15d | 2024-08-06 | 2024-08-26 | 1503 |  |  | 2024-08-05 | 2024-08-05 | 0d | 698d | 0d | finish no earlier than 2024-08-22 | Laura Kennedy | 120h |  |  | MHHSP, Avanade | 40.33 | 5.27 | Red | RED |
| 1505 | 1.6.4.1.7.6.5.3 | Non-SIT S&A QTF Environments Connection Confirmed to UIT Environment | 1d | 2024-08-27 | 2024-08-27 | 1504 |  |  | 2024-09-18 | 2024-09-18 | 0d | 698d | 0d |  | Laura Kennedy | 8h |  |  | Non-SIT S&A QT Test Team | 61.33 | 5.27 | Green | GREEN |
| 1506 | 1.6.4.1.7.6.5.4 | DIP UIT Test Stubs | 20d | 2024-08-28 | 2024-09-24 | 1505 |  |  |  |  |  | 698d |  |  |  |  |  |  |  | 62.33 | 5.27 | No BL | GREEN |
| 1507 | 1.6.4.1.7.6.6 | **DTN Onboarding** | 40d | 2024-05-20 | 2024-07-12 |  |  |  |  |  |  | 750d |  |  | Laura Kennedy | 640h |  |  | Non-SIT S&A QT Test Team | -594.67 | 5.27 |  |  |
| 1508 | 1.6.4.1.7.6.6.1 | DTN Request Raised for Onboarding | 25d | 2024-05-20 | 2024-06-21 | 1489 |  |  |  |  |  | 750d | 0d | start no earlier than 2024-05-20 | Laura Kennedy | 200h |  |  | Non-SIT S&A QT Test Team | -37.67 | 5.27 | Overdue Start | RED |
| 1509 | 1.6.4.1.7.6.6.2 | Setup, configuration of New Host and Test Flags | 5d | 2024-06-24 | 2024-06-28 | 1508 |  |  |  |  |  | 750d | 0d |  | Laura Kennedy | 40h |  |  | Electralink | -2.67 | 5.27 | Overdue Start | GREEN |
| 1510 | 1.6.4.1.7.6.6.3 | DTN Test Stubs | 10d | 2024-07-01 | 2024-07-12 | 1509 |  |  |  |  |  | 750d |  |  | Laura Kennedy | 80h |  |  | Non-SIT S&A QT Test Team | 4.33 | 5.27 | No BL | GREEN |
| 1511 | 1.6.4.1.7.7 | **Test Data (MPANs, DIP Messages, Settlement, Consumption, Reference)** | 500d | 2022-10-31 | 2024-09-27 |  |  |  | 2024-01-22 | 2024-12-23 | 241d | 695d |  |  | Laura Kennedy | 8536h |  | -0 | Non-SIT S&A QT Test Team | -385.67 | 5.27 |  |  |
| 1512 | 1.6.4.1.7.7.1 | Sample MPAN Data + Attributes from Suppliers | 17d | 2022-10-31 | 2022-11-22 |  |  |  |  |  |  | 1103d | 408d |  | Laura Kennedy | 136h |  |  | QPs | -604.67 | 5.27 | Overdue Start | RED |
| 1513 | 1.6.4.1.7.7.2 | Test Data Templates and generator tools ready | 30d | 2024-06-10 | 2024-07-19 | 1473SS+20d, 1512FF+25d |  |  | 2024-05-24 | 2024-06-06 | 10d | 695d | 0d |  | Laura Kennedy | 240h |  |  | Non-SIT S&A QT Test Team | -16.67 | 5.27 | Overdue Start | RED |

| ID | WBS | Task | Duration | Start | Finish | Predecessors | Total slack | Free slack | Constraint | Resources | Work | Task Status | Update Version | Responsible | Sched Status | RAG |
| --- | --- | --- | --- | --- | --- | --- | --- | --- | --- | --- | --- | --- | --- | --- | --- | --- |
| 1514 | 1.6.4.1.7.7.3 | **Industry Standard Data (ISD)** | 36d | 2024-08-02 | 2024-09-20 |  | 700d |  |  | Laura Kennedy | 576h | -594.67 | 5.27 |  |  |  |
| 1515 | 1.6.4.1.7.7.3.1 | Receive ISD | 1d | 2024-08-02 | 2024-08-02 |  | 700d | 0d | start no earlier than 2024-08-02 | Laura Kennedy | 8h | 36.33 | 5.27 | MHHSP | No BL | GREEN |
| 1516 | 1.6.4.1.7.7.3.2 | Create ISD Template inc. DIP ID | 20d | 2024-08-05 | 2024-08-30 | 1515 | 700d | 0d |  | Laura Kennedy | 160h | 39.33 | 5.27 | Non-SIT S&A QT Test Team | No BL | GREEN |
| 1517 | 1.6.4.1.7.7.3.3 | Publish Qualification ISD | 15d | 2024-09-02 | 2024-09-20 | 1516 | 700d |  |  | Laura Kennedy | 120h | 67.33 | 5.27 | Non-SIT S&A QT Test Team | No BL | GREEN |
| 1518 | 1.6.4.1.7.7.4 | **Wave 1 Test Data** | 50d | 2024-07-22 | 2024-09-27 |  | 695d |  |  | Laura Kennedy | 960h | -596.67 | 5.27 |  | Overdue Start |  |
| 1519 | 1.6.4.1.7.7.4.1 | Test Data Request + Templates Completed | 20d | 2024-07-22 | 2024-08-16 | 1513 | 695d | 0d |  | Laura Kennedy | 160h | 25.33 | 5.27 | QPs | No BL | GREEN |
| 1520 | 1.6.4.1.7.7.4.2 | Test Data Generated | 10d | 2024-08-19 | 2024-08-30 | 1519 | 695d | 0d |  | Laura Kennedy | 80h | 53.33 | 5.27 | Non-SIT S&A QT Test Team | No BL | GREEN |
| 1521 | 1.6.4.1.7.7.4.3 | Test Data Loaded into QP Systems | 20d | 2024-09-02 | 2024-09-27 | 1520 | 695d |  |  | Laura Kennedy | 160h | 67.33 | 5.27 | QPs | No BL | GREEN |
| 1522 | 1.6.4.1.7.7.4.4 | Test Data Loaded into QTF + ADO | 20d | 2024-09-02 | 2024-09-27 | 1520 | 695d |  |  | Laura Kennedy | 160h | 67.33 | 5.27 | Non-SIT S&A QT Test Team | No BL | GREEN |
| 1523 | 1.6.4.1.7.7.5 | **Wave 2 Test Data** | 50d | 2024-07-22 | 2024-09-27 |  | 695d |  |  | Laura Kennedy | 960h | -596.67 | 5.27 |  | Overdue Start |  |
| 1524 | 1.6.4.1.7.7.5.1 | Test Data Request + Templates Completed | 20d | 2024-07-22 | 2024-08-16 | 1513 | 695d | 0d |  | Laura Kennedy | 160h | 25.33 | 5.27 | QPs | No BL | GREEN |
| 1525 | 1.6.4.1.7.7.5.2 | Test Data Generated | 10d | 2024-08-19 | 2024-08-30 | 1524 | 695d | 0d |  | Laura Kennedy | 80h | 53.33 | 5.27 | Non-SIT S&A QT Test Team | No BL | GREEN |
| 1526 | 1.6.4.1.7.7.5.3 | Test Data Loaded into QP Systems | 20d | 2024-09-02 | 2024-09-27 | 1525 | 695d |  |  | Laura Kennedy | 160h | 67.33 | 5.27 | QPs | No BL | GREEN |
| 1527 | 1.6.4.1.7.7.5.4 | Test Data Loaded into QTF + ADO | 20d | 2024-09-02 | 2024-09-27 | 1525 | 695d |  |  | Laura Kennedy | 160h | 67.33 | 5.27 | Non-SIT S&A QT Test Team | No BL | GREEN |
| 1528 | 1.6.4.1.7.7.6 | **Wave 3 Test Data** | 50d | 2024-07-22 | 2024-09-27 |  | 695d |  |  | Laura Kennedy | 960h | -596.67 | 5.27 |  | Overdue Start |  |
| 1529 | 1.6.4.1.7.7.6.1 | Test Data Request + Templates Completed | 20d | 2024-07-22 | 2024-08-16 | 1513 | 695d | 0d |  | Laura Kennedy | 160h | 25.33 | 5.27 | QPs | No BL | GREEN |
| 1530 | 1.6.4.1.7.7.6.2 | Test Data Generated | 10d | 2024-08-19 | 2024-08-30 | 1529 | 695d | 0d |  | Laura Kennedy | 80h | 53.33 | 5.27 | Non-SIT S&A QT Test Team | No BL | GREEN |
| 1531 | 1.6.4.1.7.7.6.3 | Test Data Loaded into QP Systems | 20d | 2024-09-02 | 2024-09-27 | 1530 | 695d |  |  | Laura Kennedy | 160h | 67.33 | 5.27 | QPs | No BL | GREEN |
| 1532 | 1.6.4.1.7.7.6.4 | Test Data Loaded into QTF + ADO | 20d | 2024-09-02 | 2024-09-27 | 1530 | 695d |  |  | Laura Kennedy | 160h | 67.33 | 5.27 | Non-SIT S&A QT Test Team | No BL | GREEN |
| 1533 | 1.6.4.1.7.7.7 | **Wave 4 Test Data** | 50d | 2024-07-22 | 2024-09-27 |  | 695d |  |  | Laura Kennedy | 960h | -596.67 | 5.27 |  | Overdue Start |  |
| 1534 | 1.6.4.1.7.7.7.1 | Test Data Request + Templates Completed | 20d | 2024-07-22 | 2024-08-16 | 1513 | 695d | 0d |  | Laura Kennedy | 160h | 25.33 | 5.27 | QPs | No BL | GREEN |
| 1535 | 1.6.4.1.7.7.7.2 | Test Data Generated | 10d | 2024-08-19 | 2024-08-30 | 1534 | 695d | 0d |  | Laura Kennedy | 80h | 53.33 | 5.27 | Non-SIT S&A QT Test Team | No BL | GREEN |
| 1536 | 1.6.4.1.7.7.7.3 | Test Data Loaded into QP Systems | 20d | 2024-09-02 | 2024-09-27 | 1535 | 695d |  |  | Laura Kennedy | 160h | 67.33 | 5.27 | QPs | No BL | GREEN |
| 1537 | 1.6.4.1.7.7.7.4 | Test Data Loaded into QTF + ADO | 20d | 2024-09-02 | 2024-09-27 | 1535 | 695d |  |  | Laura Kennedy | 160h | 67.33 | 5.27 | Non-SIT S&A QT Test Team | No BL | GREEN |

| ID | WBS | Task | Type | Duration | Start | Finish | Predecessors | Complete | Remaining | Baseline start | Baseline finish | Baseline duration | Total slack | Free slack | Constraint | Resources | Work | Actual work | Baseline cost | Responsible | Task Status | Update Version | Sched Status | RAG | Milestone ID | Text29 | Involved |
| --- | --- | --- | --- | --- | --- | --- | --- | --- | --- | --- | --- | --- | --- | --- | --- | --- | --- | --- | --- | --- | --- | --- | --- | --- | --- | --- | --- |
| 1538 | 1.6.4.1.7.8 | **Governance** |  | 149d | 2024-07-01 | 2025-01-23 |  |  |  |  |  |  | 157d |  |  | Laura Kennedy | 1560h |  |  | Non-SIT S&A QT Test Team | -594.67 | 5.27 |  |  |  |  |  |
| 1539 | 1.6.4.1.7.8.1 | Onboarding Strategy and Develop Training Requirements & Materials Inc. Day in the Life |  | 65d | 2024-07-01 | 2024-09-27 |  |  |  | 2024-09-30 | 2024-10-25 | 20d | 630d | 0d | start no earlier than 2024-07-01 | Laura Kennedy | 520h |  |  | Non-SIT S&A QT Test Team | 4.33 | 5.27 | Green | GREEN |  |  |  |
| 1540 | 1.6.4.1.7.8.2 | Design Approach & Set-Up ADO Tool for Test & Defect Management Tool |  | 45d | 2024-07-01 | 2024-08-30 | 1539SS |  |  | 2024-01-31 | 2024-04-12 | 53d | 715d |  |  | Laura Kennedy | 360h |  |  | Non-SIT S&A QT Test Team | 4.33 | 5.27 | Red | RED |  |  |  |
| 1541 | 1.6.4.1.7.8.3 | Knowledge Transfer, Training, Demonstrations, Documentation, Governance |  | 85d | 2024-09-02 | 2024-12-27 | 1539SS+45d |  |  | 2024-04-15 | 2024-08-13 | 87d | 630d |  |  | Laura Kennedy | 680h |  |  | Non-SIT S&A QT Test Team | 67.33 | 5.27 | Red | RED |  |  |  |
| 1542 | 1.6.4.1.7.8.4 | Qualification Testing Wave Readiness Confirmed | milestone | 0d | 2025-01-23 | 2025-01-23 | 1543FS+4d |  |  | 2025-01-23 | 2025-01-23 | 0d | 8d | 7d |  | Laura Kennedy |  |  |  |  | 210.71 | 5.25 | Green | GREEN | T3-QU-0117 | QAG |  |
| 1543 | 1.6.4.1.7.9 | Qualification Testing Framework (Test Stubs and Supporting UI) Complete | milestone | 0d | 2025-01-17 | 2025-01-17 |  |  |  | 2025-01-17 | 2025-01-17 | 0d | 8d | 0d | finish no earlier than 2025-01-17 | Laura Kennedy |  |  |  |  | 204.71 | 5.25 | Green | GREEN | T3-QU-0093 | QAG |  |
| 1544 | 1.6.4.1.8 | **Wave Allocation** |  | 129d | 2024-01-02 A | 2024-06-28 |  | 99% | 0d | 2024-01-02 | 2024-06-28 | 128d | 77d |  |  | N/A | 2000h | 1128h | -0 | N/A | -133.67 | 5.24 |  |  |  |  | N/A |
| 1545 | 1.6.4.1.8.1 | Draft Pre-Qualification Submission (PQS) document |  | 20d | 2024-01-02 A | 2024-01-29 A |  | 100% |  | 2024-01-02 | 2024-01-29 | 20d |  |  | finish no earlier than 2024-01-26 | Laura Kennedy | 160h | 160h |  | Code Bodies |  | 5.24 | Complete | COMPLETE |  |  |  |
| 1546 | 1.6.4.1.8.2 | Publish PQS document |  | 1d | 2024-01-31 A | 2024-01-31 A |  | 100% |  | 2024-01-31 | 2024-01-31 | 1d |  |  | start no earlier than 2024-01-31 | Laura Kennedy | 8h | 8h |  | Code Bodies |  | 5.24 | Complete | COMPLETE |  |  |  |
| 1547 | 1.6.4.1.8.3 | PQS Submission window |  | 60d | 2024-02-05 A | 2024-04-26 A |  | 100% |  | 2024-02-05 | 2024-04-26 | 60d |  |  | start no earlier than 2024-02-05 | Laura Kennedy | 480h | 480h |  | Participants |  | 5.24 | Complete | COMPLETE |  |  |  |
| 1548 | 1.6.4.1.8.4 | Pre-Qualification Submission and PIT Test Plan Deadline for Submission​ | milestone | 0d | 2024-04-26 A | 2024-04-26 A | 1547 | 100% |  | 2024-04-26 | 2024-04-26 | 0d |  |  |  | Laura Kennedy |  |  |  |  |  | 5.25 | Complete | COMPLETE | T3-QU-0118 | QAG |  |
| 1549 | 1.6.4.1.8.5 | PQS Review by Code Bodies |  | 25d | 2024-04-29 A | 2024-05-31 A | 1547, 1548 | 100% |  | 2024-04-29 | 2024-05-31 | 25d |  |  |  | Laura Kennedy | 200h | 200h |  | Code Bodies |  | 5.24 | Complete | COMPLETE |  |  |  |
| 1550 | 1.6.4.1.8.6 | Draft Wave Allocations |  | 15d | 2024-06-03 A | 2024-06-21 A | 1549 | 100% |  | 2024-06-03 | 2024-06-21 | 15d |  |  |  | Laura Kennedy | 120h | 120h |  | Code Bodies |  | 5.24 | Complete | COMPLETE |  |  |  |
| 1551 | 1.6.4.1.8.7 | Confirmation of participant Qualification Wave allocation | milestone | 0d | 2024-06-28 | 2024-06-28 | 1550FS+5d |  |  | 2024-06-28 | 2024-06-28 | 0d | 77d | 76d |  | Laura Kennedy |  |  |  | Code Bodies | 1.71 | 5.24 | yellow | GREEN | T3-QU-0012 | QAG |  |
| 1552 | 1.6.4.2 | **Qualification Wave 1** |  | 229d | 2024-10-14 | 2025-08-29 |  |  |  | 2024-10-14 | 2025-08-29 | 229d | 1d |  |  | N/A | 8128h |  | -0 | N/A | -133.67 | 5.24 |  |  |  |  | N/A |
| 1553 | 1.6.4.2.1 | **Qualification Wave 1 QAD Prep** |  | 79d | 2024-10-14 | 2025-01-31 |  |  |  | 2024-10-14 | 2025-01-31 | 80d | 1d |  |  | N/A | 1264h |  | -0 | N/A | -152.67 | 5.24 |  |  |  |  | N/A |
| 1554 | 1.6.4.2.1.1 | Initial QAD Submission window opens | milestone | 0d | 2024-10-14 | 2024-10-14 | 1551, 1373FS+6d |  |  | 2024-10-14 | 2024-10-14 | 0d | 1d | 0d |  | Laura Kennedy |  |  |  | Participants | 109.71 | 5.24 | yellow | GREEN |  |  |  |
| 1555 | 1.6.4.2.1.2 | Qualification Wave 1 Participants Submit Initial QAD |  | 49d | 2024-10-15 | 2024-12-20 | 1554 |  |  | 2024-10-14 | 2024-12-20 | 50d | 1d | 0d |  | Laura Kennedy | 392h |  |  | Participants | 110.33 | 5.24 | Green | GREEN |  |  |  |
| 1556 | 1.6.4.2.1.3 | Qualification Wave 1 Participants have submitted their initial QAD | milestone | 0d | 2024-12-20 | 2024-12-20 | 1555 |  |  | 2024-12-20 | 2024-12-20 | 0d | 1d | 0d |  | Laura Kennedy |  |  |  | Participants | 176.71 | 5.25 | Green | GREEN | T3-QU-0094 | QAG |  |
| 1557 | 1.6.4.2.1.4 | Code Bodies review of Wave 1 Participants Initial QAD |  | 30d | 2024-12-23 | 2025-01-31 | 1555, 1556 |  |  | 2024-12-23 | 2025-01-31 | 30d | 1d | 0d |  | Laura Kennedy | 240h |  |  | Code Bodies | 179.33 | 5.24 | Green | GREEN |  |  |  |
| 1558 | 1.6.4.2.1.5 | Completion of Code Bodies review of Initial QAD | milestone | 0d | 2025-01-31 | 2025-01-31 | 1557 |  |  | 2025-01-31 | 2025-01-31 | 0d | 1d | 0d |  | Laura Kennedy |  |  |  | Code Bodies | 218.71 | 5.24 | Green | GREEN |  |  |  |
| 1559 | 1.6.4.2.2 | **Qualification Wave 1 Test Prep** |  | 60d | 2024-11-01 | 2025-01-24 |  |  |  | 2024-11-01 | 2025-01-24 | 60d | 7d |  |  | N/A | 1280h |  | -0 | N/A | -555.67 | 5.24 |  |  |  |  | N/A |
| 1560 | 1.6.4.2.2.1 | Confirmation from Qualification Wave 1 Participants that DIP onboarding has commenced | milestone | 0d | 2024-11-01 | 2024-11-01 |  |  |  | 2024-11-01 | 2024-11-01 | 0d | 26d | 0d | finish no earlier than 2024-11-01 | Laura Kennedy |  |  |  | Participants | 127.71 | 5.24 | Green | GREEN | T3-QU-0017 | QAG |  |
| 1561 | 1.6.4.2.2.2 | Qualification Wave 1 Participants DIP Onboarding Window |  | 35d | 2024-11-04 | 2024-12-20 | 1560 |  |  | 2024-11-04 | 2024-12-20 | 35d | 26d | 0d |  | Laura Kennedy | 280h |  |  | Participants | 130.33 | 5.24 | Green | GREEN |  |  |  |
| 1562 | 1.6.4.2.2.3 | Confirmation from Qualification Wave 1 Participants that DIP onboarding has completed | milestone | 0d | 2024-12-20 | 2024-12-20 | 1561 |  |  | 2024-12-20 | 2024-12-20 | 0d | 26d | 25d |  | Laura Kennedy |  |  |  | Participants | 176.71 | 5.24 | Green | GREEN |  |  |  |
| 1563 | 1.6.4.2.2.4 | Qualification Wave 1 Participants' to provide status of PIT completion and submit QT Test Plan | milestone | 0d | 2024-11-29 | 2024-11-29 |  |  |  | 2024-11-29 | 2024-11-29 | 0d | 26d | 0d | start no earlier than 2024-11-29 | Laura Kennedy |  |  |  | Participants | 155.33 | 5.25 | Green | GREEN | T3-QU-0095 | QAG |  |
| 1564 | 1.6.4.2.2.5 | Review of Participants' PIT Status and QT Test Plan |  | 15d | 2024-12-02 | 2024-12-20 | 1563FS+1d |  |  | 2024-12-02 | 2024-12-20 | 15d | 26d | 0d |  | Laura Kennedy | 120h |  |  | Code Bodies, Non-SIT S&A QT Test Team | 158.33 | 5.24 | Green | GREEN |  |  |  |
| 1565 | 1.6.4.2.2.6 | Qualification Test Plans for Wave 1 Participants approved | milestone | 0d | 2024-12-20 | 2024-12-20 | 1564 |  |  | 2024-12-20 | 2024-12-20 | 0d | 26d | 25d |  | Laura Kennedy |  |  |  | Non-SIT S&A QT Test Team | 176.71 | 5.24 | Green | GREEN | T3-QU-0016 | QAG |  |
| 1566 | 1.6.4.2.2.7 | Qualification Wave 1 Participants have submitted PIT Test Completion Report and evidence for QT Entry | milestone | 0d | 2024-12-20 | 2024-12-20 |  |  |  | 2024-12-20 | 2024-12-20 | 0d | 1d | 0d | finish no earlier than 2024-12-20 | Laura Kennedy |  |  |  | Participants | 176.71 | 5.25 | Green | GREEN | T3-QU-0096 | QAG |  |
| 1567 | 1.6.4.2.2.8 | Review of Participants PIT Test Completion Report |  | 25d | 2024-12-23 | 2025-01-24 | 1566 |  |  | 2024-12-23 | 2025-01-24 | 25d | 1d | 0d |  | Laura Kennedy | 200h |  |  | Code Bodies, Non-SIT S&A QT Test Team | 179.33 | 5.24 | Green | GREEN |  |  |  |
| 1568 | 1.6.4.2.2.9 | Onboarding to QTF & ADO |  | 25d | 2024-12-23 | 2025-01-24 | 1567SS |  |  |  |  |  | 7d | 6d |  | Laura Kennedy | 200h |  |  |  | 179.33 | 5.25 | No BL | GREEN |  |  |  |

Notes:
- 1543: Action: 31/5: To be linked into QTF breakdown when confirmed and added to plan

| ID | WBS | Task | Type | Duration | Start | Finish | Predecessors | Baseline start | Baseline finish | Baseline duration | Total slack | Free slack | Constraint | Resources | Work | Baseline cost | Responsible | Involved | Task Status | Update Version | Sched Status | RAG | Milestone ID | Text29 | Action |
| --- | --- | --- | --- | --- | --- | --- | --- | --- | --- | --- | --- | --- | --- | --- | --- | --- | --- | --- | --- | --- | --- | --- | --- | --- | --- |
| 1569 | 1.6.4.2.3 | **Qualification Wave 1 QT Execution** |  | 100d | 2025-01-27 | 2025-06-13 |  | 2025-01-27 | 2025-06-13 | 100d | 1d |  |  | N/A | 1600h | -0 | N/A | N/A | -152.67 | 5.24 |  |  |  |  |  |
| 1570 | 1.6.4.2.3.1 | Review Entry Criteria Evidence for each Wave 1 Participant |  | 5d | 2025-01-27 | 2025-01-31 | 1558FF, 1562, 1565, 1567 | 2025-01-27 | 2025-01-31 | 5d | 1d | 0d |  | Laura Kennedy | 40h |  | Non-SIT S&A QT Test Team |  | 214.33 | 5.24 | Green | GREEN |  |  |  |
| 1571 | 1.6.4.2.3.2 | Qualification Wave 1 Participant Test Readiness Confirmed | milestone | 0d | 2025-01-31 | 2025-01-31 | 1557, 1558, 1570 | 2025-01-31 | 2025-01-31 | 0d | 1d | 0d |  | Laura Kennedy |  |  | Non-SIT S&A QT Test Team |  | 218.71 | 5.24 | Green | GREEN | T3-QU-0027 | QAG |  |
| 1572 | 1.6.4.2.3.3 | Qualification Wave 1 QT Execution Start | milestone | 0d | 2025-02-03 | 2025-02-03 | 1571FS+1d, 1542, 1568, 1040 | 2025-02-03 | 2025-02-03 | 0d | 1d | 0d |  | Laura Kennedy |  |  | Participants |  | 221.71 | 5.24 | Green | GREEN | T3-QU-0028 | QAG |  |
| 1573 | 1.6.4.2.3.4 | Qualification Wave 1 QT Execution Window |  | 95d | 2025-02-03 | 2025-06-13 | 1572FS-1d | 2025-02-03 | 2025-06-13 | 95d | 6d | 0d |  | Laura Kennedy | 760h |  | Participants |  | 221.33 | 5.24 | Green | GREEN |  |  |  |
| 1574 | 1.6.4.2.3.5 | Qualification Wave 1 QT Projected Execution End | milestone | 0d | 2025-06-13 | 2025-06-13 | 1573 | 2025-06-13 | 2025-06-13 | 0d | 6d | 5d |  | Laura Kennedy |  |  | Participants |  | 351.71 | 5.24 | Green | GREEN | T3-QU-0054 | QAG |  |
| 1575 | 1.6.4.2.4 | **Qualification Wave 1 Exit** |  | 149d | 2025-02-03 | 2025-08-29 |  | 2025-02-03 | 2025-08-29 | 149d? | 1d |  |  | N/A | 2152h | -0 | N/A | N/A | -152.67 | 5.24 |  |  |  |  |  |
| 1576 | 1.6.4.2.4.1 | Final QAD Submission window opens | milestone | 0d | 2025-02-03 | 2025-02-03 | 1572 | 2025-02-03 | 2025-02-03 | 0d | 1d | 0d |  | Laura Kennedy |  |  | Participants |  | 221.71 | 5.24 | yellow | GREEN |  |  |  |
| 1577 | 1.6.4.2.4.2 | Qualification Wave 1 Participants submit their Final QAD |  | 99d | 2025-02-04 | 2025-06-20 | 1576 | 2025-02-03 | 2025-06-20 | 100d | 1d | 0d |  | Laura Kennedy | 792h |  | Participants |  | 222.33 | 5.24 | Green | GREEN |  |  |  |
| 1578 | 1.6.4.2.4.3 | Qualification Wave 1 Participants have submitted their final QAD | milestone | 0d | 2025-06-20 | 2025-06-20 | 1577, 1574 | 2025-06-20 | 2025-06-20 | 0d | 1d | 0d |  | Laura Kennedy |  |  | Participants |  | 358.71 | 5.25 | Green | GREEN | T3-QU-0097 | QAG |  |
| 1579 | 1.6.4.2.4.4 | Completion of Code Bodies review of Final QAD |  | 20d | 2025-06-23 | 2025-07-18 | 1577, 1578 | 2025-06-23 | 2025-07-18 | 20d | 1d | 0d |  | Laura Kennedy | 160h |  | Code Bodies |  | 361.33 | 5.24 | Green | GREEN |  |  |  |
| 1580 | 1.6.4.2.4.5 | QAD Sign Off deadline |  | 1d | 2025-07-31 | 2025-07-31 | 1579FS+8d | 2025-07-31 | 2025-07-31 | 1d | 1d | 0d |  | Laura Kennedy | 8h |  | Participants |  | 399.33 | 5.24 | Green | GREEN |  |  |  |
| 1581 | 1.6.4.2.4.6 | Qualification Wave 1 Participants Qualification approved by BSC PAB and REC Manager | milestone | 0d | 2025-08-29 | 2025-08-29 | 1580FS+21d | 2025-08-29 | 2025-08-29 | 0d | 1d | 0d |  | Laura Kennedy |  |  | Code Bodies |  | 428.71 | 5.24 | yellow | GREEN | T2-QU-0150 | QAG | link to id 405 dates work |
| 1582 | 1.6.4.3 | **Qualification Wave 2** |  | 249d | 2024-11-18 | 2025-10-31 |  | 2024-11-18 | 2025-10-31 | 249d | 1d |  |  | N/A | 8640h | -0 | N/A | N/A | -133.67 | 5.24 |  |  |  |  |  |
| 1583 | 1.6.4.3.1 | **Qualification Wave 2 QAD Prep** |  | 95d | 2024-11-18 | 2025-03-31 |  | 2024-11-18 | 2025-03-31 | 96d | 1d |  |  | N/A | 1520h | -0 | N/A | N/A | -154.67 | 5.24 |  |  |  |  |  |
| 1584 | 1.6.4.3.1.1 | Initial QAD Submission window opens | milestone | 0d | 2024-11-18 | 2024-11-18 | 1374FS+6d | 2024-11-18 | 2024-11-18 | 0d | 1d | 0d |  | Laura Kennedy |  |  | Participants |  | 144.71 | 5.24 | yellow | GREEN |  |  |  |
| 1585 | 1.6.4.3.1.2 | Qualification Wave 2 Participants Submit Initial QAD |  | 69d | 2024-11-19 | 2025-02-21 | 1584 | 2024-11-18 | 2025-02-21 | 70d | 1d | 0d |  | Laura Kennedy | 552h |  | Participants |  | 145.33 | 5.24 | Green | GREEN |  |  |  |
| 1586 | 1.6.4.3.1.3 | Qualification Wave 2 Participants have submitted their initial QAD | milestone | 0d | 2025-02-21 | 2025-02-21 | 1585 | 2025-02-21 | 2025-02-21 | 0d | 1d | 0d |  | Laura Kennedy |  |  | Participants |  | 239.71 | 5.25 | Green | GREEN | T3-QU-0098 | QAG |  |
| 1587 | 1.6.4.3.1.4 | Code Bodies review of Wave 2 Participants' Initial QAD |  | 26d | 2025-02-24 | 2025-03-31 | 1586 | 2025-02-24 | 2025-03-31 | 26d | 1d | 0d |  | Laura Kennedy | 208h |  | Code Bodies |  | 242.33 | 5.24 | Green | GREEN |  |  |  |
| 1588 | 1.6.4.3.1.5 | Completion of Code Bodies review of Initial QAD | milestone | 0d | 2025-03-31 | 2025-03-31 | 1587 | 2025-03-31 | 2025-03-31 | 0d | 1d | 0d |  | Laura Kennedy |  |  | Code Bodies |  | 277.71 | 5.24 | Green | GREEN |  |  |  |
| 1589 | 1.6.4.3.2 | **Qualification Wave 2 Test Prep** |  | 60d | 2025-01-06 | 2025-03-28 |  | 2025-01-06 | 2025-03-28 | 60d | 3d |  |  | N/A | 1320h | -0 | N/A | N/A | -555.67 | 5.24 |  |  |  |  |  |
| 1590 | 1.6.4.3.2.1 | Confirmation from Qualification Wave 2 Participants that DIP Onboarding has commenced | milestone | 0d | 2025-01-06 | 2025-01-06 |  | 2025-01-06 | 2025-01-06 | 0d | 17d | 0d | start no earlier than 2025-01-06 | Laura Kennedy |  |  | Participants |  | 193.33 | 5.24 | Green | GREEN | T3-QU-0021 | QAG |  |
| 1591 | 1.6.4.3.2.2 | Qualification Wave 2 Participants DIP Onboarding Window |  | 40d | 2025-01-06 | 2025-02-28 | 1590 | 2025-01-06 | 2025-02-28 | 40d | 17d | 0d |  | Laura Kennedy | 320h |  | Participants |  | 193.33 | 5.24 | Green | GREEN |  |  |  |
| 1592 | 1.6.4.3.2.3 | Confirmation from Qualificiation Wave 2 Participants that DIP onboarding has completed | milestone | 0d | 2025-02-28 | 2025-02-28 | 1591 | 2025-02-28 | 2025-02-28 | 0d | 17d | 16d |  | Laura Kennedy |  |  | Participants |  | 246.71 | 5.24 | Green | GREEN |  |  |  |
| 1593 | 1.6.4.3.2.4 | Qualification Wave 2 Participants' to provide status of PIT completion and submit QT Test Plan | milestone | 0d | 2025-01-31 | 2025-01-31 |  | 2025-01-31 | 2025-01-31 | 0d | 3d | 0d | start no earlier than 2025-01-31 | Laura Kennedy |  |  | Participants |  | 218.33 | 5.25 | Green | GREEN | T3-QU-0099 | QAG |  |
| 1594 | 1.6.4.3.2.5 | Review of Participants' PIT Status and QT Test Plan |  | 15d | 2025-02-03 | 2025-02-21 | 1593FS+1d | 2025-02-03 | 2025-02-21 | 15d | 3d | 0d |  | Laura Kennedy | 120h |  | Code Bodies, Non-SIT S&A QT Test Team |  | 221.33 | 5.24 | Green | GREEN |  |  |  |
| 1595 | 1.6.4.3.2.6 | Qualification Test Plans for Wave 2 Participants approved | milestone | 0d | 2025-02-21 | 2025-02-21 | 1594 | 2025-02-21 | 2025-02-21 | 0d | 3d | 0d |  | Laura Kennedy |  |  | Non-SIT S&A QT Test Team |  | 239.71 | 5.24 | Green | GREEN | T3-QU-0020 | QAG |  |
| 1596 | 1.6.4.3.2.7 | Qualification Wave 2 Participants have submitted PIT Test Completion Report and evidence for QT entry | milestone | 0d | 2025-02-21 | 2025-02-21 | 1595 | 2025-02-21 | 2025-02-21 | 0d | 3d | 0d |  | Laura Kennedy |  |  | Participants |  | 239.71 | 5.25 | yellow | GREEN | T3-QU-0100 | QAG |  |
| 1597 | 1.6.4.3.2.8 | Review of Participants' PIT Test Completion Report |  | 25d | 2025-02-24 | 2025-03-28 | 1596 | 2025-02-24 | 2025-03-28 | 25d | 3d | 0d |  | Laura Kennedy | 200h |  | Code Bodies, Non-SIT S&A QT Test Team |  | 242.33 | 5.24 | Green | GREEN |  |  |  |
| 1598 | 1.6.4.3.2.9 | Onboarding to QTF & ADO |  | 25d | 2025-02-24 | 2025-03-28 | 1597SS |  |  |  | 3d | 2d |  | Laura Kennedy | 200h |  |  |  | 242.33 | 5.25 | No BL | GREEN |  |  |  |

Notes:
- 1581: link to m14 and is there a logical dep into migration at end of each wave. 14/5: Baseline and name updated after cr48 approval at psg on 1/5

| ID | WBS | Task | Type | Duration | Start | Finish | Predecessors | Baseline start | Baseline finish | Baseline duration | Total slack | Free slack | Constraint | Resources | Work | Baseline cost | Responsible | Involved | Task Status | Update Version | Sched Status | RAG | Milestone ID | Text29 |
| --- | --- | --- | --- | --- | --- | --- | --- | --- | --- | --- | --- | --- | --- | --- | --- | --- | --- | --- | --- | --- | --- | --- | --- | --- |
| 1599 | 1.6.4.3.3 | **Qualification Wave 2 QT Execution** |  | 99d | 2025-03-25 | 2025-08-08 |  | 2025-03-25 | 2025-08-08 | 99d | 1d |  |  | N/A | 1576h | -0 | N/A | N/A | -154.67 | 5.24 |  |  |  |  |
| 1600 | 1.6.4.3.3.1 | Review Entry Criteria Evidence for each Wave 2 Participant |  | 5d | 2025-03-25 | 2025-03-31 | 1588FF, 1592 | 2025-03-25 | 2025-03-31 | 5d | 1d | 0d |  | Laura Kennedy | 40h |  | Non-SIT S&A QT Test Team |  | 271.33 | 5.24 | Green | GREEN |  |  |
| 1601 | 1.6.4.3.3.2 | Qualification Wave 2 Participant Test Readiness Confirmed | milestone | 0d | 2025-03-31 | 2025-03-31 | 1600, 1588 | 2025-03-31 | 2025-03-31 | 0d | 1d | 0d |  | Laura Kennedy |  |  | Non-SIT S&A QT Test Team |  | 277.71 | 5.24 | Green | GREEN | T3-QU-0033 | QAG |
| 1602 | 1.6.4.3.3.3 | Qualification Wave 2 Execution Start | milestone | 0d | 2025-04-01 | 2025-04-01 | 1601FS+1d, 1598 | 2025-04-01 | 2025-04-01 | 0d | 1d | 0d |  | Laura Kennedy |  |  | Participants |  | 278.71 | 5.24 | yellow | GREEN | T3-QU-0034 | QAG |
| 1603 | 1.6.4.3.3.4 | Qualification Wave 2 QT Execution Window |  | 93d | 2025-04-02 | 2025-08-08 | 1602 | 2025-04-01 | 2025-08-08 | 94d | 6d | 0d |  | Laura Kennedy | 744h |  | Participants |  | 279.33 | 5.24 | Green | GREEN |  |  |
| 1604 | 1.6.4.3.3.5 | Qualfication Wave 2 QT Execution End | milestone | 0d | 2025-08-08 | 2025-08-08 | 1603 | 2025-08-08 | 2025-08-08 | 0d | 6d | 5d |  | Laura Kennedy |  |  | Participants |  | 407.71 | 5.24 | Green | GREEN | T3-QU-0055 | QAG |
| 1605 | 1.6.4.3.4 | **Qualification Wave 2 Exit** |  | 153d | 2025-04-01 | 2025-10-31 |  | 2025-04-01 | 2025-10-31 | 153d | 1d |  |  | N/A | 2232h | -0 | N/A | N/A | -154.67 | 5.24 |  |  |  |  |
| 1606 | 1.6.4.3.4.1 | Final QAD Submission window opens | milestone | 0d | 2025-04-01 | 2025-04-01 | 1602 | 2025-04-01 | 2025-04-01 | 0d | 1d | 0d |  | Laura Kennedy |  |  | Participants |  | 278.71 | 5.24 | yellow | GREEN |  |  |
| 1607 | 1.6.4.3.4.2 | Qualification Wave 2 Participants submit their Final QAD |  | 98d | 2025-04-02 | 2025-08-15 | 1606 | 2025-04-01 | 2025-08-15 | 99d | 1d | 0d |  | Laura Kennedy | 784h |  | Participants |  | 279.33 | 5.24 | Green | GREEN |  |  |
| 1608 | 1.6.4.3.4.3 | Qualification Wave 2 Participants have submitted their final QAD | milestone | 0d | 2025-08-15 | 2025-08-15 | 1607, 1604 | 2025-08-15 | 2025-08-15 | 0d | 1d | 0d |  | Laura Kennedy |  |  | Participants |  | 414.71 | 5.25 | Green | GREEN | T3-QU-0101 | QAG |
| 1609 | 1.6.4.3.4.4 | Completion of Code Bodies review of Final QAD |  | 27d | 2025-08-18 | 2025-09-23 | 1608 | 2025-08-18 | 2025-09-23 | 27d | 1d | 0d |  | Laura Kennedy | 216h |  | Code Bodies |  | 417.33 | 5.24 | Green | GREEN |  |  |
| 1610 | 1.6.4.3.4.5 | QAD Sign Off deadline |  | 1d | 2025-09-30 | 2025-09-30 | 1609FS+4d | 2025-09-30 | 2025-09-30 | 1d | 1d | 0d |  | Laura Kennedy | 8h |  | Participants |  | 460.33 | 5.24 | Green | GREEN |  |  |
| 1611 | 1.6.4.3.4.6 | Qualification Wave 2 Participants Qualification approved by BSC PAB and REC Manager | milestone | 0d | 2025-10-31 | 2025-10-31 | 1610FS+23d | 2025-10-31 | 2025-10-31 | 0d | 1d | 0d |  | Laura Kennedy |  |  | Code Bodies |  | 491.71 | 5.24 | yellow | GREEN | T2-QU-0200 | QAG |
| 1612 | 1.6.4.4 | **Qualification Wave 3** |  | 239d | 2025-01-20 | 2025-12-19 |  | 2025-01-20 | 2025-12-19 | 239d | 1d |  |  | N/A | 8528h | -0 | N/A | N/A | -133.67 | 5.24 |  |  |  |  |
| 1613 | 1.6.4.4.1 | **Qualification Wave 3 QAD Prep** |  | 94d | 2025-01-20 | 2025-05-30 |  | 2025-01-20 | 2025-05-30 | 95d | 2d |  |  | N/A | 1504h | -0 | N/A | N/A | -154.67 | 5.24 |  |  |  |  |
| 1614 | 1.6.4.4.1.1 | Initial QAD Submission window opens | milestone | 0d | 2025-01-20 | 2025-01-20 | 1375FS+6d | 2025-01-20 | 2025-01-20 | 0d | 2d | 0d |  | Laura Kennedy |  |  | Participants |  | 207.71 | 5.24 | yellow | GREEN |  |  |
| 1615 | 1.6.4.4.1.2 | Qualification Wave 3 Participants Submit Initial QAD |  | 64d | 2025-01-21 | 2025-04-18 | 1614 | 2025-01-20 | 2025-04-18 | 65d | 2d | 0d |  | Laura Kennedy | 512h |  | Participants |  | 208.33 | 5.24 | Green | GREEN |  |  |
| 1616 | 1.6.4.4.1.3 | Qualification Wave 3 Participants have submitted their initial QAD | milestone | 0d | 2025-04-18 | 2025-04-18 | 1615 | 2025-04-18 | 2025-04-18 | 0d | 2d | 0d |  | Laura Kennedy |  |  | Participants |  | 295.71 | 5.25 | yellow | GREEN | T3-QU-0102 | QAG |
| 1617 | 1.6.4.4.1.4 | Code Bodies review of Wave 3 Participants' Initial QAD |  | 30d | 2025-04-21 | 2025-05-30 | 1616 | 2025-04-21 | 2025-05-30 | 30d | 2d | 0d |  | Laura Kennedy | 240h |  | Code Bodies |  | 298.33 | 5.24 | Green | GREEN |  |  |
| 1618 | 1.6.4.4.1.5 | Completion of Code Bodies review of Initial QAD | milestone | 0d | 2025-05-30 | 2025-05-30 | 1617 | 2025-05-30 | 2025-05-30 | 0d | 2d | 0d |  | Laura Kennedy |  |  | Code Bodies |  | 337.71 | 5.24 | Green | GREEN |  |  |
| 1619 | 1.6.4.4.2 | **Qualification Wave 3 Test Prep** |  | 65d | 2025-03-03 | 2025-05-30 |  | 2025-03-03 | 2025-05-30 | 65d | 1d |  |  | N/A | 1440h | -0 | N/A | N/A | -555.67 | 5.24 |  |  |  |  |
| 1620 | 1.6.4.4.2.1 | Qualification Wave 3 Participants' have started DIP Onboarding | milestone | 0d | 2025-03-03 | 2025-03-03 |  | 2025-03-03 | 2025-03-03 | 0d | 24d | 0d | start no earlier than 2025-03-03 | Laura Kennedy |  |  | Participants |  | 249.33 | 5.24 | Green | GREEN | T3-QU-0025 | QAG |
| 1621 | 1.6.4.4.2.2 | Qualification Wave 3 Participants DIP Onboarding window |  | 40d | 2025-03-03 | 2025-04-25 | 1620 | 2025-03-03 | 2025-04-25 | 40d | 24d | 0d |  | Laura Kennedy | 320h |  | Participants |  | 249.33 | 5.24 | Green | GREEN |  |  |
| 1622 | 1.6.4.4.2.3 | Confirmation from Qualification Wave 3 Participants that DIP onboarding has completed | milestone | 0d | 2025-04-25 | 2025-04-25 | 1621 | 2025-04-25 | 2025-04-25 | 0d | 24d | 22d |  | Laura Kennedy |  |  | Participants |  | 302.71 | 5.24 | Green | GREEN |  |  |
| 1623 | 1.6.4.4.2.4 | Qualification Wave 3 Participants' to provide status of PIT completion and submit QT Test Plan | milestone | 0d | 2025-03-31 | 2025-03-31 |  | 2025-03-31 | 2025-03-31 | 0d | 1d | 0d | start no earlier than 2025-03-31 | Laura Kennedy |  |  | Participants |  | 277.33 | 5.25 | Green | GREEN | T3-QU-0103 | QAG |
| 1624 | 1.6.4.4.2.5 | Review of Participants' PIT Status and QT Test Plan |  | 15d | 2025-03-31 | 2025-04-18 | 1623 | 2025-03-31 | 2025-04-18 | 15d | 1d | 0d |  | Laura Kennedy | 120h |  | Code Bodies, Non-SIT S&A QT Test Team |  | 277.33 | 5.24 | Green | GREEN |  |  |
| 1625 | 1.6.4.4.2.6 | Qualification Test Plans for Wave 3 Participants approved | milestone | 0d | 2025-04-18 | 2025-04-18 | 1624 | 2025-04-18 | 2025-04-18 | 0d | 1d | 0d |  | Laura Kennedy |  |  | Non-SIT S&A QT Test Team |  | 295.71 | 5.24 | Green | GREEN | T3-QU-0024 | QAG |
| 1626 | 1.6.4.4.2.7 | Qualification Wave 3 Participants have submitted PIT Test Completion Report and evidence for QT Entry | milestone | 0d | 2025-04-18 | 2025-04-18 | 1625 | 2025-04-18 | 2025-04-18 | 0d | 1d | 0d |  | Laura Kennedy |  |  | Participants |  | 295.71 | 5.25 | yellow | GREEN | T3-QU-0104 | QAG |
| 1627 | 1.6.4.4.2.8 | Review of Participants' PIT Test Completion Report |  | 30d | 2025-04-21 | 2025-05-30 | 1626 | 2025-04-21 | 2025-05-30 | 30d | 1d | 0d |  | Laura Kennedy | 240h |  | Code Bodies, Non-SIT S&A QT Test Team |  | 298.33 | 5.24 | Green | GREEN |  |  |
| 1628 | 1.6.4.4.2.9 | Onboarding to QTF & ADO |  | 30d | 2025-04-21 | 2025-05-30 | 1627SS |  |  |  | 1d | 0d |  | Laura Kennedy | 240h |  |  |  | 298.33 | 5.24 | No BL | GREEN |  |  |

Notes:
- 1611: 14/5: Baseline and name updated after cr48 approval at psg on 1/5

| ID | WBS | Task | Type | Duration | Start | Finish | Predecessors | Baseline start | Baseline finish | Baseline duration | Total slack | Free slack | Constraint | Resources | Work | Baseline cost | Responsible | Involved | Task Status | Update Version | Sched Status | RAG | Milestone ID | Text29 |
| --- | --- | --- | --- | --- | --- | --- | --- | --- | --- | --- | --- | --- | --- | --- | --- | --- | --- | --- | --- | --- | --- | --- | --- | --- |
| 1629 | 1.6.4.4.3 | **Qualification Wave 3 QT Execution** |  | 98d | 2025-05-28 | 2025-10-10 |  | 2025-05-26 | 2025-10-10 | 100d | 2d |  |  | N/A | 1560h | -0 | N/A | N/A | -154.67 | 5.24 |  |  |  |  |
| 1630 | 1.6.4.4.3.1 | Review Entry Criteria Evidence for each Wave 3 Participant |  | 3d | 2025-05-28 | 2025-05-30 | 1622, 1618FF | 2025-05-26 | 2025-05-30 | 5d | 2d | 0d |  | Laura Kennedy | 24h |  | Non-SIT S&A QT Test Team |  | 335.33 | 5.24 | Green | GREEN |  |  |
| 1631 | 1.6.4.4.3.2 | Qualification Wave 3 Participant Test Readiness confirmed | milestone | 0d | 2025-05-30 | 2025-05-30 | 1622, 1630 | 2025-05-30 | 2025-05-30 | 0d | 2d | 1d |  | Laura Kennedy |  |  | Non-SIT S&A QT Test Team |  | 337.71 | 5.24 | yellow | GREEN | T3-QU-0038 | QAG |
| 1632 | 1.6.4.4.3.3 | Qualification Wave 3 Execution Start | milestone | 0d | 2025-06-02 | 2025-06-02 | 1631, 1628FS+1d | 2025-06-02 | 2025-06-02 | 0d | 1d | 0d |  | Laura Kennedy |  |  | Participants |  | 340.71 | 5.24 | yellow | GREEN | T3-QU-0039 | QAG |
| 1633 | 1.6.4.4.3.4 | Qualification Wave 3 QT Execution Window |  | 94d | 2025-06-03 | 2025-10-10 | 1630, 1632 | 2025-06-02 | 2025-10-10 | 95d | 6d | 0d |  | Laura Kennedy | 752h |  | Participants |  | 341.33 | 5.24 | Green | GREEN |  |  |
| 1634 | 1.6.4.4.3.5 | Qualification Wave 3 Projected Execution End | milestone | 0d | 2025-10-10 | 2025-10-10 | 1633 | 2025-10-10 | 2025-10-10 | 0d | 6d | 5d |  | Laura Kennedy |  |  | Participants |  | 470.71 | 5.24 | Green | GREEN | T3-QU-0056 | QAG |
| 1635 | 1.6.4.4.4 | **Qualification Wave 3 Exit** |  | 144d | 2025-06-02 | 2025-12-19 |  | 2025-06-02 | 2025-12-19 | 144d | 1d |  |  | N/A | 2112h | -0 | N/A | N/A | -154.67 | 5.24 |  |  |  |  |
| 1636 | 1.6.4.4.4.1 | Final QAD Submission window opens | milestone | 0d | 2025-06-02 | 2025-06-02 | 1632 | 2025-06-02 | 2025-06-02 | 0d | 1d | 0d |  | Laura Kennedy |  |  | Participants |  | 340.71 | 5.24 | yellow | GREEN |  |  |
| 1637 | 1.6.4.4.4.2 | Qualification Wave 3 Participants submit their Final QAD |  | 99d | 2025-06-03 | 2025-10-17 | 1636 | 2025-06-02 | 2025-10-17 | 100d | 1d | 0d |  | Laura Kennedy | 792h |  | Participants |  | 341.33 | 5.24 | Green | GREEN |  |  |
| 1638 | 1.6.4.4.4.3 | Qualification Wave 3 Participants have submitted their Final QAD | milestone | 0d | 2025-10-17 | 2025-10-17 | 1637, 1634 | 2025-10-17 | 2025-10-17 | 0d | 1d | 0d |  | Laura Kennedy |  |  | Participants |  | 477.71 | 5.25 | Green | GREEN | T3-QU-0105 | QAG |
| 1639 | 1.6.4.4.4.4 | Completion of Code Bodies review of Final QAD |  | 20d | 2025-10-20 | 2025-11-14 | 1638 | 2025-10-20 | 2025-11-14 | 20d | 1d | 0d |  | Laura Kennedy | 160h |  | Code Bodies |  | 480.33 | 5.24 | Green | GREEN |  |  |
| 1640 | 1.6.4.4.4.5 | QAD Sign Off deadline |  | 1d | 2025-11-21 | 2025-11-21 | 1639FS+4d | 2025-11-21 | 2025-11-21 | 1d | 1d | 0d |  | Laura Kennedy | 8h |  | Participants |  | 512.33 | 5.24 | Green | GREEN |  |  |
| 1641 | 1.6.4.4.4.6 | Qualification Wave 3 Participants Qualification approved by BSC PAB and REC Manager | milestone | 0d | 2025-12-19 | 2025-12-19 | 1640FS+20d | 2025-12-19 | 2025-12-19 | 0d | 1d | 0d |  | Laura Kennedy |  |  | Code Bodies |  | 540.71 | 5.24 | yellow | GREEN | T2-QU-0250 | QAG |
| 1642 | 1.6.4.5 | **Qualification Wave 4** |  | 249d | 2025-03-17 | 2026-02-27 |  | 2025-03-17 | 2026-02-27 | 249d | 1d |  |  | N/A | 8848h | -0 | N/A | N/A | -133.67 | 5.24 |  |  |  |  |
| 1643 | 1.6.4.5.1 | **Qualification Wave 4 QAD Prep** |  | 98d | 2025-03-17 | 2025-07-31 |  | 2025-03-17 | 2025-07-31 | 99d | 2d |  |  | N/A | 1568h | -0 | N/A | N/A | -155.67 | 5.24 |  |  |  |  |
| 1644 | 1.6.4.5.1.1 | Initial QAD Submission window opens | milestone | 0d | 2025-03-17 | 2025-03-17 | 1376FS+6d | 2025-03-17 | 2025-03-17 | 0d | 2d | 0d |  | Laura Kennedy |  |  | Participants |  | 263.71 | 5.24 | yellow | GREEN |  |  |
| 1645 | 1.6.4.5.1.2 | Qualification Wave 4 Participants Submit Initial QAD |  | 69d | 2025-03-18 | 2025-06-20 | 1644 | 2025-03-17 | 2025-06-20 | 70d | 2d | 0d |  | Laura Kennedy | 552h |  | Participants |  | 264.33 | 5.24 | Green | GREEN |  |  |
| 1646 | 1.6.4.5.1.3 | Qualification Wave 4 Participants have submitted their Initial QAD | milestone | 0d | 2025-06-20 | 2025-06-20 | 1645 | 2025-06-20 | 2025-06-20 | 0d | 2d | 0d |  | Laura Kennedy |  |  | Participants |  | 358.71 | 5.25 | Green | GREEN | T3-QU-0106 | QAG |
| 1647 | 1.6.4.5.1.4 | Code Bodies review of Wave 4 Participants' Initial QAD |  | 29d | 2025-06-23 | 2025-07-31 | 1646 | 2025-06-23 | 2025-07-31 | 29d | 2d | 0d |  | Laura Kennedy | 232h |  | Code Bodies |  | 361.33 | 5.24 | Green | GREEN |  |  |
| 1648 | 1.6.4.5.1.5 | Completion of Code Bodies review of Initial QAD | milestone | 0d | 2025-07-31 | 2025-07-31 | 1647 | 2025-07-31 | 2025-07-31 | 0d | 2d | 0d |  | Laura Kennedy |  |  | Code Bodies |  | 399.71 | 5.24 | Green | GREEN |  |  |
| 1649 | 1.6.4.5.2 | **Qualification Wave 4 Test Prep** |  | 67d | 2025-05-01 | 2025-08-01 |  | 2025-05-01 | 2025-07-31 | 66d | 1d |  |  | N/A | 1472h | -0 | N/A | N/A | -555.67 | 5.24 |  |  |  |  |
| 1650 | 1.6.4.5.2.1 | Confirmation from Qualification 4 Participants that DIP Onboarding has commenced | milestone | 0d | 2025-05-01 | 2025-05-01 |  | 2025-05-01 | 2025-05-01 | 0d | 21d | 0d | start no earlier than 2025-05-01 | Laura Kennedy |  |  | Participants |  | 308.33 | 5.24 | Green | GREEN | T3-QU-0031 | QAG |
| 1651 | 1.6.4.5.2.2 | Qualification Wave 4 Participants DIP Onboarding Window |  | 42d | 2025-05-01 | 2025-06-27 | 1650 | 2025-05-01 | 2025-06-27 | 42d | 21d | 0d |  | Laura Kennedy | 336h |  | Participants |  | 308.33 | 5.24 | Green | GREEN |  |  |
| 1652 | 1.6.4.5.2.3 | Confirmation from Qualification Wave 4 Participants that DIP onboarding has completed | milestone | 0d | 2025-06-27 | 2025-06-27 | 1651 | 2025-06-27 | 2025-06-27 | 0d | 21d | 19d |  | Laura Kennedy |  |  | Participants |  | 365.71 | 5.24 | Green | GREEN |  |  |
| 1653 | 1.6.4.5.2.4 | Qualification Wave 4 Participants' to provide status of PIT completion and submit QT Test Plan | milestone | 0d | 2025-05-30 | 2025-05-30 |  | 2025-05-30 | 2025-05-30 | 0d | 1d | 0d | start no earlier than 2025-05-30 | Laura Kennedy |  |  | Participants |  | 337.33 | 5.25 | Green | GREEN | T3-QU-0107 | QAG |
| 1654 | 1.6.4.5.2.5 | Review of Participants' PIT Status and QT Test Plan |  | 16d | 2025-05-30 | 2025-06-20 | 1653 | 2025-05-30 | 2025-06-20 | 16d | 1d | 0d |  | Laura Kennedy | 128h |  | Code Bodies, Non-SIT S&A QT Test Team |  | 337.33 | 5.24 | Green | GREEN |  |  |
| 1655 | 1.6.4.5.2.6 | Qualification Test Plans for Qualification Wave 4 Participants approved | milestone | 0d | 2025-06-20 | 2025-06-20 | 1654 | 2025-06-20 | 2025-06-20 | 0d | 1d | 0d |  | Laura Kennedy |  |  | Non-SIT S&A QT Test Team |  | 358.71 | 5.24 | Green | GREEN | T3-QU-0030 | QAG |
| 1656 | 1.6.4.5.2.7 | Qualification Wave 4 Participants have submitted PIT Test Completion Report and evidence for QT entry | milestone | 0d | 2025-06-20 | 2025-06-20 | 1655 | 2025-06-20 | 2025-06-20 | 0d | 1d | 0d |  | Laura Kennedy |  |  | Participants |  | 358.71 | 5.25 | yellow | GREEN | T3-QU-0108 | QAG |
| 1657 | 1.6.4.5.2.8 | Review of Participants' PIT Test Completion Report |  | 29d | 2025-06-23 | 2025-07-31 | 1656 | 2025-06-20 | 2025-07-31 | 30d | 1d | 0d |  | Laura Kennedy | 232h |  | Code Bodies, Non-SIT S&A QT Test Team |  | 361.33 | 5.24 | Green | GREEN |  |  |
| 1658 | 1.6.4.5.2.9 | Onboarding to QTF & ADO |  | 30d | 2025-06-23 | 2025-08-01 | 1657SS |  |  |  | 1d | 0d |  | Laura Kennedy | 240h |  |  |  | 361.33 | 5.25 | No BL | GREEN |  |  |

Notes:
- 1641: 14/5: Baseline and name updated after cr48 approval at psg on 1/5

| ID | WBS | Task | Type | Duration | Start | Finish | Predecessors | Complete | Remaining | Baseline start | Baseline finish | Baseline duration | Baseline 1 start | Baseline 1 finish | Total slack | Free slack | Constraint | Resources | Work | Actual work | Baseline cost | Responsible | Involved | Task Status | Update Version | Sched Status | RAG | Milestone ID | Text29 | MHHS Programme Phase | Artefact ID | Tier |
| --- | --- | --- | --- | --- | --- | --- | --- | --- | --- | --- | --- | --- | --- | --- | --- | --- | --- | --- | --- | --- | --- | --- | --- | --- | --- | --- | --- | --- | --- | --- | --- | --- |
| 1659 | 1.6.4.5.3 | **Qualification Wave 4 QT Execution** |  | 101d | 2025-07-25 | 2025-12-12 |  |  |  | 2025-07-25 | 2025-12-12 | 101d |  |  | 2d |  |  | N/A | 1608h |  | -0 | N/A | N/A | -155.67 | 5.24 |  |  |  |  |  |  |  |
| 1660 | 1.6.4.5.3.1 | Review Entry Criteria Evidence for each Wave 4 Participant |  | 5d | 2025-07-25 | 2025-07-31 | 1648FF, 1652 |  |  | 2025-07-25 | 2025-07-31 | 5d |  |  | 2d | 0d |  | Laura Kennedy | 40h |  |  | Non-SIT S&A QT Test Team |  | 393.33 | 5.24 | Green | GREEN |  |  |  |  |  |
| 1661 | 1.6.4.5.3.2 | Qualification Test Plans for Qualification Wave 4 Participants approved | milestone | 0d | 2025-07-31 | 2025-07-31 | 1652, 1660 |  |  | 2025-07-31 | 2025-07-31 | 0d |  |  | 2d | 1d |  | Laura Kennedy |  |  |  | Non-SIT S&A QT Test Team |  | 399.71 | 5.24 | yellow | GREEN | T3-QU-0043 | QAG |  |  |  |
| 1662 | 1.6.4.5.3.3 | Qualification Wave 4 QT Execution Start | milestone | 0d | 2025-08-01 | 2025-08-01 | 1661, 1658 |  |  | 2025-08-01 | 2025-08-01 | 0d |  |  | 1d | 0d |  | Laura Kennedy |  |  |  | Participants |  | 400.71 | 5.24 | yellow | GREEN | T3-QU-0044 | QAG |  |  |  |
| 1663 | 1.6.4.5.3.4 | Qualification Wave 4 QT Execution Window |  | 95d | 2025-08-04 | 2025-12-12 | 1662, 1660 |  |  | 2025-08-01 | 2025-12-12 | 96d |  |  | 6d | 0d |  | Laura Kennedy | 760h |  |  | Participants |  | 403.33 | 5.24 | Green | GREEN |  |  |  |  |  |
| 1664 | 1.6.4.5.3.5 | Qualification Wave 4 Projected Execution End | milestone | 0d | 2025-12-12 | 2025-12-12 | 1663 |  |  | 2025-12-12 | 2025-12-12 | 0d |  |  | 6d | 5d |  | Laura Kennedy |  |  |  | Participants |  | 533.71 | 5.24 | Green | GREEN | T3-QU-0057 | QAG |  |  |  |
| 1665 | 1.6.4.5.4 | **Qualification Wave 4 Exit** |  | 150d | 2025-08-01 | 2026-02-27 |  |  |  | 2025-08-01 | 2026-02-27 | 150d |  |  | 1d |  |  | N/A | 2208h |  | -0 | N/A | N/A | -155.67 | 5.24 |  |  |  |  |  |  |  |
| 1666 | 1.6.4.5.4.1 | Final QAD Submission window opens | milestone | 0d | 2025-08-01 | 2025-08-01 | 1662 |  |  | 2025-08-01 | 2025-08-01 | 0d |  |  | 1d | 0d |  | Laura Kennedy |  |  |  | Participants |  | 400.71 | 5.24 | yellow | GREEN |  |  |  |  |  |
| 1667 | 1.6.4.5.4.2 | Qualification Wave 4 Participants submit their Final QAD |  | 100d | 2025-08-04 | 2025-12-19 | 1666 |  |  | 2025-08-01 | 2025-12-19 | 101d |  |  | 1d | 0d |  | Laura Kennedy | 800h |  |  | Participants |  | 403.33 | 5.24 | Green | GREEN |  |  |  |  |  |
| 1668 | 1.6.4.5.4.3 | Qualification Wave 4 Participants have submitted their Final QAD | milestone | 0d | 2025-12-19 | 2025-12-19 | 1667, 1664 |  |  | 2025-12-19 | 2025-12-19 | 0d |  |  | 1d | 0d |  | Laura Kennedy |  |  |  | Participants |  | 540.71 | 5.25 | Green | GREEN | T3-QU-0109 | QAG |  |  |  |
| 1669 | 1.6.4.5.4.4 | Completion of Code Bodies review of Final QAD |  | 25d | 2025-12-22 | 2026-01-23 | 1668 |  |  | 2025-12-22 | 2026-01-23 | 25d |  |  | 1d | 0d |  | Laura Kennedy | 200h |  |  | Code Bodies |  | 543.33 | 5.24 | Green | GREEN |  |  |  |  |  |
| 1670 | 1.6.4.5.4.5 | QAD Sign Off deadline |  | 1d | 2026-01-30 | 2026-01-30 | 1669FS+4d |  |  | 2026-01-30 | 2026-01-30 | 1d |  |  | 1d | 0d |  | Laura Kennedy | 8h |  |  | Participants |  | 582.33 | 5.24 | Green | GREEN |  |  |  |  |  |
| 1671 | 1.6.4.5.4.6 | Qualification Wave 4 Participants Qualification approved by BSC PAB and REC Manager | milestone | 0d | 2026-02-27 | 2026-02-27 | 1670FS+20d |  |  | 2026-02-27 | 2026-02-27 | 0d |  |  | 1d | 0d |  | Laura Kennedy |  |  |  | Code Bodies |  | 610.71 | 5.24 | yellow | GREEN | T2-QU-0300 | QAG |  |  |  |
| 1672 | 1.7 | **REGULATORY** |  | 680d | 2022-10-31 A | 2025-06-06 |  | 92% | 54.56d | 2022-10-31 | 2025-06-06 | 680d | 2022-10-31 | 2025-03-07 | 515d |  |  | N/A | 49668.5h | 31490.4h | -0 | N/A | N/A |  |  |  |  |  |  | Regulatory |  |  |
| 1673 | 1.7.1 | **Baseline MHHS Code Changes** |  | 475d | 2022-10-31 A | 2024-08-23 |  | 98% | 8.79d | 2022-10-31 | 2024-08-23 | 475d | 2022-10-31 | 2024-08-23 | 720d |  |  | N/A | 35052.5h | 27204.5h | -0 | N/A | N/A |  | 5.0 |  |  |  |  | Regulatory |  |  |
| 1674 | 1.7.1.1 | **Preparation and planning** |  | 35d | 2022-10-31 A | 2022-12-16 A |  | 100% |  | 2022-10-31 | 2022-12-16 | 35d | 2022-10-31 | 2022-12-16 |  |  |  | N/A | 1000h | 1000h |  | N/A | N/A |  | 5.0 |  |  |  |  | Regulatory |  |  |
| 1675 | 1.7.1.1.1 | Impact assessment of Programme design on codes to determine required changes |  | 20d | 2022-10-31 A | 2022-11-25 A | 48 | 100% |  | 2022-10-31 | 2022-11-25 | 20d | 2022-10-31 | 2022-11-25 |  |  |  | Andrew Margan | 160h | 160h |  | Code Bodies,SRO Code Drafters | Code Drafting PM |  | 5.0 | Complete | COMPLETE |  |  | Regulatory |  |  |
| 1676 | 1.7.1.1.2 | Become 'code draft ready' |  | 35d | 2022-10-31 A | 2022-12-16 A |  | 100% |  | 2022-10-31 | 2022-12-16 | 35d | 2022-10-31 | 2022-12-16 |  |  |  | Andrew Margan | 280h | 280h |  | Code Bodies,SRO Code Drafters | Code Drafting PM |  | 5.0 | Complete | COMPLETE |  |  | Regulatory |  |  |
| 1677 | 1.7.1.1.3 | Soft start drafting where possible |  | 35d | 2022-10-31 A | 2022-12-16 A |  | 100% |  | 2022-10-31 | 2022-12-16 | 35d | 2022-10-31 | 2022-12-16 |  |  |  | Andrew Margan | 280h | 280h |  | Code Bodies,SRO Code Drafters | Code Drafting PM |  | 5.0 | Complete | COMPLETE |  |  | Regulatory |  |  |
| 1678 | 1.7.1.2 | **Code drafting** |  | 443d | 2022-12-12 A | 2024-08-21 |  | 98% | 8.59d | 2022-12-12 | 2024-08-23 | 445d | 2022-12-12 | 2024-08-23 | 722d |  |  | N/A | 30252.5h | 26044.5h | -0 | N/A | N/A | M6 | 5.0 |  |  |  |  | Regulatory |  |  |
| 1679 | 1.7.1.2.1 | **Data Services (BSC driven)** |  | 118d | 2022-12-12 A | 2023-05-24 A |  | 100% |  | 2022-12-12 | 2023-05-24 | 118d | 2022-12-12 | 2023-05-24 |  |  |  | N/A | 1816h | 1816h |  | N/A | N/A | M6 | 5.0 |  |  |  |  | Regulatory |  |  |
| 1680 | 1.7.1.2.1.1 | Pre Code Drafting activities |  | 5d | 2022-12-12 A | 2022-12-16 A |  | 100% |  | 2022-12-12 | 2022-12-16 | 5d | 2022-12-12 | 2022-12-16 |  |  | start no earlier than 2022-12-12 | Andrew Margan | 40h | 40h |  | Code Drafting PM |  |  | 5.0 | Complete | COMPLETE |  |  | Regulatory |  |  |
| 1681 | 1.7.1.2.1.2 | Code and subsidiary document drafting takes place offline |  | 19d | 2023-01-03 A | 2023-01-27 A | 1680FS+11d | 100% |  | 2023-01-03 | 2023-01-27 | 19d | 2023-01-03 | 2023-01-27 |  |  |  | Andrew Margan | 152h | 152h |  | Code Bodies,SRO Design | Code Drafting PM |  | 5.0 | Complete | COMPLETE |  |  | Regulatory |  |  |
| 1682 | 1.7.1.2.1.3 | Internal review and cross-checking of drafting across code drafters |  | 11d | 2023-01-30 A | 2023-02-13 A | 1681 | 100% |  | 2023-01-30 | 2023-02-13 | 11d | 2023-01-30 | 2023-02-13 |  |  |  | Andrew Margan | 88h | 88h |  | Code Bodies,SRO Design | Code Drafting PM |  | 5.0 | Complete | COMPLETE |  |  | Regulatory |  |  |
| 1683 | 1.7.1.2.1.4 | External industry review via consultation |  | 20d | 2023-02-14 A | 2023-03-13 A | 1682 | 100% |  | 2023-02-14 | 2023-03-13 | 20d | 2023-02-14 | 2023-03-13 |  |  |  | Andrew Margan | 160h | 160h |  | PP | Code Drafting PM |  | 5.0 | Complete | COMPLETE |  |  | Regulatory |  |  |
| 1684 | 1.7.1.2.1.5 | Triage and action comments |  | 19d | 2023-03-10 A | 2023-04-05 A | 1683FS-2d | 100% |  | 2023-03-10 | 2023-04-05 | 19d | 2023-03-10 | 2023-04-05 |  |  |  | Andrew Margan | 152h | 152h |  | Code Bodies,SRO Design | Code Drafting PM |  | 5.0 | Complete | COMPLETE |  |  | Regulatory |  |  |
| 1685 | 1.7.1.2.1.6 | CDWG review |  | 30d | 2023-04-06 A | 2023-05-17 A | 1684 | 100% |  | 2023-04-06 | 2023-05-17 | 30d | 2023-04-06 | 2023-05-17 |  |  |  | Andrew Margan | 240h | 240h |  | PP | Code Drafting PM |  | 5.0 | Complete | COMPLETE |  |  | Regulatory |  |  |
| 1686 | 1.7.1.2.1.7 | CCAG review |  | 5d | 2023-05-18 A | 2023-05-24 A | 1685 | 100% |  | 2023-05-18 | 2023-05-24 | 5d | 2023-05-18 | 2023-05-24 |  |  |  | Andrew Margan | 40h | 40h |  | PP |  |  | 5.0 | Complete | COMPLETE |  |  | Regulatory |  |  |
| 1687 | 1.7.1.2.1.8 | Code drafting for Data Services topic area approved | milestone | 0d | 2023-05-24 A | 2023-05-24 A | 1686 | 100% |  | 2023-05-24 | 2023-05-24 | 0d | 2023-05-24 | 2023-05-24 |  |  |  | Andrew Margan |  |  |  | PP | Code Drafting PM |  | 5.0 | Complete | COMPLETE | T2-RE-0100 | CCAG | Regulatory | MHHS-ART060 | T2 |

Notes:
- 1671: 14/5: Baseline and name updated after cr48 approval at psg on 1/5

| ID | WBS | Task | Type | Duration | Start | Finish | Predecessors | Complete | Baseline start | Baseline finish | Baseline duration | Baseline 1 start | Baseline 1 finish | Constraint | Resources | Work | Actual work | Responsible | Involved | Task Status | Update Version | MHHS Programme Phase | Sched Status | RAG | Artefact ID | Milestone ID | Text29 | Tier |
| --- | --- | --- | --- | --- | --- | --- | --- | --- | --- | --- | --- | --- | --- | --- | --- | --- | --- | --- | --- | --- | --- | --- | --- | --- | --- | --- | --- | --- |
| 1688 | 1.7.1.2.2 | **Metering (REC driven)** |  | 118d | 2022-12-12 A | 2023-05-24 A |  | 100% | 2022-12-12 | 2023-05-24 | 118d | 2022-12-12 | 2023-05-24 |  | N/A | 1816h | 1816h | N/A | N/A | M6 | 5.0 | Regulatory |  |  |  |  |  |  |
| 1689 | 1.7.1.2.2.1 | Pre Code Drafting activities |  | 5d | 2022-12-12 A | 2022-12-16 A | 1680SS | 100% | 2022-12-12 | 2022-12-16 | 5d | 2022-12-12 | 2022-12-16 |  | Andrew Margan | 40h | 40h | Code Drafting PM |  |  | 5.0 | Regulatory | Complete | COMPLETE |  |  |  |  |
| 1690 | 1.7.1.2.2.2 | Code and subsidiary document drafting takes place offline |  | 19d | 2023-01-03 A | 2023-01-27 A | 1689FS+11d | 100% | 2023-01-03 | 2023-01-27 | 19d | 2023-01-03 | 2023-01-27 |  | Andrew Margan | 152h | 152h | Code Bodies,SRO Design | Code Drafting PM |  | 5.0 | Regulatory | Complete | COMPLETE |  |  |  |  |
| 1691 | 1.7.1.2.2.3 | Internal review and cross-checking of drafting across code drafters |  | 11d | 2023-01-30 A | 2023-02-13 A | 1690 | 100% | 2023-01-30 | 2023-02-13 | 11d | 2023-01-30 | 2023-02-13 |  | Andrew Margan | 88h | 88h | Code Bodies,SRO Design | Code Drafting PM |  | 5.0 | Regulatory | Complete | COMPLETE |  |  |  |  |
| 1692 | 1.7.1.2.2.4 | External industry review via consultation |  | 20d | 2023-02-14 A | 2023-03-13 A | 1691 | 100% | 2023-02-14 | 2023-03-13 | 20d | 2023-02-14 | 2023-03-13 |  | Andrew Margan | 160h | 160h | PP | Code Drafting PM |  | 5.0 | Regulatory | Complete | COMPLETE |  |  |  |  |
| 1693 | 1.7.1.2.2.5 | Triage and action comments |  | 19d | 2023-03-10 A | 2023-04-05 A | 1692FS-2d | 100% | 2023-03-10 | 2023-04-05 | 19d | 2023-03-10 | 2023-04-05 |  | Andrew Margan | 152h | 152h | Code Bodies,SRO Design | Code Drafting PM |  | 5.0 | Regulatory | Complete | COMPLETE |  |  |  |  |
| 1694 | 1.7.1.2.2.6 | CDWG review |  | 30d | 2023-04-06 A | 2023-05-17 A | 1693 | 100% | 2023-04-06 | 2023-05-17 | 30d | 2023-04-06 | 2023-05-17 |  | Andrew Margan | 240h | 240h | PP | Code Drafting PM |  | 5.0 | Regulatory | Complete | COMPLETE |  |  |  |  |
| 1695 | 1.7.1.2.2.7 | CCAG review |  | 5d | 2023-05-18 A | 2023-05-24 A | 1694 | 100% | 2023-05-18 | 2023-05-24 | 5d | 2023-05-18 | 2023-05-24 |  | Andrew Margan | 40h | 40h | PP |  |  | 5.0 | Regulatory | Complete | COMPLETE |  |  |  |  |
| 1696 | 1.7.1.2.2.8 | Code drafting for Metering topic area approved | milestone | 0d | 2023-05-24 A | 2023-05-24 A | 1695 | 100% | 2023-05-24 | 2023-05-24 | 0d | 2023-05-24 | 2023-05-24 |  | Andrew Margan |  |  | PP | Code Drafting PM |  | 5.0 | Regulatory | Complete | COMPLETE | MHHS-ART060 | T2-RE-0150 | CCAG | T2 |
| 1697 | 1.7.1.2.3 | **BSC Central Services (BSC driven)** |  | 156d | 2023-02-22 A | 2023-09-27 A |  | 100% | 2023-02-22 | 2023-09-27 | 156d | 2023-02-22 | 2023-09-14 |  | N/A | 3072h | 3072h | N/A | N/A | M6 | 5.0 | Regulatory |  |  |  |  |  |  |
| 1698 | 1.7.1.2.3.1 | Pre Code Drafting activities |  | 5d | 2023-02-22 A | 2023-02-28 A | 1699SS-5d | 100% | 2023-02-22 | 2023-02-28 | 5d | 2023-02-22 | 2023-02-28 |  | Andrew Margan | 40h | 40h | Code Drafting PM |  |  | 5.0 | Regulatory | Complete | COMPLETE |  |  |  |  |
| 1699 | 1.7.1.2.3.2 | Code Drafting (offline) |  | 80d | 2023-03-01 A | 2023-06-20 A | 1683SS | 100% | 2023-03-01 | 2023-06-20 | 80d | 2023-03-01 | 2023-06-20 | must start on 2023-03-01 | Andrew Margan | 640h | 640h | Code Bodies,SRO Design | Code Drafting PM |  | 5.0 | Regulatory | Complete | COMPLETE |  |  |  |  |
| 1700 | 1.7.1.2.3.3 | Internal review and cross-checking of drafting across code drafters |  | 70d | 2023-03-15 A | 2023-06-20 A | 1699SS+10d | 100% | 2023-03-15 | 2023-06-20 | 70d | 2023-03-15 | 2023-06-20 |  | Andrew Margan | 560h | 560h | Code Bodies,SRO Design | Code Drafting PM |  | 5.0 | Regulatory | Complete | COMPLETE |  |  |  |  |
| 1701 | 1.7.1.2.3.4 | External industry review via consultation |  | 15d | 2023-06-21 A | 2023-07-11 A | 1700 | 100% | 2023-06-21 | 2023-07-11 | 15d | 2023-06-21 | 2023-07-11 |  | Andrew Margan | 120h | 120h | PP | Code Drafting PM |  | 5.0 | Regulatory | Complete | COMPLETE |  |  |  |  |
| 1702 | 1.7.1.2.3.5 | Triage and action comments |  | 19d | 2023-07-10 A | 2023-08-03 A | 1701FS-2d | 100% | 2023-07-10 | 2023-08-03 | 19d | 2023-07-10 | 2023-08-03 |  | Andrew Margan | 152h | 152h | Code Bodies,SRO Design | Code Drafting PM |  | 5.0 | Regulatory | Complete | COMPLETE |  |  |  |  |
| 1703 | 1.7.1.2.3.6 | CDWG review |  | 28d | 2023-08-04 A | 2023-09-12 A | 1702 | 100% | 2023-08-04 | 2023-09-12 | 28d | 2023-08-04 | 2023-09-07 |  | Andrew Margan | 224h | 224h | PP | Code Drafting PM |  | 5.0 | Regulatory | Complete | COMPLETE |  |  |  |  |
| 1704 | 1.7.1.2.3.7 | CCAG review |  | 11d | 2023-09-13 A | 2023-09-27 A | 1703 | 100% | 2023-09-13 | 2023-09-27 | 11d | 2023-09-08 | 2023-09-14 |  | Andrew Margan | 88h | 88h | PP |  |  | 5.0 | Regulatory | Complete | COMPLETE |  |  |  |  |
| 1705 | 1.7.1.2.3.8 | Code drafting for BSC Central Services topic area approved | milestone | 0d | 2023-09-27 A | 2023-09-27 A | 1704 | 100% | 2023-09-27 | 2023-09-27 | 0d | 2023-09-14 | 2023-09-14 |  | Andrew Margan |  |  | PP | Code Drafting PM |  | 5.0 | Regulatory | Complete | COMPLETE | MHHS-ART060 | T2-RE-0200 | CCAG | T2 |
| 1706 | 1.7.1.2.4 | **Registration (BSC & REC driven)** |  | 131d | 2023-02-22 A | 2023-08-23 A |  | 100% | 2023-02-22 | 2023-08-23 | 131d | 2023-02-22 | 2023-08-23 |  | N/A | 2552h | 2552h | N/A | N/A | M6 | 5.0 | Regulatory |  |  |  |  |  |  |
| 1707 | 1.7.1.2.4.1 | Pre Code Drafting activities |  | 5d | 2023-02-22 A | 2023-02-28 A | 1708SS-5d | 100% | 2023-02-22 | 2023-02-28 | 5d | 2023-02-22 | 2023-02-28 |  | Andrew Margan | 40h | 40h | Code Drafting PM |  |  | 5.0 | Regulatory | Complete | COMPLETE |  |  |  |  |
| 1708 | 1.7.1.2.4.2 | Code Drafting (offline) |  | 65d | 2023-03-01 A | 2023-05-30 A | 1682, 1691 | 100% | 2023-03-01 | 2023-05-30 | 65d | 2023-03-01 | 2023-05-30 | must start on 2023-03-01 | Andrew Margan | 520h | 520h | Code Bodies,SRO Design | Code Drafting PM |  | 5.0 | Regulatory | Complete | COMPLETE |  |  |  |  |
| 1709 | 1.7.1.2.4.3 | Internal review and cross-checking of drafting across code drafters |  | 55d | 2023-03-15 A | 2023-05-30 A | 1708SS+10d | 100% | 2023-03-15 | 2023-05-30 | 55d | 2023-03-15 | 2023-05-30 |  | Andrew Margan | 440h | 440h | Code Bodies,SRO Design | Code Drafting PM |  | 5.0 | Regulatory | Complete | COMPLETE |  |  |  |  |
| 1710 | 1.7.1.2.4.4 | External industry review via consultation |  | 15d | 2023-05-31 A | 2023-06-20 A | 1709 | 100% | 2023-05-31 | 2023-06-20 | 15d | 2023-05-31 | 2023-06-20 |  | Andrew Margan | 120h | 120h | PP | Code Drafting PM |  | 5.0 | Regulatory | Complete | COMPLETE |  |  |  |  |
| 1711 | 1.7.1.2.4.5 | Triage and action comments |  | 19d | 2023-06-19 A | 2023-07-13 A | 1710FS-2d | 100% | 2023-06-19 | 2023-07-13 | 19d | 2023-06-19 | 2023-07-13 |  | Andrew Margan | 152h | 152h | Code Bodies,SRO Design | Code Drafting PM |  | 5.0 | Regulatory | Complete | COMPLETE |  |  |  |  |
| 1712 | 1.7.1.2.4.6 | CDWG review |  | 18d | 2023-07-14 A | 2023-08-08 A | 1711 | 100% | 2023-07-14 | 2023-08-08 | 18d | 2023-07-14 | 2023-08-16 |  | Andrew Margan | 144h | 144h | PP | Code Drafting PM |  | 5.0 | Regulatory | Complete | COMPLETE |  |  |  |  |
| 1713 | 1.7.1.2.4.7 | CCAG review |  | 11d | 2023-08-09 A | 2023-08-23 A | 1712 | 100% | 2023-08-09 | 2023-08-23 | 11d | 2023-08-17 | 2023-08-23 |  | Andrew Margan | 88h | 88h | PP |  |  | 5.0 | Regulatory | Complete | COMPLETE |  |  |  |  |
| 1714 | 1.7.1.2.4.8 | Code drafting for Registration topic area approved | milestone | 0d | 2023-08-23 A | 2023-08-23 A | 1713 | 100% | 2023-08-23 | 2023-08-23 | 0d | 2023-08-23 | 2023-08-23 |  | Andrew Margan |  |  | PP | Code Drafting PM |  | 5.0 | Regulatory | Complete | COMPLETE | MHHS-ART060 | T2-RE-0250 | CCAG | T2 |

| ID | WBS | Task | Type | Duration | Start | Finish | Predecessors | Complete | Baseline start | Baseline finish | Baseline duration | Baseline 1 start | Baseline 1 finish | Resources | Work | Actual work | Responsible | Involved | Task Status | Update Version | MHHS Programme Phase | Sched Status | RAG | Artefact ID | Milestone ID | Text29 | Tier |
| --- | --- | --- | --- | --- | --- | --- | --- | --- | --- | --- | --- | --- | --- | --- | --- | --- | --- | --- | --- | --- | --- | --- | --- | --- | --- | --- | --- |
| 1715 | 1.7.1.2.5 | **Governance and Qualification (BSC & REC driven)** |  | 130d | 2023-05-25 A | 2023-11-22 A |  | 100% | 2023-05-25 | 2023-11-22 | 130d | 2023-05-25 | 2023-11-13 | N/A | 2448h | 2448h | N/A | N/A | M6 | 5.0 | Regulatory |  |  |  |  |  |  |
| 1716 | 1.7.1.2.5.1 | Pre Code Drafting activities |  | 5d | 2023-05-25 A | 2023-05-31 A | 1717SS-5d | 100% | 2023-05-25 | 2023-05-31 | 5d | 2023-05-25 | 2023-05-31 | Andrew Margan | 40h | 40h | Code Drafting PM |  |  | 5.0 | Regulatory | Complete | COMPLETE |  |  |  |  |
| 1717 | 1.7.1.2.5.2 | Code Drafting (offline) |  | 55d | 2023-06-01 A | 2023-08-16 A | 1710SS+1d | 100% | 2023-06-01 | 2023-08-16 | 55d | 2023-06-01 | 2023-08-16 | Andrew Margan | 440h | 440h | Code Bodies,SRO Design | Code Drafting PM |  | 5.0 | Regulatory | Complete | COMPLETE |  |  |  |  |
| 1718 | 1.7.1.2.5.3 | Internal review and cross-checking of drafting across code drafters |  | 45d | 2023-06-15 A | 2023-08-16 A | 1717SS+10d | 100% | 2023-06-15 | 2023-08-16 | 45d | 2023-06-15 | 2023-08-16 | Andrew Margan | 360h | 360h | Code Bodies,SRO Design | Code Drafting PM |  | 5.0 | Regulatory | Complete | COMPLETE |  |  |  |  |
| 1719 | 1.7.1.2.5.4 | External industry review via consultation |  | 15d | 2023-08-18 A | 2023-09-07 A | 1718FS+1d | 100% | 2023-08-18 | 2023-09-07 | 15d | 2023-08-18 | 2023-09-07 | Andrew Margan | 120h | 120h | PP | Code Drafting PM |  | 5.0 | Regulatory | Complete | COMPLETE |  |  |  |  |
| 1720 | 1.7.1.2.5.5 | Triage and action comments |  | 19d | 2023-09-06 A | 2023-10-02 A | 1719FS-2d | 100% | 2023-09-06 | 2023-10-02 | 19d | 2023-09-06 | 2023-10-02 | Andrew Margan | 152h | 152h | Code Bodies,SRO Design | Code Drafting PM |  | 5.0 | Regulatory | Complete | COMPLETE |  |  |  |  |
| 1721 | 1.7.1.2.5.6 | CDWG review |  | 31d | 2023-10-03 A | 2023-11-14 A | 1720 | 100% | 2023-10-03 | 2023-11-14 | 31d | 2023-10-03 | 2023-11-06 | Andrew Margan | 248h | 248h | PP | Code Drafting PM |  | 5.0 | Regulatory | Complete | COMPLETE |  |  |  |  |
| 1722 | 1.7.1.2.5.7 | CCAG review |  | 6d | 2023-11-15 A | 2023-11-22 A | 1721 | 100% | 2023-11-15 | 2023-11-22 | 6d | 2023-11-07 | 2023-11-13 | Andrew Margan | 48h | 48h | PP |  |  | 5.0 | Regulatory | Complete | COMPLETE |  |  |  |  |
| 1723 | 1.7.1.2.5.8 | Code drafting for Governance and Qualification topic areas approved | milestone | 0d | 2023-11-22 A | 2023-11-22 A | 1722 | 100% | 2023-11-22 | 2023-11-22 | 0d | 2023-11-13 | 2023-11-13 | Andrew Margan |  |  | PP | Code Drafting PM |  | 5.12 | Regulatory | Complete | COMPLETE | MHHS-ART060 | T3-RE-0300 | CCAG | T2 |
| 1724 | 1.7.1.2.6 | **Interfaces / Data Specification (REC driven)** |  | 174d | 2023-05-25 A | 2024-01-23 A |  | 100% | 2023-05-25 | 2024-01-24 | 175d | 2023-05-25 | 2023-11-13 | N/A | 3472h | 3472h | N/A | N/A | M6 | 5.2 | Regulatory |  |  |  |  |  |  |
| 1725 | 1.7.1.2.6.1 | Pre Code Drafting activities |  | 5d | 2023-05-25 A | 2023-05-31 A | 1726SS-5d | 100% | 2023-05-25 | 2023-05-31 | 5d | 2023-05-25 | 2023-05-31 | Andrew Margan | 40h | 40h | Code Drafting PM |  |  | 5.0 | Regulatory | Complete | COMPLETE |  |  |  |  |
| 1726 | 1.7.1.2.6.2 | Code Drafting (offline) |  | 94d | 2023-06-01 A | 2023-10-10 A | 1710SS+1d | 100% | 2023-06-01 | 2023-10-10 | 94d | 2023-06-01 | 2023-08-16 | Andrew Margan | 752h | 752h | Code Bodies,SRO Design | Code Drafting PM |  | 5.2 | Regulatory | Complete | COMPLETE |  |  |  |  |
| 1727 | 1.7.1.2.6.3 | Internal review and cross-checking of drafting across code drafters |  | 84d | 2023-06-15 A | 2023-10-10 A | 1726SS+10d | 100% | 2023-06-15 | 2023-10-10 | 84d | 2023-06-15 | 2023-08-16 | Andrew Margan | 672h | 672h | Code Bodies,SRO Design | Code Drafting PM |  | 5.2 | Regulatory | Complete | COMPLETE |  |  |  |  |
| 1728 | 1.7.1.2.6.4 | External industry review via consultation |  | 15d | 2023-10-11 A | 2023-10-31 A | 1727 | 100% | 2023-10-11 | 2023-10-31 | 15d | 2023-08-18 | 2023-09-07 | Andrew Margan | 120h | 120h | PP | Code Drafting PM |  | 5.2 | Regulatory | Complete | COMPLETE |  |  |  |  |
| 1729 | 1.7.1.2.6.5 | Triage and action comments |  | 20d | 2023-10-30 A | 2023-11-24 A | 1728FS-2d | 100% | 2023-10-30 | 2023-11-24 | 20d | 2023-09-06 | 2023-10-02 | Andrew Margan | 160h | 160h | Code Bodies,SRO Design | Code Drafting PM |  | 5.2 | Regulatory | Complete | COMPLETE |  |  |  |  |
| 1730 | 1.7.1.2.6.6 | CDWG review |  | 37d | 2023-11-27 A | 2024-01-16 A | 1729 | 100% | 2023-11-27 | 2024-01-09 | 32d | 2023-10-03 | 2023-11-06 | Andrew Margan | 296h | 296h | PP | Code Drafting PM |  | 5.2 | Regulatory | Complete | COMPLETE |  |  |  |  |
| 1731 | 1.7.1.2.6.7 | CCAG review |  | 5d | 2024-01-17 A | 2024-01-23 A | 1730 | 100% | 2024-01-10 | 2024-01-24 | 11d | 2023-11-07 | 2023-11-13 | Andrew Margan | 40h | 40h | PP | Code Drafting PM |  | 5.2 | Regulatory | Complete | COMPLETE |  |  |  |  |
| 1732 | 1.7.1.2.6.8 | Code drafting for Interfaces / Data Specification topic areas approved | milestone | 0d | 2024-01-23 A | 2024-01-23 A | 1731 | 100% | 2024-01-24 | 2024-01-24 | 0d | 2023-11-13 | 2023-11-13 | Andrew Margan |  |  | PP | Code Drafting PM |  | 5.16 | Regulatory | Complete | COMPLETE | MHHS-ART060 | T3-RE-0350 | CCAG | T2 |
| 1733 | 1.7.1.2.7 | **Migration (BSC & REC driven)** |  | 130d | 2023-05-25 A | 2023-11-22 A |  | 100% | 2023-05-25 | 2023-11-22 | 130d | 2023-05-25 | 2023-11-13 | N/A | 2448h | 2448h | N/A | N/A | M6 | 5.0 | Regulatory |  |  |  |  |  |  |
| 1734 | 1.7.1.2.7.1 | Pre Code Drafting activities |  | 5d | 2023-05-25 A | 2023-05-31 A | 1735SS-5d | 100% | 2023-05-25 | 2023-05-31 | 5d | 2023-05-25 | 2023-05-31 | Andrew Margan | 40h | 40h | Code Drafting PM |  |  | 5.0 | Regulatory | Complete | COMPLETE |  |  |  |  |
| 1735 | 1.7.1.2.7.2 | Code Drafting (offline) |  | 55d | 2023-06-01 A | 2023-08-16 A | 1710SS+1d | 100% | 2023-06-01 | 2023-08-16 | 55d | 2023-06-01 | 2023-08-16 | Andrew Margan | 440h | 440h | Code Bodies,SRO Design | Code Drafting PM |  | 5.0 | Regulatory | Complete | COMPLETE |  |  |  |  |
| 1736 | 1.7.1.2.7.3 | Internal review and cross-checking of drafting across code drafters |  | 45d | 2023-06-15 A | 2023-08-16 A | 1735SS+10d | 100% | 2023-06-15 | 2023-08-16 | 45d | 2023-06-15 | 2023-08-16 | Andrew Margan | 360h | 360h | Code Bodies,SRO Design | Code Drafting PM |  | 5.0 | Regulatory | Complete | COMPLETE |  |  |  |  |
| 1737 | 1.7.1.2.7.4 | External industry review via consultation |  | 15d | 2023-08-18 A | 2023-09-07 A | 1736FS+1d | 100% | 2023-08-18 | 2023-09-07 | 15d | 2023-08-18 | 2023-09-07 | Andrew Margan | 120h | 120h | PP | Code Drafting PM |  | 5.0 | Regulatory | Complete | COMPLETE |  |  |  |  |
| 1738 | 1.7.1.2.7.5 | Triage and action comments |  | 19d | 2023-09-06 A | 2023-10-02 A | 1737FS-2d | 100% | 2023-09-06 | 2023-10-02 | 19d | 2023-09-06 | 2023-10-02 | Andrew Margan | 152h | 152h | Code Bodies,SRO Design | Code Drafting PM |  | 5.0 | Regulatory | Complete | COMPLETE |  |  |  |  |
| 1739 | 1.7.1.2.7.6 | CDWG review |  | 31d | 2023-10-03 A | 2023-11-14 A | 1738 | 100% | 2023-10-03 | 2023-11-14 | 31d | 2023-10-03 | 2023-11-06 | Andrew Margan | 248h | 248h | PP | Code Drafting PM |  | 5.0 | Regulatory | Complete | COMPLETE |  |  |  |  |
| 1740 | 1.7.1.2.7.7 | CCAG review |  | 6d | 2023-11-15 A | 2023-11-22 A | 1739 | 100% | 2023-11-15 | 2023-11-22 | 6d | 2023-11-07 | 2023-11-13 | Andrew Margan | 48h | 48h | PP | Code Drafting PM |  | 5.0 | Regulatory | Complete | COMPLETE |  |  |  |  |
| 1741 | 1.7.1.2.7.8 | Code drafting for Migration topic area approved | milestone | 0d | 2023-11-22 A | 2023-11-22 A | 1740 | 100% | 2023-11-22 | 2023-11-22 | 0d | 2023-11-13 | 2023-11-13 | Andrew Margan |  |  | PP | Code Drafting PM |  | 5.12 | Regulatory | Complete | COMPLETE | MHHS-ART060 | T3-RE-0400 | CCAG | T2 |

Notes:
- 1723: 10/10 - CH - Agreed at PSG on 4/10 to downgrade from T2 to T3
- 1732: 10/10 - CH - Agreed at PSG on 4/10 to downgrade from T2 to T3
- 1741: 31/07/23 - Changed date to 22/11/23 from 13/11/23 after approval from CCAG on 28/6/23. 10/10 - CH - Agreed at PSG on 4/10 to downgrade from T2 to T3

| ID | WBS | Task | Type | Duration | Start | Finish | Predecessors | Complete | Remaining | Baseline start | Baseline finish | Baseline duration | Baseline 1 start | Baseline 1 finish | Total slack | Constraint | Resources | Work | Actual work | Baseline cost | Responsible | Involved | Update Version | MHHS Programme Phase | Sched Status | RAG | Task Status | Artefact ID | Milestone ID | Text29 | Tier |
| --- | --- | --- | --- | --- | --- | --- | --- | --- | --- | --- | --- | --- | --- | --- | --- | --- | --- | --- | --- | --- | --- | --- | --- | --- | --- | --- | --- | --- | --- | --- | --- |
| 1742 | 1.7.1.2.8 | **Consequential Code Change** |  | 109d | 2023-10-11 A | 2024-03-11 |  | 99% | 0d | 2023-10-11 | 2024-03-08 | 108d | 2023-08-18 | 2024-03-08 | 0d |  | N/A | 1120h | 1054.4h | -0 | N/A | N/A | 5.0 | Regulatory |  |  |  |  |  |  |  |
| 1743 | 1.7.1.2.8.1 | External industry review via consultation - drop 1 (DCUSA) |  | 15d | 2023-10-11 A | 2023-10-31 A | 1749SS | 100% |  | 2023-10-11 | 2023-10-31 | 15d | 2023-08-18 | 2023-09-07 |  |  | Andrew Margan | 120h | 120h |  | Code Bodies | PP | 5.2 | Regulatory | Complete | COMPLETE |  |  |  |  |  |
| 1744 | 1.7.1.2.8.2 | External industry review via consultation - drop 2 (Elexon) |  | 16d | 2024-02-19 A | 2024-03-11 A | 1759SS | 100% |  | 2024-02-19 | 2024-03-08 | 15d | 2023-10-16 | 2023-11-03 |  | start no earlier than 2024-02-19 | Andrew Margan | 128h | 128h |  | Code Bodies | PP | 5.2 | Regulatory | Complete | COMPLETE |  |  |  |  |  |
| 1745 | 1.7.1.2.9 | **Transition Text (all codes)** |  | 118d | 2023-08-11 A | 2024-01-23 A |  | 100% |  | 2023-08-11 | 2024-01-24 | 119d | 2023-08-11 | 2024-01-25 |  |  | N/A | 2148.53h | 2148.53h |  | N/A | N/A | 5.2 | Regulatory |  |  | M6 |  |  |  |  |
| 1746 | 1.7.1.2.9.1 | Pre Code Drafting activities |  | 8d | 2023-08-11 A | 2023-08-22 A | 1747SS-5d | 100% |  | 2023-08-11 | 2023-08-22 | 8d | 2023-08-11 | 2023-08-17 |  |  | Andrew Margan | 64h | 64h |  | Code Drafting PM |  | 5.0 | Regulatory | Complete | COMPLETE |  |  |  |  |  |
| 1747 | 1.7.1.2.9.2 | Code Drafting (offline) |  | 38d | 2023-08-18 A | 2023-10-10 A | 1737SS | 100% |  | 2023-08-18 | 2023-10-10 | 38d | 2023-08-18 | 2023-10-12 |  |  | Andrew Margan | 304h | 304h |  | Code Bodies,SRO Design | Code Drafting PM | 5.2 | Regulatory | Complete | COMPLETE |  |  |  |  |  |
| 1748 | 1.7.1.2.9.3 | Internal review and cross-checking of drafting across code drafters |  | 28d | 2023-09-01 A | 2023-10-10 A | 1747SS+10d | 100% |  | 2023-09-01 | 2023-10-10 | 28d | 2023-09-01 | 2023-10-12 |  |  | Andrew Margan | 224h | 224h |  | Code Bodies,SRO Design | Code Drafting PM | 5.2 | Regulatory | Complete | COMPLETE |  |  |  |  |  |
| 1749 | 1.7.1.2.9.4 | External industry review via consultation |  | 15d | 2023-10-11 A | 2023-10-31 A | 1748 | 100% |  | 2023-10-11 | 2023-10-31 | 15d | 2023-10-16 | 2023-11-03 |  |  | Andrew Margan | 120h | 120h |  | PP | Code Drafting PM | 5.2 | Regulatory | Complete | COMPLETE |  |  |  |  |  |
| 1750 | 1.7.1.2.9.5 | Triage and action comments |  | 20d | 2023-10-30 A | 2023-11-24 A | 1749FS-2d | 100% |  | 2023-10-30 | 2023-11-24 | 20d | 2023-11-02 | 2023-11-21 |  |  | Andrew Margan | 160h | 160h |  | Code Bodies,SRO Design | Code Drafting PM | 5.2 | Regulatory | Complete | COMPLETE |  |  |  |  |  |
| 1751 | 1.7.1.2.9.6 | CDWG review |  | 37d | 2023-11-27 A | 2024-01-16 A | 1750 | 100% |  | 2023-11-27 | 2024-01-16 | 37d | 2023-11-22 | 2024-01-17 |  |  | Andrew Margan | 296h | 296h |  | PP | Code Drafting PM | 5.2 | Regulatory | Complete | COMPLETE |  |  |  |  |  |
| 1752 | 1.7.1.2.9.7 | CCAG review |  | 5d | 2024-01-17 A | 2024-01-23 A | 1751 | 100% |  | 2024-01-17 | 2024-01-24 | 6d | 2024-01-18 | 2024-01-25 |  |  | Andrew Margan | 40h | 40h |  | PP | Code Drafting PM | 5.2 | Regulatory | Complete | COMPLETE |  |  |  |  |  |
| 1753 | 1.7.1.2.9.8 | Code drafting for Transition Text topic area approved | milestone | 0d | 2024-01-23 A | 2024-01-23 A | 1752 | 100% |  | 2024-01-24 | 2024-01-24 | 0d | 2024-01-25 | 2024-01-25 |  |  | Andrew Margan |  |  |  | PP | Code Drafting PM | 5.16 | Regulatory | Complete | COMPLETE |  | MHHS-ART060 | T3-RE-0450 | CCAG | T2 |
| 1754 | 1.7.1.2.10 | **Final Code Drafting (mop-up) (all codes)** |  | 199d | 2023-08-18 A | 2024-05-22 A |  | 100% |  | 2023-08-18 | 2024-05-22 | 199d | 2023-08-18 | 2024-05-13 |  |  | N/A | 4248h | 4248h |  | N/A | N/A | 5.0 | Regulatory |  |  | M6 |  |  |  |  |
| 1755 | 1.7.1.2.10.1 | Forward look and confirm remaining plan |  | 15d | 2023-08-18 A | 2023-09-07 A | 1747SS | 100% |  | 2023-08-18 | 2023-09-07 | 15d | 2023-08-18 | 2023-09-07 |  |  | Andrew Margan | 120h | 120h |  | Code Drafting PM |  | 5.0 | Regulatory | Complete | COMPLETE |  |  |  |  |  |
| 1756 | 1.7.1.2.10.2 | Identify remaining or additional areas of code (e.g. consequential change requirements) to be completed |  | 15d | 2023-08-18 A | 2023-09-07 A | 1755SS | 100% |  | 2023-08-18 | 2023-09-07 | 15d | 2023-08-18 | 2023-09-07 |  |  | Andrew Margan | 120h | 120h |  | Code Bodies,SRO Design | Code Drafting PM | 5.0 | Regulatory | Complete | COMPLETE |  |  |  |  |  |
| 1757 | 1.7.1.2.10.3 | Code Drafting (offline) Interim Consultation (1) |  | 60d | 2023-09-08 A | 2023-11-30 A | 1756 | 100% |  | 2023-09-08 | 2023-11-30 | 60d | 2023-09-08 | 2024-02-15 |  |  | Andrew Margan | 480h | 480h |  | Code Bodies,SRO Design | Code Drafting PM | 5.0 | Regulatory | Complete | COMPLETE |  |  |  |  |  |
| 1758 | 1.7.1.2.10.4 | Internal review and cross-checking of drafting across code drafters Interim Consultation (1) |  | 50d | 2023-09-22 A | 2023-11-30 A | 1757SS+10d | 100% |  | 2023-09-22 | 2023-11-30 | 50d | 2023-09-22 | 2024-02-15 |  |  | Andrew Margan | 400h | 400h |  | Code Bodies,SRO Design | Code Drafting PM | 5.0 | Regulatory | Complete | COMPLETE |  |  |  |  |  |
| 1759 | 1.7.1.2.10.5 | External industry review via consultation Interim Consultation (1) |  | 23d | 2023-12-01 A | 2024-01-02 A | 1758 | 100% |  | 2023-12-01 | 2024-01-02 | 23d | 2024-02-19 | 2024-03-08 |  |  | Andrew Margan | 184h | 184h |  | PP | Code Drafting PM | 5.0 | Regulatory | Complete | COMPLETE |  |  |  |  |  |
| 1760 | 1.7.1.2.10.6 | Code Drafting (offline) Final Consultation (2) |  | 55d | 2023-12-01 A | 2024-02-15 A | 1758 | 100% |  | 2023-12-01 | 2024-02-15 | 55d | 2023-09-08 | 2024-02-15 |  |  | Andrew Margan | 440h | 440h |  | Code Bodies,SRO Design | Code Drafting PM | 5.0 | Regulatory | Complete | COMPLETE |  |  |  |  |  |
| 1761 | 1.7.1.2.10.7 | Internal review and cross-checking of drafting across code drafters Final Consultation (2) |  | 45d | 2023-12-15 A | 2024-02-15 A | 1760SS+10d | 100% |  | 2023-12-15 | 2024-02-15 | 45d | 2023-09-22 | 2024-02-15 |  |  | Andrew Margan | 360h | 360h |  | Code Bodies,SRO Design | Code Drafting PM | 5.0 | Regulatory | Complete | COMPLETE |  |  |  |  |  |
| 1762 | 1.7.1.2.10.8 | External industry review via consultation Final Consultation (2) |  | 16d | 2024-02-19 A | 2024-03-11 A | 1761FS+1d | 100% |  | 2024-02-19 | 2024-03-08 | 15d | 2024-02-19 | 2024-03-08 |  |  | Andrew Margan | 128h | 128h |  | PP | Code Drafting PM | 5.0 | Regulatory | Complete | COMPLETE |  |  |  |  |  |
| 1763 | 1.7.1.2.10.9 | Triage and action comments |  | 18d | 2024-03-11 A | 2024-04-03 A | 1762FS-1d | 100% |  | 2024-03-07 | 2024-04-01 | 18d | 2024-03-07 | 2024-04-03 |  |  | Andrew Margan | 144h | 144h |  | Code Bodies,SRO Design | Code Drafting PM | 5.0 | Regulatory | Complete | COMPLETE |  |  |  |  |  |
| 1764 | 1.7.1.2.10.10 | CDWG review |  | 29d | 2024-04-04 A | 2024-05-14 A | 1763 | 100% |  | 2024-04-02 | 2024-05-14 | 31d | 2024-04-04 | 2024-05-03 |  |  | Andrew Margan | 232h | 232h |  | PP | Code Drafting PM | 5.0 | Regulatory | Complete | COMPLETE |  |  |  |  |  |
| 1765 | 1.7.1.2.10.11 | CCAG review |  | 6d | 2024-05-15 A | 2024-05-22 A | 1764 | 100% |  | 2024-05-15 | 2024-05-22 | 6d | 2024-05-06 | 2024-05-13 |  |  | Andrew Margan | 48h | 48h |  | PP | Code Drafting PM | 5.0 | Regulatory | Complete | COMPLETE |  |  |  |  |  |
| 1766 | 1.7.1.2.10.12 | Final code drafting (mop-up) approved | milestone | 0d | 2024-05-22 A | 2024-05-22 A | 1765 | 100% |  | 2024-05-22 | 2024-05-22 | 0d | 2024-05-13 | 2024-05-13 |  |  | Andrew Margan |  |  |  | PP | Code Drafting PM | 5.25 | Regulatory | Complete | COMPLETE |  | MHHS-ART060 | T3-RE-0500 | CCAG | T2 |

Notes:
- 1743: Review of drop schedule and scope is being undertaken with CCAG.
- 1744: Review of drop schedule and scope is being undertaken with CCAG.
- 1747: Guidance: 14/8/23 - RECCo transition drafting activity is expected to take the full 38 days, noting BSE co-drafting will be expected to take approx. 21 days
- 1753: 10/10 - CH - Agreed at PSG on 4/10 to downgrade from T2 to T3
- 1766: 10/10 - CH - Agreed at PSG on 4/10 to downgrade from T2 to T3

| ID | WBS | Task | Type | Duration | Start | Finish | Predecessors | Complete | Remaining | Baseline start | Baseline finish | Baseline duration | Baseline 1 start | Baseline 1 finish | Total slack | Free slack | Resources | Work | Actual work | Baseline cost | Responsible | Involved | Task Status | Update Version | MHHS Programme Phase | Sched Status | RAG | Artefact ID | Milestone ID | Text29 | Tier |
| --- | --- | --- | --- | --- | --- | --- | --- | --- | --- | --- | --- | --- | --- | --- | --- | --- | --- | --- | --- | --- | --- | --- | --- | --- | --- | --- | --- | --- | --- | --- | --- |
| 1767 | 1.7.1.2.11 | **Final code review, consistency check and approval** |  | 100d | 2024-04-04 A | 2024-08-21 |  | 63% | 37.5d | 2024-04-04 | 2024-08-23 | 102d | 2024-05-06 | 2024-08-23 | 722d |  | N/A | 1568h | 929.6h | -0 | N/A | N/A | M6 | 5.0 | Regulatory |  |  |  |  |  |  |
| 1768 | 1.7.1.2.11.1 | Gap analysis of final code against design artefacts (reverse process to code drafting) |  | 38d | 2024-04-04 A | 2024-05-27 A | 1764SS | 100% |  | 2024-04-04 | 2024-05-27 | 38d | 2024-05-06 | 2024-05-17 |  |  | Andrew Margan | 304h | 304h |  | Code Bodies,SRO Design | Code Drafting PM |  | 5.0 | Regulatory | Complete | COMPLETE |  |  |  |  |
| 1769 | 1.7.1.2.11.2 | Outputs of gap analysis actioned offline |  | 11d | 2024-05-28 A | 2024-06-11 A | 1768 | 100% |  | 2024-05-28 | 2024-06-11 | 11d | 2024-05-20 | 2024-06-07 |  |  | Andrew Margan | 88h | 88h |  | Code Bodies,SRO Design | Code Drafting PM |  | 5.0 | Regulatory | Complete | COMPLETE |  |  |  |  |
| 1770 | 1.7.1.2.11.3 | Final documentation collated for final consultation |  | 8d | 2024-06-12 A | 2024-06-21 A | 1769 | 100% |  | 2024-06-12 | 2024-06-24 | 9d | 2024-06-10 | 2024-06-13 |  |  | Andrew Margan | 64h | 64h |  | Code Drafting PM | Code Bodies,SRO Design |  | 5.23 | Regulatory | Complete | COMPLETE |  |  |  |  |
| 1771 | 1.7.1.2.11.4 | External industry review via consultation |  | 15d | 2024-06-24 A | 2024-07-12 | 1770 | 20% | 12d | 2024-06-24 | 2024-07-19 | 20d | 2024-06-14 | 2024-07-04 | 586d | 0d | Andrew Margan | 120h | 24h |  | PP | Code Drafting PM |  | 5.0 | Regulatory | Green | GREEN |  |  |  |  |
| 1772 | 1.7.1.2.11.5 | Triage and action comments |  | 10d | 2024-07-15 | 2024-07-26 | 1771 |  |  | 2024-07-18 | 2024-08-05 | 13d | 2024-07-03 | 2024-07-19 | 586d | 0d | Andrew Margan | 80h |  |  | Code Bodies,SRO Design | Code Drafting PM | 18.33 | 5.0 | Regulatory | Green | GREEN |  |  |  |  |
| 1773 | 1.7.1.2.11.6 | Final CDWG review |  | 8d | 2024-08-02 | 2024-08-13 | 1772FS+4d |  |  | 2024-08-06 | 2024-08-13 | 6d | 2024-07-22 | 2024-08-16 | 586d | 0d | Andrew Margan | 64h |  |  | PP | Code Drafting PM | 36.33 | 5.0 | Regulatory | Green | GREEN |  |  |  |  |
| 1774 | 1.7.1.2.11.7 | Final CCAG review |  | 6d | 2024-08-14 | 2024-08-21 | 1773 |  |  | 2024-08-14 | 2024-08-23 | 8d | 2024-08-19 | 2024-08-23 | 586d | 0d | Andrew Margan | 48h |  |  | PP | Code Drafting PM | 48.33 | 5.0 | Regulatory | Green | GREEN |  |  |  |  |
| 1775 | 1.7.1.2.11.8 | CCAG recommend final code to PSG for baselining | milestone | 0d | 2024-08-21 | 2024-08-21 | 1774 |  |  | 2024-08-23 | 2024-08-23 | 0d | 2024-08-23 | 2024-08-23 | 722d |  | Andrew Margan |  |  |  | PP | Code Drafting PM | 55.71 | 5.9 | Regulatory | Green | GREEN | MHHS-ART060 | T3-RE-0550 | CCAG | T2 |
| 1776 | 1.7.1.3 | Code changes baselined (M6) | milestone | 0d | 2024-08-23 | 2024-08-23 | 1774FS+2d, 1766, 1753, 1741, 1732, 1723, 1714, 1705, 1696, 1687 |  |  | 2024-08-23 | 2024-08-23 | 0d | 2024-08-23 | 2024-08-23 | 586d | 0d | Andrew Margan |  |  |  | CPT | PP | 57.71 | 5.0 | Regulatory | Green | GREEN | MHHS-ART012 | T1-RE-1000 | PSG | T1 |
| 1777 | 1.7.2 | **Ofgem preparation and enactment of SCR powers** |  | 201d | 2024-02-05 A | 2024-11-11 |  | 70% | 59.52d | 2024-02-05 | 2024-11-12 | 201d | 2024-01-26 | 2024-11-12 | 664d |  | N/A | 4784h | 3357.9h | -0 | N/A | N/A | M7 | 5.0 | Regulatory |  |  |  |  |  |  |
| 1778 | 1.7.2.1 | **Preparation and enactment of SCR Powers** |  | 201d | 2024-02-05 A | 2024-11-11 |  | 70% | 59.52d | 2024-02-05 | 2024-11-11 | 201d | 2024-01-26 | 2024-11-11 | 664d |  | N/A | 3224h | 2259.84h | -0 | N/A | N/A |  | 5.0 | Regulatory |  |  |  |  |  |  |
| 1779 | 1.7.2.1.1 | Ofgem to keep Ofgem legal informed of process followed and nature of Code drafting to ensure that prepared for SCR go/no go decision |  | 101d | 2024-02-05 A | 2024-06-24 A | 1780SF | 100% |  | 2024-02-05 | 2024-06-25 | 101d | 2024-01-26 | 2024-06-14 |  |  | Andrew Margan | 776h | 776h |  | Ofgem | Code Bodies |  | 5.0 | Regulatory | Complete | COMPLETE |  |  |  |  |
| 1780 | 1.7.2.1.2 | OFGEM Legal to review Code Artefacts deliver policy intent and process followed and confirm that SCR powers are appropriate to use rather than SMAP - SCR go/no go |  | 14d | 2024-06-24 A | 2024-07-11 A | 1771SS | 100% |  | 2024-06-24 | 2024-07-12 | 15d | 2024-06-14 | 2024-07-04 |  |  | Andrew Margan | 112h | 112h |  | Ofgem | Code Bodies |  | 5.0 | Regulatory | Complete | COMPLETE |  |  |  |  |
| 1781 | 1.7.2.1.3 | Code Bodies to draft MOD proposal forms |  | 20d | 2024-07-12 A | 2024-08-08 | 1780 | 50% | 10d | 2024-07-15 | 2024-08-09 | 20d | 2024-07-05 | 2024-08-01 | 731d |  | Andrew Margan | 160h | 80h |  | Code Bodies | Ofgem |  | 5.0 | Regulatory | Green | GREEN |  |  |  |  |
| 1782 | 1.7.2.1.4 | Ofgem discuss and agree code mod timetable with code bodies (and MHHSP in relation to the dates for expected decisions) |  | 20d | 2024-07-12 A | 2024-08-08 A | 1780 | 100% |  | 2024-07-15 | 2024-08-09 | 20d | 2024-07-05 | 2024-08-01 |  |  | Andrew Margan | 160h | 160h |  | Ofgem | Code Bodies |  | 5.0 | Regulatory | Complete | COMPLETE |  |  |  |  |
| 1783 | 1.7.2.1.5 | Ofgem to draft open letter and direction to each code body specifying the timetable for each modification |  | 5d | 2024-08-09 | 2024-08-15 | 1782 |  |  | 2024-08-12 | 2024-08-16 | 5d | 2024-08-02 | 2024-08-08 | 726d |  | Andrew Margan | 40h |  |  | Ofgem | Code Bodies | 43.33 | 5.0 | Regulatory | Green | GREEN |  |  |  |  |
| 1784 | 1.7.2.1.6 | Ofgem to publish open letter |  | 1d | 2024-08-26 | 2024-08-26 | 1776 |  |  | 2024-08-26 | 2024-08-26 | 1d | 2024-08-26 | 2024-08-26 | 586d | 0d | Andrew Margan | 8h |  |  | Ofgem | Code Bodies | 60.33 | 5.0 | Regulatory | Green | GREEN |  |  |  |  |
| 1785 | 1.7.2.1.7 | Ofgem to publish each Direction to each code body specifying the timetable for each modification |  | 1d | 2024-08-28 | 2024-08-28 | 1784FS+1d |  |  | 2024-08-28 | 2024-08-28 | 1d | 2024-08-28 | 2024-08-28 | 717d |  | Andrew Margan | 8h |  |  | Ofgem | Code Bodies | 62.33 | 5.0 | Regulatory | Green | GREEN |  |  |  |  |
| 1786 | 1.7.2.1.8 | Formally submit (by separate email) Modification Proposal Forms and legal texts to each code body |  | 1d | 2024-08-28 | 2024-08-28 | 1784FS+1d |  |  | 2024-08-28 | 2024-08-28 | 1d | 2024-08-28 | 2024-08-28 | 586d | 0d | Andrew Margan | 8h |  |  | Ofgem | Code Bodies | 62.33 | 5.0 | Regulatory | Green | GREEN |  |  |  |  |
| 1787 | 1.7.2.1.9 | Each Code Body publishes and issues Modification Proposal Forms |  | 3d | 2024-08-29 | 2024-09-02 | 1786 |  |  | 2024-08-29 | 2024-09-02 | 3d | 2024-08-29 | 2024-09-02 | 586d | 0d | Andrew Margan | 24h |  |  | Code Bodies | Ofgem | 63.33 | 5.0 | Regulatory | Green | GREEN |  |  |  |  |
| 1788 | 1.7.2.1.10 | Each Code Body sends Modification Proposal Forms to Panel to approve Mod to go to consultation |  | 10d | 2024-09-03 | 2024-09-16 | 1787 |  |  | 2024-09-03 | 2024-09-16 | 10d | 2024-09-03 | 2024-09-16 | 586d | 0d | Andrew Margan | 80h |  |  | Code Bodies | Ofgem | 68.33 | 5.0 | Regulatory | Green | GREEN |  |  |  |  |
| 1789 | 1.7.2.1.11 | Modification Proposal approved by Panel for Consultation |  | 1d | 2024-09-17 | 2024-09-17 | 1788 |  |  | 2024-09-17 | 2024-09-17 | 1d | 2024-09-17 | 2024-09-17 | 586d | 0d | Andrew Margan | 8h |  |  | Code Bodies | Ofgem | 82.33 | 5.0 | Regulatory | Green | GREEN |  |  |  |  |
| 1790 | 1.7.2.1.12 | Draft Modification Report issued for consultation |  | 1d | 2024-09-18 | 2024-09-18 | 1789 |  |  | 2024-09-18 | 2024-09-18 | 1d | 2024-09-18 | 2024-09-18 | 586d | 0d | Andrew Margan | 8h |  |  | Code Bodies | Ofgem | 83.33 | 5.0 | Regulatory | Green | GREEN |  |  |  |  |
| 1791 | 1.7.2.1.13 | Consultation Close-out for representations |  | 15d | 2024-09-19 | 2024-10-09 | 1790 |  |  | 2024-09-19 | 2024-10-09 | 15d | 2024-09-19 | 2024-10-09 | 586d | 0d | Andrew Margan | 120h |  |  | Code Bodies | Ofgem | 84.33 | 5.0 | Regulatory | Green | GREEN |  |  |  |  |
| 1792 | 1.7.2.1.14 | Each Code Body reviews consultation response and drafts Modification Report |  | 10d | 2024-10-10 | 2024-10-23 | 1791 |  |  | 2024-10-10 | 2024-10-23 | 10d | 2024-10-10 | 2024-10-23 | 586d | 0d | Andrew Margan | 80h |  |  | Code Bodies | Ofgem | 105.33 | 5.0 | Regulatory | Green | GREEN |  |  |  |  |
| 1793 | 1.7.2.1.15 | Final Modification Report sent to Panel for decision with recommendation to approve |  | 1d | 2024-10-24 | 2024-10-24 | 1792 |  |  | 2024-10-24 | 2024-10-24 | 1d | 2024-10-24 | 2024-10-24 | 586d | 0d | Andrew Margan | 8h |  |  | Code Bodies | Ofgem | 119.33 | 5.0 | Regulatory | Green | GREEN |  |  |  |  |
| 1794 | 1.7.2.1.16 | Modification Panel decision |  | 1d | 2024-11-07 | 2024-11-07 | 1793FS+9d |  |  | 2024-11-07 | 2024-11-07 | 1d | 2024-11-07 | 2024-11-07 | 586d | 0d | Andrew Margan | 8h |  |  | Code Bodies | Ofgem | 133.33 | 5.0 | Regulatory | Green | GREEN |  |  |  |  |
| 1795 | 1.7.2.1.17 | Panel make recommendation to OFGEM |  | 1d | 2024-11-11 | 2024-11-11 | 1794FS+1d |  |  | 2024-11-08 | 2024-11-11 | 2d | 2024-11-08 | 2024-11-11 | 586d | 0d | Andrew Margan | 8h |  |  | Code Bodies | Ofgem | 137.33 | 5.0 | Regulatory | Green | GREEN |  |  |  |  |
| 1796 | 1.7.2.2 | SCR powers enabled (M7) | milestone | 0d | 2024-11-11 | 2024-11-11 | 1776, 1795 |  |  | 2024-11-11 | 2024-11-11 | 0d | 2024-11-11 | 2024-11-11 | 586d | 0d | Andrew Margan |  |  |  | CPT | PP | 137.71 | 5.0 | Regulatory | Green | AMBER | MHHS-ART012 | T2-RE-0600 | CCAG | T2 |

Notes:
- 1775: 10/10 - CH - Agreed at PSG on 4/10 to downgrade from T2 to T3

| ID | WBS | Task | Type | Duration | Start | Finish | Predecessors | Complete | Remaining | Baseline start | Baseline finish | Baseline duration | Baseline 1 start | Baseline 1 finish | Total slack | Free slack | Constraint | Resources | Work | Actual work | Baseline cost | Responsible | Involved | Update Version | MHHS Programme Phase | Task Status | RAG | Sched Status | Artefact ID | Milestone ID | Text29 | Tier | Text3 |
| --- | --- | --- | --- | --- | --- | --- | --- | --- | --- | --- | --- | --- | --- | --- | --- | --- | --- | --- | --- | --- | --- | --- | --- | --- | --- | --- | --- | --- | --- | --- | --- | --- | --- |
| 1797 | 1.7.2.3 | **Ofgem preparation to enact Smart Meter Act powers [CONTINGENCY ONLY]** | inactive | 101d | 2024-06-24 | 2024-11-12 |  |  |  | 2024-06-25 | 2024-11-12 | 100d | 2024-06-14 | 2024-11-12 | 664d |  |  | N/A | 2736h |  | -0 | N/A | N/A | 5.0 | Regulatory |  |  |  |  |  |  |  |  |
| 1798 | 1.7.2.3.1 | SRO recommends Ofgem begin preparation to enact Smart Meter Act powers [CONTINGENCY ONLY] | inactive | 1d | 2024-06-24 | 2024-06-24 | 1780SS |  |  | 2024-06-25 | 2024-06-25 | 1d | 2024-06-14 | 2024-06-14 | 729d | 0d |  | Andrew Margan | 8h |  |  | Ofgem | Code bodies | 5.0 | Regulatory | -2.67 | RED |  |  |  |  |  |  |
| 1799 | 1.7.2.3.2 | Ofgem drafts letter to DESNZ to request trigger of Smart Meter Act powers [CONTINGENCY ONLY] | inactive | 15d | 2024-06-25 | 2024-07-15 | 1798 |  |  | 2024-06-26 | 2024-07-16 | 15d | 2024-06-17 | 2024-07-05 | 729d | 0d |  | Andrew Margan | 120h |  |  | Ofgem | Code bodies | 5.0 | Regulatory | -1.67 | GREEN |  |  |  |  |  |  |
| 1800 | 1.7.2.3.3 | DESNZ SoS letter response to trigger SMAP Powers [CONTINGENCY ONLY] | inactive | 1mo | 2024-07-16 | 2024-08-12 | 1799 |  |  | 2024-07-17 | 2024-08-13 | 1mo | 2024-07-08 | 2024-08-02 | 729d |  |  | Andrew Margan | 160h |  |  | Ofgem | Code bodies | 5.0 | Regulatory | 19.33 | GREEN |  |  |  |  |  |  |
| 1801 | 1.7.2.3.4 | Ofgem enables Smart Meters Act powers (support from the Programme, where required) [CONTINGENCY ONLY] | inactive | 1d | 2024-08-05 | 2024-08-06 | 1805SF |  |  | 2024-08-05 | 2024-08-06 | 1d | 2024-08-05 | 2024-08-06 | 734d | 0d |  | Andrew Margan | 8h |  |  | Tier 2 - M7 |  | 5.0 | Regulatory | 39.33 | GREEN |  |  |  |  |  |  |
| 1802 | 1.7.2.3.5 | Smart Meters Act powers enabled (M7) [CONTINGENCY ONLY] | milestone, inactive | 0d | 2024-08-06 | 2024-08-06 | 1801 |  |  | 2024-08-06 | 2024-08-06 | 0d | 2024-08-06 | 2024-08-06 | 734d |  |  | Andrew Margan |  |  |  | Ofgem | Code bodies | 5.0 | Regulatory | 40.33 | GREEN |  |  |  |  |  |  |
| 1803 | 1.7.2.3.6 | **Deliver MHHS Code Changes [CONTINGENCY UNDER SMAP]** | inactive | 70d | 2024-08-06 | 2024-11-12 |  |  |  | 2024-08-06 | 2024-11-12 | 70d | 2024-08-06 | 2024-11-12 | 664d |  |  | N/A | 1680h |  |  | N/A | N/A | 5.0 | Regulatory |  |  |  |  |  |  |  |  |
| 1804 | 1.7.2.3.6.1 | **Ofgem consultation and decision [CONTINGENCY ONLY]** | inactive | 70d | 2024-08-06 | 2024-11-12 |  |  |  | 2024-08-06 | 2024-11-12 | 70d | 2024-08-06 | 2024-11-12 | 664d |  |  | N/A | 1120h |  |  | N/A | N/A | 5.0 | Regulatory |  |  |  |  |  |  |  |  |
| 1805 | 1.7.2.3.6.1.1 | Ofgem issue completed code to industry for consultation under SMAP (consultation confirms robustness of the process undertaken via CCAG and does not re-open the detail of drafted code) [CONTINGENCY ONLY] | inactive | 10d | 2024-08-06 | 2024-08-20 | 1806SF |  |  | 2024-08-06 | 2024-08-20 | 10d | 2024-08-06 | 2024-08-20 | 724d | 0d |  | Andrew Margan | 80h |  |  | Ofgem | Code bodies | 5.0 | Regulatory | 40.33 | GREEN |  |  |  |  |  |  |
| 1806 | 1.7.2.3.6.1.2 | Industry respond to consultation on new Code (28-day consultation) [CONTINGENCY ONLY] | inactive | 20d | 2024-08-20 | 2024-09-17 | 1807SF |  |  | 2024-08-20 | 2024-09-17 | 20d | 2024-08-20 | 2024-09-17 | 704d | 0d |  | Andrew Margan | 160h |  |  | PP | Ofgem | 5.0 | Regulatory | 54.33 | GREEN |  |  |  |  |  |  |
| 1807 | 1.7.2.3.6.1.3 | Ofgem considers consultation responses and publishes decision confirming Code Releases dates (release dates may be <56 days following publication of Ofgem decision) [CONTINGENCY ONLY] | inactive | 40d | 2024-09-17 | 2024-11-12 | 1810SF |  |  | 2024-09-17 | 2024-11-12 | 40d | 2024-09-17 | 2024-11-12 | 664d | 0d |  | Andrew Margan | 320h |  |  | Ofgem | Code bodies | 5.0 | Regulatory | 82.33 | GREEN |  |  |  |  |  |  |
| 1808 | 1.7.3 | **Deliver MHHS Code Changes** |  | 149d | 2024-11-12 | 2025-06-06 |  |  |  | 2024-11-12 | 2025-06-06 | 149d | 2024-11-12 | 2025-03-07 | 515d |  |  | N/A | 3624h |  |  | N/A | N/A | 5.0 | Regulatory | M8 |  |  |  |  |  |  |  |
| 1809 | 1.7.3.1 | **Releases** |  | 149d | 2024-11-12 | 2025-06-06 |  |  |  | 2024-11-12 | 2025-06-06 | 149d | 2024-11-12 | 2025-03-07 | 515d |  |  | N/A | 2432h |  |  | N/A | N/A | 5.0 | Regulatory |  |  |  |  |  |  |  |  |
| 1810 | 1.7.3.1.1 | Impacted codes make resourcing provisions and prepare to implement new Code via internal code body change processes |  | 78d | 2024-11-12 | 2025-02-27 | 1796 |  |  | 2024-11-12 | 2025-02-27 | 78d | 2024-11-12 | 2025-02-27 | 586d | 0d |  | Andrew Margan | 624h |  |  | Code Bodies |  | 5.0 | Regulatory | 138.33 | GREEN | Green |  |  |  |  |  |
| 1811 | 1.7.3.1.2 | **Main Code Release** |  | 71d | 2025-02-28 | 2025-06-06 |  |  |  | 2025-02-28 | 2025-06-06 | 71d | 2025-02-28 | 2025-03-07 | 515d |  |  | N/A | 616h |  |  | N/A | N/A | 5.0 | Regulatory |  |  |  |  |  |  |  |  |
| 1812 | 1.7.3.1.2.1 | Release preparation (e.g. preparing release documentation) |  | 6d | 2025-02-28 | 2025-03-07 | 1813SF |  |  | 2025-02-28 | 2025-03-07 | 5d | 2025-02-28 | 2025-03-07 | 580d |  |  | Andrew Margan | 48h |  |  | Code Bodies |  | 5.0 | Regulatory | 246.33 | GREEN | yellow |  |  |  |  |  |
| 1813 | 1.7.3.1.2.2 | Implement new code on day of code release | milestone | 0d | 2025-03-07 | 2025-03-07 | 1814SF |  |  | 2025-03-07 | 2025-03-07 | 1d | 2025-03-07 | 2025-03-07 | 580d | 0d |  | Andrew Margan |  |  |  | Code Bodies |  | 5.0 | Regulatory | 253.71 | GREEN | Green |  |  |  |  |  |
| 1814 | 1.7.3.1.2.3 | Code changes delivered (M8) | milestone | 0d | 2025-03-07 | 2025-03-07 | 2021SS, 1796, 1776 |  |  | 2025-03-07 | 2025-03-07 | 0d | 2025-03-07 | 2025-03-07 | 515d | 0d |  | Andrew Margan |  |  |  | CPT | Code Bodies,PP | 5.0 | Regulatory | 253.71 | GREEN | Green | MHHS-ART060 | T2-RE-0650 | CCAG | T2 |  |
| 1815 | 1.7.3.1.2.4 | Code changes delivered (M8*) late exit | milestone | 0d | 2025-06-06 | 2025-06-06 | 1814FS+65d |  |  | 2025-06-06 | 2025-06-06 | 0d |  |  | 515d |  |  | Andrew Margan |  |  |  | CPT | Code Bodies,PP | 5.1 | Regulatory | 344.71 | GREEN | Green | MHHS-ART060 | T2-RE-0700 | CCAG | T2 |  |
| 1816 | 1.7.4 | **External Programme Dependency Management** |  | 38d | 2023-12-01 A | 2024-01-24 A |  | 100% |  | 2023-12-01 | 2024-01-24 | 38d | 2023-09-08 | 2024-01-24 |  |  |  | N/A | 768h | 768h |  | N/A | N/A | 5.0 | Regulatory |  |  |  |  |  |  |  |  |
| 1817 | 1.7.4.1 | **DCP397** |  | 38d | 2023-12-01 A | 2024-01-24 A |  | 100% |  | 2023-12-01 | 2024-01-24 | 38d | 2023-09-08 | 2024-01-24 |  |  |  | N/A | 464h | 464h |  | N/A | N/A | 5.0 | Regulatory |  |  |  |  |  |  |  |  |
| 1818 | 1.7.4.1.1 | Ensure DCP397 drafting included in mop-up code drafting activity (link to mop-up) |  | 20d | 2023-12-01 A | 2023-12-28 A | 1760SS, 1757SS | 100% |  | 2023-12-01 | 2023-12-28 | 20d | 2023-09-08 | 2023-10-05 |  |  |  | Andrew Margan | 160h | 160h |  | CPT | Code Bodies,SRO Design, Code Drafting PM | 5.0 | Regulatory |  | COMPLETE | Complete |  |  |  |  |  |
| 1819 | 1.7.4.1.2 | Implementation of DCP397 | milestone | 0d | 2024-01-24 A | 2024-01-24 A |  | 100% |  | 2024-01-24 | 2024-01-24 | 0d | 2024-01-24 | 2024-01-24 |  |  | start no earlier than 2024-01-24 | Andrew Margan |  |  |  | Code Bodies |  | 5.0 | Regulatory |  | COMPLETE | Complete |  |  |  |  |  |
| 1820 | 1.8 | **MIGRATION** |  | 1091d | 2022-10-31 A | 2027-01-04 |  | 29% | 777.11d | 2022-10-31 | 2027-01-05 | 1092d | 2022-10-31 | 2027-01-05 | 104d |  |  | N/A | 133202h | 41244.4h | -0 | N/A | N/A |  | Migration |  |  |  |  |  |  |  | 1 Oct 2024 - 31 Oct 2025 |
| 1821 | 1.8.1 | **Migration Artefact Development and Publication** |  | 635d | 2022-10-31 A | 2025-04-04 |  | 79% | 136.03d | 2022-10-31 | 2025-04-04 | 635d | 2022-10-31 | 2025-04-04 | 560d |  |  | N/A | 31376h | 16370.7h | -0 | N/A | N/A | 5.0 | Migration |  |  |  |  |  |  |  |  |
| 1822 | 1.8.1.1 | **Migration Approach** |  | 28d | 2022-10-31 A | 2022-12-07 A |  | 100% |  | 2022-10-31 | 2022-12-07 | 28d | 2022-10-31 | 2022-12-07 |  |  |  | N/A | 592h | 592h |  | N/A | N/A | 5.0 | Migration |  |  |  |  |  |  |  |  |
| 1823 | 1.8.1.1.1 | Option analysis (via MWG and PPIR) and recommendation |  | 23d | 2022-10-31 A | 2022-11-30 A |  | 100% |  | 2022-10-31 | 2022-11-30 | 23d | 2022-10-31 | 2022-11-30 |  |  |  | John Wiggins; Matthew Breen | 368h | 368h |  | PP | SI Migration | 5.0 | Migration |  | COMPLETE | Complete |  |  |  |  |  |
| 1824 | 1.8.1.1.2 | Migration Approach approved | milestone | 0d | 2022-12-07 A | 2022-12-07 A | 1823FS+5d | 100% |  | 2022-12-07 | 2022-12-07 | 0d | 2022-12-07 | 2022-12-07 |  |  |  | John Wiggins; Matthew Breen |  |  |  | SI Migration | PP,IPA | 5.0 | Migration |  | COMPLETE | Complete | MHHS-DEL770 | T3-MI-0010 | PSG | T3 |  |

Notes:
- 1807: KEEP NOTE IN MS PROJECT PLAN: "This includes publishing decision to the Ofgem website and providing written direction to each code body with code release instruction & date."

| ID | WBS | Task | Type | Duration | Start | Finish | Predecessors | Complete | Baseline start | Baseline finish | Baseline duration | Baseline 1 start | Baseline 1 finish | Resources | Work | Actual work | Baseline cost | Responsible | Involved | Update Version | MHHS Programme Phase | Sched Status | RAG | Milestone ID | Text29 | Tier | Guidance |
| --- | --- | --- | --- | --- | --- | --- | --- | --- | --- | --- | --- | --- | --- | --- | --- | --- | --- | --- | --- | --- | --- | --- | --- | --- | --- | --- | --- |
| 1825 | 1.8.1.2 | **Migration Design** |  | 100d | 2022-11-14 A | 2023-03-31 A |  | 100% | 2022-11-14 | 2023-03-31 | 100d | 2022-11-14 | 2023-03-31 | N/A | 2016h | 2016h |  | N/A | N/A | 5.0 | Migration |  |  |  |  |  |  |
| 1826 | 1.8.1.2.1 | Review and update existing design artefacts and socialise with participants ahead of MDSG |  | 10d | 2022-11-14 A | 2022-11-25 A |  | 100% | 2022-11-14 | 2022-11-25 | 10d | 2022-11-14 | 2022-11-25 | John Wiggins; Matthew Breen | 160h | 160h |  | SI Migration | SRO Design,CPT | 5.0 | Migration | Complete | COMPLETE |  |  |  |  |
| 1827 | 1.8.1.2.2 | Develop design artefacts and supporting technical documents in line with MDSG |  | 53d | 2022-11-30 A | 2023-02-10 A | 1826FS+2d | 100% | 2022-11-30 | 2023-02-10 | 53d | 2022-11-30 | 2023-02-10 | John Wiggins; Matthew Breen | 848h | 848h |  | SI Migration | PP,SRO Function,CPT | 5.0 | Migration | Complete | COMPLETE |  |  |  |  |
| 1828 | 1.8.1.2.3 | Migration design artefacts issued for consultation | milestone | 0d | 2023-02-13 A | 2023-02-13 A | 1827FS+1d | 100% | 2023-02-13 | 2023-02-13 | 0d | 2023-02-13 | 2023-02-13 | John Wiggins; Matthew Breen |  |  |  | SI Migration | PP,SRO Function,CPT | 5.0 | Migration | Complete | COMPLETE | T3-MI-0011 | DAG | T3 |  |
| 1829 | 1.8.1.2.4 | Industry consultation |  | 5d | 2023-02-14 A | 2023-02-20 A | 1828SS | 100% | 2023-02-14 | 2023-02-20 | 5d | 2023-02-14 | 2023-02-20 | John Wiggins; Matthew Breen | 80h | 80h |  | PP | SI Migration | 5.0 | Migration | Complete | COMPLETE |  |  |  |  |
| 1830 | 1.8.1.2.5 | Review consultation feedback, address comments and update artefacts |  | 5d | 2023-02-21 A | 2023-02-27 A | 1829 | 100% | 2023-02-21 | 2023-02-27 | 5d | 2023-02-21 | 2023-02-27 | John Wiggins; Matthew Breen | 80h | 80h |  | SI Migration | PP | 5.0 | Migration | Complete | COMPLETE |  |  |  |  |
| 1831 | 1.8.1.2.6 | Internal artefact review and comms preparation |  | 3d | 2023-02-28 A | 2023-03-02 A | 1830 | 100% | 2023-02-28 | 2023-03-02 | 3d | 2023-02-28 | 2023-03-02 | John Wiggins; Matthew Breen | 48h | 48h |  | SI Migration | SRO Function | 5.0 | Migration | Complete | COMPLETE |  |  |  |  |
| 1832 | 1.8.1.2.7 | Updated Migration Design artefacts issued to PPs for assurance review | milestone | 0d | 2023-03-03 A | 2023-03-03 A | 1831FS+1d | 100% | 2023-03-03 | 2023-03-03 | 0d | 2023-03-03 | 2023-03-03 | John Wiggins; Matthew Breen |  |  |  | SI Migration | PP | 5.0 | Migration | Complete | COMPLETE | T3-MI-0013 | DAG | T3 |  |
| 1833 | 1.8.1.2.8 | Final Migration Design artefacts walkthrough with PPs | milestone | 0d | 2023-03-22 A | 2023-03-22 A | 1832FS+13d | 100% | 2023-03-22 | 2023-03-22 | 0d | 2023-03-22 | 2023-03-22 | John Wiggins; Matthew Breen |  |  |  | SI Migration | PP | 5.0 | Migration | Complete | COMPLETE |  |  |  |  |
| 1834 | 1.8.1.2.9 | Migration Design approved | milestone | 0d | 2023-03-31 A | 2023-03-31 A | 1833FS+7d | 100% | 2023-03-31 | 2023-03-31 | 0d | 2023-03-31 | 2023-03-31 | John Wiggins; Matthew Breen |  |  |  | SI Migration | PP,SRO Function,CPT | 5.0 | Migration | Complete | COMPLETE | T2-MI-0050 | DAG | T2 |  |
| 1835 | 1.8.1.3 | **Transition Design** |  | 186d | 2023-03-01 A | 2023-11-15 A |  | 100% | 2023-03-01 | 2023-11-15 | 186d | 2023-03-01 | 2023-08-03 | N/A | 4328h | 4328h | -0 | N/A | N/A | 5.0 | Migration |  |  |  |  |  |  |
| 1836 | 1.8.1.3.1 | **Tranche 1** |  | 56d | 2023-03-01 A | 2023-05-17 A |  | 100% | 2023-03-01 | 2023-05-17 | 56d | 2023-03-01 | 2023-05-17 | N/A | 856h | 856h |  | N/A | N/A | 5.0 | Migration |  |  |  |  |  |  |
| 1837 | 1.8.1.3.1.1 | Develop design artefacts and supporting technical details with participants |  | 50d | 2023-03-01 A | 2023-05-09 A |  | 100% | 2023-03-01 | 2023-05-09 | 50d | 2023-03-01 | 2023-05-09 | Andrew Margan | 400h | 400h |  | SI Design | PP | 5.0 | Migration | Complete | COMPLETE |  |  |  |  |
| 1838 | 1.8.1.3.1.2 | Issue Material for DAG approval |  | 1d | 2023-05-10 A | 2023-05-10 A | 1837 | 100% | 2023-05-10 | 2023-05-10 | 1d | 2023-05-10 | 2023-05-10 | Andrew Margan | 8h | 8h |  | PP | SI Design | 5.0 | Migration | Complete | COMPLETE |  |  |  |  |
| 1839 | 1.8.1.3.1.3 | Tranche 1 Transition Design approved | milestone | 0d | 2023-05-17 A | 2023-05-17 A | 1838FS+5d | 100% | 2023-05-17 | 2023-05-17 | 0d | 2023-05-17 | 2023-05-17 | Andrew Margan |  |  |  | SI Design | PP | 5.0 | Migration | Complete | COMPLETE | T2-DB-0150 | DAG | T2 |  |
| 1840 | 1.8.1.3.2 | **Tranche 2** |  | 130d | 2023-05-18 A | 2023-11-15 A |  | 100% | 2023-05-18 | 2023-11-15 | 130d | 2023-05-18 | 2023-08-03 | N/A | 1984h | 1984h | -0 | N/A | N/A | 5.0 | Migration |  |  |  |  |  |  |
| 1841 | 1.8.1.3.2.1 | Develop Initial design artefacts and supporting technical details |  | 76d | 2023-05-18 A | 2023-08-31 A | 1839 | 100% | 2023-05-18 | 2023-08-31 | 76d | 2023-05-18 | 2023-07-26 | Andrew Margan | 608h | 608h |  | SRO | PP, CPT, SRO Design | 5.5 | Migration | Complete | COMPLETE |  |  |  |  |
| 1842 | 1.8.1.3.2.2 | Communicate Initial Design Artefacts with Industry (MTDSG) |  | 1d | 2023-09-01 A | 2023-09-01 A | 1841 | 100% | 2023-09-01 | 2023-09-01 | 1d |  |  | Andrew Margan | 8h | 8h |  | SRO | PP, CPT, SRO Design | 5.5 | Migration | Complete | COMPLETE |  |  |  |  |
| 1843 | 1.8.1.3.2.3 | Host MTDSG |  | 1d | 2023-09-11 A | 2023-09-11 A | 1842FS+5d | 100% | 2023-09-11 | 2023-09-11 | 1d |  |  | Andrew Margan | 8h | 8h |  | SRO | PP, CPT, SRO Design | 5.5 | Migration | Complete | COMPLETE |  |  |  |  |
| 1844 | 1.8.1.3.2.4 | Process MTDSG Feedback and Amend Design Artefacts |  | 4d | 2023-09-12 A | 2023-09-15 A | 1843 | 100% | 2023-09-12 | 2023-09-15 | 4d |  |  | Andrew Margan | 32h | 32h |  | SRO | PP, CPT, SRO Design | 5.5 | Migration | Complete | COMPLETE |  |  |  |  |
| 1845 | 1.8.1.3.2.5 | Communicate Amended Design Artefacts with Industry |  | 1d | 2023-09-15 A | 2023-09-15 A | 1844FF | 100% | 2023-09-15 | 2023-09-15 | 1d |  |  | Andrew Margan | 8h | 8h |  | SRO | PP, CPT, SRO Design | 5.5 | Migration | Complete | COMPLETE |  |  |  |  |
| 1846 | 1.8.1.3.2.6 | Host MTDSG |  | 1d | 2023-09-26 A | 2023-09-26 A | 1845FS+6d | 100% | 2023-09-26 | 2023-09-26 | 1d |  |  | Andrew Margan | 8h | 8h |  | SRO | PP, CPT, SRO Design | 5.5 | Migration | Complete | COMPLETE |  |  |  |  |
| 1847 | 1.8.1.3.2.7 | Make Final Amendments to Design Artefact |  | 5d | 2023-09-27 A | 2023-10-03 A | 1846 | 100% | 2023-09-27 | 2023-10-03 | 5d |  |  | Andrew Margan | 40h | 40h |  | SRO | PP, CPT, SRO Design | 5.5 | Migration | Complete | COMPLETE |  |  |  |  |
| 1848 | 1.8.1.3.2.8 | Request DAG Consultation |  | 1d | 2023-10-04 A | 2023-10-04 A | 1847 | 100% | 2023-10-04 | 2023-10-04 | 1d |  |  | Andrew Margan | 8h | 8h |  | SRO | PP, CPT, SRO Design | 5.5 | Migration | Complete | COMPLETE |  |  |  |  |
| 1849 | 1.8.1.3.2.9 | Consultation Period |  | 11d | 2023-10-04 A | 2023-10-18 A | 1848SS | 100% | 2023-10-04 | 2023-10-18 | 11d |  |  | Andrew Margan | 88h | 88h |  | SRO | PP, CPT, SRO Design | 5.5 | Migration | Complete | COMPLETE |  |  |  |  |
| 1850 | 1.8.1.3.2.10 | Action Consultation Comments |  | 5d | 2023-10-19 A | 2023-10-25 A | 1849 | 100% | 2023-10-19 | 2023-10-25 | 5d |  |  | Andrew Margan | 40h | 40h |  | SRO | PP, CPT, SRO Design | 5.5 | Migration | Complete | COMPLETE |  |  |  |  |
| 1851 | 1.8.1.3.2.11 | Post Consultation Industry Assurance |  | 5d | 2023-10-26 A | 2023-11-01 A | 1850 | 100% | 2023-10-26 | 2023-11-01 | 5d |  |  | Andrew Margan | 40h | 40h |  | SRO | PP, CPT, SRO Design | 5.5 | Migration | Complete | COMPLETE |  |  |  |  |
| 1852 | 1.8.1.3.2.12 | Request DAG Approval |  | 1d | 2023-11-01 A | 2023-11-01 A | 1851FF | 100% | 2023-11-01 | 2023-11-01 | 1d |  |  | Andrew Margan | 8h | 8h |  | SRO | PP, CPT, SRO Design | 5.5 | Migration | Complete | COMPLETE |  |  |  |  |
| 1853 | 1.8.1.3.2.13 | DAG Transition Design Approved |  | 1d | 2023-11-08 A | 2023-11-08 A | 1852FS+4d | 100% | 2023-11-08 | 2023-11-08 | 1d |  |  | Andrew Margan | 8h | 8h |  | SRO | PP, CPT, SRO Design | 5.5 | Migration | Complete | COMPLETE |  |  |  |  |
| 1854 | 1.8.1.3.2.14 | Update Transition Design Admin |  | 5d | 2023-11-09 A | 2023-11-15 A | 1853 | 100% | 2023-11-09 | 2023-11-15 | 5d |  |  | Andrew Margan | 40h | 40h |  | SRO | PP, CPT, SRO Design | 5.5 | Migration | Complete | COMPLETE |  |  |  |  |
| 1855 | 1.8.1.3.2.15 | Tranche 2 Transition Design Baselined | milestone | 0d | 2023-11-15 A | 2023-11-15 A | 1854 | 100% | 2023-11-15 | 2023-11-15 | 0d | 2023-08-03 | 2023-08-03 | Andrew Margan |  |  |  | SRO | PP, CPT, SRO Design | 5.12 | Migration | Complete | COMPLETE | T2-DB-0250 | DAG | T2 | 14/8 - Date aligns with DAG |

Notes:
- 1855: 14/8 - Milestone aligned to 5 days after DAG approval, to update comms and admin on collaboration base. CR number to be added. 15/9 - Rebaseline approved at DAG on 13/9/23 / Action: 2/8/23 - needs to be replanned to 15//11/23. AM to raise CR as T2 milestone

| ID | WBS | Task | Type | Duration | Start | Finish | Predecessors | Complete | Remaining | Baseline start | Baseline finish | Baseline duration | Baseline 1 start | Baseline 1 finish | Total slack | Free slack | Resources | Work | Actual work | Responsible | Involved | Update Version | MHHS Programme Phase | Sched Status | RAG | Milestone ID | Text29 | Tier | Action | Task Status |
| --- | --- | --- | --- | --- | --- | --- | --- | --- | --- | --- | --- | --- | --- | --- | --- | --- | --- | --- | --- | --- | --- | --- | --- | --- | --- | --- | --- | --- | --- | --- |
| 1856 | 1.8.1.4 | **Data Assessment Report** |  | 61d | 2022-12-06 A | 2023-02-28 A |  | 100% |  | 2022-12-06 | 2023-02-28 | 61d | 2022-12-06 | 2023-02-28 |  |  | N/A | 1672h | 1672h | N/A | N/A | 5.0 | Migration |  |  |  |  |  |  |  |
| 1857 | 1.8.1.4.1 | Develop document with MWG |  | 49d | 2022-12-06 A | 2023-02-10 A |  | 100% |  | 2022-12-06 | 2023-02-10 | 49d | 2022-12-06 | 2023-02-10 |  |  | John Wiggins; Matthew Breen | 784h | 784h | SI Migration |  | 5.0 | Migration | Complete | COMPLETE |  |  |  |  |  |
| 1858 | 1.8.1.4.2 | Artefact review (via TMAG) and updates |  | 25d | 2023-01-18 A | 2023-02-21 A | 1857FS-18d | 100% |  | 2023-01-18 | 2023-02-21 | 25d | 2023-01-18 | 2023-02-21 |  |  | John Wiggins; Matthew Breen | 400h | 400h | PP | IPA,SI Migration | 5.0 | Migration | Complete | COMPLETE |  |  |  |  |  |
| 1859 | 1.8.1.4.3 | Data Assessment Report approved | milestone | 0d | 2023-02-28 A | 2023-02-28 A | 1858FS+5d | 100% |  | 2023-02-28 | 2023-02-28 | 0d | 2023-02-28 | 2023-02-28 |  |  | John Wiggins; Matthew Breen |  |  | SI Migration | PP,IPA | 5.0 | Migration | Complete | COMPLETE | T3-MI-0012 | MCAG | T3 |  |  |
| 1860 | 1.8.1.5 | **Migration, Cutover & Data Strategy (incl. Migration Entry Criteria)** |  | 102d | 2022-12-08 A | 2023-04-28 A |  | 100% |  | 2022-12-08 | 2023-04-28 | 102d | 2022-12-08 | 2023-04-28 |  |  | N/A | 2336h | 2336h | N/A | N/A | 5.0 | Migration |  |  |  |  |  |  |  |
| 1861 | 1.8.1.5.1 | Develop document with MWG |  | 67d | 2022-12-08 A | 2023-03-10 A | 1824 | 100% |  | 2022-12-08 | 2023-03-10 | 67d | 2022-12-08 | 2023-03-10 |  |  | John Wiggins; Matthew Breen | 1072h | 1072h | SI Migration | PP | 5.0 | Migration | Complete | COMPLETE |  |  |  |  |  |
| 1862 | 1.8.1.5.2 | Artefact review (via TMAG) and updates |  | 28d | 2023-03-15 A | 2023-04-21 A | 1861FS+2d | 100% |  | 2023-03-15 | 2023-04-21 | 28d | 2023-03-15 | 2023-04-21 |  |  | John Wiggins; Matthew Breen | 448h | 448h | PP | SI Migration | 5.0 | Migration | Complete | COMPLETE |  |  |  |  |  |
| 1863 | 1.8.1.5.3 | Migration, Cutover & Data Strategy approved | milestone | 0d | 2023-04-28 A | 2023-04-28 A | 1862FF+5d | 100% |  | 2023-04-28 | 2023-04-28 | 0d | 2023-04-28 | 2023-04-28 |  |  | John Wiggins; Matthew Breen |  |  | SI Migration | PP | 5.0 | Migration | Complete | COMPLETE | T3-MI-0014 | MCAG | T3 |  |  |
| 1864 | 1.8.1.6 | **Data Cleanse Plan** |  | 547d | 2023-03-02 A | 2025-04-04 |  | 61% | 210.62d | 2023-03-02 | 2025-04-04 | 547d | 2023-03-02 | 2025-04-04 | 560d |  | N/A | 15352h | 5266.67h | N/A | N/A | 5.0 | Migration |  |  |  |  |  |  |  |
| 1865 | 1.8.1.6.1 | Develop document with MWG |  | 50d | 2023-03-02 A | 2023-05-10 A |  | 100% |  | 2023-03-02 | 2023-05-10 | 50d | 2023-03-02 | 2023-05-10 |  |  | John Wiggins; Matthew Breen | 800h | 800h | SI Migration | PP | 5.0 | Migration | Complete | COMPLETE |  |  |  |  |  |
| 1866 | 1.8.1.6.2 | Artefact review (via TMAG) and updates |  | 20d | 2023-05-11 A | 2023-06-07 A | 1865 | 100% |  | 2023-05-11 | 2023-06-07 | 20d | 2023-05-11 | 2023-06-07 |  |  | John Wiggins; Matthew Breen | 320h | 320h | PP | SI Migration,IPA | 5.0 | Migration | Complete | COMPLETE |  |  |  |  |  |
| 1867 | 1.8.1.6.3 | Data Cleanse Plan approved | milestone | 0d | 2023-07-19 A | 2023-07-19 A | 1866FS+30d | 100% |  | 2023-07-19 | 2023-07-19 | 0d | 2023-06-14 | 2023-06-14 |  |  | John Wiggins; Matthew Breen |  |  | SI Migration | PP | 5.0 | Migration | Complete | COMPLETE | T3-MI-0020 | MCAG | T3 |  |  |
| 1868 | 1.8.1.6.4 | Monitor Programme Participant adherence to Data Cleanse Plan |  | 467d | 2023-06-15 A | 2025-03-28 | 1867 | 57% | 202d | 2023-06-15 | 2025-03-28 | 467d | 2023-06-15 | 2025-03-28 | 560d | 0d | Matthew Breen | 3736h | 2120h | SI Migration | PP | 5.0 | Migration | Green | GREEN |  |  |  |  |  |
| 1869 | 1.8.1.6.5 | **MTDs** |  | 91d | 2024-08-16 | 2024-12-20 |  |  |  | 2024-08-16 | 2024-12-23 | 91d |  |  | 635d |  | N/A | 2200h |  | N/A | N/A | 5.4 | Migration |  |  |  |  |  |  |  |
| 1870 | 1.8.1.6.5.1 | **ESME ID** |  | 90d | 2024-08-16 | 2024-12-20 |  |  |  | 2024-08-16 | 2024-12-23 | 90d |  |  | 635d |  | N/A | 728h |  | N/A | N/A | 5.4 | Migration |  |  |  |  |  |  |  |
| 1871 | 1.8.1.6.5.1.1 | DCC to extract ESME ID and share with LDSO | milestone | 0d | 2024-08-16 | 2024-08-16 | 1867FS+282d |  |  | 2024-08-16 | 2024-08-16 | 0d |  |  | 635d | 0d | Matthew Breen |  |  | DCC/SI |  | 5.5 | Migration | Green | GREEN | T3-MI-0024 | MCAG | T3 | 27/7 - add in as T3 Milestone | 50.71 |
| 1872 | 1.8.1.6.5.1.2 | LDSO ‘full refresh’ between their Registration Service and the EES (ESME ID) | milestone | 0d | 2024-09-27 | 2024-09-27 | 1871FS+30d |  |  | 2024-09-27 | 2024-09-27 | 0d |  |  | 635d | 0d | Matthew Breen |  |  | LDSO/EES |  | 5.5 | Migration | Green | GREEN | T3-MI-0025 | MCAG | T3 | 27/7 - add in as T3 Milestone. Actual start is 29/9/24 | 92.71 |
| 1873 | 1.8.1.6.5.1.3 | Suppliers complete investigation of exceptions and resolution of exceptions |  | 1d | 2024-12-20 | 2024-12-20 | 1872FS+59d |  |  | 2024-12-20 | 2024-12-20 | 1d |  |  | 635d | 0d | Matthew Breen | 8h |  | Supplier |  | 5.4 | Migration | Green | GREEN |  |  |  |  | 176.33 |
| 1874 | 1.8.1.6.5.1.4 | ESME ID Complete | milestone | 0d | 2024-12-20 | 2024-12-20 | 1873 |  |  | 2024-12-23 | 2024-12-23 | 0d |  |  | 635d | 75d | Matthew Breen |  |  |  |  | 5.4 | Migration | Green | GREEN |  |  |  |  | 176.71 |
| 1875 | 1.8.1.6.5.2 | **Meter Location and Number of Displayed Register Digits** |  | 91d | 2024-08-16 | 2024-12-20 |  |  |  | 2024-08-16 | 2024-12-23 | 91d |  |  | 635d |  | N/A | 744h |  | N/A | N/A | 5.4 | Migration |  |  |  |  |  |  |  |
| 1876 | 1.8.1.6.5.2.1 | MEM to extract data and share with LDSO |  | 1d | 2024-08-16 | 2024-08-16 | 1867FS+281d |  |  | 2024-08-16 | 2024-08-16 | 1d |  |  | 635d | 0d | Matthew Breen | 8h |  | MEM/SI |  | 5.4 | Migration | Green | GREEN |  |  |  |  | 50.33 |
| 1877 | 1.8.1.6.5.2.2 | LDSO ‘full refresh’ between their Registration Service and the EES (Meter Location and Number of Displayed Register Digits) | milestone | 0d | 2024-09-27 | 2024-09-27 | 1876FS+30d |  |  | 2024-09-27 | 2024-09-27 | 0d |  |  | 635d | 0d | Matthew Breen |  |  | LDSO /EES |  | 5.5 | Migration | Green | GREEN | T3-MI-0026 | MCAG | T3 | 27/7 - add in as T3 Milestone | 92.71 |
| 1878 | 1.8.1.6.5.2.3 | Suppliers complete investigation of exceptions and resolution of exceptions |  | 1d | 2024-12-20 | 2024-12-20 | 1877FS+59d |  |  | 2024-12-20 | 2024-12-20 | 1d |  |  | 635d | 0d | Matthew Breen | 8h |  | Supplier |  | 5.4 | Migration | Green | GREEN |  |  |  |  | 176.33 |
| 1879 | 1.8.1.6.5.2.4 | Meter Location and Number of Displayed Register Digits Complete | milestone | 0d | 2024-12-20 | 2024-12-20 | 1878 |  |  | 2024-12-23 | 2024-12-23 | 0d |  |  | 635d | 75d | Matthew Breen |  |  |  |  | 5.4 | Migration | Green | GREEN |  |  |  |  | 176.71 |

Notes:
- 1869: 27/7 - CH added in with Matthew Breen
- 1870: 27/7 - CH added in with Matthew Breen
- 1871: 27/7 - CH added in with Matthew Breen
- 1872: 27/7 - CH added in with Matthew Breen
- 1873: 27/7 - CH added in with Matthew Breen
- 1874: 27/7 - CH added in with Matthew Breen
- 1875: 27/7 - CH added in with Matthew Breen
- 1876: 27/7 - CH added in with Matthew Breen
- 1877: 27/7 - CH added in with Matthew Breen
- 1878: 27/7 - CH added in with Matthew Breen
- 1879: 27/7 - CH added in with Matthew Breen

| ID | WBS | Task | Type | Duration | Start | Finish | Predecessors | Complete | Remaining | Baseline start | Baseline finish | Baseline duration | Baseline 1 start | Baseline 1 finish | Total slack | Free slack | Resources | Work | Actual work | Baseline cost | Responsible | Involved | Update Version | MHHS Programme Phase | Action | Task Status | Sched Status | RAG | Milestone ID | Text29 | Tier | Guidance |
| --- | --- | --- | --- | --- | --- | --- | --- | --- | --- | --- | --- | --- | --- | --- | --- | --- | --- | --- | --- | --- | --- | --- | --- | --- | --- | --- | --- | --- | --- | --- | --- | --- |
| 1880 | 1.8.1.6.6 | **Registration Data** |  | 147d | 2024-09-06 | 2025-03-31 |  |  |  | 2024-09-06 | 2025-03-31 | 147d |  |  | 564d |  | N/A | 1480h |  |  | N/A | N/A | 5.4 | Migration |  |  |  |  |  |  |  |  |
| 1881 | 1.8.1.6.6.1 | **Connection Type** |  | 16d | 2024-09-06 | 2024-09-27 |  |  |  | 2024-09-06 | 2024-09-27 | 16d |  |  | 695d |  | N/A | 144h |  |  | N/A | N/A | 5.4 | Migration |  |  |  |  |  |  |  |  |
| 1882 | 1.8.1.6.6.1.1 | Automated Population of Connection Type for Measurement Classes ‘B’, ‘D’, ‘F’ & ‘G’ | milestone | 0d | 2024-09-13 | 2024-09-13 | 1867FS+302d |  |  | 2024-09-13 | 2024-09-13 | 0d |  |  | 705d | 10d | Matthew Breen |  |  |  | LDSO |  | 5.5 | Migration | 27/7 - add in as T3 Milestone | 78.71 | Green | GREEN | T3-MI-0027 | MCAG | T3 |  |
| 1883 | 1.8.1.6.6.1.2 | BAU Population of Connection Type for Site Specific LLFCs within Measurement Classes ‘C’ & ‘E’ | milestone | 0d | 2024-09-13 | 2024-09-13 | 1867FS+302d |  |  | 2024-09-13 | 2024-09-13 | 0d |  |  | 705d | 10d | Matthew Breen |  |  |  | LDSO |  | 5.5 | Migration | 27/7 - add in as T3 Milestone | 78.71 | Green | GREEN | T3-MI-0028 | MCAG | T3 |  |
| 1884 | 1.8.1.6.6.1.3 | Automated Population of Connection Type for Smart Meters within Measurement Class ‘A’ | milestone | 0d | 2024-09-13 | 2024-09-13 | 1867FS+302d |  |  | 2024-09-13 | 2024-09-13 | 0d |  |  | 705d | 10d | Matthew Breen |  |  |  | LDSO |  | 5.5 | Migration | 27/7 - add in as T3 Milestone | 78.71 | Green | GREEN | T3-MI-0029 | MCAG | T3 |  |
| 1885 | 1.8.1.6.6.1.4 | Population of Connection Type for Traditional and Advanced Meters within Measurement Class ‘A’ |  | 1d | 2024-09-06 | 2024-09-06 | 1867FS+296d |  |  | 2024-09-06 | 2024-09-06 | 1d |  |  | 710d | 15d | Matthew Breen | 8h |  |  | Suppliers |  | 5.4 | Migration |  | 71.33 | Green | GREEN |  |  |  |  |
| 1886 | 1.8.1.6.6.1.5 | Automated Population of Null Connection Type | milestone | 0d | 2024-09-13 | 2024-09-13 | 1867FS+302d |  |  | 2024-09-13 | 2024-09-13 | 0d |  |  | 705d | 10d | Matthew Breen |  |  |  | LDSO |  | 5.5 | Migration | 27/7 - add in as T3 Milestone | 78.71 | Green | GREEN | T3-MI-0030 | MCAG | T3 |  |
| 1887 | 1.8.1.6.6.1.6 | Full MPAN refresh to ESS |  | 1d | 2024-09-27 | 2024-09-27 | 1867FS+311d |  |  | 2024-09-27 | 2024-09-27 | 1d |  |  | 695d | 0d | Matthew Breen | 8h |  |  | LDSO/EES |  | 5.4 | Migration |  | 92.33 | Green | GREEN |  |  |  | Actually takes place on 29/9/24 which is a Sunday |
| 1888 | 1.8.1.6.6.1.7 | Connection Type Complete | milestone | 0d | 2024-09-27 | 2024-09-27 | 1882, 1883, 1884, 1885, 1886, 1887 |  |  | 2024-09-27 | 2024-09-27 | 0d |  |  | 695d | 135d | Matthew Breen |  |  |  |  |  | 5.4 | Migration |  | 92.71 | Green | GREEN |  |  |  |  |
| 1889 | 1.8.1.6.6.2 | **Domestic Premises Indicator** |  | 17d | 2025-03-07 | 2025-03-31 |  |  |  | 2025-03-07 | 2025-03-31 | 17d |  |  | 564d |  | N/A | 160h |  |  | N/A | N/A | 5.4 | Migration |  |  |  |  |  |  |  |  |
| 1890 | 1.8.1.6.6.2.1 | The DCC to extract Domestic Premises Indicator from the CSS and provide a file to each LDSO and EES. |  | 1d | 2025-03-07 | 2025-03-07 | 1867FS+426d |  |  | 2025-03-07 | 2025-03-07 | 1d |  |  | 564d | 0d | Matthew Breen | 8h |  |  | DCC |  | 5.4 | Migration |  | 253.33 | Green | GREEN |  |  |  | 27/7 - needs to end on date of M10 7/3/25 |
| 1891 | 1.8.1.6.6.2.2 | Each LDSO notifies the DCC of any exceptions |  | 1d | 2025-03-07 | 2025-03-07 | 1867FS+426d |  |  | 2025-03-07 | 2025-03-07 | 1d |  |  | 564d | 0d | Matthew Breen | 8h |  |  | LDSO |  | 5.4 | Migration |  | 253.33 | Green | GREEN |  |  |  | 27/7 - needs to end on date of M10 7/3/25 |
| 1892 | 1.8.1.6.6.2.3 | Each LDSO and DCC completes investigation and resolution of exceptions |  | 1d | 2025-03-31 | 2025-03-31 | 1890FS+15d, 1891FS+15d |  |  | 2025-03-31 | 2025-03-31 | 1d |  |  | 564d | 0d | Matthew Breen | 8h |  |  | LDSO / DCC |  | 5.4 | Migration |  | 277.33 | Green | GREEN |  |  |  | 27/7 Needs to take place approx. 1 month after M10 |
| 1893 | 1.8.1.6.6.2.4 | Domestic Premises Indicator Complete | milestone | 0d | 2025-03-31 | 2025-03-31 | 1892 |  |  | 2025-03-31 | 2025-03-31 | 0d |  |  | 564d | 4d | Matthew Breen |  |  |  |  |  | 5.4 | Migration |  | 277.71 | Green | GREEN |  |  |  |  |
| 1894 | 1.8.1.6.7 | **Export / Import MPANs** |  | 151d | 2024-03-22 A | 2024-10-18 |  | 67% | 50.33d | 2024-03-22 | 2024-10-18 | 151d |  |  | 680d |  | N/A | 2440h | 1626.67h |  | N/A | N/A | 5.4 | Migration |  |  |  |  |  |  |  |  |
| 1895 | 1.8.1.6.7.1 | **Linking of Export / Import MPANS** |  | 151d | 2024-03-22 A | 2024-10-18 |  | 67% | 50.33d | 2024-03-22 | 2024-10-18 | 151d |  |  | 680d |  | N/A | 1232h | 821.33h |  | N/A | N/A | 5.4 | Migration |  |  |  |  |  |  |  |  |
| 1896 | 1.8.1.6.7.1.1 | LDSO utilises BAU processing (DB05s) to populate each import/export association |  | 1d | 2024-03-22 A | 2024-03-22 A | 1867FS+176d | 100% |  | 2024-03-22 | 2024-03-22 | 1d |  |  |  |  | Matthew Breen | 8h | 8h |  | LDSO |  | 5.4 | Migration |  |  | Complete | COMPLETE |  |  |  |  |
| 1897 | 1.8.1.6.7.1.2 | Each LDSO notifies the Registered Supplier of any exceptions |  | 1d | 2024-04-19 A | 2024-04-19 A | 1896FS+19d | 100% |  | 2024-04-19 | 2024-04-19 | 1d |  |  |  |  | Matthew Breen | 8h | 8h |  | LDSO |  | 5.4 | Migration |  |  | Complete | COMPLETE |  |  |  |  |
| 1898 | 1.8.1.6.7.1.3 | Each Supplier completes investigation and resolution of exceptions |  | 1d | 2024-08-23 | 2024-08-23 | 1897FS+89d |  |  | 2024-08-23 | 2024-08-23 | 1d |  |  | 680d | 0d | Matthew Breen | 8h |  |  | Supplier |  | 5.4 | Migration |  | 57.33 | Green | GREEN |  |  |  |  |
| 1899 | 1.8.1.6.7.1.4 | Each LDSO has linked al relevant import/export MPANS | milestone | 0d | 2024-10-18 | 2024-10-18 | 1898FS+40d |  |  | 2024-10-18 | 2024-10-18 | 0d |  |  | 680d | 0d | Matthew Breen |  |  |  | LDSO |  | 5.5 | Migration | 27/7 - add in as T3 Milestone | 113.71 | Green | GREEN | T3-MI-0031 | MCAG | T3 |  |
| 1900 | 1.8.1.6.7.1.5 | Linking of Export / Import MPANS Complete | milestone | 0d | 2024-10-18 | 2024-10-18 | 1899 |  |  | 2024-10-18 | 2024-10-18 | 0d |  |  | 680d | 120d | Matthew Breen |  |  |  |  |  | 5.4 | Migration |  | 113.71 | Green | GREEN |  |  |  |  |
| 1901 | 1.8.1.6.8 | Pre-migration data cleanse complete | milestone | 0d | 2025-04-04 | 2025-04-04 | 2025FS-20d, 2027FS-20d, 1868FS+5d, 1874, 1879, 1888, 1893, 1900 |  |  | 2025-04-04 | 2025-04-04 | 0d | 2025-04-04 | 2025-04-04 | 560d |  | Matthew Breen |  |  |  | SI Migration | PP | 5.0 | Migration |  | 281.71 | Green | GREEN | T2-MI-0450 | MCAG | T2 |  |
| 1902 | 1.8.2 | **Migration Period Planning** |  | 851d | 2023-07-03 A | 2026-10-05 |  | 18% | 700.22d | 2023-07-03 | 2026-10-05 | 851d | 2023-07-03 | 2026-10-05 | 169d |  | N/A | 38482.4h | 6217.72h | -0 | N/A | N/A | 5.0 | Migration |  | M10 |  |  |  |  |  |  |
| 1903 | 1.8.2.1 | **Migration Implementation Plan (incl. Migration Exit Criteria)** |  | 851d | 2023-07-03 A | 2026-10-05 |  | 24% | 647.82d | 2023-07-03 | 2026-10-05 | 851d | 2023-07-03 | 2026-10-05 | 169d |  | N/A | 25938.2h | 6217.72h | -0 | N/A | N/A | 5.0 | Migration |  |  |  |  |  |  |  |  |
| 1904 | 1.8.2.1.1 | **Migration Threshold Volumes** |  | 101d | 2023-07-03 A | 2023-11-20 A |  | 100% |  | 2023-07-03 | 2023-11-15 | 98d | 2023-07-03 | 2023-08-31 |  |  | N/A | 2424h | 2424h | -0 | N/A | N/A | 5.0 | Migration |  |  |  |  |  |  |  |  |
| 1905 | 1.8.2.1.1.1 | Threshold volumes reviewed by MWG |  | 54d | 2023-07-03 A | 2023-09-14 A |  | 100% |  | 2023-07-03 | 2023-09-14 | 54d | 2023-07-03 | 2023-07-28 |  |  | John Wiggins; Matthew Breen | 864h | 864h |  | SI Migration | PP | 5.6 | Migration |  |  | Complete | COMPLETE |  |  |  |  |
| 1906 | 1.8.2.1.1.2 | Artefact review (via TMAG) and updates |  | 47d | 2023-09-15 A | 2023-11-20 A | 1905 | 100% |  | 2023-09-15 | 2023-11-15 | 44d | 2023-07-31 | 2023-08-31 |  |  | John Wiggins; Matthew Breen | 752h | 752h |  | PP | SI Migration | 5.9 | Migration |  |  | Complete | COMPLETE |  |  |  |  |
| 1907 | 1.8.2.1.1.3 | Threshold volumes approved at TMAG | milestone | 0d | 2023-11-20 A | 2023-11-20 A | 1906 | 100% |  | 2023-11-15 | 2023-11-15 | 0d | 2023-08-31 | 2023-08-31 |  |  | John Wiggins; Matthew Breen |  |  |  | SI Migration | PP | 5.12 | Migration | 25/8 - Alex said update date to 31/8 |  | Complete | COMPLETE | T3-MI-0021 | SITAG | T3 |  |

Notes:
- 1880: 27/7 - CH added in with Matthew Breen
- 1881: 27/7 - CH added in with Matthew Breen
- 1882: 27/7 - CH added in with Matthew Breen
- 1883: 27/7 - CH added in with Matthew Breen
- 1884: 27/7 - CH added in with Matthew Breen
- 1885: 27/7 - CH added in with Matthew Breen
- 1886: 27/7 - CH added in with Matthew Breen
- 1887: 27/7 - CH added in with Matthew Breen
- 1888: 27/7 - CH added in with Matthew Breen
- 1889: 27/7 - CH added in with Matthew Breen
- 1890: 27/7 - CH added in with Matthew Breen
- 1891: 27/7 - CH added in with Matthew Breen
- 1892: 27/7 - CH added in with Matthew Breen
- 1893: 27/7 - CH added in with Matthew Breen
- 1894: 27/7 - CH added in with Matthew Breen
- 1895: 27/7 - CH added in with Matthew Breen
- 1896: 27/7 - CH added in with Matthew Breen
- 1897: 27/7 - CH added in with Matthew Breen
- 1898: 27/7 - CH added in with Matthew Breen
- 1899: 27/7 - CH added in with Matthew Breen
- 1900: 27/7 - CH added in with Matthew Breen
- 1906: 7/11 - Red because date of TMAG chnaged
- 1907: Red as plan was to approve at extraordinary TMAG on 8/11, however regular TMAG taking place on 15/11 so deferred approval to this date. To go to TMAG for date change. Approved for date change at TMAG on 23/10/23. 7/11 - Red because date of TMAG changed

| ID | WBS | Task | Type | Duration | Start | Finish | Predecessors | Complete | Remaining | Baseline start | Baseline finish | Baseline duration | Baseline 1 start | Baseline 1 finish | Total slack | Free slack | Constraint | Resources | Work | Actual work | Baseline cost | Responsible | Involved | Update Version | MHHS Programme Phase | Task Status | Sched Status | RAG | Milestone ID | Text29 | Tier |
| --- | --- | --- | --- | --- | --- | --- | --- | --- | --- | --- | --- | --- | --- | --- | --- | --- | --- | --- | --- | --- | --- | --- | --- | --- | --- | --- | --- | --- | --- | --- | --- |
| 1908 | 1.8.2.1.2 | **Operational Migration Planning** |  | 526d | 2024-09-30 | 2026-10-05 |  |  |  | 2024-09-30 | 2026-10-05 | 526d | 2024-09-30 | 2026-10-05 | 169d |  |  | N/A | 10576h |  |  | N/A | N/A | 5.0 | Migration |  |  |  |  |  |  |
| 1909 | 1.8.2.1.2.1 | Agree migration plans for each SIT MVC Supplier |  | 55d | 2024-09-30 | 2024-12-16 | 2021SF-3mo |  |  | 2024-09-30 | 2024-12-16 | 55d | 2024-09-30 | 2024-12-16 | 605d | 0d |  | Warren Fulton | 440h |  |  | SRO | PP | 5.0 | Migration | 95.33 | Green | GREEN |  |  |  |
| 1910 | 1.8.2.1.2.2 | Initial migration plan agreed at SITAG |  | 35d | 2024-12-16 | 2025-01-31 | 1909 |  |  | 2024-12-16 | 2025-01-31 | 35d | 2024-12-16 | 2025-01-31 | 605d | 0d |  | Warren Fulton | 280h |  |  | SRO |  | 5.0 | Migration | 172.33 | Green | GREEN |  |  |  |
| 1911 | 1.8.2.1.2.3 | Migration Period Plan Review 1 Completed | milestone | 0d | 2025-01-31 | 2025-01-31 | 1910 |  |  | 2025-01-31 | 2025-01-31 | 0d | 2025-01-31 | 2025-01-31 | 605d |  |  | Warren Fulton |  |  |  | SRO | PP,IPA | 5.0 | Migration | 218.71 | Green | GREEN | T3-MI-0016 | MCAG | T3 |
| 1912 | 1.8.2.1.2.4 | Finalise initial live plan |  | 1d | 2025-04-07 | 2025-04-07 | 2025 |  |  | 2025-04-07 | 2025-04-07 | 1d | 2025-04-07 | 2025-04-07 | 559d |  |  | Warren Fulton | 8h |  |  | SRO |  | 5.0 | Migration | 284.33 | Green | GREEN |  |  |  |
| 1913 | 1.8.2.1.2.5 | Agree migration plans with suppliers aligned with qualification tranches |  | 314d | 2024-12-30 | 2026-03-12 | 2029FF |  |  | 2025-01-01 | 2026-03-16 | 314d | 2025-01-01 | 2026-03-16 | 316d |  |  | Warren Fulton | 2512h |  |  | SRO | PP | 5.0 | Migration | 186.33 | Green | GREEN |  |  |  |
| 1914 | 1.8.2.1.2.6 | Migration control centre undertakes iterative planning and performance monitoring |  | 391d | 2025-04-07 | 2026-10-05 | 2025 |  |  | 2025-04-07 | 2026-10-05 | 391d | 2025-04-07 | 2026-10-05 | 169d |  |  | Warren Fulton | 3128h |  |  | SRO |  | 5.0 | Migration | 284.33 | Green | GREEN |  |  |  |
| 1915 | 1.8.2.1.3 | **Define acceptance criteria for M15** |  | 78d | 2023-09-04 A | 2023-12-20 A |  | 100% |  | 2023-09-04 | 2023-12-20 | 78d | 2023-09-04 | 2023-11-30 |  |  |  | N/A | 1872h | 1872h | -0 | N/A | N/A | 5.0 | Migration |  |  |  |  |  |  |
| 1916 | 1.8.2.1.3.1 | Review acceptance criteria and reporting requirements with MWG |  | 49d | 2023-09-04 A | 2023-11-09 A |  | 100% |  | 2023-09-04 | 2023-10-27 | 40d | 2023-09-04 | 2023-10-27 |  |  | start no earlier than 2023-09-04 | John Wiggins; Matthew Breen | 784h | 784h |  | SI Migration |  | 5.0 | Migration |  | Complete | COMPLETE |  |  |  |
| 1917 | 1.8.2.1.3.2 | Artefact review (via TMAG) and updates |  | 29d | 2023-11-10 A | 2023-12-20 A | 1916 | 100% |  | 2023-11-10 | 2023-12-20 | 29d | 2023-10-30 | 2023-11-30 |  |  | start no earlier than 2023-10-30 | John Wiggins; Matthew Breen | 464h | 464h |  | PP | SI Migration | 5.0 | Migration |  | Complete | COMPLETE |  |  |  |
| 1918 | 1.8.2.1.3.3 | Acceptance criteria for M15 agreed at TMAG | milestone | 0d | 2023-12-20 A | 2023-12-20 A | 1917 | 100% |  | 2023-12-20 | 2023-12-20 | 0d | 2023-11-30 | 2023-11-30 |  |  | finish no earlier than 2023-11-30 | John Wiggins; Matthew Breen |  |  |  | SI Migration |  | 5.14 | Migration |  | Complete | COMPLETE | T3-MI-0022 | SITAG | T3 |
| 1919 | 1.8.2.1.4 | **M10/M11 cut-over plan** |  | 119d | 2023-12-21 A | 2024-06-04 |  | 99% | 0d | 2023-12-21 | 2024-06-04 | 119d | 2024-01-01 | 2024-05-31 | 0d |  |  | N/A | 1728h | 1640.99h | -0 | N/A | N/A | 5.16 | Migration |  |  |  |  |  |  |
| 1920 | 1.8.2.1.4.1 | Draft Document |  | 84d | 2023-12-21 A | 2024-04-16 A | 1918 | 100% |  | 2023-12-21 | 2024-04-16 | 84d |  |  |  |  |  | Matthew Breen | 672h | 672h |  | SI Transition | SI Transition,PP,SRO | 5.16 | Migration |  | Complete | COMPLETE |  |  |  |
| 1921 | 1.8.2.1.4.2 | Share Document with SRO |  | 1d | 2024-04-17 A | 2024-04-17 A | 1920 | 100% |  | 2024-04-17 | 2024-04-17 | 1d |  |  |  |  |  | Matthew Breen | 8h | 8h |  | SI Transition | SI Transition,PP,SRO | 5.16 | Migration |  | Complete | COMPLETE |  |  |  |
| 1922 | 1.8.2.1.4.3 | Industry Consultation |  | 11d | 2024-04-23 A | 2024-05-07 A | 1921FS+3d | 100% |  | 2024-04-23 | 2024-05-07 | 11d |  |  |  |  |  | Matthew Breen | 88h | 88h |  | SI Transition | SI Transition,PP,SRO | 5.16 | Migration |  | Complete | COMPLETE |  |  |  |
| 1923 | 1.8.2.1.4.4 | Assurance Meeting |  | 1d | 2024-05-21 A | 2024-05-21 A | 1922FS+9d | 100% |  | 2024-05-14 | 2024-05-14 | 1d |  |  |  |  |  | Matthew Breen | 8h | 8h |  | SI Transition | SI Transition,PP,SRO | 5.16 | Migration |  | Complete | COMPLETE |  |  |  |
| 1924 | 1.8.2.1.4.5 | MCAG Approval of M10/M11 Cut-over Plan | milestone | 0d | 2024-06-04 A | 2024-06-04 A | 1923FS+10d | 100% |  | 2024-06-04 | 2024-06-04 | 0d | 2024-05-31 | 2024-05-31 |  |  |  | Matthew Breen |  |  |  | SI Transition | SI Transition,PP,SRO | 5.26 | Migration |  | Complete | COMPLETE | T3-MI-0023 | MCAG | T3 |
| 1925 | 1.8.2.1.5 | **M15/M16 cut-over plan** |  | 105d | 2024-06-05 A | 2024-10-29 |  | 18% | 85.91d | 2024-06-05 | 2024-10-29 | 105d | 2024-01-01 | 2024-05-31 | 504d |  |  | N/A | 1544h | 280.73h | -0 | N/A | N/A | 5.16 | Migration |  |  |  |  |  |  |
| 1926 | 1.8.2.1.5.1 | Draft Document |  | 75d | 2024-06-05 A | 2024-09-17 | 1924 | 21% | 59d | 2024-06-05 | 2024-09-17 | 75d |  |  | 504d | 0d |  | Matthew Breen | 600h | 128h |  | SI Transition | SI Transition,PP,SRO | 5.26 | Migration |  | Green | GREEN |  |  |  |
| 1927 | 1.8.2.1.5.2 | Share Document with SRO |  | 1d | 2024-09-18 | 2024-09-18 | 1926 |  |  | 2024-09-18 | 2024-09-18 | 1d |  |  | 504d | 0d |  | Matthew Breen | 8h |  |  | SI Transition | SI Transition,PP,SRO | 5.26 | Migration | 83.33 | Green | GREEN |  |  |  |
| 1928 | 1.8.2.1.5.3 | Industry Consultation |  | 11d | 2024-09-24 | 2024-10-08 | 1927FS+3d |  |  | 2024-09-24 | 2024-10-08 | 11d |  |  | 504d | 0d |  | Matthew Breen | 88h |  |  | SI Transition | SI Transition,PP,SRO | 5.26 | Migration | 89.33 | Green | GREEN |  |  |  |
| 1929 | 1.8.2.1.5.4 | Assurance Meeting |  | 1d | 2024-10-22 | 2024-10-22 | 1928FS+9d |  |  | 2024-10-22 | 2024-10-22 | 1d |  |  | 504d | 0d |  | Matthew Breen | 8h |  |  | SI Transition | SI Transition,PP,SRO | 5.26 | Migration | 117.33 | Green | GREEN |  |  |  |
| 1930 | 1.8.2.1.5.5 | Approval of M15/M16 cut-over plan | milestone | 0d | 2024-10-29 | 2024-10-29 | 1929FS+5d |  |  | 2024-10-29 | 2024-10-29 | 0d | 2024-05-31 | 2024-05-31 | 504d | 503d |  | Matthew Breen |  |  |  | SI Transition | SI Transition,PP,SRO | 5.26 | Migration | 124.71 | Green | GREEN | T3-MI-0032 | MCAG | T3 |
| 1931 | 1.8.2.1.6 | **M16 Methodology** |  | 85d | 2024-07-31 | 2024-11-26 |  |  |  | 2024-07-31 | 2024-11-26 | 85d | 2023-10-02 | 2024-04-26 | 529d |  |  | N/A | 1024h |  | -0 | N/A | N/A | 5.0 | Migration |  |  |  |  |  |  |
| 1932 | 1.8.2.1.6.1 | Draft Document |  | 50d | 2024-07-31 | 2024-10-08 | 1926SS+40d |  |  | 2024-07-31 | 2024-10-08 | 50d | 2023-10-02 | 2023-12-29 | 529d | 0d |  | Matthew Breen | 400h |  |  | SI Transition | SI Transition,PP,SRO | 5.26 | Migration | 34.33 | Green | GREEN |  |  |  |
| 1933 | 1.8.2.1.6.2 | Share Document with SRO |  | 1d | 2024-10-09 | 2024-10-09 | 1932 |  |  | 2024-10-09 | 2024-10-09 | 1d | 2024-01-01 | 2024-01-26 | 529d | 0d |  | Matthew Breen | 8h |  |  | SI Transition | SI Transition,PP,SRO | 5.26 | Migration | 104.33 | Green | GREEN |  |  |  |
| 1934 | 1.8.2.1.6.3 | Industry Consultation |  | 11d | 2024-10-15 | 2024-10-29 | 1933FS+3d |  |  | 2024-10-15 | 2024-10-29 | 11d | 2024-01-29 | 2024-03-29 | 529d | 0d |  | Matthew Breen | 88h |  |  | SI Transition | SI Transition,PP,SRO | 5.26 | Migration | 110.33 | Green | GREEN |  |  |  |
| 1935 | 1.8.2.1.6.4 | Assurance Meeting |  | 1d | 2024-11-12 | 2024-11-12 | 1934FS+9d |  |  | 2024-11-12 | 2024-11-12 | 1d | 2024-04-01 | 2024-04-26 | 529d | 0d |  | Matthew Breen | 8h |  |  | SI Transition | SI Transition,PP,SRO | 5.26 | Migration | 138.33 | Green | GREEN |  |  |  |
| 1936 | 1.8.2.1.6.5 | M16 methodology approved | milestone | 0d | 2024-11-26 | 2024-11-26 | 1935FS+10d |  |  | 2024-11-26 | 2024-11-26 | 0d | 2024-04-26 | 2024-04-26 | 529d |  |  | Matthew Breen |  |  |  | SI Transition | SI Transition,PP,SRO | 5.26 | Migration | 152.71 | Green | GREEN | T3-MI-0500 | MCAG | T2 |

Notes:
- 1918: 17/10 - Red because initial date was not aligned to a TMAG. On track to delivery by 20/12. To go to 20/11/23 TMAG for approval to change date. 20/11 - Date rebaselined. 20/12 - Approved at TMAG on 20/12
- 1924: 27/2 - Approved at MCAG on 27/2/24. 30/4: To go to 8th Red MCAG for rebaselining because MCAG is being rescheduled. 8/5 - Approved date change at MCAG on 8/5/24
- 1930: 28/5 - Date change due to re-planning following other transition activities. 4/6: Baseline date change from 24/9/24 to 29/10/24 approved at mcag on 4/6/24
- 1936: 28/5 - Date change due to re-planning following other transition activities. 4/6: Baseline date change from 24/9/24 to 29/10/24 approved at mcag on 4/6/24

| ID | WBS | Task | Type | Duration | Start | Finish | Predecessors | Baseline start | Baseline finish | Baseline duration | Baseline 1 start | Baseline 1 finish | Total slack | Free slack | Constraint | Resources | Work | Baseline cost | Responsible | Involved | Update Version | MHHS Programme Phase | Action | Task Status | Sched Status | RAG | Milestone ID | Text29 | Tier |
| --- | --- | --- | --- | --- | --- | --- | --- | --- | --- | --- | --- | --- | --- | --- | --- | --- | --- | --- | --- | --- | --- | --- | --- | --- | --- | --- | --- | --- | --- |
| 1937 | 1.8.2.2 | **Migration Processes, Procedures and Tools** |  | 300d | 2024-01-01 | 2025-02-21 |  | 2024-01-01 | 2025-02-21 | 300d | 2024-01-01 | 2025-02-21 | 0d |  |  | N/A | 5800h |  | N/A | N/A | 5.0 | Migration |  |  |  |  |  |  |  |
| 1938 | 1.8.2.2.1 | Design Migration control centre processes and procedures |  | 130d | 2024-01-01 | 2024-06-28 | 1907 | 2024-01-01 | 2024-06-28 | 130d | 2024-01-01 | 2024-06-28 | 0d |  | must start on 2024-01-01 | Warren Fulton | 1040h |  | SRO |  | 5.0 | Migration | 23/4: Simon is working on this currently | -177.67 | Overdue Start | GREEN |  |  |  |
| 1939 | 1.8.2.2.2 | Develop migration planning and management tool requirements |  | 130d | 2024-01-01 | 2024-06-28 | 1907 | 2024-01-01 | 2024-06-28 | 130d | 2024-01-01 | 2024-06-28 | 0d |  | must start on 2024-01-01 | Warren Fulton | 1040h |  | SRO |  | 5.0 | Migration | 23/4: Simon is working on this currently | -177.67 | Overdue Start | GREEN |  |  |  |
| 1940 | 1.8.2.2.3 | SITAG approval of migration processes, procedures and tools |  | 20d | 2024-07-01 | 2024-07-26 | 1938 | 2024-07-01 | 2024-07-26 | 20d | 2024-07-01 | 2024-07-26 | 0d |  |  | Warren Fulton | 160h |  | SRO |  | 5.0 | Migration |  | 4.33 | Green | GREEN |  |  |  |
| 1941 | 1.8.2.2.4 | Migration Processes & Procedures approved | milestone | 0d | 2024-08-02 | 2024-08-02 | 1940FF+5d | 2024-08-02 | 2024-08-02 | 0d | 2024-08-02 | 2024-08-02 | 0d |  |  | Warren Fulton |  |  | SRO | PP,IPA | 5.0 | Migration |  | 36.71 | Green | GREEN | T3-MI-0017 | MCAG | T3 |
| 1942 | 1.8.2.2.5 | Build and test migration tool |  | 105d | 2024-08-05 | 2024-12-27 | 1941 | 2024-08-05 | 2024-12-27 | 105d | 2024-08-05 | 2024-12-27 | 0d |  |  | Warren Fulton | 840h |  | SRO |  | 5.0 | Migration |  | 39.33 | Green | GREEN |  |  |  |
| 1943 | 1.8.2.2.6 | Deploy migration tool |  | 20d | 2024-12-30 | 2025-01-24 | 1942 | 2024-12-30 | 2025-01-24 | 20d | 2024-12-30 | 2025-01-24 | 0d |  |  | Warren Fulton | 160h |  | SRO |  | 5.0 | Migration |  | 186.33 | Green | GREEN |  |  |  |
| 1944 | 1.8.2.2.7 | Operationalisation of migration control centre | manual | 20d | 2025-01-27 | 2025-02-21 | 1943 | 2025-01-27 | 2025-02-21 | 20d | 2025-01-27 | 2025-02-21 |  |  |  | Warren Fulton | 160h |  | SRO |  | 5.0 | Migration |  | 214.33 | Green | GREEN |  |  |  |
| 1945 | 1.8.3 | **Go-Live Dress Rehearsals** | inactive | 114d | 2024-09-30 | 2025-03-06 |  | 2024-10-04 | 2025-03-06 | 110d | 2024-10-04 | 2025-03-06 | 581d |  |  | N/A | 1224h |  | N/A | N/A | 5.24 | Migration |  |  |  |  |  |  |  |
| 1946 | 1.8.3.1 | Define dress rehearsal scenarios (incl. engagement with MWG) | inactive | 20d | 2024-09-30 | 2024-10-25 | 2025FS-135d, 2027FS-135d | 2024-10-04 | 2024-10-31 | 20d | 2024-10-04 | 2024-10-31 | 675d |  |  | Matthew Breen | 160h |  | SI Migration | PP | 5.24 | Migration |  | 95.33 |  | GREEN |  |  |  |
| 1947 | 1.8.3.2 | Set up, coordinate and conduct dress rehearsals | inactive | 9d | 2025-02-10 | 2025-02-20 | 1073 | 2025-02-07 | 2025-02-20 | 10d | 2025-02-07 | 2025-02-20 | 581d | 0d |  | Matthew Breen | 72h |  | SI Migration | PP | 5.24 | Migration |  | 228.33 |  | GREEN |  |  |  |
| 1948 | 1.8.3.3 | Evaluate dress rehearsals and identify lessons learned | inactive | 10d | 2025-02-21 | 2025-03-06 | 1947 | 2025-02-21 | 2025-03-06 | 10d | 2025-02-21 | 2025-03-06 | 581d |  |  | Matthew Breen | 80h |  | SI Migration | PP | 5.24 | Migration |  | 239.33 |  | GREEN |  |  |  |
| 1949 | 1.8.4 | **Preparation for Cutover to Live** |  | 201d | 2024-06-28 | 2025-04-04 |  | 2024-06-28 | 2025-04-04 | 201d | 2025-02-07 | 2025-04-04 | 0d |  |  | N/A | 3400h | -0 | N/A | N/A | 5.27 | Migration |  |  |  |  |  |  |  |
| 1950 | 1.8.4.1 | **Central Systems Prepare for Cutover to Live** |  | 186d | 2024-06-28 | 2025-03-14 |  | 2024-06-28 | 2025-03-14 | 186d | 2025-02-07 | 2025-03-07 | 11d |  |  | N/A | 1488h |  | N/A | N/A | 5.27 | Migration |  | M13 |  |  |  |  |  |
| 1951 | 1.8.4.1.1 | DCC (Functionality available June 2024) | milestone | 0d | 2024-06-28 | 2024-06-28 |  | 2024-06-28 | 2024-06-28 | 0d |  |  | 181d |  | start no earlier than 2024-06-28 | Matthew Breen |  |  |  |  | 5.27 |  |  | 1.33 | Green | GREEN |  |  |  |
| 1952 | 1.8.4.1.2 | Production DIP Portal (DIP Deployment) | milestone | 0d | 2025-02-20 | 2025-02-20 | 1073FS+9d | 2025-02-20 | 2025-02-20 | 0d |  |  | 11d |  |  | Matthew Breen |  |  |  |  | 5.27 |  |  | 238.71 | Green | GREEN |  |  |  |
| 1953 | 1.8.4.1.3 | Production Certificates (DIP Deployment) | milestone | 0d | 2025-02-20 | 2025-02-20 | 1073FS+9d | 2025-02-20 | 2025-02-20 | 0d |  |  | 11d |  |  | Matthew Breen |  |  |  |  | 5.27 |  |  | 238.71 | Green | GREEN |  |  |  |
| 1954 | 1.8.4.1.4 | Completion of the MHHS Data Cleanse | milestone | 0d | 2025-02-26 | 2025-02-26 | 1867FS+420d | 2025-02-26 | 2025-02-26 | 0d |  |  | 5d | 0d |  | Matthew Breen |  |  |  |  | 5.27 |  |  | 244.71 | Green | GREEN |  |  |  |
| 1955 | 1.8.4.1.5 | Market-wide Participant MHHS Supporting Functionality Ready - Confirmation from Code Bodies | milestone | 0d | 2025-03-03 | 2025-03-03 | 1834FS+501d | 2025-03-03 | 2025-03-03 | 0d |  |  | 0d |  |  | Matthew Breen |  |  |  |  | 5.27 |  |  | 249.71 | Green | GREEN |  |  |  |
| 1956 | 1.8.4.1.6 | Market-wide Participant MHHS Supporting Functionality Ready | milestone | 0d | 2025-03-07 | 2025-03-07 | 1955FS+4d | 2025-03-07 | 2025-03-07 | 0d |  |  | 0d |  |  | Matthew Breen |  |  |  |  | 5.27 |  |  | 253.71 | Green | GREEN |  |  |  |
| 1957 | 1.8.4.1.7 | Elexon Central Services Deployment | milestone | 0d | 2025-03-07 | 2025-03-07 | 1976 | 2025-03-07 | 2025-03-07 | 0d |  |  | 0d |  |  | Matthew Breen |  |  |  |  | 5.27 |  |  | 253.71 | Green | GREEN |  |  |  |
| 1958 | 1.8.4.1.8 | Service Management Go-Live | milestone | 0d | 2025-03-07 | 2025-03-07 | 1976 | 2025-03-07 | 2025-03-07 | 0d |  |  | 0d |  |  | Matthew Breen |  |  |  |  | 5.27 |  |  | 253.71 | Green | GREEN |  |  |  |
| 1959 | 1.8.4.1.9 | Data Transfer Service (DTS) New Functionality Deployment | milestone | 0d | 2025-03-07 | 2025-03-07 | 1976 | 2025-03-07 | 2025-03-07 | 0d |  |  | 0d |  |  | Matthew Breen |  |  |  |  | 5.27 |  |  | 253.71 | Green | GREEN |  |  |  |
| 1960 | 1.8.4.1.10 | Electricity Enquiry Service (EES) Deployment | milestone | 0d | 2025-03-07 | 2025-03-07 | 1976 | 2025-03-07 | 2025-03-07 | 0d |  |  | 0d |  |  | Matthew Breen |  |  |  |  | 5.27 |  |  | 253.71 | Green | GREEN |  |  |  |
| 1961 | 1.8.4.1.11 | MPRS, UMSO Role, LDSO Role Operational | milestone | 0d | 2025-03-07 | 2025-03-07 | 1976 | 2025-03-07 | 2025-03-07 | 0d |  |  | 0d |  |  | Matthew Breen |  |  |  |  | 5.27 |  |  | 253.71 | Green | GREEN |  |  |  |
| 1962 | 1.8.4.1.12 | Population of Domestic Premises Indicator | milestone | 0d | 2025-03-07 | 2025-03-07 | 1976 | 2025-03-07 | 2025-03-07 | 0d |  |  | 0d |  |  | Matthew Breen |  |  |  |  | 5.27 |  |  | 253.71 | Green | GREEN |  |  |  |
| 1963 | 1.8.4.1.13 | Population of Market Segment | milestone | 0d | 2025-03-07 | 2025-03-07 | 1976 | 2025-03-07 | 2025-03-07 | 0d |  |  | 0d |  |  | Matthew Breen |  |  |  |  | 5.27 |  |  | 253.71 | Green | GREEN |  |  |  |
| 1964 | 1.8.4.1.14 | Early Life Support Implemented | milestone | 0d | 2025-03-07 | 2025-03-07 | 2044FS+158d | 2025-03-07 | 2025-03-07 | 0d |  |  | 0d |  |  | Matthew Breen |  |  |  |  | 5.27 |  |  | 253.71 | Green | GREEN |  |  |  |
| 1965 | 1.8.4.1.15 | MCC Tested and Ready to Operate | milestone | 0d | 2025-03-07 | 2025-03-07 | 1944FS+10d | 2025-03-07 | 2025-03-07 | 0d |  |  | 0d |  |  | Matthew Breen |  |  |  |  | 5.27 |  |  | 253.71 | Green | GREEN |  |  |  |
| 1966 | 1.8.4.1.16 | MCC Operational | milestone | 0d | 2025-03-07 | 2025-03-07 | 1965 | 2025-03-07 | 2025-03-07 | 0d |  |  | 0d |  |  | Matthew Breen |  |  |  |  | 5.27 |  |  | 253.71 | Green | GREEN |  |  |  |
| 1967 | 1.8.4.1.4 | Central Systems live and Codes designated at 00:00 | milestone | 0d | 2025-03-07 | 2025-03-07 | 1956, 1957, 1958, 1959, 1960, 1961, 1962, 1963, 1951 | 2025-03-07 | 2025-03-07 | 0d |  |  | 0d |  |  | Matthew Breen |  |  |  |  | 5.27 |  |  | 253.71 | Green | GREEN | T3-MI-0034 | MCAG |  |
| 1968 | 1.8.4.1.18 | SIT Participant Qualification - The final date by which participant qualification status can be confirmed for participants to be ready for the start of Migration at M11. | milestone | 0d | 2025-03-14 | 2025-03-14 | 1073FS+25d | 2025-03-14 | 2025-03-14 | 0d |  |  | 11d |  |  | Matthew Breen |  |  |  |  | 5.27 |  |  | 260.71 | Green | GREEN |  |  |  |

Notes:
- 1945: Activity no longer needed to be superceeded by activivity in the cutover plan
- 1967: 18/6: New T3 milestone agreed at MCAG on 4/6/24

| ID | WBS | Task | Type | Duration | Start | Finish | Predecessors | Baseline start | Baseline finish | Baseline duration | Total slack | Free slack | Resources | Work | Baseline cost | Task Status | Update Version | Sched Status | RAG | Milestone ID | Text29 | Responsible | Involved |
| --- | --- | --- | --- | --- | --- | --- | --- | --- | --- | --- | --- | --- | --- | --- | --- | --- | --- | --- | --- | --- | --- | --- | --- |
| 1969 | 1.8.4.2 | **Cutover Governance** |  | 27d | 2025-02-26 | 2025-04-04 |  | 2025-02-26 | 2025-04-04 | 27d | 0d |  | N/A | 304h |  | -595.67 | 5.27 |  |  |  |  |  |  |
| 1970 | 1.8.4.2.1 | Confirmation that Pre-migration Data Cleanse Activities have successfully taken place | milestone | 0d | 2025-02-26 | 2025-02-26 | 1954 | 2025-02-26 | 2025-02-26 | 0d | 5d |  | Matthew Breen |  |  | 244.71 | 5.27 | Green | GREEN |  |  |  |  |
| 1971 | 1.8.4.2.2 | Confirmation of Qualification Status for SIT MVC | milestone | 0d | 2025-03-03 | 2025-03-03 | 1073FS+16d | 2025-03-03 | 2025-03-03 | 0d | 0d |  | Matthew Breen |  |  | 249.71 | 5.27 | Green | GREEN |  |  |  |  |
| 1972 | 1.8.4.2.3 | Confirmation of Qualification Status for Non-SIT LDSOs | milestone | 0d | 2025-03-03 | 2025-03-03 | 1306FS+6d | 2025-03-03 | 2025-03-03 | 0d | 0d |  | Matthew Breen |  |  | 249.71 | 5.27 | Green | GREEN |  |  |  |  |
| 1973 | 1.8.4.2.4 | Confirmation of Qualification Status of at least one Supplier and their contracted Agents | milestone | 0d | 2025-03-03 | 2025-03-03 | 1971 | 2025-03-03 | 2025-03-03 | 0d | 0d |  | Matthew Breen |  |  | 249.71 | 5.27 | Green | GREEN |  |  |  |  |
| 1974 | 1.8.4.2.5 | Declaration from all Central Services and LDSOs that they are in a position to move forwards | milestone | 0d | 2025-03-03 | 2025-03-03 | 1073, 1306FS+6d | 2025-03-03 | 2025-03-03 | 0d | 2d |  | Matthew Breen |  |  | 249.71 | 5.27 | Green | GREEN |  |  |  |  |
| 1975 | 1.8.4.2.6 | TORWG (Recommendation from TORWG that the Programme should enter M10) | milestone | 0d | 2025-03-05 | 2025-03-05 | 1970, 1971FS+2d, 1972FS+2d, 1973FS+2d, 1974 | 2025-03-05 | 2025-03-05 | 0d | 0d |  | Matthew Breen |  |  | 251.71 | 5.27 | Green | GREEN |  |  |  |  |
| 1976 | 1.8.4.1.4 | MCAG (Confirm that the Programme can Enter M10) | milestone | 0d | 2025-03-07 | 2025-03-07 | 1952, 1953, 1975FS+2d | 2025-03-07 | 2025-03-07 | 0d | 0d |  | Matthew Breen |  |  | 253.71 | 5.27 | Green | GREEN | T3-MI-0035 | MCAG |  |  |
| 1977 | 1.8.4.2.8 | Self-Declaration from all Central Services and LDSOs that Cutover activities have been successfully carried out | milestone | 0d | 2025-03-10 | 2025-03-10 | 1976FS+1d | 2025-03-10 | 2025-03-10 | 0d | 0d |  | Matthew Breen |  |  | 256.71 | 5.27 | Green | GREEN |  |  |  |  |
| 1978 | 1.8.4.2.9 | Confirmation that DIP and ECS have been deployed, Service management is active, ISD has been populated | milestone | 0d | 2025-03-10 | 2025-03-10 | 1976FS+1d | 2025-03-10 | 2025-03-10 | 0d | 0d |  | Matthew Breen |  |  | 256.71 | 5.27 | Green | GREEN |  |  |  |  |
| 1979 | 1.8.4.2.10 | Self-Declarations against all M10 Data Cleanse Activities | milestone | 0d | 2025-03-10 | 2025-03-10 | 1976FS+1d | 2025-03-10 | 2025-03-10 | 0d | 0d |  | Matthew Breen |  |  | 256.71 | 5.27 | Green | GREEN |  |  |  |  |
| 1980 | 1.8.4.2.11 | IF-047 has been sent | milestone | 0d | 2025-03-10 | 2025-03-10 | 1976FS+1d | 2025-03-10 | 2025-03-10 | 0d | 0d |  | Matthew Breen |  |  | 256.71 | 5.27 | Green | GREEN |  |  |  |  |
| 1981 | 1.8.4.2.12 | Recommendation from TORWG that PSG should approve M10 | milestone | 0d | 2025-03-11 | 2025-03-11 | 1977FS+1d, 1978FS+1d, 1979FS+1d, 1980FS+1d | 2025-03-11 | 2025-03-11 | 0d | 0d |  | Matthew Breen |  |  | 257.71 | 5.27 | Green | GREEN |  |  |  |  |
| 1982 | 1.8.4.2.13 | PSG (OFGEM and PSG to Approve That Conditions of M10 and M13 Have Been Met) | milestone | 0d | 2025-03-12 | 2025-03-12 | 1981FS+1d | 2025-03-12 | 2025-03-12 | 0d | 0d |  | Matthew Breen |  |  | 258.71 | 5.27 | Green | GREEN |  |  |  |  |
| 1983 | 1.8.4.2.14 | Confirmation of Qualified Parties from Code Bodies |  | 11d | 2025-03-14 | 2025-03-28 | 1982FS+1d | 2025-03-14 | 2025-03-28 | 11d | 0d |  | Matthew Breen | 88h |  | 260.33 | 5.27 | Green | GREEN |  |  |  |  |
| 1984 | 1.8.4.2.15 | Self-Declaration that MHHS Functionality will be deployed to Production by Qualified parties | milestone | 0d | 2025-03-28 | 2025-03-28 | 1982FS+12d | 2025-03-28 | 2025-03-28 | 0d | 0d |  | Matthew Breen |  |  | 274.71 | 5.27 | Green | GREEN |  |  |  |  |
| 1985 | 1.8.4.2.16 | Production Service Activation Activities have taken place | milestone | 0d | 2025-03-28 | 2025-03-28 | 1982FS+12d | 2025-03-28 | 2025-03-28 | 0d | 0d |  | Matthew Breen |  |  | 274.71 | 5.27 | Green | GREEN |  |  |  |  |
| 1986 | 1.8.4.2.17 | TORWG (Confirmation of Qualified Parties from TORWG) | milestone | 0d | 2025-03-31 | 2025-03-31 | 1983FS+1d, 1984FS+1d, 1985FS+1d, 1968 | 2025-03-31 | 2025-03-31 | 0d | 0d |  | Matthew Breen |  |  | 277.71 | 5.27 | Green | GREEN |  |  |  |  |
| 1987 | 1.8.4.2.18 | MCAG (Provide recommedation to PSG on M11 decision) | milestone | 0d | 2025-04-02 | 2025-04-02 | 1986FS+2d | 2025-04-02 | 2025-04-02 | 0d | 0d |  | Matthew Breen |  |  | 279.71 | 5.27 | Green | GREEN | T3-MI-0036 | MCAG |  |  |
| 1988 | 1.8.4.2.19 | PSG (OFGEM and PSG Decision to Confirm M11 and M12) | milestone | 0d | 2025-04-04 | 2025-04-04 | 1987FS+2d | 2025-04-04 | 2025-04-04 | 0d | 0d |  | Matthew Breen |  |  | 281.71 | 5.27 | Green | GREEN |  |  |  |  |
| 1989 | 1.8.5 | **UMS / Advanced Migration** |  | 391d | 2025-04-04 | 2026-10-02 |  | 2025-04-04 | 2026-10-02 | 391d | 1d |  | N/A | 3128h | -0 | -555.67 | 5.24 |  |  |  |  | N/A | N/A |
| 1990 | 1.8.5.1 | SIT MVC UMS / Advanced Migration |  | 391d | 2025-04-04 | 2026-10-02 | 2049 | 2025-04-04 | 2026-10-02 | 391d | 1d | 0d |  |  |  | 281.33 | 5.24 | Green | GREEN |  |  |  |  |
| 1991 | 1.8.5.2 | SIT Non-MVC UMS / Advanced Migration |  | 326d | 2025-07-04 | 2026-10-02 | 2050 | 2025-07-04 | 2026-10-02 | 326d | 1d | 0d |  |  |  | 372.33 | 5.24 | Green | GREEN |  |  |  |  |
| 1992 | 1.8.5.3 | Wave 1 UMS / Advanced Migration |  | 261d | 2025-10-03 | 2026-10-02 | 2051 | 2025-10-03 | 2026-10-02 | 261d | 1d | 0d |  |  |  | 463.33 | 5.24 | Green | GREEN |  |  |  |  |
| 1993 | 1.8.5.4 | Wave 2 UMS / Advanced Migration |  | 216d | 2025-12-05 | 2026-10-02 | 2052 | 2025-12-05 | 2026-10-02 | 216d | 1d | 0d |  |  |  | 526.33 | 5.24 | Green | GREEN |  |  |  |  |
| 1994 | 1.8.5.5 | Wave 3 UMS / Advanced Migration |  | 181d | 2026-01-23 | 2026-10-02 | 2053 | 2026-01-23 | 2026-10-02 | 181d | 1d | 0d |  |  |  | 575.33 | 5.24 | Green | GREEN |  |  |  |  |
| 1995 | 1.8.5.6 | Wave 4 UMS / Advanced Migration |  | 131d | 2026-04-03 | 2026-10-02 | 2054 | 2026-04-03 | 2026-10-02 | 131d | 1d | 0d |  |  |  | 645.33 | 5.24 | Green | GREEN |  |  |  |  |

Notes:
- 1976: 18/6: New T3 milestone agreed at MCAG on 4/6/24
- 1987: 18/6: New T3 milestone agreed at MCAG on 4/6/24

| ID | WBS | Task | Type | Duration | Start | Finish | Predecessors | Complete | Remaining | Baseline start | Baseline finish | Baseline duration | Baseline 1 start | Baseline 1 finish | Total slack | Free slack | Constraint | Resources | Work | Actual work | Baseline cost | Responsible | Involved | Task Status | Update Version | Sched Status | RAG | MHHS Programme Phase | Milestone ID | Text29 | Tier | Action |
| --- | --- | --- | --- | --- | --- | --- | --- | --- | --- | --- | --- | --- | --- | --- | --- | --- | --- | --- | --- | --- | --- | --- | --- | --- | --- | --- | --- | --- | --- | --- | --- | --- |
| 1996 | 1.8.6 | **Smart / Non-Smart Migration** |  | 391d | 2025-04-04 | 2026-10-02 |  |  |  | 2025-04-04 | 2026-10-02 | 391d |  |  | 1d |  |  | N/A | 3128h |  | -0 | N/A | N/A | -555.67 | 5.24 |  |  |  |  |  |  |  |
| 1997 | 1.8.6.1 | SIT MVC Smart / Non-Smart Migration |  | 391d | 2025-04-04 | 2026-10-02 | 2049 |  |  | 2025-04-04 | 2026-10-02 | 391d |  |  | 1d | 0d |  |  |  |  |  |  |  | 281.33 | 5.24 | Green | GREEN |  |  |  |  |  |
| 1998 | 1.8.6.2 | SIT Non-MVC Smart / Non-Smart Migration |  | 326d | 2025-07-04 | 2026-10-02 | 2050 |  |  | 2025-07-04 | 2026-10-02 | 326d |  |  | 1d | 0d |  |  |  |  |  |  |  | 372.33 | 5.24 | Green | GREEN |  |  |  |  |  |
| 1999 | 1.8.6.3 | Wave 1 Smart / Non-Smart Migration |  | 261d | 2025-10-03 | 2026-10-02 | 2051 |  |  | 2025-10-03 | 2026-10-02 | 261d |  |  | 1d | 0d |  |  |  |  |  |  |  | 463.33 | 5.24 | Green | GREEN |  |  |  |  |  |
| 2000 | 1.8.6.4 | Wave 2 Smart / Non-Smart Migration |  | 216d | 2025-12-05 | 2026-10-02 | 2052 |  |  | 2025-12-05 | 2026-10-02 | 216d |  |  | 1d | 0d |  |  |  |  |  |  |  | 526.33 | 5.24 | Green | GREEN |  |  |  |  |  |
| 2001 | 1.8.6.5 | Wave 3 Smart / Non-Smart Migration |  | 181d | 2026-01-23 | 2026-10-02 | 2053 |  |  | 2026-01-23 | 2026-10-02 | 181d |  |  | 1d | 0d |  |  |  |  |  |  |  | 575.33 | 5.24 | Green | GREEN |  |  |  |  |  |
| 2002 | 1.8.6.6 | Wave 4 Smart / Non-Smart Migration |  | 131d | 2026-04-03 | 2026-10-02 | 2054 |  |  | 2026-04-03 | 2026-10-02 | 131d |  |  | 1d | 0d |  |  |  |  |  |  |  | 645.33 | 5.24 | Green | GREEN |  |  |  |  |  |
| 2003 | 1.8.7 | **Migration Management** |  | 391d | 2025-04-04 | 2026-10-02 |  |  |  | 2025-04-07 | 2026-10-05 | 391d | 2025-04-07 | 2026-10-05 | 170d |  |  | N/A | 6256h |  |  | N/A | N/A | M15 | 5.0 |  |  | Migration |  |  |  |  |
| 2004 | 1.8.7.1 | Migration Management |  | 391d | 2025-04-04 | 2026-10-02 | 1990SS, 1997SS |  |  | 2025-04-07 | 2026-10-05 | 391d | 2025-04-07 | 2026-10-05 | 170d |  |  | Warren Fulton | 3128h |  |  | SRO | PPC | 281.33 | 5.0 | Green | GREEN | Migration |  |  |  |  |
| 2005 | 1.8.8 | **External Programme Dependency Management** |  | 713d | 2022-10-31 A | 2025-07-23 |  | 66% | 244.19d | 2022-10-31 | 2025-12-30 | 827d | 2022-10-31 | 2025-07-01 | 482d |  |  | N/A | 34896h | 18656h | -0 | N/A | N/A |  | 5.0 |  |  | Migration |  |  |  |  |
| 2006 | 1.8.8.1 | **BSC Mod P432 & REC CP R0015** |  | 392d | 2022-10-31 A | 2024-04-30 |  | 99% | 0d | 2022-10-31 | 2025-12-30 | 827d | 2022-10-31 | 2025-07-01 | 0d |  |  | N/A | 6272h | 5760h | -0 | N/A | N/A |  | 5.0 |  |  | Migration |  |  |  |  |
| 2007 | 1.8.8.1.1 | MHHSP engagement with BSCCo until Ofgem decision |  | 316d | 2022-10-31 A | 2024-01-15 A |  | 100% |  | 2022-10-31 | 2024-05-10 | 400d | 2022-10-31 | 2022-12-30 |  |  |  | MHHS Programme | 2528h | 2528h |  | CPT,SRO Function | Code Bodies |  | 5.0 | Complete | COMPLETE | Migration |  |  |  |  |
| 2008 | 1.8.8.1.2 | Monitor progress and await implementation date |  | 76d | 2024-01-16 A | 2024-04-30 A | 2007 | 100% |  | 2023-07-03 | 2025-12-30 | 652d | 2023-01-02 | 2025-07-01 |  |  |  | MHHS Programme | 608h | 608h |  | CPT,SRO Function | Code Bodies |  | 5.0 | Complete | COMPLETE | Migration |  |  |  |  |
| 2009 | 1.8.8.2 | **BSC Mod P434** |  | 713d | 2022-10-31 A | 2025-07-23 |  | 57% | 310d | 2022-10-31 | 2025-07-23 | 713d | 2022-10-31 | 2025-07-01 | 482d |  |  | N/A | 11408h | 6448h |  | N/A | N/A |  | 5.0 |  |  | Migration |  |  |  |  |
| 2010 | 1.8.8.2.1 | MHHSP engagement with BSCCo until Ofgem decision |  | 61d | 2022-10-31 A | 2023-01-23 A |  | 100% |  | 2022-10-31 | 2023-01-23 | 61d | 2022-10-31 | 2022-12-30 |  |  |  | MHHS Programme | 488h | 488h |  | CPT,SRO Function | Code Bodies |  | 5.0 | Complete | COMPLETE | Migration |  |  |  |  |
| 2011 | 1.8.8.2.2 | Monitor progress and await implementation date |  | 652d | 2023-01-24 A | 2025-07-23 | 2010 | 52% | 310d | 2023-01-24 | 2025-07-23 | 652d | 2023-01-02 | 2025-07-01 | 482d |  |  | MHHS Programme | 5216h | 2736h |  | CPT,SRO Function | Code Bodies |  | 5.0 | Green | GREEN | Migration |  |  |  |  |
| 2012 | 1.8.8.3 | **Elexon System Capacity Upgrade** |  | 697d | 2022-10-31 A | 2025-07-01 |  | 58% | 294d | 2022-10-31 | 2025-07-01 | 697d | 2022-10-31 | 2025-07-01 | 498d |  |  | N/A | 11152h | 6448h |  | N/A | N/A |  | 5.0 |  |  | Migration |  |  |  |  |
| 2013 | 1.8.8.3.1 | Monitor progress to implementation |  | 697d | 2022-10-31 A | 2025-07-01 |  | 58% | 294d | 2022-10-31 | 2025-07-01 | 697d | 2022-10-31 | 2025-07-01 | 498d | 0d |  | MHHS Programme | 5576h | 3224h |  | SI Migration | PP |  | 5.0 | Green | GREEN | Migration |  |  |  |  |
| 2014 | 1.8.8.3.2 | Implementation date | milestone | 0d | 2025-07-01 | 2025-07-01 | 2013 |  |  | 2025-07-01 | 2025-07-01 | 0d | 2025-07-01 | 2025-07-01 | 498d |  |  | MHHS Programme |  |  |  | PP | SI Migration | 369.71 | 5.0 | Green | GREEN | Migration |  |  |  |  |
| 2015 | 1.8.8.4 | **DCC System Capacity Upgrade** |  | 25d | 2025-01-13 | 2025-02-14 |  |  |  | 2025-01-13 | 2025-02-14 | 25d | 2025-01-13 | 2025-02-14 | 595d |  |  | N/A | 360h |  |  | N/A | N/A |  | 5.0 |  |  | Migration |  |  |  |  |
| 2016 | 1.8.8.4.1 | Assurance of DCC capacity upgrade to ensure suitability to support migration |  | 20d | 2025-01-13 | 2025-02-07 | 2021FF-20d |  |  | 2025-01-13 | 2025-02-07 | 20d | 2025-01-13 | 2025-02-07 | 595d | 0d |  | MHHS Programme | 160h |  |  | SI Migration | PP | 200.33 | 5.0 | Green | GREEN | Migration |  |  |  |  |
| 2017 | 1.8.8.4.2 | DCC Capacity Upgrade Operational | milestone | 0d | 2025-02-14 | 2025-02-14 | 2016FS+5d |  |  | 2025-02-14 | 2025-02-14 | 0d | 2025-02-14 | 2025-02-14 | 595d |  |  | MHHS Programme |  |  |  | PP | SI Migration,IPA | 232.71 | 5.0 | Green | GREEN | Migration | T2-MI-0350 | MCAG | T2 |  |
| 2018 | 1.8.8.5 | **Performance Assurance Arrangements** |  | 0d | 2025-07-01 | 2025-07-01 |  |  |  | 2025-07-01 | 2025-07-01 | 0d | 2025-07-01 | 2025-07-01 | 499d |  |  | N/A |  |  |  | N/A | N/A |  | 5.0 |  |  | Migration |  |  |  |  |
| 2019 | 1.8.8.5.1 | Performance assurance regime for migration success delivered | milestone | 0d | 2025-07-01 | 2025-07-01 |  |  |  | 2025-07-01 | 2025-07-01 | 0d | 2025-07-01 | 2025-07-01 | 499d |  | start no earlier than 2025-07-01 | Simon chidwick |  |  |  | Code Bodies | SI Migration | 369.33 | 5.0 | Green | GREEN | Migration |  |  |  | 30/1/24 - To sit with Waren? |

| ID | WBS | Task | Type | Duration | Start | Finish | Predecessors | Complete | Remaining | Baseline start | Baseline finish | Baseline duration | Baseline 1 start | Baseline 1 finish | Total slack | Free slack | Constraint | Resources | Work | Actual work | Baseline cost | Responsible | Involved | Update Version | MHHS Programme Phase | Task Status | Sched Status | RAG | Milestone ID | Text29 | Tier | Issue |
| --- | --- | --- | --- | --- | --- | --- | --- | --- | --- | --- | --- | --- | --- | --- | --- | --- | --- | --- | --- | --- | --- | --- | --- | --- | --- | --- | --- | --- | --- | --- | --- | --- |
| 2020 | 1.8.9 | **Migration - Tier 1 Milestones** |  | 476d | 2025-03-07 | 2027-01-04 |  |  |  | 2025-03-07 | 2027-01-05 | 477d | 2025-03-07 | 2027-01-05 | 0d |  |  | N/A | 3808h |  |  | N/A | N/A | 5.0 | Migration |  |  |  |  |  |  |  |
| 2021 | 1.8.9.1 | Central systems ready for migrating MPANs (M10) | milestone | 0d | 2025-03-07 | 2025-03-07 | 1073FS+20d, 2055, 1967, 1964, 1976, 1966 |  |  | 2025-03-07 | 2025-03-07 | 0d | 2025-03-07 | 2025-03-07 | 0d |  |  | CPT |  |  |  | CPT | CPT | 5.0 | Migration | 253.71 | Green | GREEN | T1-MI-1000 | PSG | T1 |  |
| 2022 | 1.8.9.2 | Central systems ready for migrating MPANs (M10*) - Late Exit | milestone | 0d | 2025-06-06 | 2025-06-06 | 2021FS+65d |  |  | 2025-06-06 | 2025-06-06 | 0d | 2025-06-06 | 2025-06-06 | 515d |  |  | CPT |  |  |  | CPT | CPT | 5.0 | Migration | 344.71 | Green | GREEN | T2-MI-1500 | PSG | T1 |  |
| 2023 | 1.8.9.3 | Load Shaping Service switched on (M13) | milestone | 0d | 2025-03-07 | 2025-03-07 | 2021 |  |  | 2025-03-07 | 2025-03-07 | 0d | 2025-03-07 | 2025-03-07 | 20d | 0d |  | CPT |  |  |  | CPT | CPT | 5.0 | Migration | 253.71 | Green | GREEN | T1-MI-2000 | PSG | T1 |  |
| 2024 | 1.8.9.4 | Load Shaping Service switched on (M13*) - Late Exit | milestone | 0d | 2025-06-06 | 2025-06-06 | 2023FS+65d |  |  | 2025-06-06 | 2025-06-06 | 0d | 2025-06-06 | 2025-06-06 | 515d |  |  | CPT |  |  |  | CPT | CPT | 5.0 | Migration | 344.71 | Green | GREEN | T2-MI-2500 | PSG | T1 |  |
| 2025 | 1.8.9.5 | Start of 18-month migration for UMS / Advanced (M11) | milestone | 0d | 2025-04-04 | 2025-04-04 | 2021FS+20d, 2023, 2049, 1987, 1988 |  |  | 2025-04-04 | 2025-04-04 | 0d | 2025-04-04 | 2025-04-04 | 0d |  |  | CPT |  |  |  | CPT | CPT | 5.0 | Migration | 281.71 | Green | GREEN | T1-MI-3000 | PSG | T1 |  |
| 2026 | 1.8.9.6 | Start of 18-month migration for UMS / Advanced (M11*) - Late Exit | milestone | 0d | 2025-07-04 | 2025-07-04 | 2025FS+65d |  |  | 2025-07-04 | 2025-07-04 | 0d | 2025-07-04 | 2025-07-04 | 495d |  |  | CPT |  |  |  | CPT | CPT | 5.0 | Migration | 372.71 | Green | GREEN | T2-MI-3500 | PSG | T1 |  |
| 2027 | 1.8.9.7 | Start of 18-month migration for Smart / Non-smart (M12) | milestone | 0d | 2025-04-04 | 2025-04-04 | 2021FS+20d, 2023 |  |  | 2025-04-04 | 2025-04-04 | 0d | 2025-04-04 | 2025-04-04 | 495d | 0d |  | CPT |  |  |  | CPT | CPT | 5.0 | Migration | 281.71 | Green | GREEN | T1-MI-4000 | PSG | T1 |  |
| 2028 | 1.8.9.8 | Start of 18-month migration for Smart / Non-smart (M12*) - Late Exit | milestone | 0d | 2025-07-04 | 2025-07-04 | 2027FS+65d |  |  | 2025-07-04 | 2025-07-04 | 0d | 2025-07-04 | 2025-07-04 | 495d |  |  | CPT |  |  |  | CPT | CPT | 5.0 | Migration | 372.71 | Green | GREEN | T2-MI-4500 | PSG | T1 |  |
| 2029 | 1.8.9.9 | All suppliers must be able to access MPANs under the new TOM (M14) | milestone | 0d | 2026-03-12 | 2026-03-12 |  |  |  | 2026-03-16 | 2026-03-16 | 0d | 2026-03-16 | 2026-03-16 | 0d |  | must start on 2026-03-12 | CPT |  |  |  | CPT | CPT | 5.0 | Migration | 623.71 | Green | GREEN | T1-MI-5000 | PSG | T1 |  |
| 2030 | 1.8.9.10 | All suppliers must be able to access MPANs under the new TOM (M14*) - Late Exit | milestone | 0d | 2026-06-12 | 2026-06-12 | 2029FS+66d |  |  | 2026-06-16 | 2026-06-16 | 0d | 2026-06-16 | 2026-06-16 | 250d |  |  | CPT |  |  |  | CPT | CPT | 5.0 | Migration | 715.71 | Green | GREEN | T1-MI-5500 | PSG | T1 |  |
| 2031 | 1.8.9.11 | Full transition complete (M15) | milestone | 0d | 2026-10-02 | 2026-10-02 | 1990, 1991, 1992, 1993, 1994, 1995, 1997, 1998, 1999, 2000, 2001, 2002, 1930 |  |  | 2026-10-05 | 2026-10-05 | 0d | 2026-10-05 | 2026-10-05 | 1d | 0d |  | CPT |  |  |  | CPT | CPT | 5.0 | Migration | 827.71 | Green | GREEN | T1-MI-6000 | PSG | T1 |  |
| 2032 | 1.8.9.12 | Full transition complete (M15*) - Late Exit | milestone | 0d | 2027-01-04 | 2027-01-04 | 2031FS+66d |  |  | 2027-01-05 | 2027-01-05 | 0d | 2027-01-05 | 2027-01-05 | 104d |  |  | CPT |  |  |  | CPT | CPT | 5.0 | Migration | 921.71 | Green | GREEN | T2-MI-6500 | PSG | T1 |  |
| 2033 | 1.9 | **BUSINESS & OPERATIONAL READINESS** |  | 964d | 2023-09-19 A | 2027-05-28 |  | 8% | 888.31d | 2023-09-19 | 2027-05-28 | 964d | 2023-03-01 | 2026-12-07 | 0d |  |  | N/A | 47249.7h | 5233.7h | -0 | N/A | N/A |  | Business & Operational Readiness |  |  |  |  |  |  |  |
| 2034 | 1.9.1 | **Service Management** |  | 839d | 2023-09-19 A | 2026-12-04 |  | 26% | 621.65d | 2023-09-19 | 2026-12-07 | 840d | 2023-03-01 | 2026-12-07 | 125d |  |  | N/A | 17904h | 4751.99h | -0 | N/A | N/A | 5.0 | Business & Operational Readiness |  |  |  |  |  |  |  |
| 2035 | 1.9.1.1 | **Service Management Strategy** |  | 116d | 2023-09-19 A | 2024-02-27 A |  | 100% |  | 2023-09-19 | 2024-02-27 | 116d | 2023-03-01 | 2023-05-31 |  |  |  | N/A | 1848h | 1848h | -0 | N/A | N/A | 5.0 | Business & Operational Readiness |  |  |  |  |  |  |  |
| 2036 | 1.9.1.1.1 | Develop document with relevant participants (incl. review of the design baseline to ensure service management arrangements are in place across the solution architecture) |  | 84d | 2023-09-19 A | 2024-01-12 A |  | 100% |  | 2023-09-19 | 2024-01-12 | 84d | 2023-03-01 | 2023-04-28 |  |  | start no earlier than 2023-09-19 | Matthew Breen | 672h | 672h |  | SI Design |  | 5.0 | Business & Operational Readiness |  | Complete | COMPLETE |  |  |  |  |
| 2037 | 1.9.1.1.2 | Artefact review (via relevant Advisory Group) and updates |  | 31d | 2024-01-15 A | 2024-02-26 A | 2036 | 100% |  | 2024-01-15 | 2024-02-26 | 31d | 2023-05-01 | 2023-05-24 |  |  |  | Matthew Breen | 248h | 248h |  | PP | SI Design,IPA | 5.0 | Business & Operational Readiness |  | Complete | COMPLETE |  |  |  |  |
| 2038 | 1.9.1.1.3 | Service Management Strategy approved | milestone | 0d | 2024-02-27 A | 2024-02-27 A | 2037FS+1d | 100% |  | 2024-02-27 | 2024-02-27 | 0d | 2023-05-31 | 2023-05-31 |  |  |  | Matthew Breen |  |  |  | SI Design | PP | 5.16 | Business & Operational Readiness |  | Complete | COMPLETE | T3-BC-0010 | MCAG | T3 |  |
| 2039 | 1.9.1.2 | **Early Life Support Model** |  | 110d | 2024-02-28 A | 2024-07-30 |  | 82% | 20.23d | 2024-02-28 | 2024-07-30 | 110d |  |  | 0d |  |  | N/A | 1576h | 1286.16h | -0 | N/A | N/A | 5.16 | Business & Operational Readiness | -441.67 |  |  |  |  |  |  |
| 2040 | 1.9.1.2.1 | Draft Document |  | 74d | 2024-02-28 A | 2024-06-10 | 2038 | 96% | 3d | 2024-02-28 | 2024-06-10 | 74d |  |  | 0d |  |  | Matthew Breen | 592h | 568h |  | SI Transition | SI Transition,PP,SRO | 5.24 | Business & Operational Readiness |  | Overdue | RED |  |  |  |  |
| 2041 | 1.9.1.2.2 | Share document with SRO |  | 1d | 2024-06-11 | 2024-06-11 | 2040 |  |  | 2024-06-11 | 2024-06-11 | 1d |  |  | 0d |  |  | Matthew Breen | 8h |  |  | SI Transition | SI Transition,PP,SRO | 5.24 | Business & Operational Readiness | -15.67 | Overdue Start | RED |  |  |  |  |
| 2042 | 1.9.1.2.3 | Industry Consultation |  | 11d | 2024-06-18 | 2024-07-02 | 2041FS+4d |  |  | 2024-06-18 | 2024-07-02 | 11d |  |  | 0d |  |  | Matthew Breen | 88h |  |  | SI Transition | SI Transition,PP,SRO | 5.24 | Business & Operational Readiness | -8.67 | Overdue Start | GREEN |  |  |  |  |
| 2043 | 1.9.1.2.4 | Assurance Meeting |  | 1d | 2024-07-16 | 2024-07-16 | 2042FS+9d |  |  | 2024-07-16 | 2024-07-16 | 1d |  |  | 0d |  |  | Matthew Breen | 8h |  |  | SI Transition | SI Transition,PP,SRO | 5.24 | Business & Operational Readiness | 19.33 | Green | GREEN |  |  |  |  |
| 2044 | 1.9.1.2.5 | MCAG Approval of Early Life Support Model | milestone | 0d | 2024-07-30 | 2024-07-30 | 2043FS+10d |  |  | 2024-07-30 | 2024-07-30 | 0d |  |  | 0d |  |  | Matthew Breen |  |  |  | SI Transition | PP,SRO,SI Transition | 5.24 | Business & Operational Readiness | 33.71 | Green | RED | T3-MI-0033 | MCAG |  | 25/6: Late based on input required from Code-Bodies |

Notes:
- 2021: Text3: Central systems ready for migrating MPANs
- 2022: Text3: Central systems ready for migrating MPANs
- 2023: Text3: Load Shaping Service switched on
- 2024: Text3: Load Shaping Service switched on
- 2025: Text3: Start of 1 year migration for UMS / Advanced
- 2026: Text3: Start of 1 year migration for UMS / Advanced
- 2027: Text3: Start of 1 year migration for Smart / Non-smart
- 2028: Text3: Start of 1 year migration for Smart / Non-smart
- 2029: Text3: All suppliers must be able to accept MPANs under the new TOM (one way gate)
- 2030: Text3: All suppliers must be able to accept MPANs under the new TOM (one way gate)
- 2031: Text3: Full transition complete
- 2032: Text3: Full transition complete
- 2038: 17/1 - Baseline change approved at TMAG to change date from 21/2/24 to 27/2/24. Changed because MCAG has been scheduled for 27/2/24. Approved at TMAG on 7/1/24
- 2044: 12/6: Late based on input required from Code-Bodies - further update will be given when further discussions have been had with the Code Bodies / Action: 25/6: Update will be given when further discussions have been held with the Code Bodies / Impact: 25/6: Drafting and publication of the document have been delayed. Impact will be further defined once timelines are understood

| ID | WBS | Task | Type | Duration | Start | Finish | Predecessors | Baseline start | Baseline finish | Baseline duration | Baseline 1 start | Baseline 1 finish | Total slack | Free slack | Constraint | Resources | Work | Baseline cost | Responsible | Involved | Update Version | MHHS Programme Phase | Task Status | Sched Status | RAG | Artefact ID | Action |
| --- | --- | --- | --- | --- | --- | --- | --- | --- | --- | --- | --- | --- | --- | --- | --- | --- | --- | --- | --- | --- | --- | --- | --- | --- | --- | --- | --- |
| 2045 | 1.9.1.3 | **Service Management Arrangements Implementation** |  | 455d | 2025-03-10 | 2026-12-04 |  | 2025-03-10 | 2026-12-07 | 456d | 2025-03-10 | 2026-12-07 | 125d |  |  | N/A | 7768h |  | N/A | N/A | 5.0 | Business & Operational Readiness |  |  |  |  |  |
| 2046 | 1.9.1.3.1 | Hypercare post M10 |  | 80d | 2025-03-10 | 2025-06-27 | 2021 | 2025-03-10 | 2025-06-27 | 80d | 2025-03-10 | 2025-06-27 | 500d |  |  | Claire Silk | 640h |  | SI Design | PP | 5.0 | Business & Operational Readiness | 256.33 | Green | GREEN |  |  |
| 2047 | 1.9.1.3.2 | Monitor Elexon implementation of Service Management arrangements |  | 436d | 2025-04-04 | 2026-12-04 | 1990SS, 1997SS | 2025-04-07 | 2026-12-07 | 436d | 2025-04-07 | 2026-12-07 | 125d |  |  | Claire Silk | 3488h |  | PP | SI Design | 5.0 | Business & Operational Readiness | 281.33 | Green | GREEN |  |  |
| 2048 | 1.9.2 | **Service Activation** |  | 289d | 2025-02-24 | 2026-04-02 |  | 2025-02-24 | 2026-04-02 | 289d |  |  | 1d |  |  | N/A | 2312h | -0 | N/A | N/A | 5.24 |  | -555.67 |  |  |  |  |
| 2049 | 1.9.2.1 | SIT MVC Service Activation |  | 24d | 2025-03-03 | 2025-04-03 | 1389 | 2025-02-28 | 2025-04-03 | 25d |  |  | 1d | 0d |  |  |  |  |  |  | 5.24 |  | 249.33 | Green | GREEN |  |  |
| 2050 | 1.9.2.2 | SIT Non-MVC Service Activation |  | 24d | 2025-06-02 | 2025-07-03 | 1395 | 2025-05-30 | 2025-07-03 | 25d |  |  | 1d | 0d |  |  |  |  |  |  | 5.24 |  | 340.33 | Green | GREEN |  |  |
| 2051 | 1.9.2.3 | Wave 1 Service Activation |  | 24d | 2025-09-01 | 2025-10-02 | 1581 | 2025-08-29 | 2025-10-02 | 25d |  |  | 1d | 0d |  |  |  |  |  |  | 5.24 |  | 431.33 | Green | GREEN |  |  |
| 2052 | 1.9.2.4 | Wave 2 Service Activation |  | 24d | 2025-11-03 | 2025-12-04 | 1611 | 2025-10-31 | 2025-12-04 | 25d |  |  | 1d | 0d |  |  |  |  |  |  | 5.24 |  | 494.33 | Green | GREEN |  |  |
| 2053 | 1.9.2.5 | Wave 3 Service Activation |  | 24d | 2025-12-22 | 2026-01-22 | 1641 | 2025-12-19 | 2026-01-22 | 25d |  |  | 1d | 0d |  |  |  |  |  |  | 5.24 |  | 543.33 | Green | GREEN |  |  |
| 2054 | 1.9.2.6 | Wave 4 Service Activation |  | 24d | 2026-03-02 | 2026-04-02 | 1671 | 2026-02-27 | 2026-04-02 | 25d |  |  | 1d | 0d |  |  |  |  |  |  | 5.24 |  | 613.33 | Green | GREEN |  |  |
| 2055 | 1.9.2.7 | Non-SIT LDSO Service Activation |  | 9d | 2025-02-24 | 2025-03-06 | 1306 | 2025-02-24 | 2025-03-06 | 9d |  |  | 1d |  |  |  |  |  |  |  | 5.24 |  | 242.33 | Green | GREEN |  |  |
| 2056 | 1.9.3 | **Implement Early Life Support Plan** |  | 45d | 2025-01-06 | 2025-03-07 |  | 2025-01-06 | 2025-03-07 | 45d | 2025-01-06 | 2025-02-28 | 580d |  |  | N/A | 720h | -0 | N/A | N/A | 5.0 | Business & Operational Readiness |  |  |  |  |  |
| 2057 | 1.9.3.1 | Implement Early Life Support Plan |  | 45d | 2025-01-06 | 2025-03-07 | 2044 | 2025-01-06 | 2025-03-07 | 45d | 2025-02-28 | 2025-02-28 | 580d |  | start no earlier than 2025-01-06 | Matthew Breen | 360h |  | SI Transition | SI Transition,CPT | 5.23 | Business & Operational Readiness | 193.33 | Green | GREEN | MHHS-ART095 |  |
| 2058 | 1.9.4 | **Business Continuity and Disaster Recovery Plan** |  | 40d | 2025-01-13 | 2025-03-07 |  | 2025-01-13 | 2025-03-07 | 40d | 2025-01-13 | 2025-03-07 | 580d |  |  | N/A | 640h |  | N/A | N/A | 5.0 | Business & Operational Readiness |  |  |  |  |  |
| 2059 | 1.9.4.1 | Central Parties BCDRs in Place |  | 20d | 2025-01-13 | 2025-02-07 | 1814FS-40d | 2025-01-13 | 2025-02-07 | 20d | 2025-01-13 | 2025-02-07 | 580d | 0d |  | MHHS Programme | 160h |  | SI Design |  | 5.0 | Business & Operational Readiness | 200.33 | Green | GREEN |  |  |
| 2060 | 1.9.4.2 | Risk Based Assurance of Cental Party BCDRs |  | 20d | 2025-02-10 | 2025-03-07 | 2059 | 2025-02-10 | 2025-03-07 | 20d | 2025-02-10 | 2025-03-07 | 580d |  |  | MHHS Programme | 160h |  | PP | SI Design | 5.0 | Business & Operational Readiness | 228.33 | Green | GREEN |  |  |
| 2061 | 1.9.5 | **Operations Support Guide** |  | 40d | 2025-02-03 | 2025-03-28 |  | 2025-02-03 | 2025-03-28 | 40d | 2025-02-03 | 2025-03-28 | 565d |  |  | N/A | 640h |  | N/A | N/A | 5.0 | Business & Operational Readiness |  |  |  |  |  |
| 2062 | 1.9.5.1 | Develop document |  | 20d | 2025-02-03 | 2025-02-28 | 2027FS-45d | 2025-02-03 | 2025-02-28 | 20d | 2025-02-03 | 2025-02-28 | 565d | 0d |  | Warren Fulton | 160h |  | SRO | SRO | 5.0 | Business & Operational Readiness | 221.33 | Green | GREEN |  |  |
| 2063 | 1.9.5.2 | Document review and update |  | 20d | 2025-03-03 | 2025-03-28 | 2062 | 2025-03-03 | 2025-03-28 | 20d | 2025-03-03 | 2025-03-28 | 565d | 0d |  | Warren Fulton | 160h |  | SRO | SRO | 5.0 | Business & Operational Readiness | 249.33 | Green | GREEN |  |  |
| 2064 | 1.9.5.3 | Operations Support Guide approved | milestone | 0d | 2025-03-28 | 2025-03-28 | 2063 | 2025-03-28 | 2025-03-28 | 0d | 2025-03-28 | 2025-03-28 | 565d |  |  | Warren Fulton |  |  | SRO | SRO | 5.0 | Business & Operational Readiness | 274.71 | Green | GREEN | MHHS-ART116 |  |
| 2065 | 1.9.6 | **Training and Support Materials** |  | 39d | 2025-02-03 | 2025-03-27 |  | 2025-02-03 | 2025-03-28 | 40d | 2025-02-03 | 2025-03-28 | 566d |  |  | N/A | 624h |  | N/A | N/A | 5.0 | Business & Operational Readiness |  |  |  |  | 10/5: To be reworked with better clarity (LH) |
| 2066 | 1.9.6.1 | Develop document |  | 20d | 2025-02-03 | 2025-02-28 | 2027FS-45d | 2025-02-03 | 2025-02-28 | 20d | 2025-02-03 | 2025-02-28 | 566d | 0d |  | PPC | 160h |  | SI Migration | CPT | 5.0 | Business & Operational Readiness | 221.33 | Green | GREEN |  |  |
| 2067 | 1.9.6.2 | Document review and update |  | 19d | 2025-03-03 | 2025-03-27 | 2066 | 2025-03-03 | 2025-03-28 | 20d | 2025-03-03 | 2025-03-28 | 566d | 0d |  | PPC | 152h |  | SI Migration | PMO,CPT,IPA,PP | 5.0 | Business & Operational Readiness | 249.33 | Green | GREEN |  |  |
| 2068 | 1.9.6.3 | Training and Support Materials approved | milestone | 0d | 2025-03-27 | 2025-03-27 | 2067 | 2025-03-28 | 2025-03-28 | 0d | 2025-03-28 | 2025-03-28 | 566d |  |  | PPC |  |  | SI Migration | PMO,CPT | 5.0 | Business & Operational Readiness | 273.71 | Green | GREEN | MHHS-ART118 |  |

Notes:
- 2046: 10/5: Detail to be added when available
- 2047: 10/5: Detail to be added when available

| ID | WBS | Task | Type | Duration | Start | Finish | Predecessors | Baseline start | Baseline finish | Baseline duration | Baseline 1 start | Baseline 1 finish | Total slack | Constraint | Resources | Work | Baseline cost | Responsible | Involved | Action | Task Status | Update Version | MHHS Programme Phase | Sched Status | RAG | Milestone ID | Text29 | Tier |
| --- | --- | --- | --- | --- | --- | --- | --- | --- | --- | --- | --- | --- | --- | --- | --- | --- | --- | --- | --- | --- | --- | --- | --- | --- | --- | --- | --- | --- |
| 2069 | 1.9.7 | **PP Business Change** |  | 129d | 2025-02-03 | 2025-07-31 |  | 2025-02-03 | 2025-07-31 | 129d | 2025-02-03 | 2025-07-31 | 476d |  | N/A | 7224h |  | N/A | N/A | 10/5: Review with PPC (LH) | M11 | 5.0 | Business & Operational Readiness |  |  |  |  |  |
| 2070 | 1.9.7.1 | Plan stakeholder management |  | 129d | 2025-02-03 | 2025-07-31 |  | 2025-02-03 | 2025-07-31 | 129d | 2025-02-03 | 2025-07-31 | 476d | start no earlier than 2025-02-03 | PPC | 1032h |  | PP | PPC |  | 221.33 | 5.0 | Business & Operational Readiness | Green | GREEN |  |  |  |
| 2071 | 1.9.7.2 | Manage stakeholders |  | 129d | 2025-02-03 | 2025-07-31 |  | 2025-02-03 | 2025-07-31 | 129d | 2025-02-03 | 2025-07-31 | 476d | start no earlier than 2025-02-03 | PPC | 1032h |  | PP | PPC |  | 221.33 | 5.0 | Business & Operational Readiness | Green | GREEN |  |  |  |
| 2072 | 1.9.7.3 | Develop & implement changes to KPIs, organisation & people management |  | 129d | 2025-02-03 | 2025-07-31 |  | 2025-02-03 | 2025-07-31 | 129d | 2025-02-03 | 2025-07-31 | 476d | start no earlier than 2025-02-03 | PPC | 1032h |  | PP | PPC |  | 221.33 | 5.0 | Business & Operational Readiness | Green | GREEN |  |  |  |
| 2073 | 1.9.7.4 | Develop & test changes to business processes |  | 129d | 2025-02-03 | 2025-07-31 |  | 2025-02-03 | 2025-07-31 | 129d | 2025-02-03 | 2025-07-31 | 476d | start no earlier than 2025-02-03 | PPC | 1032h |  | PP | PPC |  | 221.33 | 5.0 | Business & Operational Readiness | Green | GREEN |  |  |  |
| 2074 | 1.9.7.5 | Develop and deliver training |  | 129d | 2025-02-03 | 2025-07-31 |  | 2025-02-03 | 2025-07-31 | 129d | 2025-02-03 | 2025-07-31 | 476d | start no earlier than 2025-02-03 | PPC | 1032h |  | PP | PPC |  | 221.33 | 5.0 | Business & Operational Readiness | Green | GREEN |  |  |  |
| 2075 | 1.9.7.6 | Programme support for PP Business Change activities |  | 129d | 2025-02-03 | 2025-07-31 |  | 2025-02-03 | 2025-07-31 | 129d | 2025-02-03 | 2025-07-31 | 476d | start no earlier than 2025-02-03 | PPC | 1032h |  | PPC | PP |  | 221.33 | 5.0 | Business & Operational Readiness | Green | GREEN |  |  |  |
| 2076 | 1.9.8 | **Supplier Business Readiness for Cutover** | inactive | 283d | 2025-10-01 | 2026-10-30 |  | 2025-10-01 | 2026-10-30 | 283d | 2025-10-01 | 2026-10-30 | 150d |  | N/A | 4528h |  | N/A | N/A |  | M11 | 5.24 | Business & Operational Readiness |  |  |  |  |  |
| 2077 | 1.9.8.1 | Programme support for Supplier Business Readiness for Cutover activities (incl. setup, management and evaluation of dress rehearsals) | inactive | 283d | 2025-10-01 | 2026-10-30 |  | 2025-10-01 | 2026-10-30 | 283d | 2025-10-01 | 2026-10-30 | 150d | start no earlier than 2025-10-01 | Matthew Breen | 2264h |  | PPC | PP |  | 461.33 | 5.24 | Business & Operational Readiness |  | GREEN |  |  |  |
| 2078 | 1.9.9 | **Transition to New Settlement Timetable (M16)** |  | 560d | 2025-04-04 | 2027-05-28 |  | 2025-04-04 | 2027-05-28 | 560d |  |  | 0d |  | N/A | 9952h | -0 | N/A | N/A |  | -434.67 | 5.15 | Business & Operational Readiness |  |  |  |  |  |
| 2079 | 1.9.9.1 | Elexon to produce Settlement Calendar for Settlement Year 2025/2026 | milestone | 0d | 2025-04-04 | 2025-04-04 | 2025 | 2025-04-04 | 2025-04-04 | 0d |  |  | 0d |  | Matthew Breen |  |  | PP | PP, Code Bodies |  | 281.71 | 5.15 | Business & Operational Readiness | Green | GREEN |  |  |  |
| 2080 | 1.9.9.2 | Elexon monitor settlement data of migrated MPANs |  | 436d | 2025-04-07 | 2026-12-07 | 2079 | 2025-04-07 | 2026-12-07 | 436d |  |  | 0d |  | Matthew Breen | 3488h |  | PP | PP, Code Bodies |  | 284.33 | 5.15 | Business & Operational Readiness | Green | GREEN |  |  |  |
| 2081 | 1.9.9.3 | M16 Checkpoint 1 | milestone | 0d | 2025-12-08 | 2025-12-08 | 2079FS+176d | 2025-12-08 | 2025-12-08 | 0d |  |  | 0d |  | Matthew Breen |  |  | PP | PP, Code Bodies |  | 529.71 | 5.15 | Business & Operational Readiness | Green | GREEN |  |  |  |
| 2082 | 1.9.9.4 | Confirm if M16 date retained as 07/12/2026 | milestone | 0d | 2026-01-05 | 2026-01-05 | 2081FS+20d | 2026-01-05 | 2026-01-05 | 0d |  |  | 0d |  | Matthew Breen |  |  | CPT | PP |  | 557.71 | 5.15 | Business & Operational Readiness | Green | GREEN |  |  |  |
| 2083 | 1.9.9.5 | Readiness assessment of participants' readiness to transition to new Settlement Timetable | milestone | 0d | 2026-02-02 | 2026-02-02 | 2082FS+20d | 2026-02-02 | 2026-02-02 | 0d |  |  | 0d |  | Matthew Breen |  |  | CPT | PP |  | 585.71 | 5.15 | Business & Operational Readiness | Green | GREEN |  |  |  |
| 2084 | 1.9.9.6 | Elexon to produce Settlement Calendar for Settlement Year 2026 up until day before M16 cutover | milestone | 0d | 2026-04-01 | 2026-04-01 | 2083FS+42d | 2026-04-01 | 2026-04-01 | 0d |  |  | 0d |  | Matthew Breen |  |  | PP | PP, Code Bodies |  | 643.71 | 5.15 | Business & Operational Readiness | Green | GREEN |  |  |  |
| 2085 | 1.9.9.7 | M16 Checkpoint 2 | milestone | 0d | 2026-09-15 | 2026-09-15 | 2084FS+119d | 2026-09-15 | 2026-09-15 | 0d |  |  | 0d |  | Matthew Breen |  |  | PP | PP, Code Bodies |  | 810.71 | 5.15 | Business & Operational Readiness | Green | GREEN |  |  |  |
| 2086 | 1.9.9.8 | Readiness assessment of participants' readiness to transition to new Settlement Timetable | milestone | 0d | 2026-09-30 | 2026-09-30 | 2085FS+11d | 2026-09-30 | 2026-09-30 | 0d |  |  | 0d |  | Matthew Breen |  |  | CPT | PP |  | 825.71 | 5.15 | Business & Operational Readiness | Green | GREEN |  |  |  |
| 2087 | 1.9.9.9 | Confirm M16 Date | milestone | 0d | 2026-10-13 | 2026-10-13 | 2086FS+9d | 2026-10-13 | 2026-10-13 | 1d |  |  | 0d |  | Matthew Breen |  |  | CPT | Code Bodies,CPT,PP,SRO |  | 838.71 | 5.3 | Business & Operational Readiness | Green | GREEN | T2-EL-0100 | PSG/BSC PAB | T2 |
| 2088 | 1.9.9.10 | Raise fast track change to ISD (November publish) | milestone | 0d | 2026-10-13 | 2026-10-13 | 2087 | 2026-10-13 | 2026-10-13 | 0d |  |  | 39d |  | Matthew Breen |  |  | PP | PP,CPT,Code Bodies |  | 838.71 | 5.15 | Business & Operational Readiness | Green | GREEN |  |  |  |
| 2089 | 1.9.9.11 | **M16 Approval Window** |  | 124d | 2026-12-07 | 2027-05-28 |  | 2026-12-07 | 2027-05-28 | 124d | 2026-12-07 | 2027-05-24 | 0d |  | N/A | 1984h |  | N/A | N/A |  |  | 5.0 | Business & Operational Readiness |  |  |  |  |  |
| 2090 | 1.9.9.11.1 | Panel approval that M16 criteria met | milestone | 0d | 2026-12-07 | 2026-12-07 | 2087FS+39d | 2026-12-07 | 2026-12-07 | 0d | 2026-12-07 | 2026-12-07 | 0d |  | Matthew Breen |  |  | Panel | Code Bodies,CPT,PP,SRO |  | 893.71 | 5.0 | Business & Operational Readiness | Green | GREEN |  |  |  |
| 2091 | 1.9.9.11.2 | Cut over to new settlement timetable (M16) | milestone | 0d | 2026-12-07 | 2026-12-07 | 2090, 2031FS+45d, 2080, 2088, 1936 | 2026-12-07 | 2026-12-07 | 0d | 2026-12-07 | 2026-12-07 | 0d |  | Matthew Breen |  |  | CPT | PP |  | 893.71 | 5.0 | Business & Operational Readiness | Green | GREEN | T1-EL-1000 | PSG | T1 |
| 2092 | 1.9.9.11.3 | Maximum 6-month window for approval of M16 |  | 124d | 2026-12-08 | 2027-05-28 | 2091 | 2026-12-08 | 2027-05-28 | 124d | 2026-12-08 | 2027-05-24 | 0d |  | Matthew Breen | 992h |  | CPT |  |  | 894.33 | 5.0 | Business & Operational Readiness | Green | GREEN |  |  |  |
| 2093 | 1.9.9.11.4 | Cut over to new settlement timetable (M16*) - Late Exit | milestone | 0d | 2027-05-28 | 2027-05-28 | 2092 | 2027-05-28 | 2027-05-28 | 0d | 2027-05-24 | 2027-05-24 | 0d |  | Matthew Breen |  |  | CPT | PP |  | 1065.71 | 5.0 | Business & Operational Readiness | Green | GREEN | T1-EL-2000 | PSG | T1 |

Notes:
- 2076: 10/5: coverEd in other areas of the plan

| ID | WBS | Task | Type | Duration | Start | Finish | Predecessors | Baseline start | Baseline finish | Baseline duration | Baseline 1 start | Baseline 1 finish | Total slack | Free slack | Resources | Work | Responsible | Involved | Text3 | MHHS Programme Phase | Update Version | Task Status | Sched Status | RAG | Artefact ID | Milestone ID | Text29 | Tier |
| --- | --- | --- | --- | --- | --- | --- | --- | --- | --- | --- | --- | --- | --- | --- | --- | --- | --- | --- | --- | --- | --- | --- | --- | --- | --- | --- | --- | --- |
| 2094 | 1.10 | **EARLY LIVE RUNNING** |  | 45d | 2026-10-05 | 2026-12-04 |  | 2024-01-02 | 2027-05-28 | 889d | 2024-01-02 | 2027-05-28 | 125d |  | N/A | 1440h | N/A | N/A | 1 Nov 2025 - 30 Apr 2026 | Early Live Running |  |  |  |  |  |  |  |  |
| 2095 | 1.10.1 | **Early Live Running Stabilisation Period** |  | 45d | 2026-10-05 | 2026-12-04 |  | 2026-10-06 | 2026-12-07 | 45d | 2026-10-06 | 2026-12-07 | 125d |  | N/A | 1080h | N/A | N/A |  | Early Live Running | 5.0 |  |  |  |  |  |  |  |
| 2096 | 1.10.1.1 | Manage Early Live Running stabilisation period |  | 45d | 2026-10-05 | 2026-12-04 | 2031 | 2026-10-06 | 2026-12-07 | 45d | 2026-10-06 | 2026-12-07 | 125d | 0d | Matthew Breen | 360h | Code Bodies | PP |  | Early Live Running | 5.0 | 830.33 | Green | GREEN |  |  |  |  |
| 2097 | 1.10.1.2 | Monitor Early Live Running stabilisation period |  | 45d | 2026-10-05 | 2026-12-04 | 2096SS | 2026-10-06 | 2026-12-07 | 45d | 2026-10-06 | 2026-12-07 | 125d |  | Matthew Breen | 360h | SI Migration | Code Bodies,PP |  | Early Live Running | 5.0 | 830.33 | Green | GREEN |  |  |  |  |
| 2098 | 1.11 | **PROGRAMME CLOSURE** |  | 86d | 2026-08-03 | 2026-11-30 |  | 2026-08-04 | 2026-11-30 | 85d | 2026-08-04 | 2026-11-30 | 129d |  | N/A | 4576h | N/A | N/A |  | Programme Closure |  |  |  |  |  |  |  |  |
| 2099 | 1.11.1 | **Handover Pack** |  | 86d | 2026-08-03 | 2026-11-30 |  | 2026-08-04 | 2026-11-30 | 85d | 2026-08-04 | 2026-11-30 | 129d |  | N/A | 1328h | N/A | N/A |  | Programme Closure | 5.0 |  |  |  |  |  |  |  |
| 2100 | 1.11.1.1 | **Draft Handover Pack (for M15)** |  | 40d | 2026-08-03 | 2026-09-25 |  | 2026-08-04 | 2026-09-28 | 40d | 2026-08-04 | 2026-09-28 | 175d |  | N/A | 320h | N/A | N/A |  | Programme Closure | 5.0 |  |  |  |  |  |  |  |
| 2101 | 1.11.1.1.1 | Develop document |  | 20d | 2026-08-03 | 2026-08-28 | 2031FS-45d | 2026-08-04 | 2026-08-31 | 20d | 2026-08-04 | 2026-08-31 | 175d | 0d |  |  | PMO | CPT |  | Programme Closure | 5.0 | 767.33 | Green | GREEN |  |  |  |  |
| 2102 | 1.11.1.1.2 | Document review and update |  | 20d | 2026-08-31 | 2026-09-25 | 2101 | 2026-09-01 | 2026-09-28 | 20d | 2026-09-01 | 2026-09-28 | 175d | 0d |  |  | SRO | PMO,CPT,IPA,PP |  | Programme Closure | 5.0 | 795.33 | Green | GREEN |  |  |  |  |
| 2103 | 1.11.1.1.3 | Draft Handover Pack approved | milestone | 0d | 2026-09-25 | 2026-09-25 | 2102 | 2026-09-28 | 2026-09-28 | 0d | 2026-09-28 | 2026-09-28 | 175d |  |  |  | SRO | PMO,CPT |  | Programme Closure | 5.0 | 820.71 | Green | GREEN | MHHS-ART126 |  |  |  |
| 2104 | 1.11.1.2 | **Master Handover Pack (for M16)** |  | 40d | 2026-10-06 | 2026-11-30 |  | 2026-10-06 | 2026-11-30 | 40d | 2026-10-06 | 2026-11-30 | 129d |  | N/A | 320h | N/A | N/A |  | Programme Closure | 5.0 |  |  |  |  |  |  |  |
| 2105 | 1.11.1.2.1 | Update document |  | 20d | 2026-10-06 | 2026-11-02 | 2091FS-45d | 2026-10-06 | 2026-11-02 | 20d | 2026-10-06 | 2026-11-02 | 129d | 0d |  |  | PMO | CPT |  | Programme Closure | 5.0 | 831.33 | Green | GREEN |  |  |  |  |
| 2106 | 1.11.1.2.2 | Document review and update |  | 20d | 2026-11-03 | 2026-11-30 | 2105 | 2026-11-03 | 2026-11-30 | 20d | 2026-11-03 | 2026-11-30 | 129d | 0d |  |  | SRO | PMO,CPT,IPA,PP |  | Programme Closure | 5.0 | 859.33 | Green | GREEN |  |  |  |  |
| 2107 | 1.11.1.2.3 | Master Handover Pack approved | milestone | 0d | 2026-11-30 | 2026-11-30 | 2106 | 2026-11-30 | 2026-11-30 | 0d | 2026-11-30 | 2026-11-30 | 129d |  |  |  | SRO | PMO,CPT |  | Programme Closure | 5.0 | 886.71 | Green | GREEN | MHHS-ART126 |  |  |  |
| 2108 | 1.11.2 | **Programme Lessons Learned** |  | 40d | 2026-08-03 | 2026-09-25 |  | 2026-08-04 | 2026-09-28 | 40d | 2026-08-04 | 2026-09-28 | 175d |  | N/A | 320h | N/A | N/A |  | Programme Closure | 5.0 |  |  |  |  |  |  |  |
| 2109 | 1.11.2.1 | Develop document |  | 20d | 2026-08-03 | 2026-08-28 | 2031FS-45d | 2026-08-04 | 2026-08-31 | 20d | 2026-08-04 | 2026-08-31 | 175d | 0d |  |  | PMO | CPT |  | Programme Closure | 5.0 | 767.33 | Green | GREEN |  |  |  |  |
| 2110 | 1.11.2.2 | Document review and update |  | 20d | 2026-08-31 | 2026-09-25 | 2109 | 2026-09-01 | 2026-09-28 | 20d | 2026-09-01 | 2026-09-28 | 175d | 0d |  |  | SRO | PMO,CPT,IPA |  | Programme Closure | 5.0 | 795.33 | Green | GREEN |  |  |  |  |
| 2111 | 1.11.2.3 | Programme Lessons Learned document approved | milestone | 0d | 2026-09-25 | 2026-09-25 | 2110 | 2026-09-28 | 2026-09-28 | 0d | 2026-09-28 | 2026-09-28 | 175d |  |  |  | SRO | PMO,CPT |  | Programme Closure | 5.0 | 820.71 | Green | GREEN | MHHS-ART131 |  |  |  |
| 2112 | 1.11.3 | **Programme Closure Report** |  | 40d | 2026-08-03 | 2026-09-25 |  | 2026-08-04 | 2026-09-28 | 40d | 2026-08-04 | 2026-09-28 | 175d |  | N/A | 320h | N/A | N/A |  | Programme Closure | 5.0 |  |  |  |  |  |  |  |
| 2113 | 1.11.3.1 | Develop document |  | 20d | 2026-08-03 | 2026-08-28 | 2031FS-45d | 2026-08-04 | 2026-08-31 | 20d | 2026-08-04 | 2026-08-31 | 175d | 0d |  |  | PMO | CPT |  | Programme Closure | 5.0 | 767.33 | Green | GREEN |  |  |  |  |
| 2114 | 1.11.3.2 | Document review and update |  | 20d | 2026-08-31 | 2026-09-25 | 2113 | 2026-09-01 | 2026-09-28 | 20d | 2026-09-01 | 2026-09-28 | 175d | 0d |  |  | Ofgem | PMO,CPT,IPA,SRO |  | Programme Closure | 5.0 | 795.33 | Green | GREEN |  |  |  |  |
| 2115 | 1.11.3.3 | Programme Closure Report approved | milestone | 0d | 2026-09-25 | 2026-09-25 | 2114 | 2026-09-28 | 2026-09-28 | 0d | 2026-09-28 | 2026-09-28 | 175d |  |  |  | Ofgem | PMO,CPT,IPA,SRO |  | Programme Closure | 5.0 | 820.71 | Green | GREEN | MHHS-ART130 |  |  |  |
| 2116 | 1.11.4 | **Benefit Realisation Report** |  | 45d | 2026-08-03 | 2026-10-02 |  | 2026-08-04 | 2026-10-05 | 45d | 2026-08-04 | 2026-10-05 | 170d |  | N/A | 360h | N/A | N/A |  | Programme Closure | 5.0 |  |  |  |  |  |  |  |
| 2117 | 1.11.4.1 | Develop document |  | 20d | 2026-08-03 | 2026-08-28 | 2031FS-45d | 2026-08-04 | 2026-08-31 | 20d | 2026-08-04 | 2026-08-31 | 170d | 0d |  |  | PMO | CPT |  | Programme Closure | 5.0 | 767.33 | Green | GREEN |  |  |  |  |
| 2118 | 1.11.4.2 | Document review and update |  | 20d | 2026-08-31 | 2026-09-25 | 2117 | 2026-09-01 | 2026-09-28 | 20d | 2026-09-01 | 2026-09-28 | 170d | 0d |  |  | PP | PMO,CPT,IPA,SRO |  | Programme Closure | 5.0 | 795.33 | Green | GREEN |  |  |  |  |
| 2119 | 1.11.4.3 | Benefit Realisation Report approved | milestone | 0d | 2026-10-02 | 2026-10-02 | 2118FS+5d | 2026-10-05 | 2026-10-05 | 0d | 2026-10-05 | 2026-10-05 | 170d |  |  |  | PMO | CPT,PP,IPA,SRO |  | Programme Closure | 5.0 | 827.71 | Green | GREEN | MHHS-ART124 | T3-PC-0010 | PSG | T3 |

| ID | WBS | Task | Type | Duration | Start | Finish | Predecessors | Complete | Remaining | Baseline start | Baseline finish | Baseline duration | Baseline 1 start | Baseline 1 finish | Total slack | Free slack | Constraint | Resources | Work | Actual work | Responsible | Involved | Update Version | MHHS Programme Phase | Task Status | Sched Status | RAG | Artefact ID | Milestone ID | Text29 | Tier | Text3 |
| --- | --- | --- | --- | --- | --- | --- | --- | --- | --- | --- | --- | --- | --- | --- | --- | --- | --- | --- | --- | --- | --- | --- | --- | --- | --- | --- | --- | --- | --- | --- | --- | --- |
| 2120 | 1.11.5 | **Operating Model Gap Review with recommendations** |  | 45d | 2026-08-03 | 2026-10-02 |  |  |  | 2026-08-04 | 2026-10-05 | 45d | 2026-08-04 | 2026-10-05 | 170d |  |  | N/A | 360h |  | N/A | N/A | 5.0 | Programme Closure |  |  |  |  |  |  |  |  |
| 2121 | 1.11.5.1 | Develop document |  | 20d | 2026-08-03 | 2026-08-28 | 2031FS-45d |  |  | 2026-08-04 | 2026-08-31 | 20d | 2026-08-04 | 2026-08-31 | 170d | 0d |  |  |  |  | PMO | CPT | 5.0 | Programme Closure | 767.33 | Green | GREEN |  |  |  |  |  |
| 2122 | 1.11.5.2 | Document review and update |  | 20d | 2026-08-31 | 2026-09-25 | 2121 |  |  | 2026-09-01 | 2026-09-28 | 20d | 2026-09-01 | 2026-09-28 | 170d | 0d |  |  |  |  | PP | PMO,CPT,IPA,SRO | 5.0 | Programme Closure | 795.33 | Green | GREEN |  |  |  |  |  |
| 2123 | 1.11.5.3 | Operating Model Gap Review with recommendations approved | milestone | 0d | 2026-10-02 | 2026-10-02 | 2122FS+5d |  |  | 2026-10-05 | 2026-10-05 | 0d | 2026-10-05 | 2026-10-05 | 170d |  |  | Paul Pettitt |  |  | Paul Pettitt | CPT,PP,IPA,SRO | 5.0 | Programme Closure | 827.71 | Green | GREEN | MHHS-ART128 | T3-PC-0020 | DAG | T3 |  |
| 2124 | 1.11.6 | **Post-Implementation Review** |  | 45d | 2026-08-03 | 2026-10-02 |  |  |  | 2026-08-04 | 2026-10-05 | 45d | 2026-08-04 | 2026-10-05 | 170d |  |  | N/A | 360h |  | N/A | N/A | 5.0 | Programme Closure |  |  |  |  |  |  |  |  |
| 2125 | 1.11.6.1 | Develop document |  | 20d | 2026-08-03 | 2026-08-28 | 2031FS-45d |  |  | 2026-08-04 | 2026-08-31 | 20d | 2026-08-04 | 2026-08-31 | 170d | 0d |  |  |  |  | PMO | CPT | 5.0 | Programme Closure | 767.33 | Green | GREEN |  |  |  |  |  |
| 2126 | 1.11.6.2 | Document review and update |  | 20d | 2026-08-31 | 2026-09-25 | 2125 |  |  | 2026-09-01 | 2026-09-28 | 20d | 2026-09-01 | 2026-09-28 | 170d | 0d |  |  |  |  | PP | PMO,CPT,IPA,SRO | 5.0 | Programme Closure | 795.33 | Green | GREEN |  |  |  |  |  |
| 2127 | 1.11.6.3 | Post-Implementation Review approved | milestone | 0d | 2026-10-02 | 2026-10-02 | 2126FS+5d |  |  | 2026-10-05 | 2026-10-05 | 0d | 2026-10-05 | 2026-10-05 | 170d |  |  |  |  |  | PMO | CPT,PP,IPA,SRO | 5.0 | Programme Closure | 827.71 | Green | GREEN | MHHS-ART129 | T3-PC-0030 | PSG | T3 |  |
| 2128 | 1.11.7 | **Reinforcement Guide** |  | 45d | 2026-08-03 | 2026-10-02 |  |  |  | 2026-08-04 | 2026-10-05 | 45d | 2026-08-04 | 2026-10-05 | 170d |  |  | N/A | 360h |  | N/A | N/A | 5.0 | Programme Closure |  |  |  |  |  |  |  |  |
| 2129 | 1.11.7.1 | Develop document |  | 20d | 2026-08-03 | 2026-08-28 | 2031FS-45d |  |  | 2026-08-04 | 2026-08-31 | 20d | 2026-08-04 | 2026-08-31 | 170d | 0d |  |  |  |  | PMO | CPT | 5.0 | Programme Closure | 767.33 | Green | GREEN |  |  |  |  |  |
| 2130 | 1.11.7.2 | Document review and update |  | 20d | 2026-08-31 | 2026-09-25 | 2129 |  |  | 2026-09-01 | 2026-09-28 | 20d | 2026-09-01 | 2026-09-28 | 170d | 0d |  |  |  |  | PP | PMO,CPT,IPA,SRO | 5.0 | Programme Closure | 795.33 | Green | GREEN |  |  |  |  |  |
| 2131 | 1.11.7.3 | Reinforcement Guide approved | milestone | 0d | 2026-10-02 | 2026-10-02 | 2130FS+5d |  |  | 2026-10-05 | 2026-10-05 | 0d | 2026-10-05 | 2026-10-05 | 170d |  |  |  |  |  | PMO | CPT,PP,IPA,SRO | 5.0 | Programme Closure | 827.71 | Green | GREEN | MHHS-ART133 | T3-PC-0040 | PSG | T3 |  |
| 2132 | 1.11.8 | **Material and Licenses Transfer** |  | 60d | 2026-09-08 | 2026-11-30 |  |  |  | 2026-09-08 | 2026-11-30 | 60d | 2026-09-08 | 2026-11-30 | 129d |  |  | N/A | 480h |  | N/A | N/A | 5.0 | Programme Closure |  |  |  |  |  |  |  |  |
| 2133 | 1.11.8.1 | Transfer of Programme material to Elexon and perpetual licenses as appropriate |  | 60d | 2026-09-08 | 2026-11-30 | 2091FF-5d |  |  | 2026-09-08 | 2026-11-30 | 60d | 2026-09-08 | 2026-11-30 | 129d |  |  |  |  |  | PMO | CPT,PP | 5.0 | Programme Closure | 803.33 | Green | GREEN | MHHS-ART139 |  |  |  |  |
| 2134 | 1.12 | **READINESS ASSESSMENTS** |  | 849d | 2023-09-05 A | 2026-12-04 |  | 23% | 657.29d | 2023-09-05 | 2026-12-04 | 849d | 2023-09-11 | 2026-12-04 | 125d |  |  | N/A | 13264h | 2230.45h | N/A | N/A |  | Readiness Assessments |  |  |  |  |  |  |  |  |
| 2135 | 1.12.1 | **Readiness Assessment 3 - Design and Build Progress Check and CP2 Check** |  | 60d | 2023-09-05 A | 2023-11-27 A |  | 100% |  | 2023-09-05 | 2023-11-13 | 50d | 2023-09-11 | 2023-11-17 |  |  |  | N/A | 1040h | 1040h | N/A | N/A | 5.5 | Readiness Assessments | M5,M6 |  |  |  |  |  |  |  |
| 2136 | 1.12.1.1 | Launch Readiness Assessment survey | milestone | 0d | 2023-09-05 A | 2023-09-05 A | 1001FS-40d | 100% |  | 2023-09-05 | 2023-09-05 | 0d | 2023-09-11 | 2023-09-11 |  |  |  | PPC |  |  | PPC |  | 5.5 | Readiness Assessments |  | Complete | COMPLETE |  |  |  |  |  |
| 2137 | 1.12.1.2 | PPs submit survey responses |  | 15d | 2023-09-05 A | 2023-09-25 A | 2136 | 100% |  | 2023-09-05 | 2023-09-25 | 15d | 2023-09-11 | 2023-09-29 |  |  |  | PPC | 120h | 120h | PP | PPC | 5.5 | Readiness Assessments |  | Complete | COMPLETE |  |  |  |  |  |
| 2138 | 1.12.1.3 | Analyse survey responses |  | 15d | 2023-09-26 A | 2023-10-16 A | 2137 | 100% |  | 2023-09-26 | 2023-10-16 | 15d | 2023-10-02 | 2023-10-20 |  |  |  | PPC | 120h | 120h | PPC | CPT | 5.5 | Readiness Assessments |  | Complete | COMPLETE |  |  |  |  |  |
| 2139 | 1.12.1.4 | Conduct deep-dive interviews (sample of PPs) |  | 15d | 2023-09-26 A | 2023-10-16 A | 2137 | 100% |  | 2023-09-26 | 2023-10-16 | 15d | 2023-10-02 | 2023-10-20 |  |  |  | PPC | 120h | 120h | PPC | CPT | 5.5 | Readiness Assessments |  | Complete | COMPLETE |  |  |  |  |  |
| 2140 | 1.12.1.5 | Produce Readiness Assessment Reports (Overall Report & Individual Participant Reports) |  | 25d | 2023-10-17 A | 2023-11-20 A | 2138, 2139 | 100% |  | 2023-10-17 | 2023-11-06 | 15d | 2023-10-23 | 2023-11-10 |  |  |  | PPC | 200h | 200h | PPC |  | 5.5 | Readiness Assessments |  | Complete | COMPLETE |  |  |  |  |  |
| 2141 | 1.12.1.6 | Readiness Assessment 3 - Design & Build Checkpoint 1 - Completed (incl. Readiness Assessment Report approval) | milestone | 0d | 2023-11-27 A | 2023-11-27 A | 2140FS+5d | 100% |  | 2023-11-13 | 2023-11-13 | 0d | 2023-11-17 | 2023-11-17 |  |  |  | PPC |  |  | CPT | PPC | 5.13 | Readiness Assessments |  | Complete | COMPLETE |  | T2-RA-0200 | PSG | T2 |  |
| 2142 | 1.12.2 | **Readiness Assessment 5 / 6 - Start of Qualification and Participant Readiness for M10 and M11 and CP3/CP4 check** |  | 47d | 2024-11-12 | 2025-01-15 |  |  |  | 2024-11-12 | 2025-01-17 | 49d | 2024-11-12 | 2025-01-17 | 0d |  |  | N/A | 856h |  | N/A | N/A | 5.0 | Readiness Assessments | M11 |  |  |  |  |  |  | D25 - RA6 Readiness Report |
| 2143 | 1.12.2.1 | Launch Readiness Assessment survey | milestone | 0d | 2024-11-12 | 2024-11-12 |  |  |  | 2024-11-12 | 2024-11-12 | 0d | 2024-11-12 | 2024-11-12 | 0d |  | must start on 2024-11-12 | PPC |  |  | PPC |  | 5.0 | Readiness Assessments | 138.33 | Green | GREEN |  |  |  |  |  |
| 2144 | 1.12.2.2 | PPs submit survey responses |  | 15d | 2024-11-12 | 2024-12-02 | 2143 |  |  | 2024-11-12 | 2024-12-02 | 15d | 2024-11-12 | 2024-12-02 | 617d | 0d |  | PPC | 120h |  | PP | PPC | 5.0 | Readiness Assessments | 138.33 | Green | GREEN |  |  |  |  |  |
| 2145 | 1.12.2.3 | Analyse survey responses |  | 15d | 2024-12-03 | 2024-12-23 | 2144 |  |  | 2024-12-03 | 2024-12-23 | 15d | 2024-12-03 | 2024-12-23 | 617d | 0d |  | PPC | 120h |  | PPC | CPT | 5.0 | Readiness Assessments | 159.33 | Green | GREEN |  |  |  |  |  |
| 2146 | 1.12.2.4 | Conduct deep-dive interviews (sample of PPs) |  | 15d | 2024-12-03 | 2024-12-23 | 2144 |  |  | 2024-12-03 | 2024-12-23 | 15d | 2024-12-03 | 2024-12-23 | 617d | 0d |  | PPC | 120h |  | PPC | CPT | 5.0 | Readiness Assessments | 159.33 | Green | GREEN |  |  |  |  |  |
| 2147 | 1.12.2.5 | Produce Readiness Assessment Reports (Overall Report & Individual Participant Reports) |  | 15d | 2024-12-24 | 2025-01-13 | 2145, 2146 |  |  | 2024-12-24 | 2025-01-13 | 15d | 2024-12-24 | 2025-01-13 | 617d | 0d |  | PPC | 120h |  | PPC |  | 5.0 | Readiness Assessments | 180.33 | Green | GREEN |  |  |  |  |  |
| 2148 | 1.12.2.6 | Readiness Assessment 5 / 6 - Start of Qualification and Participant Readiness for M10 and M11 and CP3/CP4 check (incl. Readiness Assessment Report approval) Completed | milestone | 0d | 2025-01-15 | 2025-01-15 | 2147FS+2d |  |  | 2025-01-17 | 2025-01-17 | 0d | 2025-01-17 | 2025-01-17 | 617d |  |  | PPC |  |  | CPT | PPC | 5.18 | Readiness Assessments | 202.71 | Green | GREEN |  | T2-RA-0400 | PSG | T2 |  |

Notes:
- 2123: Action: 5/2 - PP said ask MB if belonged to him. MB says doesn't sit with him
- 2139: 16/11- FD confirmed activity didn't take place for RA3 because responses did not warrant follow-up
- 2141: 16/11-RA3 outputs and initial findings shared with PSG to support M9 decision making. Individual reports and final closure report being finalised. No impact to Programme timelines or activities
- 2148: 08/02/2024 Name change approval at PSG on 07/02/24 from 'Readiness Assessment 5 - Start of Qualification - Completed (incl. Readiness Assessment Report approval)'

| ID | WBS | Task | Type | Duration | Start | Finish | Predecessors | Baseline start | Baseline finish | Baseline duration | Baseline 1 start | Baseline 1 finish | Total slack | Free slack | Constraint | Resources | Work | Responsible | Involved | Text3 | Task Status | Update Version | MHHS Programme Phase | Sched Status | RAG | Milestone ID | Text29 | Tier |
| --- | --- | --- | --- | --- | --- | --- | --- | --- | --- | --- | --- | --- | --- | --- | --- | --- | --- | --- | --- | --- | --- | --- | --- | --- | --- | --- | --- | --- |
| 2149 | 1.12.3 | **Readiness Assessment 7 - Migration Checkpoint** |  | 49d | 2025-08-04 | 2025-10-09 |  | 2025-08-04 | 2025-10-09 | 49d | 2025-08-04 | 2025-10-09 | 0d |  |  | N/A | 872h | N/A | N/A | D29 - RA8 Readiness Report | M14 | 5.0 | Readiness Assessments |  |  |  |  |  |
| 2150 | 1.12.3.1 | Launch Readiness Assessment survey | milestone | 0d | 2025-08-04 | 2025-08-04 |  | 2025-08-04 | 2025-08-04 | 0d | 2025-08-04 | 2025-08-04 | 0d |  | must start on 2025-08-04 | PPC |  | PPC |  |  | 403.33 | 5.0 | Readiness Assessments | Green | GREEN |  |  |  |
| 2151 | 1.12.3.2 | PPs submit survey responses |  | 15d | 2025-08-04 | 2025-08-22 | 2150 | 2025-08-04 | 2025-08-22 | 15d | 2025-08-04 | 2025-08-22 | 426d | 0d |  | PPC | 120h | PP | PPC |  | 403.33 | 5.0 | Readiness Assessments | Green | GREEN |  |  |  |
| 2152 | 1.12.3.3 | Analyse survey responses |  | 15d | 2025-08-25 | 2025-09-12 | 2151 | 2025-08-25 | 2025-09-12 | 15d | 2025-08-25 | 2025-09-12 | 426d | 0d |  | PPC | 120h | PPC | CPT |  | 424.33 | 5.0 | Readiness Assessments | Green | GREEN |  |  |  |
| 2153 | 1.12.3.4 | Conduct deep-dive interviews (sample of PPs) |  | 15d | 2025-08-25 | 2025-09-12 | 2151 | 2025-08-25 | 2025-09-12 | 15d | 2025-08-25 | 2025-09-12 | 426d | 0d |  | PPC | 120h | PPC | CPT |  | 424.33 | 5.0 | Readiness Assessments | Green | GREEN |  |  |  |
| 2154 | 1.12.3.5 | Produce Readiness Assessment Reports (Overall Report & Individual Participant Reports) |  | 15d | 2025-09-15 | 2025-10-03 | 2152, 2153 | 2025-09-15 | 2025-10-03 | 15d | 2025-09-15 | 2025-10-03 | 426d | 0d |  | PPC | 120h | PPC |  |  | 445.33 | 5.0 | Readiness Assessments | Green | GREEN |  |  |  |
| 2155 | 1.12.3.6 | Readiness Assessment 7 - Migration Checkpoint - Completed (incl. Readiness Assessment Report approval) | milestone | 0d | 2025-10-09 | 2025-10-09 | 2154FS+4d | 2025-10-09 | 2025-10-09 | 0d | 2025-10-09 | 2025-10-09 | 426d |  |  | PPC |  | CPT | PPC |  | 469.71 | 5.0 | Readiness Assessments | Green | GREEN | T2-RA-0600 | PSG | T2 |
| 2156 | 1.12.4 | **Readiness Assessment 8 - Ready to Accept New MPANs** |  | 49d | 2026-01-02 | 2026-03-11 |  | 2026-01-06 | 2026-03-13 | 49d | 2026-01-06 | 2026-03-13 | 317d |  |  | N/A | 872h | N/A | N/A | D29 - RA8 Readiness Report | M14 | 5.0 | Readiness Assessments |  |  |  |  |  |
| 2157 | 1.12.4.1 | Launch Readiness Assessment survey | milestone | 0d | 2026-01-02 | 2026-01-02 | 2029FS-50d | 2026-01-06 | 2026-01-06 | 0d | 2026-01-06 | 2026-01-06 | 317d | 0d |  | PPC |  | PPC |  |  | 554.33 | 5.0 | Readiness Assessments | Green | GREEN |  |  |  |
| 2158 | 1.12.4.2 | PPs submit survey responses |  | 15d | 2026-01-02 | 2026-01-22 | 2157 | 2026-01-06 | 2026-01-26 | 15d | 2026-01-06 | 2026-01-26 | 317d | 0d |  | PPC | 120h | PP | PPC |  | 554.33 | 5.0 | Readiness Assessments | Green | GREEN |  |  |  |
| 2159 | 1.12.4.3 | Analyse survey responses |  | 15d | 2026-01-23 | 2026-02-12 | 2158 | 2026-01-27 | 2026-02-16 | 15d | 2026-01-27 | 2026-02-16 | 317d | 0d |  | PPC | 120h | PPC | CPT |  | 575.33 | 5.0 | Readiness Assessments | Green | GREEN |  |  |  |
| 2160 | 1.12.4.4 | Conduct deep-dive interviews (sample of PPs) |  | 15d | 2026-01-23 | 2026-02-12 | 2158 | 2026-01-27 | 2026-02-16 | 15d | 2026-01-27 | 2026-02-16 | 317d | 0d |  | PPC | 120h | PPC | CPT |  | 575.33 | 5.0 | Readiness Assessments | Green | GREEN |  |  |  |
| 2161 | 1.12.4.5 | Produce Readiness Assessment Reports (Overall Report & Individual Participant Reports) |  | 15d | 2026-02-13 | 2026-03-05 | 2159, 2160 | 2026-02-17 | 2026-03-09 | 15d | 2026-02-17 | 2026-03-09 | 317d | 0d |  | PPC | 120h | PPC |  |  | 596.33 | 5.0 | Readiness Assessments | Green | GREEN |  |  |  |
| 2162 | 1.12.4.6 | Readiness Assessment 8 - Ready to Accept New MPANs - Completed (incl. Readiness Assessment Report approval) | milestone | 0d | 2026-03-11 | 2026-03-11 | 2161FS+4d | 2026-03-13 | 2026-03-13 | 0d | 2026-03-13 | 2026-03-13 | 317d |  |  | PPC |  | CPT | PPC |  | 622.71 | 5.0 | Readiness Assessments | Green | GREEN | T2-RA-0700 | PSG | T2 |
| 2163 | 1.12.5 | **Readiness Assessment 9 - Ready for New Settlement Timetable and CP5 Check** |  | 49d | 2026-09-29 | 2026-12-04 |  | 2026-09-29 | 2026-12-04 | 49d | 2026-09-29 | 2026-12-04 | 125d |  |  | N/A | 872h | N/A | N/A | D32 - RA10 Readiness Report | M16 | 5.0 | Readiness Assessments |  |  |  |  |  |
| 2164 | 1.12.5.1 | Launch Readiness Assessment survey | milestone | 0d | 2026-09-29 | 2026-09-29 | 2091FS-50d | 2026-09-29 | 2026-09-29 | 0d | 2026-09-29 | 2026-09-29 | 125d | 0d |  | PPC |  | PPC |  |  | 824.33 | 5.0 | Readiness Assessments | Green | GREEN |  |  |  |
| 2165 | 1.12.5.2 | PPs submit survey responses |  | 15d | 2026-09-29 | 2026-10-19 | 2164 | 2026-09-29 | 2026-10-19 | 15d | 2026-09-29 | 2026-10-19 | 125d | 0d |  | PPC | 120h | PP | PPC |  | 824.33 | 5.0 | Readiness Assessments | Green | GREEN |  |  |  |
| 2166 | 1.12.5.3 | Analyse survey responses |  | 15d | 2026-10-20 | 2026-11-09 | 2165 | 2026-10-20 | 2026-11-09 | 15d | 2026-10-20 | 2026-11-09 | 125d | 0d |  | PPC | 120h | PPC | CPT |  | 845.33 | 5.0 | Readiness Assessments | Green | GREEN |  |  |  |
| 2167 | 1.12.5.4 | Conduct deep-dive interviews (sample of PPs) |  | 15d | 2026-10-20 | 2026-11-09 | 2165 | 2026-10-20 | 2026-11-09 | 15d | 2026-10-20 | 2026-11-09 | 125d | 0d |  | PPC | 120h | PPC | CPT |  | 845.33 | 5.0 | Readiness Assessments | Green | GREEN |  |  |  |
| 2168 | 1.12.5.5 | Produce Readiness Assessment Reports (Overall Report & Individual Participant Reports) |  | 15d | 2026-11-10 | 2026-11-30 | 2166, 2167 | 2026-11-10 | 2026-11-30 | 15d | 2026-11-10 | 2026-11-30 | 125d | 0d |  | PPC | 120h | PPC |  |  | 866.33 | 5.0 | Readiness Assessments | Green | GREEN |  |  |  |
| 2169 | 1.12.5.6 | Readiness Assessment 9 - Readiness for New Settlement Timetable - Completed (incl. Readiness Assessment Report approval) | milestone | 0d | 2026-12-04 | 2026-12-04 | 2168FS+4d | 2026-12-04 | 2026-12-04 | 0d | 2026-12-04 | 2026-12-04 | 125d |  |  | PPC |  | CPT | PPC |  | 890.71 | 5.0 | Readiness Assessments | Green | GREEN | T2-RA-0800 | PSG | T2 |
| 2170 | 1.12.6 | **Readiness Assessments - Tier 1 Milestones** |  | 435d | 2025-04-04 | 2026-12-04 |  | 2023-11-13 | 2026-12-04 | 799d | 2023-11-17 | 2026-12-04 | 125d |  |  | N/A | 3480h | N/A | N/A |  |  | 5.0 | Readiness Assessments |  |  |  |  |  |
| 2171 | 1.12.6.1 | Readiness Assessment 6 - Start of Migration - Completed (incl. Readiness Assessment Report approval) | milestone | 0d | 2025-04-04 | 2025-04-04 |  | 2025-04-04 | 2025-04-04 | 0d | 2025-04-04 | 2025-04-04 | 560d |  | finish no earlier than 2025-04-04 | PPC |  | CPT | PPC |  | 281.71 | 5.0 | Readiness Assessments | Green | GREEN | T2-RA-0500 | PSG | T2 |
| 2172 | 1.12.6.2 | Readiness Assessment 7 - Migration Checkpoint - Completed (incl. Readiness Assessment Report approval) | milestone | 0d | 2025-10-09 | 2025-10-09 | 2154FS+4d | 2025-10-09 | 2025-10-09 | 0d | 2025-10-09 | 2025-10-09 | 426d |  |  | PPC |  | CPT | PPC |  | 469.71 | 5.0 | Readiness Assessments | Green | GREEN | T2-RA-0600 | PSG | T2 |
| 2173 | 1.12.6.3 | Readiness Assessment 8 - Ready to Accept New MPANs - Completed (incl. Readiness Assessment Report approval) | milestone | 0d | 2026-03-11 | 2026-03-11 | 2161FS+4d | 2026-03-13 | 2026-03-13 | 0d | 2026-03-13 | 2026-03-13 | 317d |  |  | PPC |  | CPT | PPC |  | 622.71 | 5.0 | Readiness Assessments | Green | GREEN | T2-RA-0700 | PSG | T2 |
| 2174 | 1.12.6.4 | Readiness Assessment 9 - Readiness for New Settlement Timetable - Completed (incl. Readiness Assessment Report approval) | milestone | 0d | 2026-12-04 | 2026-12-04 | 2168FS+4d | 2026-12-04 | 2026-12-04 | 0d | 2026-12-04 | 2026-12-04 | 125d |  |  | PPC |  | CPT | PPC |  | 890.71 | 5.0 | Readiness Assessments | Green | GREEN | T2-RA-0800 | PSG | T2 |

| ID | WBS | Task | Type | Duration | Start | Finish | Predecessors | Complete | Remaining | Baseline start | Baseline finish | Baseline duration | Baseline 1 start | Baseline 1 finish | Total slack | Free slack | Constraint | Resources | Work | Actual work | Responsible | Involved | MHHS Programme Phase | Update Version | Sched Status | RAG | Text3 | Milestone ID | Text29 | Tier | Task Status |
| --- | --- | --- | --- | --- | --- | --- | --- | --- | --- | --- | --- | --- | --- | --- | --- | --- | --- | --- | --- | --- | --- | --- | --- | --- | --- | --- | --- | --- | --- | --- | --- |
| 2175 | 1.13 | **CONTROL POINTS** |  | 1063d | 2022-11-10 A | 2026-12-07 |  | 51% | 522.49d | 2022-11-10 | 2026-12-07 | 1063d | 2022-11-10 | 2026-12-07 | 124d |  |  | N/A | 14424h | 680h | N/A | N/A | Control Points |  |  |  |  |  |  |  |  |
| 2176 | 1.13.1 | **Control Point 1 - Start of System Design, Build & Test** |  | 20d | 2022-11-10 A | 2022-12-07 A |  | 100% |  | 2022-11-10 | 2022-12-07 | 20d | 2022-11-10 | 2022-12-07 |  |  |  | N/A | 280h | 280h | N/A | N/A | Control Points | 5.0 |  |  |  |  |  |  |  |
| 2177 | 1.13.1.1 | Control Point 1 Preparation (incl. Control Point Report development and review) |  | 15d | 2022-11-10 A | 2022-11-30 A | 2178SS-20d | 100% |  | 2022-11-10 | 2022-11-30 | 15d | 2022-11-10 | 2022-11-30 |  |  |  | PMO | 120h | 120h | CPT | PMO | Control Points | 5.0 | Complete | COMPLETE |  |  |  |  |  |
| 2178 | 1.13.1.2 | Control Point 1 - Start of System Design, Build & Test (incl. Control Point Report approval) | milestone | 0d | 2022-12-07 A | 2022-12-07 A |  | 100% |  | 2022-12-07 | 2022-12-07 | 0d | 2022-12-07 | 2022-12-07 |  |  | must finish on 2022-12-07 | PMO |  |  | CPT | PMO | Control Points | 5.0 | Complete | COMPLETE | D24 - CP2 Approval | T1-CP-1000 | PSG | T1 |  |
| 2179 | 1.13.2 | **Control Point 2 - Start of Integration & Test** |  | 20d | 2023-10-02 A | 2023-10-30 A |  | 100% |  | 2023-10-03 | 2023-10-30 | 20d | 2023-10-02 | 2023-10-30 |  |  |  | N/A | 280h | 280h | N/A | N/A | Control Points | 5.0 |  |  |  |  |  |  |  |
| 2180 | 1.13.2.1 | Control Point 2 Preparation (incl. Control Point Report development and review) |  | 15d | 2023-10-02 A | 2023-10-20 A | 2181SS-20d | 100% |  | 2023-10-03 | 2023-10-23 | 15d | 2023-10-02 | 2023-10-20 |  |  |  | PMO | 120h | 120h | CPT | PMO | Control Points | 5.0 | Complete | COMPLETE |  |  |  |  |  |
| 2181 | 1.13.2.2 | Control Point 2 - Start of Integration & Test (incl. Control Point Report approval) | milestone | 0d | 2023-10-30 A | 2023-10-30 A | 1001 | 100% |  | 2023-10-30 | 2023-10-30 | 0d | 2023-10-30 | 2023-10-30 |  |  |  | PMO |  |  | CPT | PMO | Control Points | 5.11 | Complete | COMPLETE | D24 - CP2 Approval | T1-CP-2000 | PSG | T1 |  |
| 2182 | 1.13.3 | **Control Point 3/4 - Readiness for Migration** |  | 20d | 2025-02-28 | 2025-03-27 |  |  |  | 2025-03-03 | 2025-03-28 | 20d | 2025-03-03 | 2025-03-28 | 20d |  |  | N/A | 272h |  | N/A | N/A | Control Points | 5.0 |  |  | D26 - CP3 Approval |  |  |  |  |
| 2183 | 1.13.3.1 | Control Point 3/4 Preparation (incl. Control Point Report development and review) |  | 14d | 2025-02-28 | 2025-03-19 | 2184SS-20d |  |  | 2025-03-03 | 2025-03-20 | 14d | 2025-03-03 | 2025-03-21 | 572d |  |  | PMO | 112h |  | CPT | PMO | Control Points | 5.0 | Green | GREEN |  |  |  |  | 246.33 |
| 2184 | 1.13.3.2 | Control Point 3/4 - Readiness for Migration (incl. Control Point Report approval) | milestone | 0d | 2025-03-27 | 2025-03-27 |  |  |  | 2025-03-28 | 2025-03-28 | 0d | 2025-03-28 | 2025-03-28 | 0d |  | must start on 2025-03-27 | PMO |  |  | CPT | PMO | Control Points | 5.0 | Green | GREEN |  | T1-CP-3000 | PSG | T1 | 273.71 |
| 2185 | 1.13.4 | **Control Point 5 - Cut Over to New Settlement Timetable** |  | 20d | 2026-11-10 | 2026-12-07 |  |  |  | 2026-11-10 | 2026-12-07 | 20d | 2026-11-10 | 2026-12-07 | 124d |  |  | N/A | 280h |  | N/A | N/A | Control Points | 5.0 |  |  | D33 - Control Point 6 Approval |  |  |  | M16 |
| 2186 | 1.13.4.1 | Control Point 5 Preparation (incl. Control Point Report development and review) |  | 15d | 2026-11-10 | 2026-11-30 | 2187SS-20d |  |  | 2026-11-10 | 2026-11-30 | 15d | 2026-11-10 | 2026-11-30 | 129d |  |  | PMO | 120h |  | CPT | PP | Control Points | 5.0 | Green | GREEN |  |  |  |  | 866.33 |
| 2187 | 1.13.4.2 | Control Point 5 - Cut Over to New Settlement Timetable (incl. Control Point Report approval) | milestone | 0d | 2026-12-07 | 2026-12-07 | 2091 |  |  | 2026-12-07 | 2026-12-07 | 0d | 2026-12-07 | 2026-12-07 | 124d | 0d |  | PMO |  |  | CPT | CPT | Control Points | 5.0 | Green | GREEN | D33 - Control Point 6 Approval | T1-CP-4000 | PSG | T1 | 893.71 |
| 2188 | 1.13.5 | **Control Points - Tier 1 Milestones** |  | 1043d | 2022-12-07 A | 2026-12-07 |  |  | 1043d | 2022-12-07 | 2026-12-07 | 1043d | 2022-12-07 | 2026-12-07 | 124d |  |  | N/A | 4808h |  | N/A | N/A | Control Points | 5.0 |  |  |  |  |  |  |  |
| 2189 | 1.13.5.1 | Control Point 1 - Start of System Design, Build & Test (incl. Control Point Report approval) | milestone | 0d | 2022-12-07 A | 2022-12-07 A | 2178SS | 100% |  | 2022-12-07 | 2022-12-07 | 0d | 2022-12-07 | 2022-12-07 |  |  |  | PMO |  |  | CPT | PMO | Control Points | 5.0 | Complete | COMPLETE |  | T1-CP-1000 | PSG | T1 |  |
| 2190 | 1.13.5.2 | Control Point 2 - Start of Integration & Test (incl. Control Point Report approval) | milestone | 0d | 2023-10-30 A | 2023-10-30 A | 2181SS | 100% |  | 2023-10-30 | 2023-10-30 | 0d | 2023-10-30 | 2023-10-30 |  |  |  | PMO |  |  | CPT | PMO | Control Points | 5.11 | Complete | COMPLETE | D24 - CP2 Approval | T1-CP-2000 | PSG | T1 |  |
| 2191 | 1.13.5.3 | Control Point 3/4 - Readiness for Migration (incl. Control Point Report approval) | milestone | 0d | 2025-03-27 | 2025-03-27 | 2184SS |  |  | 2025-03-28 | 2025-03-28 | 0d | 2025-03-28 | 2025-03-28 | 566d |  |  | PMO |  |  | CPT | PMO | Control Points | 5.0 | Green | GREEN |  | T1-CP-3000 | PSG | T1 | 273.71 |
| 2192 | 1.13.5.4 | Control Point 5 - Cut Over to New Settlement Timetable (incl. Control Point Report approval) | milestone | 0d | 2026-12-07 | 2026-12-07 | 2187SS |  |  | 2026-12-07 | 2026-12-07 | 0d | 2026-12-07 | 2026-12-07 | 124d |  |  | PMO |  |  | CPT | CPT | Control Points | 5.0 | Green | GREEN | D33 - Control Point 6 Approval | T1-CP-4000 | PSG | T1 | 893.71 |
| 2193 | 1.14 | **MILESTONE RANGE CHECKPOINTS** |  | 436d | 2025-01-13 | 2026-09-15 |  |  |  | 2025-01-13 | 2026-09-15 | 436d | 2025-01-13 | 2026-09-15 | 184d |  |  | N/A | 3488h |  | N/A | N/A | Milestone Range Checkpoints |  |  |  |  |  |  |  |  |
| 2194 | 1.14.1 | **M10, M11, M12 and M13 milestone checkpoint** |  | 0d | 2025-01-13 | 2025-01-13 |  |  |  | 2025-01-13 | 2025-01-13 | 0d | 2025-01-13 | 2025-01-13 | 620d |  |  | N/A |  |  | N/A | N/A | Milestone Range Checkpoints | 5.0 |  |  |  |  |  |  |  |
| 2195 | 1.14.1.1 | M10, M11, M12, and M13 milestone checkpoint - date approval | milestone | 0d | 2025-01-13 | 2025-01-13 | 2021FS-3mo, 2025FS-3mo, 2027FS-3mo, 2023FS-3mo |  |  | 2025-01-13 | 2025-01-13 | 0d | 2025-01-13 | 2025-01-13 | 620d |  |  | PMO |  |  | CPT | CPT | Milestone Range Checkpoints | 5.0 | Green | GREEN |  | T2-MR-0100 | PSG | T2 | 200.33 |
| 2196 | 1.14.2 | **M14 milestone checkpoint** |  | 0d | 2025-12-19 | 2025-12-19 |  |  |  | 2025-12-23 | 2025-12-23 | 0d | 2025-12-23 | 2025-12-23 | 376d |  |  | N/A |  |  | N/A | N/A | Milestone Range Checkpoints | 5.0 |  |  |  |  |  |  |  |
| 2197 | 1.14.2.1 | M14 milestone checkpoint - date approval | milestone | 0d | 2025-12-19 | 2025-12-19 | 2029FS-3mo |  |  | 2025-12-23 | 2025-12-23 | 0d | 2025-12-23 | 2025-12-23 | 376d |  |  | PMO |  |  | CPT | CPT | Milestone Range Checkpoints | 5.0 | Green | GREEN |  | T2-MR-0200 | PSG | T2 | 540.33 |
| 2198 | 1.14.3 | **M15 milestone checkpoint** |  | 0d | 2026-07-13 | 2026-07-13 |  |  |  | 2026-07-14 | 2026-07-14 | 0d | 2026-07-14 | 2026-07-14 | 230d |  |  | N/A |  |  | N/A | N/A | Milestone Range Checkpoints | 5.0 |  |  |  |  |  |  |  |
| 2199 | 1.14.3.1 | M15 milestone checkpoint - date approval | milestone | 0d | 2026-07-13 | 2026-07-13 | 2031FS-3mo |  |  | 2026-07-14 | 2026-07-14 | 0d | 2026-07-14 | 2026-07-14 | 230d |  |  | PMO |  |  | CPT | CPT | Milestone Range Checkpoints | 5.0 | Green | GREEN |  | T2-MR-0300 | PSG | T2 | 746.33 |

| ID | WBS | Task | Type | Duration | Start | Finish | Predecessors | Baseline start | Baseline finish | Baseline duration | Baseline 1 start | Baseline 1 finish | Total slack | Resources | Responsible | Involved | Update Version | MHHS Programme Phase | Task Status | Sched Status | RAG | Milestone ID | Text29 | Tier |
| --- | --- | --- | --- | --- | --- | --- | --- | --- | --- | --- | --- | --- | --- | --- | --- | --- | --- | --- | --- | --- | --- | --- | --- | --- |
| 2200 | 1.14.4 | **M16 milestone checkpoint** |  | 0d | 2026-09-15 | 2026-09-15 |  | 2026-09-15 | 2026-09-15 | 0d | 2026-09-15 | 2026-09-15 | 184d | N/A | N/A | N/A | 5.0 | Milestone Range Checkpoints |  |  |  |  |  |  |
| 2201 | 1.14.4.1 | M16 milestone checkpoint - date approval | milestone | 0d | 2026-09-15 | 2026-09-15 | 2091FS-3mo | 2026-09-15 | 2026-09-15 | 0d | 2026-09-15 | 2026-09-15 | 184d | PMO | CPT | CPT | 5.0 | Milestone Range Checkpoints | 810.33 | Green | GREEN | T2-MR-0400 | PSG | T2 |
